# 3GPP_Release-2000

Schedule from MS Project, 1998-12-07 to 2011-09-16, A marks actual dates.

## Calendars

- Standard: Mon-Fri 08:00-12:00, 13:00-17:00; Sat-Sun off. Exceptions (off unless hours are given): 2000-01-15 08:00-12:00, 13:00-17:00, 2009-05-30 08:00-12:00, 13:00-17:00.

## Resources

| Resource |
| --- |
| NP |
| N1 |
| N2 |
| N3 |
| N4 |
| N5 |
| TP |
| T1 |
| T2 |
| T3 |
| RP |
| R1 |
| R2 |
| R3 |
| R4 |
| SP |
| S1 |
| S2 |
| S3 |
| S4 |
| S5 |
| PCG |
| GP |
| No |
| CN4 |
| ? |
| WG G2 |
| G2 |
| G1 |
| G4 |
| G3 |
| All |
| Generic |
| MLST |
| G5 |
| S3, G2 |
| WG T2 |
| GP,G1 |
| G4,G5 |
| OMA |
| GP-G2 |
| Yes |
| GP, |
| N4, |
| GP, N1 |
| CT5 |
| C5 |
| C1 |
| C4 |
| C3 |
| C6 |
| G1, |
| 4 |
| ct |
| c,s,r |
| CT,RAN,SA |
| G2, |
| G1, G3 |
| CT6 |
| CT1 |
| CT1, CT3, CT4 |
| C1, C3, C4 |
| CP |
| R5 |
| C |
| Rel-8 |
| GP, G2 |
| R1,R4 |
| S5,C1 |
| CT,RAN,SA,GERAN |
| S3,C1,C4 |
| 5 |
| S1,C1,C3,C4,S5 |
| S1,C1,C3,C5 |
| S1,C1,C3,C4 |
| S1,S5 |
| S2,S3 |
| RAN,SA |
| RP,S5 |
| S2,CT |
| S1,CT |
| S1,CT,GERAN |
| S1,C5 |
| S3,CT |
| S4,CT |
| C1,SA |
| S1,S2 |
| S1,S4 |
| S2,S2,S3,CT |
| S2,S3,CT |
| S1,CT,GX |
| S1,S4,CT |
| S2,S2,S3,S5,CT |
| S1,S2,CT |
| S1,S2,S3,CT |
| S1,S2,S3,S5CT |
| S1,S2,S3,S5,CT |
| S2,S5,CT |
| S4,S3 |
| S1,C1 |
| CP,C1 |
| C1,C3 |
| C1,C3,C4 |
| S1,S5,CT |
| C4,C3 |
| CP,RAN,SA,GERAN |
| S1,S2,S3,S5,CP |
| S2,S3,CP |
| S2,CP |
| S1,CP,GX |
| S1,CP |
| S1,S4,CP |
| S1,S2,CP |
| S1,S2,S3,CP |
| S2,S5,CP |
| S3,CP |
| S1,S5,CP |
| RAN,SA,GERAN |
| S1,S2,S3,S5,C1,C3,C4,C6 |
| S2,S3,C1,C3,C4 |
| S2,C4 |
| S2,C1,C3,C4 |
| S2,C1,C4 |
| S2,S3,C1,C4 |
| S1,C1,C4,G2 |
| C1,C4 |
| S1,C1,C3 |
| S1,S4,C1,C3,C4 |
| S1,S2,S3,C1,C3,C4 |
| S2,S5,C3 |
| S1,S2,C1,C4 |
| S2,C1 |
| S2,C1,C3 |
| S3,C1,C3,C4 |
| S1,S5,C1,C3,C4 |
| S2,C3,C4 |
| C3,C1 |
| R2,R4 |
| R2,R5 |
| RP,R5 |
| RP,S5,R5 |
| R1,R5 |
| S1,C1,R5 |
| S1,C1,S4,R5 |
| GERAN |
| G3new |
| G1, G3new |
| C4,C1,C3 |
| R1.R4 |
| R1, R4 |
| R2,R3 |
| C3,C4 |
| S4,C3 |
| S4,C3,C1,C4 |
| S1,S2,C1 |
| S1,S2<C1,C3,C4 |
| S1,S2,C1,C3,C4 |
| S5,C1,C3,C4 |
| GP,C4 |
| C4,C1 |
| S2,S1 |
| RP,SP,GP |
| RP,SP,CP,GP |
| CP,GP,RP,SP |
| GP,C4,S4 |
| S1,C1,C4 |
| S1,S2,C3,C1 |
| R2,R4,R3 |
| CP,GP, RP,SP |
| S2,S1,C1,S5 |
| S2,S1,C1 |
| S1,C1,S4 |
| S1,S2,GP,C4,R2 |
| S1,GP,R2 |
| S1,C6 |
| S1,S2,C1,S4 |
| S2,S3,S5,C1,C3,C4 |
| S2,S5,C1 |
| S2,S3,S5 |
| CP,GP, RP,SP,TP |
| S2,C4,C1 |
| S1,C1,C4,S3 |
| S2,S5 |
| S3,C1 |
| S3,C4 |
| S1,C4 |
| S2,S5,C3,C1 |
| S2,S1,S5,C1,C4 |
| S1,R1,C3 |
| S1,C1,R2 |
| S2,S1,C1,C4 |
| S1,C1,C6 |
| GP,S4,C4,C1,C3 |
| C3,C1,C4 |
| S1,C4,C1 |
| S1,S3 |
| S1,S2,S5,C3,C4 |
| R4,G1 |
| G1,R4 |
| RP,GP |
| R4,GP |
| R3,R2 |
| C6,RP,SP |
| R5,C6 |
| CP,RP,SP |
| RP,SP,CP |
| R3,S5 |
| S1,S2,RP |
| S1,S2,S5,RP |
| S2,S1,RP |
| Rel-9 |
| S3,C6 |
| S1,S2,S3,S5,RP |
| S2,S1,S3 |
| S1,S2,S3 |
| S1,S2,S3,S5 |
| C6,R5 |
| S1,S2,RP,GP |
| S1,S2,S4,S5,RP,GP |
| GP,G2 |
| GP,GP, N1 |
| GP,S2,G1,G2 |
| GP,R2,R3,S2,G1,G2 |
| GP,S2,S5,R2,R3,G2,G1 |
| GP,R3 |
| N4,S2 |
| GP,RP |
| GP,S2,RP |
| G5,G4 |
| G4,R3 |
| S2,R2,R4 |
| S1,S2,R2,R4 |
| GP,S5 |
| S1,S2,S5 |
| R4,R5 |
| R4,R2,R3,R5 |
| S2,S5,N4,RP |
| S1,S2,S3,S5,NP |
| S2,S4,S5 |
| T2,S1,S4,S5 |
| SP,RP |
| S2,RP |
| S1,S2,CP,G2 |
| CP,SP |
| S1,G2 |
| SP,CP |
| S1,S2,S5,C3 |
| S1,C1,S3 |
| G1,G3new |
| C4, C3, C1C4 |
| C4,C3,C1 |
| S1,S2,S3,S5,R2,R3,R4 |
| S1,S2,S3,R2 |
| S2,S3,S5,C4,R2 |
| S1,S5,C1 |
| S1,S2,S3,C1,C3,C4,R2 |
| Ggp |
| S3,S2,C1,C4,G2 G3new |
| R1,R2,R3,R4 |
| R4,R1,R2,R3 |
| R4,R2,R3 |
| S1,C1,C4,R2 |
| R4,R2 |
| S2,C4,R2,R4 |
| S2,C4,R2 |
| S2,S3,S5,C3,C4,R2 |
| S1,S2,S4,T2 |
| S1,S2,S4 |
| S1,S2,S4,R5 |
| S3,S2,C1,C4,G2,G3new |
| GP,C1 |
| S1,S5,C4 |
| S1,S2,S3,S5,R2,R3,R4,GP |
| GP,C4,C3,C1 |
| SMG9 |
| SMG1 |
| SMG2 |
| N3,R5 |
| N1, N2, N4, G1, G2, R3, S1, SMG2 |
| S1,SMG1 |
| SMG1,N4 |
| N1,C1,N4,S1,T2,G2,SMG1,SMG2,SMG3,SMG7,SMG9 |
| SMG1,N2 |
| S1,S2,N2,N4 |
| N4,N2 |
| G1,G2 |
| G1,G2,C1 |
| G1,G2,N1 |
| SMG2, SMG1, SMG3, SMG4, SMG7, SMG9, SMG10, G1, G2, G3, N1, N3, T2 |
| SMG2,G1 |
| S1,G1,G2 |
| SMG1,N1,G1,G2 |
| G2,G1 |
| G1,G2,G3,S1,S2,SMG1,SMG2,SMG7,N1,N2,N3,N4,T2 |
| 23.003, 23.008, 29.060 |
| S1, S2, SMG1, SMG2, SMG12, G2, N1, N2, N4 |
| S1,S2,SMG1,SMG2,SMG12,G2,N1,N2,N4 |
| S1,SMG2,N1,N2,N4 |
| SMG1,T2 |
| S1,N1,N2,N4 |
| S1,S2,N5 |
| SMG2,SMG7,G2,T2 |
| S3,N1,N2,N3 |
| S3,N1,N2,N4 |
| SMG9,T3 |
| SMG2,SMG3,SMG7,G2,N2 |
| SMG2,N1,G1,G2 |
| S1,N2 |
| N1,N3 |
| S2,N1 |
| N1,N2,N4 |
| N2,N1,N4 |
| N2,N4 |
| S1,T3 |
| T2,N3 |
| S3,N2 |
| T2,S1 |
| S1,N4 |
| SMG1,SMG2,SMG7 |
| N1,S1,T1 |
| SMG1,SMG3 |
| N4,S2,N1 |
| S1,S2,SMG1,SMG2,SMG7,G1,G2,G3,N1,N2,N3,N4,T2 |
| SMG1,N3 |
| S1,N3 |
| CP,SP,SMG |
| CP,SP,TP,GP,SMG |
| NP,SP,TP,GP,SMG |
| NP,GP, RP,SP,TP |
| SMG2,SMG1,SMG3,SMG4,SMG7,SMG9,SMG10,G1,G2,G3,N1,N3,T2 |
| S1,N2,N4 |
| S1,S2,S3,C1,C3,C4,R2,R3 |
| R2,R3,R1,R4 |
| R2,R3,R4 |
| R2,R1,R3,R4 |
| S2,C4,R2,R3,R4 |
| S2,C4,R2,R1,R3,R4 |
| S2,S3,S5,C3,C4,R2,R3,R4 |
| R1,R2,R4 |
| R3,R1,R4 |
| S2, |
| S2,G2, |
| S1,S2,G2, |
| S1,S2,G2,R2,R3, |
| S1,S2,C4,G2,R2,R3 |
| S1,S2,N4,G2,R2,R3 |
| S1,S2,SMG1,SMG2,SMG12,G2,N1,N2,N4,R2,R3 |
| S1,SMG1,T2 |
| S1,SMG1,S2 |
| S1,N4,N2 |
| T2,N1,N3 |
| S3,N2,N4 |
| SMG1,SMG2,SMG3,SMG7,SMG9,N1,C1,N4,S1,T2,G2 |
| SMG1,N2,N4 |
| S2,T2,N1,N2,N4 |
| S1,T2 |
| S1,S2,C4 |
| S1,S2,N4,RP |
| S2,N4 |
| S1,S2,N3,N4,RP |
| S1,S2,SMG1,SMG2,SMG12,T2,G2,N1,N2,N4,R2,R3 |
| S1,T2,N1,N3 |
| S1,S2,SMG1,SMG2,SMG12,T2,G2,N1,N2,N3,N4,R2,R3 |
| S1,S2,S3,SMG1,SMG2,SMG12,G2,N1,N2,N4,R2,R3 |
| S1,S2,SMG,G1,G2,G3,N1,N2,N3,N4,T2 |
| S1,S2,SMG,T2,G2,N1,N2,N3,N4,R2,R3 |
| S1,S3,SMG,G1,G2,G3,N1,N2,N3,N4,T2 |
| S1,S3,T2,N2,N4 |
| S1,S2,SMG,T2,G1,G2,G3,N1,N2,N3,N4 |
| G2,S2 |
| T1,R5 |
| R5,T1 |
| S1,S2,S4,T1,R5 |
| S1,S2,S4,S5,T1,RP,GP |
| S1,S2,S3,S5,R2,R3,R4,GP,C1 |
| S1,S2,S3,SMG1,SMG2,SMG12,N1,N2,N4,R2,R3 |
| S1,S2,SMG,T2,N1,N2,N3,N4,R2,R3 |
| NP,SP,TP,SMG |
| S1,S2,SMG,T2,N1,N2,N3,N4 |
| SMG,N1 |
| SMG |
| S1,S2,SMG1,SMG2,SMG7,N1,N2,N3,N4,T2 |
| SMG2,SMG1,SMG3,SMG4,SMG7,SMG9,SMG10,N1,N3,T2 |
| S1,SMG |
| SMG2,SMG7,T2 |
| SMG2,S2 |
| N1,N2,N4,R3,S1,SMG |
| SMG2,SMG3,SMG7,N2 |
| SMG1,SMG2,SMG3,SMG7,SMG9,N1,C1,N4,S1,T2 |
| S1,S2,SMG,N3,N4,RP |
| S1,S2,S4,SMG,N3,N4,RP |
| S2,C1,C4,R2,R1,R3,R4 |
| R2,S2,S4 |
| G3new,R5 |
| GP,R4 |
| S2,S4,R2 |
| SP,GP |
| RP,SP |
| S2,S1,S3,S5 |
| S3,S1 |
| N4,N1,N2,S2 |
| S2,G1,G2,R2,R3 |
| S2,G1,G2 |
| G1,G2,R2,R3 |
| N4,T3 |
| S3,S2,N1,N4,T3,OMA |
| T2,S1,S4,S5,OMA |
| S2,N3 |
| S4,S1 |
| N4,N3,S1 |
| R5,G3new |
| R4,R2,R1 |
| S2,R2 |
| C3, C4,C1 |
| S3,C1,C4,C3 |
| C1,C4,C3 |
| S2,C1,C4,C3 |
| R3,R5 |
| S1,S2,C3 |
| R1,R2 |
| S3,C1,C4,G2,G3new |
| R1,R3 |

## Schedule

| ID | WBS | Task | Type | Duration | Start | Finish | Complete | Remaining | Baseline start | Baseline finish | Baseline duration | Total slack | Constraint | Resources | Work | Actual work | Text6 | Text1 | Text2 | Text4 | Text5 | Text7 | Text8 |
| --- | --- | --- | --- | --- | --- | --- | --- | --- | --- | --- | --- | --- | --- | --- | --- | --- | --- | --- | --- | --- | --- | --- | --- |
| 1 | 1 | Version 2010 Feb 14 |  | 3318d? | 1998-12-07 | 2011-08-22 |  |  | 1998-12-07 | 2011-08-22 | 3318d? | 19d | start no earlier than 1998-12-07 |  |  |  |  |  |  |  |  |  |  |
| 2 | 2 | 2 Rel-9 SA3 Stage 2 exceptions to 03/2010 | milestone | 0d? | 1998-12-07 | 1998-12-07 |  |  | 1998-12-07 | 1998-12-07 | 0d? | 3337d | finish no earlier than 1998-12-07 |  |  |  |  |  |  |  |  |  |  |
| 3 | 3 | 59 Rel-9 Stage 3 exceptions to 03/2010 | milestone | 0d | 1998-12-07 | 1998-12-07 |  |  | 1998-12-07 | 1998-12-07 | 0d | 3337d | finish no earlier than 1998-12-07 |  |  |  |  |  |  |  |  |  |  |
| 4 | 4 | "CTRL + a" to display all the 3GPP fields | milestone | 0d | 1998-12-07 | 1998-12-07 |  |  | 1998-12-07 | 1998-12-07 | 0d | 3337d | finish no earlier than 1998-12-07 |  |  |  |  |  |  |  |  |  |  |
| 5 | 5 | Gantt: dark blue=done; light blue=to be done; grey: previous values; black=summary | milestone | 0d? | 1998-12-07 | 1998-12-07 |  |  | 1998-12-07 | 1998-12-07 | 0d? | 3337d | finish no earlier than 1998-12-07 |  |  |  |  |  |  |  |  |  |  |
| 7 | 6 | Release 11 Studies | milestone | 0d? | 2000-01-01 | 2000-01-01 |  |  | 2000-01-01 | 2000-01-01 | 0d? | 3057d | start no earlier than 2000-01-01 | SP |  |  | Rel-11 |  |  |  |  |  |  |
| 8 | 7 | Study on Non Voice Emergency Services |  | 206d? | 2009-12-10 | 2010-09-23 |  |  | 2009-12-10 | 2010-09-23 | 206d? | 256d | start no earlier than 2009-12-10 | S1 | 1648h |  | Rel-11 | FS_NOVES | PCG-24 | Qualcomm Europe | dwilliams@qualcomm.com | SP-46 | Alain |
| 9 | 8 | Study on UICC/USIM enhancements |  | 206d? | 2009-12-10 | 2010-09-23 |  |  | 2009-12-10 | 2010-09-23 | 206d? | 256d | start no earlier than 2009-12-10 | S1 | 1648h |  | Rel-11 | FS_U2e | PCG-24 | Giesecke & Devrient | Ilario Macchi | SP-46 | Alain |
| 10 | 9 | Release 10 Features | milestone | 0d? | 2000-01-01 | 2000-01-01 |  |  | 2000-01-01 | 2000-01-01 | 0d? | 3057d |  | CP,RP,SP |  |  | Rel-10 |  |  |  |  |  |  |
| 11 | 10 | **Extended H(e)NB features** |  | 467d? | 2008-12-11 A | 2010-09-23 | 32% | 316.26d? | 2008-12-11 | 2010-09-23 | 467d? | 256d |  | S1,S2 | 7012.8h | 1541.6h | Rel-10 | EHNBF | PCG-23 | NEC | joerg.swetina@nw.neclab.eu | SP-45 | Alain |
| 12 | 10.1 | Stage 1 of Extended H(e)NB features |  | 131d? | 2009-09-24 A | 2010-03-25 | 5% | 124.7d? | 2009-09-24 | 2010-03-25 | 131d? | 386d | finish no earlier than 2010-03-25 | S1 | 1048h | 50.4h | Rel-10 | EHNBF | PCG-23 | NEC | joerg.swetina@nw.neclab.eu | SP-45 | Alain |
| 13 | 10.2 | IMS aspects of Architecture for Home NodeB |  | 466d? | 2008-12-11 A | 2010-09-23 | 40% | 279.6d? | 2008-12-11 | 2010-09-23 | 466d? | 256d | finish no earlier than 2010-09-23 | S2 | 3728h | 1491.2h | Rel-10 | EHNB-IMS | PCG-22 | Alcatel-Lucent | Nicolas Drevon | SP-42 | Maurice |
| 14 | 11 | **Network Improvements for Machine-Type Communications** |  | 523d? | 2008-09-18 A | 2010-09-17 | 39% | 320.49d? | 2008-09-18 | 2010-09-17 | 523d? | 260d |  | S1,S2,S3 | 10929.2h | 4231.94h | Rel-10 | NIMTC | PCG-21 | KPN | Toon Norp (toon.norp AT tno.nl) | SP-41 | Alain |
| 15 | 11.1 | Stage 1 for NIMTC |  | 397d? | 2008-09-18 A | 2010-03-25 | 79% | 83.37d? | 2008-09-18 | 2010-03-25 | 397d? | 386d | finish no earlier than 2009-12-10 | S1 | 3176h | 2509.04h | Rel-10 | NIMTC | PCG-21 | KPN | Toon Norp (toon.norp AT tno.nl) | SP-41 | Alain |
| 16 | 11.2 | Stage 2 for NIMTC |  | 257d? | 2009-09-24 A | 2010-09-17 | 5% | 244.15d? | 2009-09-24 | 2010-09-17 | 257d? | 260d | finish no earlier than 2010-09-17 | S2 | 2056h | 102.8h | Rel-10 | NIMTC | PCG-23 | Samsung | Erik Guttman (erik.guttman@partner.samsung.com) | SP-45 | Maurice |
| 17 | 11.3 | Security for NIMTC |  | 189.15d? | 2009-12-10 | 2010-09-17 |  |  | 2009-12-10 | 2010-09-17 | 189.15d? | 260d | start no earlier than 2009-12-10 | S3 | 1513.2h |  | Rel-10 | NIMTC | PCG-24 | Samsung | Rajavelsamy R (rajvel@samsung.com) | SP-46 | Dionisio |
| 18 | 12 | **GTP-based S8 chaining** |  | 327d? | 2008-12-11 A | 2010-03-11 | 35% | 212.55d? | 2008-12-11 | 2010-03-11 | 327d? | 396d |  | S2 | 5232h | 1831.2h | Rel-10 | GTPchaining | PCG-22 | Huawei | Haining Wang (wanghaining@huawei.com) | SP-42 | Maurice |
| 19 | 12.1 | Stage 2 for GTPchaining |  | 327d? | 2008-12-11 A | 2010-03-11 | 35% | 212.55d? | 2008-12-11 | 2010-03-11 | 327d? | 396d | finish no earlier than 2010-03-11 | S2 | 2616h | 915.6h | Rel-10 | GTPchaining | PCG-22 | Huawei | Haining Wang (wanghaining@huawei.com) | SP-42 | Maurice |
| 20 | 13 | Multi Access PDN Connectivity |  | 261d? | 2009-03-13 A | 2010-03-11 | 75% | 65.25d? | 2009-03-13 | 2010-03-11 | 261d? | 396d | finish no earlier than 2010-03-11 | S2 | 2088h | 1566h | Rel-10 | MAPCON | PCG-22 | Telecom Italia | ivano.guardini@telecomitalia.it | SP-43 | Maurice |
| 21 | 14 | **IMS Service Continuity – Inter Device Transfer enhancements** |  | 266d? | 2009-06-04 A | 2010-06-10 | 58% | 113d? | 2009-06-04 | 2010-06-10 | 266d? | 331d |  | S1,S2 | 5304h | 2466.8h | Rel-10 | IMS_SC_eIDT | PCG-23 | Huawei | Amar Deol (adeol@huawei.com) | SP-44 | Alain |
| 22 | 14.1 | Stage 1 for IMS_SC_eIDT |  | 211d? | 2009-06-04 A | 2010-03-25 | 95% | 10.55d? | 2009-06-04 | 2010-03-25 | 211d? | 386d | finish no earlier than 2010-03-25 | S1 | 1688h | 1603.6h | Rel-10 | IMS_SC_eIDT | PCG-23 | Huawei | Amar Deol (adeol@huawei.com) | SP-44 | Alain |
| 23 | 14.2 | IMS Inter-UE Transfer enhancements (Stage 2) |  | 186d? | 2009-09-24 A | 2010-06-10 | 15% | 158.1d? | 2009-09-24 | 2010-06-10 | 186d? | 331d | finish no earlier than 2010-06-10 | S2 | 1488h | 223.2h | Rel-10 | IMS_SC_eIDT | PCG-23 | Huawei | HengLiang Zhang (hl_zhang@huawei.com) | SP-45 | Maurice |
| 24 | 15 | **IP-Short-Message-Gateway enhancements for CPM-SMS Interworking** |  | 192d? | 2009-09-24 A | 2010-06-18 | 52% | 93.08d? | 2009-09-24 | 2010-06-18 | 192d? | 325d |  | S1,S2,C3 | 5192.8h | 2242.48h | Rel-10 | CPM-SMS | PCG-23 | China Mobile | Qing Huang | SP-45 | Alain |
| 25 | 15.1 | Stage 1 for CPM-SMS |  | 131d? | 2009-09-24 A | 2010-03-25 | 95% | 6.55d? | 2009-09-24 | 2010-03-25 | 131d? | 386d | finish no earlier than 2010-03-25 | S1 | 1048h | 995.6h | Rel-10 | CPM-SMS | PCG-23 | China Mobile | Qing Huang | SP-45 | Alain |
| 26 | 15.2 | Stage 2 for CPM-SMS |  | 185.1d? | 2009-09-24 A | 2010-06-10 | 60% | 74.04d? | 2009-09-24 | 2010-06-10 | 185.1d? | 331d | finish no earlier than 2010-06-10 | S2 | 1480.8h | 888.48h | Rel-10 | CPM-SMS | PCG-23 | Orange | Antoine Mouquet | SP-45 | Maurice |
| 27 | 15.3 | Stage 3 for CPM-SMS |  | 141d? | 2009-12-04 | 2010-06-18 |  |  | 2009-12-04 | 2010-06-18 | 141d? | 325d | finish no earlier than 2010-06-18 | C3 | 1128h |  | Rel-10 | CPM-SMS | PCG-24 | Ericsson | Jan Holm | CP-46 | Gwiho |

Notes:
- 1: -
- 2: -
- 3: -
- 4: -
- 5: -
- 7: -
- 8: - / Text3: 22.8xx Study on Non Voice Emergency Services
- 9: Triggered by GSMA Smart SIM and 3GNBK projects, and to evolve from traditional USAT to multimedia USIM toolkit support, particularly to Smart Card Web Server / Text3: 22.8xx Study on UICC/USIM enhancements
- 10: -
- 11: Items beyond Rel-9 UID_400035 Enhanced Home NodeB / eNodeB (EHNB)
- 12: - / Text3: 22.220
- 13: SP#46 completion 06/10 (was 12/09)=>09/10 / Text3: new 23.832, 23.232
- 14: SP#46 updated WID SP-090658 =>SP-090832 (added SA3 part). Stage 2 completion 06/10=>09/10. Triggered by Rel-8 UID_7027 Study on Facilitating Machine to Machine Communication in GSM and UMTS (FS_M2M) TR 22.868
- 15: - / Text3: new 22.368
- 16: SP#46 Stage 2 completion 06/10=>09/10 / Text3: new 23.888 (Architectural Enhancements for machine-type communications)
- 17: SP#46 updated WID SP-090658=>SP-090832 (added SA3 part) / Text3: new 33.868
- 18: Stage 1 in UID_320022 Rel-8 Requirements for evolution of the 3GPP system architecture (AIPN-SAE): 22.278, 22.011, 22.246
- 19: SP#46 completion 12/09=>09/10 / Text3: 23.402 (Chaining GTP-S8 based architecture and procedures)
- 20: SP#45 WID updated SP-090100=>SP-090659. Triggered by TR 23.861 UID_410043 FS_MAPIM. Stage 1 in Rel-9 22.278 (6.2 - IP session control) / Text3: 23.401, 23.402, 23.237
- 21: Rel-9 set Inter-Device Transfer requirements UID_410033 (IMS_SCC-IDT). Add additional scenarios and requirements for IDT.
- 22: - / Text3: 22.228
- 23: - / Text3: 23.237, 23.292, new 23.831
- 24: IP-SM-GW enhancements for interworking with OMA CPM
- 25: External requirements (Stage 1 in OMA-RD-CPM-V1_0-20090310-C) / Text3: 22.340
- 26: SP#46 TR 23.824v100 for Information / Text3: 23.204, new TR 23.824
- 27: Linked to Rel-8 UID_340031 Service-Level Interworking for Messaging Services (MESSIW) 23.204 / Text3: 29.311

| ID | WBS | Task | Duration | Start | Finish | Complete | Remaining | Baseline start | Baseline finish | Baseline duration | Total slack | Constraint | Resources | Work | Actual work | Text1 | Text2 | Text4 | Text6 | Text7 | Text8 |
| --- | --- | --- | --- | --- | --- | --- | --- | --- | --- | --- | --- | --- | --- | --- | --- | --- | --- | --- | --- | --- | --- |
| 28 | 16 | **Completion of Communications on Not Logged-in** | 1d? | 2009-09-24 A | 2009-09-24 A | 100% |  | 2009-09-24 | 2009-09-24 | 1d? |  |  | S1 | 16h | 16h | CCNL | PCG-23 | Deutsche Telekom | Rel-10 | SP-45 | Alain |
| 29 | 16.1 | Stage 1 for CCNL | 1d? | 2009-09-24 A | 2009-09-24 A | 100% |  | 2009-09-24 | 2009-09-24 | 1d? |  | start no earlier than 2009-09-24 | S1 | 8h | 8h | CCNL | PCG-23 | Deutsche Telekom | Rel-10 | SP-45 | Alain |
| 30 | 17 | **Local IP Access and Selected Internet IP Traffic Offload** | 321d? | 2009-09-24 A | 2010-12-16 | 13% | 277.8d? | 2009-09-24 | 2010-12-16 | 321d? | 196d |  | S2,S1,S3,S5 | 13384h | 1455.6h | LIPA_SIPTO | PCG-23 | Huawei, China Mobile | Rel-10 | SP-45 | Maurice |
| 31 | 17.1 | TR on LIPA_SIPTO | 186d? | 2009-09-24 A | 2010-06-10 | 45% | 102.3d? | 2009-09-24 | 2010-06-10 | 186d? | 331d | finish no earlier than 2010-06-10 | S2 | 1488h | 669.6h | LIPA_SIPTO | PCG-23 | Huawei, China Mobile | Rel-10 | SP-45 | Maurice |
| 32 | 17.2 | Stage 1 for LIPA_SIPTO | 131d? | 2009-09-24 A | 2010-03-25 | 75% | 32.75d? | 2009-09-24 | 2010-03-25 | 131d? | 386d | finish no earlier than 2010-03-25 | S1 | 1048h | 786h | LIPA_SIPTO | PCG-23 | Huawei, China Mobile | Rel-10 | SP-45 | Alain |
| 33 | 17.3 | Stage 2 for LIPA_SIPTO | 257d? | 2009-09-24 | 2010-09-17 |  |  | 2009-09-24 | 2010-09-17 | 257d? | 260d | finish no earlier than 2010-09-17 | S2 | 2056h |  | LIPA_SIPTO | PCG-23 | Huawei, China Mobile | Rel-10 | SP-45 | Maurice |
| 34 | 17.4 | Security for LIPA_SIPTO | 256d? | 2009-09-24 | 2010-09-16 |  |  | 2009-09-24 | 2010-09-16 | 256d? | 261d | finish no earlier than 2010-09-16 | S3 | 2048h |  | LIPA_SIPTO | PCG-23 | Huawei, Qualcomm Europe | Rel-10 | SP-45 | Dionisio |
| 35 | 17.5 | OAM&P for LIPA_SIPTO | 256d? | 2009-09-24 | 2010-09-16 |  |  | 2009-09-24 | 2010-09-16 | 256d? | 261d | finish no earlier than 2010-09-16 | S5 | 2048h |  | LIPA_SIPTO | PCG-23 | Huawei, China Mobile | Rel-10 | SP-45 | Dionisio |
| 36 | 17.6 | Charging for LIPA_SIPTO | 266d? | 2009-12-10 | 2010-12-16 |  |  | 2009-12-10 | 2010-12-16 | 266d? | 196d | finish no earlier than 2010-12-16 | S5 | 2128h |  | LIPA_SIPTO | PCG-24 | Huawei, China Mobile | Rel-10 | SP-46 | Dionisio |
| 37 | 18 | **IP Flow Mobility and seamless WLAN offload** | 186d? | 2009-09-24 A | 2010-06-10 | 46% | 100.07d? | 2009-09-24 | 2010-06-10 | 186d? | 331d |  | S2,S1 | 3424h | 1581.83h | IFOM | PCG-23 | Qualcomm Europe | Rel-10 | SP-45 | Maurice |
| 38 | 18.1 | Stage 1 for IFOM | 56d? | 2009-09-24 A | 2009-12-10 A | 100% |  | 2009-09-24 | 2009-12-10 | 56d? |  | finish no earlier than 2009-12-10 | S1 | 448h | 448h | IFOM | PCG-23 | Qualcomm Europe | Rel-10 | SP-45 | Alain |
| 39 | 18.2 | Stage 2 for IFOM | 186d? | 2009-09-24 A | 2010-06-10 | 30% | 130.2d? | 2009-09-24 | 2010-06-10 | 186d? | 331d | finish no earlier than 2010-06-10 | S2 | 1488h | 446.4h | IFOM | PCG-23 | Qualcomm Europe | Rel-10 | SP-45 | Maurice |
| 40 | 19 | **Enabling Coder Selection and Rate Adaptation for UTRAN and E-UTRAN for Load Adaptive Applications** | 257d? | 2009-09-24 A | 2010-09-17 | 2% | 251.6d? | 2009-09-24 | 2010-09-17 | 257d? | 260d |  | S2,S4,R2 | 5600h | 117.56h | ECSRA_LAA | PCG-23 | Qualcomm Europe | Rel-10 | SP-45 | Maurice |
| 41 | 19.1 | TR on ECSRA_LAA | 186d? | 2009-09-24 A | 2010-06-10 | 5% | 176.7d? | 2009-09-24 | 2010-06-10 | 186d? | 331d | finish no earlier than 2010-06-10 | S2,S4,R2 | 1488h | 74.4h | ECSRA_LAA | PCG-23 | Qualcomm Europe | Rel-10 | SP-45 | Maurice |
| 42 | 19.2 | Stage 2 for ECSRA_LAA | 257d? | 2009-09-24 | 2010-09-17 |  |  | 2009-09-24 | 2010-09-17 | 257d? | 260d | finish no earlier than 2010-09-17 | S2 | 2056h |  | ECSRA_LAA | PCG-23 | Qualcomm Europe | Rel-10 | SP-45 | Maurice |
| 43 | 20 | Support BroadBand Forum (BBF) Accesses Interworking | 76d? | 2009-12-10 | 2010-03-25 |  |  | 2009-12-10 | 2010-03-25 | 76d? | 386d | start no earlier than 2009-12-10 | S1 | 608h |  | BBAI | PCG-24 | Ericsson | Rel-10 | SP-46 | Alain |
| 44 | 21 | Optimal Media Routeing | 76d? | 2009-12-10 | 2010-03-25 |  |  | 2009-12-10 | 2010-03-25 | 76d? | 386d | finish no earlier than 2010-03-25 | S2 | 608h |  | OMR | PCG-24 | Alcatel-Lucent | Rel-10 | SP-46 | Maurice |
| 45 | 22 | Enhanced Multimedia Priority Service - Phase 2 | 137d? | 2009-12-10 | 2010-06-18 |  |  | 2009-12-10 | 2010-06-18 | 137d? | 325d | finish no earlier than 2010-06-18 | S2 | 1096h |  | PRIOR2 | PCG-24 | Telcordia, NTT DoCoMo | Rel-10 | SP-46 | Maurice |
| 46 | 23 | EEA3 and EIA3 (new Encryption & Integrity EPS security algorithms) | 401d? | 2009-06-04 | 2010-12-16 |  |  | 2009-06-04 | 2010-12-16 | 401d? | 196d | finish no earlier than 2010-12-16 | S3 | 3208h |  | EEA3_EIA3 | PCG-23 | CATR | Rel-10 | SP-44 | Dionisio |
| 47 | 24 | **OAM&P 10** | 332d? | 2009-12-10 | 2011-03-18 |  |  | 2009-12-10 | 2011-03-18 | 332d? | 130d |  | S5 | 14352h |  | OAM10 | PCG-24 |  | Rel-10 | SP-46 | Dionisio |
| 48 | 24.1 | **Network Infrastructure Management** | 332d? | 2009-12-10 | 2011-03-18 |  |  | 2009-12-10 | 2011-03-18 | 332d? | 130d |  | S5 | 5312h |  | OAM10-NIM | PCG-24 |  | Rel-10 | SP-46 | Dionisio |
| 49 | 24.1.1 | Common RAT Network Resource Model (NRM) | 332d? | 2009-12-10 | 2011-03-18 |  |  | 2009-12-10 | 2011-03-18 | 332d? | 130d | finish no earlier than 2011-03-18 | S5 | 2656h |  | RAT_NRM_common | PCG-24 | Ericsson | Rel-10 | SP-46 | Dionisio |
| 50 | 24.2 | **Self-Organizing Networks (SON) - OAM aspects** | 266d? | 2009-12-10 | 2010-12-16 |  |  | 2009-12-10 | 2010-12-16 | 266d? | 196d |  | S5 | 6384h |  | OAM10-SON | PCG-24 |  | Rel-10 | SP-46 | Dionisio |
| 51 | 24.2.1 | SON Self-optimization management continuation | 266d? | 2009-12-10 | 2010-12-16 |  |  | 2009-12-10 | 2010-12-16 | 266d? | 196d | finish no earlier than 2010-12-16 | S5 | 2128h |  | LTE-SON-OAM_SO | PCG-24 | Huawei | Rel-10 | SP-46 | Dionisio |
| 52 | 24.2.2 | SON Self-healing management | 266d? | 2009-12-10 | 2010-12-16 |  |  | 2009-12-10 | 2010-12-16 | 266d? | 196d | finish no earlier than 2010-12-16 | S5 | 2128h |  | LTE-SON-OAM_SH | PCG-24 | ZTE | Rel-10 | SP-46 | Dionisio |
| 53 | 25 | Definition of 3GPP UICC services over the new high-speed interface | 786d? | 2007-12-10 A | 2010-12-10 | 15% | 666.6d? | 2007-12-10 | 2010-12-10 | 786d? | 200d | finish no earlier than 2010-12-10 | C6 | 6288h | 955.2h | UICCHS | PCG-21 | Gemalto | Rel-10 | CP-38 | Xavier |

Notes:
- 28: SP#45 WID approved. Stage 1 completed / Text5: Kurt Bischinger
- 29: SP#45 WID approved. Stage 1 completed / Text3: 22.173 CR#0056r1 Call Completion on Not Logged in (CCNL) / Text5: Kurt Bischinger
- 30: SP#46 updated WID SP-090618=>SP-090761 (added SA5 aspects). UID_400035 Enhanced Home NodeB/eNodeB (EHNB) formerly covered Local IP Access to Internet and Local access to Home Network from the Home NodeB/eNodeB Features now covered by this WI / Text5: patrice.hede@huawei.com, Tao Sun (suntao@chinamobile.com)
- 31: SP#46 completion 03/10=>06/10 / Text3: new 23.829 / Text5: patrice.hede@huawei.com, Tao Sun (suntao@chinamobile.com)
- 32: - / Text3: 22.101, 22.220 / Text5: Amar Deol (adeolf@huawei.com), Gang Li (ligangyf@chinamobile.com)
- 33: SP#46 completion 06/10=>09/10 / Text3: 23.060, 23.203, 23.401 / Text5: patrice.hede@huawei.com, Tao Sun (suntao@chinamobile.com)
- 34: - / Text3: 33.102, 33.107, 33.108, 33.320, 33.401 / Text5: Marcus Wong (mwong@huawei.com), Brian Rosenberg (bmr@qualcomm.com)
- 35: SP#46 updated WID SP-090618=>SP-090761 (added SA5 aspects) / Text3: 32.101, 32.102, 32.405, 32.425, 32.452, 32.453, 32.581, 32.582, 32.583, 32.584, 32.591, 32.592, 32.593, 32.594, 32.64x, 32.76x / Text5: Zou Lan (zlan@huawei.com), Chen Gang (chengang@chinamobile.com)
- 36: SP#46 updated WID SP-090618=>SP-090761 (added SA5 aspects) / Text3: 32.240, 32.251, 32.298, 32.299 / Text5: shan.mingjun@huawei.com, Ai Chen (chenai@chinamobile.com)
- 37: SP#46 WID updated SP-090616=>SP-090804. Triggered by Rel-10 TR 23.861 (UID_410043 Study on Multi Access PDN connectivity and IP flow mobility - MAPIM) / Text5: Gerardo Giaretta (gerardo@qualcomm.com)
- 38: SP#46 completed / Text3: 22.278 / Text5: David Williams (dwilliam@qualcomm.com)
- 39: SP#46 WID nupdated SP-090616=>SP-090804. / Text3: 23.203, 23.402, new TS 23.261 (IP Flow Mobility and Seamless WLAN Offload) / Text5: Gerardo Giaretta (gerardo@qualcomm.com)
- 40: Triggered by Rel-9 UID_440013 Vocoder rate adaptation for LTE / Text5: AC Mahendran (ac@qualcomm.com)
- 41: Needs Liaison with SA4, RAN2 / Text3: new 23.860 / Text5: AC Mahendran (ac@qualcomm.com)
- 42: SP#46 completion 06/10=>09/10 / Text3: 23.060, 23.203, 23.228, 23.401 / Text5: AC Mahendran (ac@qualcomm.com)
- 43: Triggered by BBF WT 203. Interworking between the 3GPP EPS and the fixed broadband accesses as defined by BBF / Text3: 22.278 / Text5: Peter Bleckert
- 44: Triggered by TR 23.894 (UID_370050 Study on System enhancements for the use of IMS services in local breakout) / Text3: 23.228 (IMS Stage 2) / Text5: andy.bennett@alcatel-lucent.com
- 45: - / Text3: 23.203, 23.272, 23.401, new TR 23.8yz (Enhanced Multimedia Priority Service for E-UTRAN) / Text5: Vijay Varma, Katsutoshi Nishida
- 46: develop new EPS algorithms acceptable to regions such as China / Text3: 35.xxx (EEA3 & EIA3 Algorithm Specification, Implementers’ test data, Design and evaluation report, Final project report), 33.401 (SAE Security Architecture) / Text5: Yuan Qi, yuanqi@mail.ritt.com.cn
- 47: -
- 48: -
- 49: To reduce costs, some equipment can be shared between several RATs, e.g. RET, TMA and repeaters. With existing modelling it is very difficult for an operator to see that several cells are affected when an antenna tilt is changed etc / Text3: new (TR 32.9xx, TSs 32.7x1, 32.7x2, 32.7x3, 32.7x5), 32.615, 32.642, 32.643, 32.645, 32.652, 32.653, 32.655, 32.762, 32.763, 32.765 / Text5: Robert Petersen
- 50: umbrella BB
- 51: Continuation of Rel-9 work UID_390007 SON self-optimization management / Text3: 32.425, 32.521, 32.522, 32.752, 32.753, 32.755, 32.762, 32.763, 32.765 / Text5: Lan Zou (zlan@huawei.com)
- 52: Work moved to Rel-10 after split of the Rel-9 UID_390007 SON self-optimization (removed Self-Healing handling) / Text3: new TS (32.541, 32.542, 32.543), 32.752, 32.753, 32.755, 32.762, 32.763, 32.765 / Text5: zhu.weihong@zte.com.cn
- 53: CP#46 moved to Rel-10. Provide updated WID at CP#47 / Text3: 31.xyz / Text5: Denis L'Heriteau

| ID | WBS | Task | Duration | Start | Finish | Complete | Remaining | Baseline start | Baseline finish | Baseline duration | Total slack | Constraint | Resources | Work | Actual work | Text1 | Text2 | Text4 | Text5 | Text6 | Text7 | Text8 | Text11 |
| --- | --- | --- | --- | --- | --- | --- | --- | --- | --- | --- | --- | --- | --- | --- | --- | --- | --- | --- | --- | --- | --- | --- | --- |
| 54 | 26 | **UMTS/LTE 3500 MHz** | 657d? | 2007-11-30 A | 2010-06-04 | 26% | 486.6d? | 2007-11-30 | 2010-06-04 | 657d? | 335d |  | R4,R2,R3,R5 | 13754h | 3567.27h | RInImp8-UMTSLTE3500 | PCG-21 | Ericsson | Jjohan.skold@ericsson.com | Rel-10 | RP-38 | Issam |  |
| 55 | 26.1 | UMTS/LTE 3500 MHz | 645d? | 2007-11-30 A | 2010-06-04 | 55% | 290.25d? | 2007-11-30 | 2010-06-04 | 645d? | 335d | finish no earlier than 2010-06-04 | R4,R2,R3 | 5160h | 2838h | RInImp8-UMTSLTE3500 | PCG-21 | Ericsson | Jjohan.skold@ericsson.com | Rel-10 | RP-38 | Issam | RP-091032 |
| 56 | 26.2 | Conformance Test Aspects – LTE 3500 | 392d? | 2008-12-05 A | 2010-06-04 | 2% | 383.96d? | 2008-12-05 | 2010-06-04 | 392d? | 335d | finish no earlier than 2010-06-04 | R5 | 3136h | 64.32h | LTE-UEConTest_LTE3500 | PCG-22 | Ericsson | fredrik.sundstrom@ericsson.com | Rel-10 | RP-42 | Ingbert | RP-091063 |
| 57 | 26.3 | Conformance Test Aspects – UMTS 3500 | 392d? | 2008-12-05 A | 2010-06-04 | 2% | 384.16d? | 2008-12-05 | 2010-06-04 | 392d? | 335d | finish no earlier than 2010-06-04 | R5 | 3136h | 62.72h | RInImp-UEConTest_UMTS3500 | PCG-22 | Nokia | jukka.vikstedt@nokia.com | Rel-10 | RP-42 | Ingbert | RP-091064 |
| 58 | 27 | 1.28 Mcps TDD Repeater | 654d? | 2007-12-04 A | 2010-06-04 | 85% | 98.1d? | 2007-12-04 | 2010-06-04 | 654d? | 335d | finish no earlier than 2010-06-04 | R4 | 5232h | 4447.2h | RANimp-Repeaters1.28TDD | PCG-21 | RITT | qinyan@chinattl.com | Rel-10 | RP-38 | Issam | RP-091053 |
| 59 | 28 | 1.28 Mcps TDD Multi-carrier HSUPA | 321d? | 2009-09-18 A | 2010-12-10 | 5% | 305.2d? | 2009-09-18 | 2010-12-10 | 321d? | 200d | finish no earlier than 2010-12-10 | R1,R2,R3,R4 | 2568h | 126.4h | TDD_MC_HSUPA | PCG-23 | CATR | Aihui Song (songaihui@mail.ritt.com.cn) | Rel-10 | RP-45 | Patrick | RP-091056 |
| 60 | 29 | **1.28 Mcps TDD Home NodeB RF requirements** | 266d? | 2009-12-04 | 2010-12-10 |  |  | 2009-12-04 | 2010-12-10 | 266d? | 200d |  | R4 | 5384h |  | HNB_LCRTDD_RF | PCG-24 | TD Tech | Li Rong (lirong@td-tech.com) | Rel-10 | RP-46 | Issam |  |
| 61 | 29.1 | Core - 1.28 Mcps TDD Home NodeB RF requirements | 141d? | 2009-12-04 | 2010-06-18 |  |  | 2009-12-04 | 2010-06-18 | 141d? | 325d | finish no earlier than 2010-06-18 | R4 | 1128h |  | HNB_LCRTDD_RF-Core | PCG-24 | TD Tech | Li Rong (lirong@td-tech.com) | Rel-10 | RP-46 | Issam |  |
| 62 | 29.2 | Perf - 1.28 Mcps TDD Home NodeB RF requirements | 266d? | 2009-12-04 | 2010-12-10 |  |  | 2009-12-04 | 2010-12-10 | 266d? | 200d | finish no earlier than 2010-12-10 | R4 | 2128h |  | HNB_LCRTDD_RF-Perf | PCG-24 | TD Tech | Li Rong (lirong@td-tech.com) | Rel-10 | RP-46 | Issam |  |
| 63 | 30 | UTRAN 2 ms TTI uplink range improvement | 402d? | 2009-03-06 A | 2010-09-17 | 8% | 369.84d? | 2009-03-06 | 2010-09-17 | 402d? | 260d | finish no earlier than 2010-09-17 | R1,R2,R3,R4 | 3216h | 257.28h | RANimp-2mTTI_ULimp | PCG-22 | Nokia Siemens Networks | Karri Ranta-aho (karri.ranta-aho@nsn.com) | Rel-10 | RP-43 | Patrick | RP-091054 |
| 64 | 31 | A-GNSS Minimum Performance for UTRAN | 261d? | 2009-09-18 | 2010-09-17 |  |  | 2009-09-18 | 2010-09-17 | 261d? | 260d | finish no earlier than 2010-09-17 | R4 | 2088h |  | AGNSSPerf_UTRAN | PCG-23 | Thales | Michel.monnerat@thalesaleniaspace.com | Rel-10 | RP-45 | Issam | RP-091055 |
| 65 | 32 | UE Over The Air (Antenna) conformance testing methodology - Laptop mounted equipment Free Space test | 521d? | 2009-09-18 A | 2011-09-16 | 5% | 494.95d? | 2009-09-18 | 2011-09-16 | 521d? | 0d | finish no earlier than 2011-09-16 | R4 | 4168h | 208.4h | UEAnt_FSTest | PCG-23 | CATR | Guo Lin (guolin@emcite.com) | Rel-10 | RP-45 | Issam | RP-091057 |
| 66 | 33 | **Inclusion of "RF Pattern Matching Technologies" as positioning method in the UTRAN** | 141d? | 2009-12-04 | 2010-06-18 |  |  | 2009-12-04 | 2010-06-18 | 141d? | 325d |  | R2,R3 | 2256h |  | LCS_UMTS_RFPMT | PCG-24 | Polaris Wireless | Norman Shaw | Rel-10 | RP-46 | Joern |  |
| 67 | 33.1 | Core - Inclusion of “RF Pattern Matching Technologies” as positioning method in the UTRAN | 141d? | 2009-12-04 | 2010-06-18 |  |  | 2009-12-04 | 2010-06-18 | 141d? | 325d | finish no earlier than 2010-06-18 | R2,R3 | 1128h |  | LCS_UMTS_RFPMT | PCG-24 | Polaris Wireless | Norman Shaw | Rel-10 | RP-46 | Joern |  |
| 68 | 34 | **Minimization of Drive Tests for E-UTRAN and UTRAN** | 266d? | 2009-12-04 | 2010-12-10 |  |  | 2009-12-04 | 2010-12-10 | 266d? | 200d |  | R2,R4,R3 | 4256h |  | MDT_UMTSLTE | PCG-24 | Nokia Siemens Networks | Malgorzata Tomala | Rel-10 | RP-46 | Joern |  |
| 69 | 34.1 | Core - MDT for E-UTRAN and UTRAN | 266d? | 2009-12-04 | 2010-12-10 |  |  | 2009-12-04 | 2010-12-10 | 266d? | 200d | finish no earlier than 2010-12-10 | R2,R4,R3 | 2128h |  | MDT_UMTSLTE-Core | PCG-24 | Nokia Siemens Networks | Malgorzata Tomala | Rel-10 | RP-46 | Joern |  |
| 70 | 35 | **Fixed Wireless Customer-Premises Equipment (CPE) RF Requirements** | 270d? | 2009-12-04 | 2010-12-16 |  |  | 2009-12-04 | 2010-12-16 | 270d? | 196d |  | R4,R5 | 6008h |  | FW_CPE_RF | PCG-24 | Verizon Wireless | zheng.zhao@verizonwireless.com | Rel-10 | RP-46 | Issam |  |
| 71 | 35.1 | Core - Fixed Wireless CPE RF Requirements | 211d? | 2009-12-04 | 2010-09-24 |  |  | 2009-12-04 | 2010-09-24 | 211d? | 255d | finish no earlier than 2010-09-24 | R4 | 1688h |  | FW_CPE_RF-Core | PCG-24 | Verizon Wireless | zheng.zhao@verizonwireless.com | Rel-10 | RP-46 | Issam |  |
| 72 | 35.2 | Test - Fixed Wireless CPE RF Requirements | 270d? | 2009-12-04 | 2010-12-16 |  |  | 2009-12-04 | 2010-12-16 | 270d? | 196d | finish no earlier than 2010-12-16 | R5 | 2160h |  | FW_CPE_RF-UEConfTest | PCG-24 | Verizon Wireless | zheng.zhao@verizonwireless.com | Rel-10 | RP-46 | Ingbert |  |
| 73 | 36 | **Four carrier HSDPA** | 400d? | 2009-12-04 | 2011-06-16 |  |  | 2009-12-04 | 2011-06-16 | 400d? | 66d |  | R1,R2,R3,R4 | 8528h |  | 4C_HSDPA | PCG-24 | Qualcomm Europe | Arjun Bharadwaj (arjunb@qualcomm.com) | Rel-10 | RP-46 | Patrick |  |
| 74 | 36.1 | Core - Four carrier HSDPA | 266d? | 2009-12-04 | 2010-12-10 |  |  | 2009-12-04 | 2010-12-10 | 266d? | 200d | finish no earlier than 2010-12-10 | R1,R2,R3,R4 | 2128h |  | 4C_HSDPA-Core | PCG-24 | Qualcomm Europe | Arjun Bharadwaj (arjunb@qualcomm.com) | Rel-10 | RP-46 | Patrick |  |
| 75 | 36.2 | Perf - Four carrier HSDPA | 400d? | 2009-12-04 | 2011-06-16 |  |  | 2009-12-04 | 2011-06-16 | 400d? | 66d | finish no earlier than 2011-06-16 | R4 | 3200h |  | 4C_HSDPA-Perf | PCG-24 | Qualcomm Europe | Arjun Bharadwaj (arjunb@qualcomm.com) | Rel-10 | RP-46 | Issam |  |
| 76 | 37 | **Carrier Aggregation for LTE** | 400d? | 2009-12-04 | 2011-06-16 |  |  | 2009-12-04 | 2011-06-16 | 400d? | 66d |  | R1,R2,R3,R4 | 8528h |  | LTE_CA | PCG-24 | Nokia | Asbjørn Grøvlen | Rel-10 | RP-46 | Patrick |  |
| 77 | 37.1 | Core - Carrier Aggregation for LTE | 266d? | 2009-12-04 | 2010-12-10 |  |  | 2009-12-04 | 2010-12-10 | 266d? | 200d | finish no earlier than 2010-12-10 | R1,R2,R3,R4 | 2128h |  | LTE_CA-Core | PCG-24 | Nokia | Asbjørn Grøvlen | Rel-10 | RP-46 | Patrick |  |
| 78 | 37.2 | Perf - Carrier Aggregation for LTE | 400d? | 2009-12-04 | 2011-06-16 |  |  | 2009-12-04 | 2011-06-16 | 400d? | 66d | finish no earlier than 2011-06-16 | R4 | 3200h |  | LTE_CA-Perf | PCG-24 | Nokia | Asbjørn Grøvlen | Rel-10 | RP-46 | Issam |  |

Notes:
- 54: RP#46 moved to Rel-10. WID updated RP-081096=>RP-091380
- 55: RP#46 moved to Rel-10. WID updated RP-081096=>RP-091380 / Text3: 25.101, 25.104, 25.113, 25.133, 25.141, 25.307, 25.307, 25.331, 25.461, 25.463, 34.124, 36.101, 36.104, 36.113, 36.141, 36.331
- 56: RP#46 moved to Rel-10 / Text3: 36.508, 36.521-1, 36.521-2, 36.521-3
- 57: RP#46 moved to Rel-10 / Text3: 34.108, 34.121-1, 34.121-2
- 58: RP#45 completion 12/09=>06/10 / Text3: 25.113, new 25.116, 25.153 (testing)
- 59: - / Text3: 25.102, 25.105, 25.123, 25.221, 25.222, 25.223, 25.224, 25.225, 25.306, 25.319, 25.321, 25.331, 25.423, 25.427, 25.433
- 60: Triggered by FS_RAN-HNBLCRTDD UID_410016 Study on 1.28 Mcps TDD Home NodeB (TR 25.866)
- 61: - / Text3: 25.105
- 62: - / Text3: 25.142
- 63: RP#46 moved to Rel-10 (No activity in WGs=>RP#47 to decide a way forward). Cell sets the TTI (Transmission Time Interval) to 2 ms / Text3: 25.133, 25.212, 25.214, 25.321, 25.331
- 64: RP#46 definition of GNSS min performance reqs in GERAN delayed. Triggered by Rel-7 UID_20050 (GNSS in UTRAN) and Rel-8 UID_400051 (Support for Additional NSS). Linked to GERAN Rel-9 UID_38002 (A-GNSS Performances and Testing Procedures) / Text3: 25.171, 34.108, 34.123, 34.171, 34.109
- 65: - / Text3: 25.144, 25.914, 34.114
- 66: Triggered by Study UID_380079 Evaluation of the inclusion of Path Loss Based Technology in the UTRAN (25.907)
- 67: - / Text3: 25.305, 25.453
- 68: Triggered by UID_430021 TR 36.805 (Study on Minimization of drive-tests in NGN)
- 69: - / Text3: 25.133, 25.215, 25.304, 25.331, 25.423, 36.133, 36.214, 36.300, 36.304, 36.331, 36.413, 36.423
- 70: Add new power classes in E-UTRAN UL to allow CPE type applications to be operated at higher max output power
- 71: - / Text3: 36.101
- 72: - / Text3: 36.521-1
- 73: -
- 74: - / Text3: 25.101, 25.104, 25.133, 25.211, 25.212, 25.213, 25.214, 25.215, 25.308, 25.331, 25.423, 25.433, 26.306
- 75: - / Text3: 25.101, 25.104, 25.133, 25.141
- 76: Triggered by FS_RAN_LTEA (Study on LTE-Advanced) 36.912, 36. 814
- 77: - / Text3: 36.101, 36.104, 36.133, 36.211, 36.212, 36.213, 36.300, 36.302, 36.306, 36.321, 36.331, 36.413, 36.423
- 78: - / Text3: 36.101, 36.104, 36.133, 36.141, 36.211, 36.212, 36.213, 36.300, 36.302, 36.306, 36.321, 36.331, 36.413, 36.423

| ID | WBS | Task | Type | Duration | Start | Finish | Complete | Remaining | Baseline start | Baseline finish | Baseline duration | Total slack | Constraint | Resources | Work | Actual work | Text1 | Text2 | Text4 | Text6 | Text7 | Text8 | Text9 | Text12 | Text11 |
| --- | --- | --- | --- | --- | --- | --- | --- | --- | --- | --- | --- | --- | --- | --- | --- | --- | --- | --- | --- | --- | --- | --- | --- | --- | --- |
| 79 | 38 | **Enhanced Downlink Multiple Antenna Transmission for LTE** |  | 400d? | 2009-12-04 | 2011-06-16 |  |  | 2009-12-04 | 2011-06-16 | 400d? | 66d |  | R1,R2,R4 | 8528h |  | LTE_eDL_MIMO | PCG-24 | NTT DoCoMo | Rel-10 | RP-46 | Patrick |  |  |  |
| 80 | 38.1 | Core - Enhanced Downlink Multiple Antenna Transmission for LTE |  | 266d? | 2009-12-04 | 2010-12-10 |  |  | 2009-12-04 | 2010-12-10 | 266d? | 200d | finish no earlier than 2010-12-10 | R1,R2,R4 | 2128h |  | LTE_eDL_MIMO-Core | PCG-24 | NTT DoCoMo | Rel-10 | RP-46 | Patrick |  |  |  |
| 81 | 38.2 | Perf - Enhanced Downlink Multiple Antenna Transmission for LTE |  | 400d? | 2009-12-04 | 2011-06-16 |  |  | 2009-12-04 | 2011-06-16 | 400d? | 66d | finish no earlier than 2011-06-16 | R4 | 3200h |  | LTE_eDL_MIMO-Perf | PCG-24 | NTT DoCoMo | Rel-10 | RP-46 | Issam |  |  |  |
| 82 | 39 | **Uplink Multiple Antenna Transmission for LTE** |  | 400d? | 2009-12-04 | 2011-06-16 |  |  | 2009-12-04 | 2011-06-16 | 400d? | 66d |  | R1,R2,R4 | 8528h |  | LTE_UL_MIMO | PCG-24 | Huawei | Rel-10 | RP-46 | Patrick |  |  |  |
| 83 | 39.1 | Core - UL Multiple Antenna Transmission for LTE |  | 266d? | 2009-12-04 | 2010-12-10 |  |  | 2009-12-04 | 2010-12-10 | 266d? | 200d | finish no earlier than 2010-12-10 | R1,R2,R4 | 2128h |  | LTE_UL_MIMO-Core | PCG-24 | Huawei | Rel-10 | RP-46 | Patrick |  |  |  |
| 84 | 39.2 | Perf - UL Multiple Antenna Transmission for LTE |  | 400d? | 2009-12-04 | 2011-06-16 |  |  | 2009-12-04 | 2011-06-16 | 400d? | 66d | finish no earlier than 2011-06-16 | R4 | 3200h |  | LTE_UL_MIMO-Perf | PCG-24 | Huawei | Rel-10 | RP-46 | Issam |  |  |  |
| 85 | 40 | **Latency reductions for LTE** |  | 266d? | 2009-12-04 | 2010-12-10 |  |  | 2009-12-04 | 2010-12-10 | 266d? | 200d |  | R1,R2 | 4256h |  | LTE_LATRED | PCG-24 | Ericsson | Rel-10 | RP-46 | Patrick |  |  |  |
| 86 | 40.1 | Core - Latency reductions for LTE |  | 266d? | 2009-12-04 | 2010-12-10 |  |  | 2009-12-04 | 2010-12-10 | 266d? | 200d | finish no earlier than 2010-12-10 | R1,R2 | 2128h |  | LTE_LATRED-Core | PCG-24 | Ericsson | Rel-10 | RP-46 | Patrick |  |  |  |
| 87 | 41 | **Relays for LTE** |  | 336d? | 2009-12-04 | 2011-03-18 |  |  | 2009-12-04 | 2011-03-18 | 336d? | 130d |  | R1,R2,R4 | 7504h |  | LTE_Relay | PCG-24 | Ericsson | Rel-10 | RP-46 | Patrick |  |  |  |
| 88 | 41.1 | Core - Relays for LTE |  | 266d? | 2009-12-04 | 2010-12-10 |  |  | 2009-12-04 | 2010-12-10 | 266d? | 200d | finish no earlier than 2010-12-10 | R1,R2,R4 | 2128h |  | LTE_Relay-Core | PCG-24 | Ericsson | Rel-10 | RP-46 | Patrick |  |  |  |
| 89 | 41.2 | Perf - Relays for LTE |  | 336d? | 2009-12-04 | 2011-03-18 |  |  | 2009-12-04 | 2011-03-18 | 336d? | 130d | finish no earlier than 2011-03-18 | R4 | 2688h |  | LTE_Relay-Perf | PCG-24 | Ericsson | Rel-10 | RP-46 | Issam |  |  |  |
| 90 | 42 | (Small) Technical Enhancements and Improvements for Rel-10 |  | 136d? | 2009-06-04 | 2009-12-10 |  |  | 2009-06-04 | 2009-12-10 | 136d? | 461d | finish no earlier than 2009-12-10 | All | 1088h |  | TEI10 | PCG-23 | ALL | Rel-10 | SP-44 |  |  |  |  |
| 91 | 43 | **Deleted - Network Selection for non-3GPP Access** |  | 471d? | 2007-12-07 A | 2009-09-24 A | 100% |  | 2007-12-07 | 2009-09-24 | 471d? |  |  | S1,C6 | 10452.8h | 10452.8h | N3GtoNSP | PCG-21 | Telefonica O2 | Rel-10 | SP-38 | Alain | PCG-23 | SP-45 |  |
| 92 | 43.1 | Deleted - Stage 1 for N3GtoNSP |  | 471d? | 2007-12-07 A | 2009-09-24 A | 100% |  | 2007-12-07 | 2009-09-24 | 471d? |  | finish no earlier than 2009-12-10 | S1 | 3768h | 3768h | N3GtoNSP | PCG-21 | Telefonica O2 | Rel-10 | SP-38 | Alain | PCG-23 | SP-45 |  |
| 93 | 43.2 | Deleted - CT6 issues for N3GtoNSP |  | 471d? | 2007-12-07 A | 2009-09-24 A | 100% |  | 2007-12-07 | 2009-09-24 | 471d? |  | finish no earlier than 2009-12-04 | C6 | 3768h | 3768h | N3GtoNSP | PCG-21 | Telefonica O2 | Rel-10 | CP-38 | Xavier | PCG-23 | CP-45 |  |
| 94 | 44 | **Deleted - Registration in Densely-populated area (RED)** |  | 665d? | 2007-03-12 A | 2009-09-24 A | 100% |  | 2007-03-12 | 2009-09-24 | 665d? |  |  | S1 | 9544h | 9544h | RED |  | NTT DoCoMo | Rel-10 | SP-35 | Alain | PCG-24 | SP-46 |  |
| 95 | 44.1 | Deleted - Stage 1 for RED |  | 4d? | 2007-03-12 A | 2007-03-15 A | 100% |  | 2007-03-12 | 2007-03-15 | 4d? |  | start no earlier than 2007-03-12 | S1 | 32h | 32h | RED |  | NTT DoCoMo | Rel-10 | SP-35 | Alain | PCG-24 | SP-46 |  |
| 96 | 44.2 | Deleted - Stage 2 for RED |  | 524d? | 2007-09-25 A | 2009-09-24 A | 100% |  | 2007-09-25 | 2009-09-24 | 524d? |  | finish no earlier than 2009-09-24 | S2 | 4192h | 4192h | RED |  | NTT DoCoMo | Rel-10 | SP-37 | Maurice | PCG-23 | SP-45 |  |
| 97 | 45 | **Deleted - Network Selection for non-3GPP Access** |  | 471d? | 2007-12-07 A | 2009-09-24 A | 100% |  | 2007-12-07 | 2009-09-24 | 471d? |  |  | S1,C6 | 10452.8h | 10452.8h | N3GtoNSP | PCG-21 | Telefonica O2 | Rel-10 | SP-38 | Alain | PCG-23 | SP-45 |  |
| 98 | 45.1 | Deleted - Stage 1 for N3GtoNSP |  | 471d? | 2007-12-07 A | 2009-09-24 A | 100% |  | 2007-12-07 | 2009-09-24 | 471d? |  | finish no earlier than 2009-12-10 | S1 | 3768h | 3768h | N3GtoNSP | PCG-21 | Telefonica O2 | Rel-10 | SP-38 | Alain | PCG-23 | SP-45 |  |
| 99 | 45.2 | Deleted - CT6 issues for N3GtoNSP |  | 471d? | 2007-12-07 A | 2009-09-24 A | 100% |  | 2007-12-07 | 2009-09-24 | 471d? |  | finish no earlier than 2009-12-04 | C6 | 3768h | 3768h | N3GtoNSP | PCG-21 | Telefonica O2 | Rel-10 | CP-38 | Xavier | PCG-23 | CP-45 |  |
| 100 | 46 | Deleted - Enhanced Home NodeB / eNodeB continuation of Rel-9 |  | 337d? | 2008-12-11 A | 2010-03-25 A | 100% |  | 2008-12-11 | 2010-03-25 | 337d? |  |  | S2 | 2696h | 2696h | eEHNB | PCG-23 | Alcatel-Lucent | Rel-10 | SP-44 | Maurice | PCG-24 | SP-47 |  |
| 101 | 47 | Release 10 Studies | milestone | 0d? | 2000-01-01 | 2000-01-01 |  |  | 2000-01-01 | 2000-01-01 | 0d? | 3057d | start no earlier than 2000-01-01 | CP,GP,RP,SP |  |  |  |  |  | Rel-10 |  |  |  |  |  |
| 102 | 48 | **Study on enhanced voice service requirements for the Evolved Packet System (EPS)** |  | 670d? | 2007-09-03 A | 2010-03-25 A | 100% |  | 2007-09-03 | 2010-03-25 | 670d? |  |  | S1,S4 | 13384h | 13384h | FS_EV_EPS |  | Orange | Rel-10 | SP-37 | Alain |  |  |  |
| 103 | 48.1 | Use cases definition and service and system requirements |  | 334d? | 2007-09-03 A | 2008-12-11 A | 100% |  | 2007-09-03 | 2008-12-11 | 334d? |  | finish no earlier than 2008-12-11 | S1 | 2672h | 2672h | FS_EV_EPS-S1 |  | Orange | Rel-10 | SP-37 | Alain |  |  |  |
| 104 | 48.2 | Codec specific part of FS_EV_EPS |  | 669d? | 2007-09-03 A | 2010-03-25 A | 100% |  | 2007-09-03 | 2010-03-25 | 669d? |  | finish no earlier than 2010-03-25 | S4 | 5352h | 5352h | FS_EV_EPS-S4 |  | Ericsson | Rel-10 | SP-37 | Paolo |  |  |  |
| 105 | 49 | Study on advanced requirements for IP interconnect |  | 528d? | 2007-12-04 A | 2009-12-10 A | 100% |  | 2007-12-04 | 2009-12-10 | 528d? |  | finish no earlier than 2009-12-10 | S1 | 4224h | 4224h | FS_IPXS | PCG-21 | Telefonica O2 | Rel-10 | SP-38 | Alain |  |  |  |
| 106 | 50 | Study on Unauthenticated PS Emergency Calls |  | 471d? | 2008-06-05 A | 2010-03-25 | 20% | 376.8d? | 2008-06-05 | 2010-03-25 | 471d? | 386d | finish no earlier than 2010-03-25 | S1 | 3768h | 753.6h | FS_UAPSEC | PCG-21 | Nokia Siemens Networks | Rel-10 | SP-40 | Alain |  |  |  |
| 107 | 51 | Study on Personal Broadcast Service |  | 397d? | 2008-09-18 A | 2010-03-25 | 90% | 39.7d? | 2008-09-18 | 2010-03-25 | 397d? | 386d | finish no earlier than 2010-03-25 | S1 | 3168h | 2850.4h | FS_PBS | PCG-21 | ETRI | Rel-10 | SP-41 | Alain |  |  |  |
| 108 | 52 | Study on LCS support in SAE for non-3GPP accesses |  | 397d? | 2008-09-18 A | 2010-03-25 | 70% | 119.1d? | 2008-09-18 | 2010-03-25 | 397d? | 386d | finish no earlier than 2010-03-25 | S1 | 3168h | 2215.2h | FS_LCS_n3GPP | PCG-21 | SK Telecom | Rel-10 | SP-41 | Alain |  |  |  |
| 109 | 53 | Study on Haptic Services |  | 272d? | 2009-03-12 A | 2010-03-25 | 80% | 54.4d? | 2009-03-12 | 2010-03-25 | 272d? | 386d | finish no earlier than 2010-03-25 | S1 | 2168h | 1732.8h | FS_Haptics | PCG-22 | SK Telecom | Rel-10 | SP-43 | Alain |  |  |  |
| 110 | 54 | Study on IMS based Peer-to-Peer Content Distribution Services |  | 196d? | 2009-09-24 A | 2010-06-24 | 50% | 98d? | 2009-09-24 | 2010-06-24 | 196d? | 321d | finish no earlier than 2010-06-24 | S1,S2 | 1568h | 784h | FS_IMS_P2P | PCG-23 | China Mobile | Rel-10 | SP-45 | Alain |  |  |  |
| 111 | 55 | Study on System enhancements for the use of IMS services in Local BreakOut and Optimal Routing of Media |  | 575d? | 2007-10-01 A | 2009-12-10 A | 100% |  | 2007-10-01 | 2009-12-10 | 575d? |  | finish no earlier than 2009-12-10 | S2 | 4600h | 4600h | FS_IMS_LBO_ORM |  | Telecom Italia, BT | Rel-10 | SP-37 | Maurice |  |  |  |
| 112 | 56 | Study on Intra Domain Connection of RAN Nodes to Multiple CN Nodes |  | 533d? | 2008-03-12 A | 2010-03-25 | 70% | 159.9d? | 2008-03-12 | 2010-03-25 | 533d? | 386d | finish no earlier than 2010-03-25 | S2 | 4264h | 2984.8h | FS_IDC | PCG-21 | China Mobile | Rel-10 | SP-39 | Maurice |  |  |  |
| 113 | 57 | Study on IMS Evolution |  | 397d? | 2008-09-18 A | 2010-03-25 | 70% | 119.1d? | 2008-09-18 | 2010-03-25 | 397d? | 386d | finish no earlier than 2010-03-25 | S2 | 3176h | 2223.2h | FS_eIMS | PCG-21 | China Mobile | Rel-10 | SP-41 | Maurice |  |  |  |
| 114 | 58 | Study on enhancements to IMS border functions for IMS Interconnection of services |  | 452d? | 2008-09-18 A | 2010-06-10 | 30% | 315.5d? | 2008-09-18 | 2010-06-10 | 452d? | 331d | finish no earlier than 2010-06-10 | S2 | 3616h | 1092h | FS_eIMS_IBCF | PCG-21 | Starent Networks | Rel-10 | SP-41 | Maurice |  |  |  |
| 115 | 59 | Study on Multi Access PDN connectivity and IP flow Mobility |  | 397d? | 2008-09-18 A | 2010-03-25 | 75% | 99.25d? | 2008-09-18 | 2010-03-25 | 397d? | 386d | finish no earlier than 2010-03-25 | S2,S1 | 3176h | 2382h | FS_MAPIM | PCG-21 | Qualcomm Europe | Rel-10 | SP-41 | Maurice |  |  |  |
| 116 | 60 | Study on Policy solutions and enhancements |  | 401d? | 2009-06-04 A | 2010-12-16 | 15% | 339.95d? | 2009-06-04 | 2010-12-16 | 401d? | 196d | finish no earlier than 2010-12-16 | S2,S1 | 3208h | 488.4h | FS_PP | PCG-23 | AT&T | Rel-10 | SP-44 | Maurice |  |  |  |
| 117 | 61 | Study on IPv6 Migration |  | 266d? | 2009-06-04 A | 2010-06-10 | 25% | 198.75d? | 2009-06-04 | 2010-06-10 | 266d? | 331d | finish no earlier than 2010-06-10 | S2 | 2128h | 538h | FS_IP6M | PCG-23 | China Mobile | Rel-10 | SP-44 | Maurice |  |  |  |
| 118 | 62 | Study on SR-VCC Enhancements |  | 337d? | 2009-06-04 A | 2010-09-17 | 20% | 269.4d? | 2009-06-04 | 2010-09-17 | 337d? | 260d | finish no earlier than 2010-09-17 | S2 | 2696h | 540.8h | FS_eSRVCC | PCG-23 | China Mobile | Rel-10 | SP-44 | Maurice |  |  |  |
| 119 | 63 | Study on SR-VCC from UTRAN/GERAN to E-UTRAN/HSPA |  | 137d? | 2009-12-10 | 2010-06-18 |  |  | 2009-12-10 | 2010-06-18 | 137d? | 325d | finish no earlier than 2010-06-18 | S2 | 1096h |  | FS_rSRVCC | PCG-24 | Orange | Rel-10 | SP-46 | Maurice |  |  |  |
| 120 | 64 | Study on UTRAN key management enhancements |  | 592d? | 2007-12-20 A | 2010-03-25 | 30% | 415.6d? | 2007-12-20 | 2010-03-25 | 592d? | 386d | finish no earlier than 2010-03-25 | S3 | 4736h | 1411.2h | FS_UKM | PCG-21 | Ericsson | Rel-10 | SP-38 | Dionisio |  |  |  |
| 121 | 65 | Study on Surround Sound codec extension for PSS and MBMS |  | 326d? | 2009-03-12 A | 2010-06-10 | 60% | 130.4d? | 2009-03-12 | 2010-06-10 | 326d? | 331d | finish no earlier than 2010-06-10 | S4 | 2608h | 1564.8h | FS_SS_PSS_MBMS | PCG-22 | Fraunhofer Gesellschaft | Rel-10 | SP-43 | Paolo |  |  |  |
| 122 | 66 | Study on Rc Reference Point Functionalities and Message Flows |  | 587d? | 2008-09-18 A | 2010-12-16 | 90% | 58.7d? | 2008-09-18 | 2010-12-16 | 587d? | 196d | finish no earlier than 2010-12-16 | S5 | 4688h | 4218.48h | FS_OAM_Rc | PCG-21 | Huawei | Rel-10 | SP-41 | Dionisio |  |  |  |
| 123 | 67 | Study on Telecommunication Management; Energy Savings Management |  | 461d? | 2009-03-12 A | 2010-12-16 | 60% | 184.4d? | 2009-03-12 | 2010-12-16 | 461d? | 196d | finish no earlier than 2010-12-16 | S5 | 3688h | 2212.8h | FS_OAM_ESM | PCG-22 | Orange, Vodafone | Rel-10 | SP-43 | Dionisio |  |  |  |
| 124 | 68 | Study on Integration of Device Management Information with Itf-N |  | 401d? | 2009-06-04 A | 2010-12-16 | 40% | 240.6d? | 2009-06-04 | 2010-12-16 | 401d? | 196d | finish no earlier than 2010-12-16 | S5 | 3208h | 1283.2h | FS_IDMI_Itf-N | PCG-23 | Motorola | Rel-10 | SP-44 | Dionisio |  |  |  |
| 125 | 69 | Study on EPC Charging enhancement |  | 401d? | 2009-06-04 A | 2010-12-16 | 5% | 380.65d? | 2009-06-04 | 2010-12-16 | 401d? | 196d | finish no earlier than 2010-12-16 | S5 | 3208h | 162.8h | FS_EPCcharg | PCG-23 | Nokia Siemens Networks | Rel-10 | SP-44 | Dionisio |  |  |  |
| 126 | 70 | Study on Alignment of 3GPP Generic NRM IRP and TMF Shared Information Data (SID) model |  | 131d? | 2000-01-03 | 2000-06-30 |  |  | 2000-01-03 | 2000-06-30 | 131d? | 2926d |  | S5 | 1048h |  | FS_3GNRM_TMFSID | PCG-24 | Nokia Siemens Networks | Rel-10 | SP-46 | Dionisio |  |  |  |
| 127 | 71 | Study on Harmonization of 3GPP Alarm IRP and TMF Interface Program (TIP) Fault Management |  | 131d? | 2009-12-10 | 2010-06-10 |  |  | 2009-12-10 | 2010-06-10 | 131d? | 331d | finish no earlier than 2010-06-10 | S5 | 1048h |  | FS_3G_TMF_FM | PCG-24 | Nokia Siemens Networks, Alcatel-Lucent | Rel-10 | SP-46 | Dionisio |  |  |  |
| 128 | 72 | Study on Policy and Charging Rules Function (PCRF) failure and restoration |  | 186d? | 2009-08-18 A | 2010-06-04 | 50% | 93d? | 2009-08-18 | 2010-06-04 | 186d? | 335d | finish no earlier than 2010-06-04 | C3 | 1488h | 744h | FS_PCRF-FR | PCG-23 | NEC | Rel-10 | CP-45 | Gwiho |  |  |  |
| 129 | 73 | Study on Measurement of Radiated Performance for MIMO and multi-antenna reception for HSPA and LTE terminals |  | 256.8d? | 2009-03-06 A | 2010-06-04 | 35% | 166.92d? | 2009-03-06 | 2010-06-04 | 256.8d? | 335d | finish no earlier than 2010-06-04 | R4 | 2054.4h | 719.03h | FS_HSPA_LTE_measRP_MIMO_multi-antenna | PCG-22 | Vodafone | Rel-10 | RP-43 | Issam |  |  | RP-091410 |
| 130 | 74 | Study on Extending 850 MHz |  | 266d? | 2009-05-30 A | 2010-06-04 | 5% | 252.7d? | 2009-05-30 | 2010-06-04 | 266d? | 335d | finish no earlier than 2010-06-04 | R4 | 2128h | 106.4h | FS_e850 | PCG-23 | Ericsson | Rel-10 | RP-44 | Issam |  |  | RP-091085 |
| 131 | 75 | Study on Uplink Tx Diversity for HSPA |  | 208.4d? | 2009-08-18 A | 2010-06-04 | 20% | 166.72d? | 2009-08-18 | 2010-06-04 | 208.4d? | 335d | finish no earlier than 2010-06-04 | R4 | 1667.2h | 333.43h | FS_UL-TxDiv-HSPA | PCG-23 | Qualcomm Europe | Rel-10 | RP-45 | Issam |  |  | RP-091086 |
| 132 | 76 | Study on RAN improvements for Machine-Type Communications |  | 186d? | 2009-09-18 | 2010-06-04 |  |  | 2009-09-18 | 2010-06-04 | 186d? | 335d | finish no earlier than 2010-06-04 | R2,R1,R3,R4 | 1488h |  | FS_NIMTC_RAN | PCG-23 | Huawei | Rel-10 | RP-45 | Joern |  |  | RP-091087 |
| 133 | 77 | Study on GERAN improvements for Machine-Type Communications |  | 206d? | 2009-11-20 | 2010-09-03 |  |  | 2009-11-20 | 2010-09-03 | 206d? | 270d | finish no earlier than 2010-09-03 | GP | 1648h |  | FS_NIMTC_GERAN | PCG-24 | Ericsson | Rel-10 | GP-44 | Paolo |  |  |  |
| 134 | 78 | Study on Solutions for energy saving within UTRA Node B |  | 141d? | 2009-12-04 | 2010-06-18 |  |  | 2009-12-04 | 2010-06-18 | 141d? | 325d | finish no earlier than 2010-06-18 | R1,R3 | 1128h |  | FS_Energy_UMTS | PCG-24 | Vodafone | Rel-10 | RP-46 | Patrick |  |  |  |
| 135 | 79 | Release 9 Features | milestone | 0d? | 2000-01-01 | 2000-01-01 |  |  | 2000-01-01 | 2000-01-01 | 0d? | 3057d |  | CP,GP,RP,SP |  |  |  |  |  | Rel-9 |  |  |  |  |  |

Notes:
- 79: Triggered by FS_RAN_LTEA (Study on LTE-Advanced) 36.912, 36. 814 / Text5: Hidekazu Taoka
- 80: - / Text3: 36.101, 36.104, 36.133, 36.201, 36.211, 36.212, 36.213, 36.300, 36.306, 36.321, 36.331 / Text5: Hidekazu Taoka
- 81: - / Text3: 36.101, 36.104, 36.133, 36.141 / Text5: Hidekazu Taoka
- 82: Triggered by FS_RAN_LTEA (Study on LTE-Advanced) 36.912, 36. 814 / Text5: Mattias Wennström
- 83: - / Text3: 36.101, 36.104, 36.133, 36.201, 36.211, 36.212, 36.213, 36.300, 36.306, 36.321, 36.331 / Text5: Mattias Wennström
- 84: - / Text3: 36.101, 36.104, 36.133, 36.141 / Text5: Mattias Wennström
- 85: Triggered by FS_RAN_LTEA (Study on LTE-Advanced) 36.912, 36. 814 / Text5: Henrik Enbuske
- 86: - / Text3: 36.213, 36.300, 36.306, 36.321, 36.331 / Text5: Henrik Enbuske
- 87: Triggered by FS_RAN_LTEA (Study on LTE-Advanced) 36.912, 36. 814 / Text5: Christian Hoymann
- 88: - / Text3: 36.133, 36.201, 36.211, 36.212, 36.213, 36.300, 36.321, 36.323, 36.331 / Text5: Christian Hoymann
- 89: - / Text3: 36.133 / Text5: Christian Hoymann
- 90: -
- 91: SP#45 work stopped/abandoned / Text5: chris.friel@O2.com
- 92: SP#45 work stopped/abandoned / Text3: 22.011 / Text5: chris.friel@O2.com
- 93: SP#45 work stopped/abandoned / Text3: 36.300 / Text5: chris.friel@O2.com
- 94: SP#35 Stage 1 completed. SP#45 Stage 2 work stopped. SP#46 work stopped/abandoned / Text3: WID identifies also impacted CT1 24.008, RAN2 25.331 / Text5: tanakai@nttdocomo.co.jp
- 95: SP#35 completed. SP#46 work stopped/abandoned / Text3: 22.101 CR#0207 / Text5: takakurat@s1.nttdocomo.co.jp
- 96: SP#45 Stage 2 work stopped / Text3: draft TR 23.880 withdrawn, 23.002, 23.060, 23.221, 23.236 / Text5: tanakai@nttdocomo.co.jp
- 97: SP#45 work stopped/abandoned / Text5: chris.friel@O2.com
- 98: SP#45 work stopped/abandoned / Text3: 22.011 / Text5: chris.friel@O2.com
- 99: SP#45 work stopped/abandoned / Text3: 36.300 / Text5: chris.friel@O2.com
- 100: SP#47 deleted (SA2 work moved under SA1 UID_450053). SP#44 Umbrella Feature created to host WIs moved out of Rel-9 (SA2 UID_420034 on IMS aspects of Architecture for Home NodeB) / Text5: Nicolas Drevon
- 101: -
- 102: SP#47 completed. TR 22.813-100 for Approval / Text3: 22.813 / Text5: tim.haysom@orange-ftgroup.com
- 103: SP#47 completed. TR 22.813-100 for Approval / Text3: 22.813 / Text5: tim.haysom@orange-ftgroup.com
- 104: SP#47 completed. TR 22.813-100 for Approval / Text3: 22.813 / Text5: stefan.bruhn@ericson.com
- 105: SP#46 completed. Linked to Rel-8 Feature UID_380060 IP Interconnection of Services (IPinterc) / Text3: 22.893 / Text5: chris.friel@O2.com
- 106: SP#44/45/46 stagnating at 20% / Text3: 22.984 / Text5: Juergen Merkel
- 107: SP#45 TR 22.947 for Information / Text3: 22.947 / Text5: Jaihyung Cho
- 108: SP#44 TR 22.913 for Information / Text3: 22.913 / Text5: Donghee Shim
- 109: SP#46 TR 22.987 for Information. Covers Mobile/Fixed/Cordless/etc terminals. Haptic (human-machine tactile communication) extend service offering & richness of user experience beyond current visual & auditory senses / Text3: 22.987 / Text5: Jinhan Song
- 110: Linked to OMA work? / Text3: 22.8xy / Text5: Li Gang (ligangyf@chinamobile.com)
- 111: SP#46 completed. Spin-off Feature UID_460028 Optimal Media Routeing (OMR). Linked to Study on Multimedia Session Continuity UID_350051, Study on Centralized IMS Service Control UID_330012, IMS inter-operator service interconnection interface UID_360011 / Text3: 23.894 / Text5: mario.madella@telecomitalia.it, victor.kueh@bt.com
- 112: SP#45 TR 23.823 for Information. Completion 12/09=>03/10. Linked to 23.236 / Text3: 23.823 / Text5: LIU HONG (liuhongyfw@chinamobile.com)
- 113: - / Text3: 23.812 / Text5: Li Gang (ligangyf@chinamobile.com), Yu Qing (yuqing@chinamobile.com)
- 114: SP#46 updated WID SP-080559=>SP-090809 (extended scope to include the IMS AGW) / Text3: 23.848 / Text5: Rajat Ghai (rghai@starentnetworks.com)
- 115: SP#45 completion 09/09=>03/10 (SA1 completed). Spin-off UID_430035 MAPCON and UID_450041 IFOM / Text3: 23.861 / Text5: Gerardo Giaretta (gerardog@qualcomm.com)
- 116: SP#46 updated WID SP-090361=>SP-090805. Study an evolved policy solution through enhancement of 3GPP policy framework (Stage 2). Consider aspects such as DPI, traffic steering, enhancing service policies / Text3: 23.813 / Text5: farooq.bari@att.com
- 117: Study how to migrate from IPv4 to IPv6-only with the help of transition mechanisms defined in IETF, and how to handle scenarios where not all services are provided via IPv6. Some of these solutions may have impacts on 3GPP network elements and terminals. / Text3: 23.975 / Text5: Li Lianyuan (lilianyuan@chinamobile.com), Liu Hong (liuhongyfw@chinamobile.com)
- 118: SP#45 completion 03/10=>09/10. Analyze current performance of SR-VCC solution in Rel-8 from E-UTRAN/HSPA to UTRAN/GERAN, and then evaluate additional mechanisms to improve user experience. Study if SR-VCC performance needs to be enhanced. / Text3: 23.856 / Text5: Hou zhiqiang (houzhiqiang@chinamobile.com), Jiang Yi (jiangyi@chinamobile.com)
- 119: Study on "reverse direction" from UTRAN/GERAN to E-UTRAN/HSPA (Rel-8 SRVCC was in the other direction E-UTRAN/HSPA to GERAN/UTRAN) / Text3: 23.885 / Text5: delphin.barankanira@orange-ftgroup.com
- 120: SP#44 SID updated SP-070782=>SP-090283 (removed UTRAN/E-UTRAN IRAT signalling cases from Study scope (while IRAT handling is left as specified by 33.401). Study also focuses on support for a key hierarchy locally in UTRAN and intra-UTRAN mobility cases.) / Text3: 33.8xy / Text5: Karl Norrman
- 121: SP#47 moved to Rel-10. TR 26.950-100 for Information. Work to extend Rel-8 UID_34043 PSS_MBMS_OMTV (Extending PSS and MBMS User Services for optimized Mobile TV) / Text3: 26.950 / Text5: jan.plogsties@iis.franhofer.de
- 122: SP#44 for SA Information / Text3: 32.825 / Text5: shan.mingjun@huawei.com
- 123: Study result might impact Feature UID_420011 Self Organising Networks (SON) / Text3: 32.826 / Text5: Jean-Michel Cornilly (Orange)
- 124: Study the missing Itf-N part in the Framework. Study changes to Itf-N to utilize UE based measurements / Text3: 32.827 / Text5: Yizhi Yao (yzyao@motorola.com)
- 125: Study grouping the investigation of various minor EPC charging enhancements / Text3: It has to be decided whether it will be a new TR or Rel-10 CRs on TR 32.820 / Text5: Gerald.Goermer@nsn.com
- 126: - / Text3: 32.8xy / Text5: Olaf Pollakowski
- 127: - / Text3: 32.8xy / Text5: Olaf Pollakowski, Padma Sudarsan
- 128: CP#46 completion 03/10=>06/10. WID updated CP-090588=>CP-090861 / Text3: 29.816 / Text5: gottfried.punz@nw.neclab.eu
- 129: RP#46 completion 12/09=>06/10 / Text3: TR (25/36) / Text5: soonleh.ling@vodafone.com
- 130: RP#46 completion 12/09=>06/10 / Text3: TR xx.yyy / Text5: Christian Bergljung (christian.bergljung@stericsson.com)
- 131: - / Text3: 25.8xx / Text5: Heechoon Lee (heechoon@qualcomm.com)
- 132: Triggered by UID_7027 Study on Facilitating Machine to Machine Communication in GSM and UMTS (M2M) TR 22.868 and Rel-10 UID_410030 Network Improvements for Machine-Type Communications (NIMTC) / Text3: 37.868 / Text5: arnaud.meylan@huawei.com
- 133: SA1 TS 22.36 (Stage 1) to be approved before GERAN work starts / Text3: 45.8/9xy / Text5: Paul Schliwa-Bertling
- 134: Linked to SA5 Rel-9 UID_430044 TR 32.826 (Study on Telecommunication Management; Energy Savings Management) / Text3: 25.927 / Text5: Prakash Bhat
- 135: -

| ID | WBS | Task | Duration | Start | Finish | Complete | Remaining | Baseline start | Baseline finish | Baseline duration | Total slack | Constraint | Resources | Work | Actual work | Text1 | Text2 | Text4 | Text5 | Text6 | Text7 | Text8 | Text11 |
| --- | --- | --- | --- | --- | --- | --- | --- | --- | --- | --- | --- | --- | --- | --- | --- | --- | --- | --- | --- | --- | --- | --- | --- |
| 136 | 80 | **Enhanced Home NodeB / eNodeB** | 513d? | 2008-06-05 A | 2010-05-21 | 79% | 108.37d? | 2008-06-05 | 2010-05-21 | 513d? | 345d |  | S1,S2,S3,S5,R2,R3,R4,GP,C1 | 29896h | 23579.1h | EHNB | PCG-21 | T-Mobile | michael.kurz@t-mobile.at | Rel-9 | SP-40 | Alain |  |
| 137 | 80.1 | Stage 1 for EHNB | 261d? | 2008-06-05 A | 2009-06-04 A | 100% |  | 2008-06-05 | 2009-06-04 | 261d? |  | finish no earlier than 2009-06-04 | S1 | 2088h | 2088h | EHNB | PCG-21 | T-Mobile | michael.kurz@t-mobile.at | Rel-9 | SP-40 | Alain |  |
| 138 | 80.2 | Architecture aspects of EHNB | 266d? | 2008-09-18 A | 2009-09-24 A | 100% |  | 2008-09-18 | 2009-09-24 | 266d? |  | finish no earlier than 2009-09-22 | S2 | 2128h | 2128h | EHNB | PCG-21 | T-Mobile | Sebastian Speicher | Rel-9 | SP-41 | Maurice |  |
| 139 | 80.3 | Security aspects of Enhanced Home NodeB / eNodeB | 262d? | 2008-12-11 A | 2009-12-10 A | 100% |  | 2008-12-11 | 2009-12-10 | 262d? |  | finish no earlier than 2009-12-10 | S3 | 2096h | 2096h | EHNB-Sec | PCG-22 | Huawei | Marcus Wong (mwong@huawei.com) | Rel-9 | SP-42 | Dionisio |  |
| 140 | 80.4 | CT1 aspects - Support of Home NB and Home eNB enhancements | 131d? | 2009-09-18 A | 2010-03-19 | 95% | 6.55d? | 2009-09-18 | 2010-03-19 | 131d? | 390d | finish no earlier than 2010-03-19 | C1 | 1048h | 995.6h | EHNB-CT1 | PCG-23 | Qualcomm Europe | Ramachandran Subramanian (rsubrama@qualcomm.com) | Rel-9 | CP-45 | Frederic |  |
| 141 | 80.5 | CT6 aspects - Support of Home NB and Home eNB enhancements | 131d? | 2009-09-18 A | 2010-03-19 | 90% | 13.1d? | 2009-09-18 | 2010-03-19 | 131d? | 390d | finish no earlier than 2010-03-19 | C6 | 1048h | 943.2h | EHNB-CT6 | PCG-23 | Qualcomm Europe | Alfredo Ruvacalba | Rel-9 | CP-45 | Xavier |  |
| 142 | 80.6 | 3G HNB Gateway and LTE HeNB Gateway OAM&P | 336d? | 2008-12-11 A | 2010-03-25 | 60% | 134.4d? | 2008-12-11 | 2010-03-25 | 336d? | 386d | finish no earlier than 2010-03-25 | S5 | 2688h | 1612.8h | HNB-OAM_GW | PCG-22 | China Mobile | GangChen (chengang@chinamobile.com) | Rel-9 | SP-42 | Dionisio | SP-090743 |
| 143 | 80.7 | 3G HNB and LTE HeNB OAM&P Type 1 Interface | 272d? | 2009-03-12 A | 2010-03-25 | 60% | 108.8d? | 2009-03-12 | 2010-03-25 | 272d? | 386d | finish no earlier than 2010-03-25 | S5 | 2168h | 1297.6h | HNB_eHNB-OAM_Type1 | PCG-22 | Huawei | Zou Lan (zlan@huawei.com) | Rel-9 | SP-43 | Dionisio | SP-090744 |
| 144 | 80.8 | 3G HNB and LTE HeNB OAM&P Type 2 Interface | 225d? | 2009-05-15 A | 2010-03-25 | 60% | 90d? | 2009-05-15 | 2010-03-25 | 225d? | 386d | finish no earlier than 2010-03-25 | S5 | 1800h | 1080h | HNB_eHNB-OAM_Type2 | PCG-23 | Ericsson | edwin.tse@ericsson.com | Rel-9 | SP-44 | Dionisio | SP-090751 |
| 145 | 80.9 | LTE FDD Home eNodeB RF Requirements | 336d? | 2008-12-05 A | 2010-03-19 | 70% | 100.8d? | 2008-12-05 | 2010-03-19 | 336d? | 390d | finish no earlier than 2010-03-19 | R4 | 2688h | 1881.6h | HeNB-RF_FDD | PCG-22 | Motorola | Ying Cai (yingcai@motorola.com) | Rel-9 | RP-42 | Issam | RP-091047 |
| 146 | 80.10 | LTE TDD Home eNodeB RF Requirements | 271d? | 2009-03-06 A | 2010-03-19 | 80% | 54.2d? | 2009-03-06 | 2010-03-19 | 271d? | 390d | finish no earlier than 2010-03-19 | R4 | 2168h | 1734.4h | HeNB-RF_TDD | PCG-22 | China Mobile | Nan Li (linan@chinamobile.com) | Rel-9 | RP-43 | Issam | RP-091048 |
| 147 | 80.11 | Home NB and Home eNB enhancements - RAN3 aspects | 197d? | 2009-03-06 A | 2009-12-04 A | 100% |  | 2009-03-06 | 2009-12-04 | 197d? |  | finish no earlier than 2009-12-04 | R3 | 1576h | 1576h | EHNB-RAN3 | PCG-22 | Alcatel-Lucent | Martin Warner (mw15@alcatel-lucent.com) | Rel-9 | RP-43 | Juha | RP-091050 |
| 148 | 80.12 | Home NB and Home eNB enhancements - RAN2 aspects | 271d? | 2009-03-06 A | 2010-03-19 | 90% | 27.1d? | 2009-03-06 | 2010-03-19 | 271d? | 390d | finish no earlier than 2010-03-19 | R2 | 2168h | 1951.2h | EHNB-RAN2 | PCG-22 | Huawei | Yang Xudong (yangxudong@huawei.com) | Rel-9 | RP-43 | Joern | RP-091361 |
| 149 | 80.13 | Home NB and Home eNB enhancements - GERAN aspects | 266d? | 2009-05-18 A | 2010-05-21 | 45% | 146.3d? | 2009-05-18 | 2010-05-21 | 266d? | 345d | finish no earlier than 2010-05-21 | GP | 2128h | 957.6h | EHNB-GERAN | PCG-23 | Nokia Siemens Networks | Leonardo Provvedi | Rel-9 | GP-42 | Paolo |  |
| 150 | 81 | **Services Alignment and Migration** | 467d? | 2006-12-06 A | 2008-09-18 A | 100% |  | 2006-12-06 | 2008-09-18 | 467d? |  |  | S1 | 7472h | 7472h | ServAl |  | China Mobile | fenglingjuan@chinamobile.com | Rel-9 | SP-33 | Alain |  |
| 151 | 81.1 | Stage 1 for ServAl | 467d? | 2006-12-06 A | 2008-09-18 A | 100% |  | 2006-12-06 | 2008-09-18 | 467d? |  | finish no earlier than 2008-12-11 | S1 | 3736h | 3736h | ServAl | PCG-21 | China Mobile | fenglingjuan@chinamobile.com | Rel-9 | SP-33 | Alain |  |
| 152 | 82 | **Value-Added Services for Short Message Service** | 586d? | 2007-09-10 A | 2009-12-04 A | 100% |  | 2007-09-10 | 2009-12-04 | 586d? |  |  | S1,C4,C1 | 10888h | 10888h | VAS4SMS |  | China Mobile | Wu Bin (wubin@chinamobile.com) | Rel-9 | SP-37 | Alain |  |
| 153 | 82.1 | Stage 1 for VAS4SMS | 133d? | 2007-09-10 A | 2008-03-12 A | 100% |  | 2007-09-10 | 2008-03-12 | 133d? |  | finish no earlier than 2008-03-21 | S1 | 1064h | 1064h | VAS4SMS |  | China Mobile | Wu Bin (wubin@chinamobile.com) | Rel-9 | SP-37 | Alain |  |
| 154 | 82.2 | VAS4SMS Interface and Signalling Flow - CT4 aspects | 322d? | 2008-09-12 A | 2009-12-04 A | 100% |  | 2008-09-12 | 2009-12-04 | 322d? |  | finish no earlier than 2009-12-04 | C4 | 2568h | 2568h | VAS4SMS | PCG-21 | China Mobile | Wu Bin (wubin@chinamobile.com) | Rel-9 | CP-41 | Kimmo |  |
| 155 | 82.3 | VAS4SMS Interface and Signalling Flow - CT1 aspects | 321d? | 2008-09-09 A | 2009-12-04 A | 100% |  | 2008-09-09 | 2009-12-04 | 321d? |  | finish no earlier than 2009-12-04 | C1 | 2568h | 2568h | VAS4SMS | PCG-21 | China Mobile | Wu Bin (wubin@chinamobile.com) | Rel-9 | CP-41 | Frederic |  |
| 156 | 83 | **End-User Identity** | 334d? | 2007-09-03 A | 2008-12-11 A | 100% |  | 2007-09-03 | 2008-12-11 | 334d? |  |  | S1 | 5344h | 5344h | EUI |  | Nokia Siemens Networks | Juergen.Merkel@NSN.com | Rel-9 | SP-38 | Alain |  |
| 157 | 83.1 | Definition of EUI | 334d? | 2007-09-03 A | 2008-12-11 A | 100% |  | 2007-09-03 | 2008-12-11 | 334d? |  | finish no earlier than 2008-12-11 | S1 | 2672h | 2672h | EUI | PCG-21 | Nokia Siemens Networks | Juergen.Merkel@NSN.com | Rel-9 | SP-38 | Alain |  |
| 158 | 84 | **Customized Ringing Signal** | 598d? | 2007-12-06 A | 2010-03-19 | 93% | 39.78d? | 2007-12-06 | 2010-03-19 | 598d? | 390d |  | S1,C1 | 7728h | 4908.8h | CRS | PCG-21 | SK Telecom, China Mobile | Donghee Shim (SK Telecom), Jianping Zheng (China Mobile) | Rel-9 | SP-38 | Alain |  |
| 159 | 84.1 | Stage 1 for CRS | 266d? | 2007-12-06 A | 2008-12-11 A | 100% |  | 2007-12-06 | 2008-12-11 | 266d? |  | finish no earlier than 2008-12-11 | S1 | 2128h | 2128h | CRS | PCG-21 | SK Telecom, China Mobile | Donghee Shim (SK Telecom), Jianping Zheng (China Mobile) | Rel-9 | SP-38 | Alain |  |
| 160 | 84.2 | Stage 3 for IMS CRS Service | 212d? | 2009-05-29 A | 2010-03-19 | 85% | 31.8d? | 2009-05-29 | 2010-03-19 | 212d? | 390d | finish no earlier than 2010-03-19 | C1 | 816h | 652.8h | CRS | PCG-23 | China Mobile | wangzhao | Rel-9 | CP-44 | Frederic | CP-090868 |

Notes:
- 136: SP#43 WID updated SP-080791=>SP-090197 to include RAN items/BBs
- 137: SP#44 completed / Text3: 22.220, 22.011
- 138: SP#45 completed. TR 23.830 for Approval / Text3: 23.830, 23.401, 23.402, 23.060
- 139: SP#46 completed. TS 33.320 for Approval / Text3: new 33.320
- 140: CP#46 completion 12/09=>03/10. Roaming aspects for manual CSG selection, Support of temporary users and CSG membership changes, Support of user controlled and operator controlled lists / Text3: 23.122, 24.008, 24.285, 24.301
- 141: CP#46 completion 12/09=>03/10. Storing of CSG related data items on the USIM / Text3: 31.102
- 142: SP#46 exception to 03/10 in SP-090743. TS 32.771 & 32.781 v200 for Approval / Text3: 32.771, 32.772, 32.773, 32.775, 32.781, 32.782, 32.783, 32.785, 32.452, 32.453, 32.632, 32.633, 32.635
- 143: SP#46 exception to 03/10 in SP-090744. TS 32.593 v200 for Approval / Text3: 32.591, 32.592, 32.593, 32.594, 32.581, 32.582, 32.583, 32.584
- 144: SP#46 exception to 03/10 in SP-090751. SP#46 32.571 v100 for Information / Text3: new 32.571, 32.572
- 145: RP#46 exception to 03/10 in RP-091108. WID updated RP-081080=>RP-091300 / Text3: new TR 36.921, 36.104, 36.141
- 146: RP#46 exception to 03/10 in RP-091148. WID updated RP-090160=>RP-091386 / Text3: new TR 36.922, 36.104, 36.141, 36.300, 36.331, 36.413
- 147: RP#46 completed (based on high priority items specified in RP-090995) / Text3: 25.413, 25.467, 25.467, 25.468, 25.469, 25.469, 36.401, 36.413, new 25.444
- 148: RP#46 exception to 03/10 in RP-091442. WID updated RP-090351=>RP-091392 / Text3: 25.304, 25.331, 25.367, 36.300, 36.304, 36.331
- 149: GP#44 exception to 05/10 in GP-092474. GP#42 WID approved / Text3: 43.055, 43.129, 44.018, 44.060, 45.008, 48.008, 48.018
- 150: SP#41 Stage 1 completed. Triggered by Study UID_370086 (FSServAl).
- 151: SP#41 completed / Text3: 22.182
- 152: CP#46 completed. SP#43 Feature moved to Rel-9. Stage 1 TS 22.142 promoted to Rel-9 and dismissed the Rel-8 version.
- 153: SP#39 completed. SP#43 Feature moved to Rel-9. Stage 1 TS 22.142 promoted to Rel-9 and dismissed the Rel-8 version. / Text3: 22.142
- 154: CP#46 completed. WID updated CP-090021=>CP-090813 / Text3: new 23.142
- 155: CP#46 completed. WID updated CP-090021=>CP-090813 / Text3: 23.040
- 156: SP#42 completed. SP#44 WID updated SP-070651=>SP-090380 (reduced scope of the work)
- 157: SP#42 completed. SP#44 WID updated SP-070651=>SP-090380 (reduced scope of the work) / Text3: 21.905
- 158: SP#42 Stage 1 completed (need for Input in SA2). SP#41 WID updated SP-070875=>SP-080502
- 159: SP#42 completed. / Text3: 22.183, 22.173
- 160: CP#46 exception to 03/10 in CP-090868 / Text3: 24.173, new 24.183

| ID | WBS | Task | Type | Duration | Start | Finish | Complete | Remaining | Baseline start | Baseline finish | Baseline duration | Total slack | Constraint | Resources | Work | Actual work | Text1 | Text2 | Text4 | Text6 | Text7 | Text8 | Text3 | Text11 |
| --- | --- | --- | --- | --- | --- | --- | --- | --- | --- | --- | --- | --- | --- | --- | --- | --- | --- | --- | --- | --- | --- | --- | --- | --- |
| 161 | 85 | **Public Warning System** |  | 523d? | 2007-12-06 A | 2009-12-04 A | 100% |  | 2007-12-06 | 2009-12-04 | 523d? |  |  | S1,C1,C4,R2 | 10232h | 10232h | PWS | PCG-21 | T-Mobile | Rel-9 | SP-38 | Alain |  |  |
| 162 | 85.1 | Stage 1 for PWS |  | 266d? | 2007-12-06 A | 2008-12-11 A | 100% |  | 2007-12-06 | 2008-12-11 | 266d? |  | finish no earlier than 2008-12-11 | S1 | 2128h | 2128h | PWS | PCG-21 | T-Mobile | Rel-9 | SP-38 | Alain | 22.268 |  |
| 163 | 85.2 | **Stage 3 for PWS** |  | 137d? | 2009-05-29 A | 2009-12-04 A | 100% |  | 2009-05-29 | 2009-12-04 | 137d? |  |  | C1,C4 | 3272h | 3272h | PWS-St3 | PCG-23 | Qualcomm Europe | Rel-9 | CP-44 | Frederic |  |  |
| 164 | 85.2.1 | CT1 aspects of PWS-St3 |  | 137d? | 2009-05-29 A | 2009-12-04 A | 100% |  | 2009-05-29 | 2009-12-04 | 137d? |  | finish no earlier than 2009-12-04 | C1 | 1088h | 1088h | PWS-St3 | PCG-23 | Qualcomm Europe | Rel-9 | CP-44 | Frederic | 23.041 |  |
| 165 | 85.2.2 | CT4 aspects of PWS-St3 |  | 136d? | 2009-05-30 A | 2009-12-04 A | 100% |  | 2009-05-30 | 2009-12-04 | 136d? |  | finish no earlier than 2009-12-04 | C4 | 1088h | 1088h | PWS-St3 | PCG-23 | Qualcomm Europe | Rel-9 | CP-44 | Kimmo | 29.168 |  |
| 166 | 85.3 | Public Warning System (PWS) – RAN aspects |  | 81d? | 2009-05-30 A | 2009-12-04 A | 100% |  | 2009-05-30 | 2009-12-04 | 81d? |  | finish no earlier than 2009-12-04 | R2,R3 | 648h | 648h | PWS-RAN | PCG-23 | AT&T | Rel-9 | RP-44 | Joern | 36.300, 36.302, 36.331, 36.413 | RP-091052 |
| 167 | 86 | **Enhancements to Multimedia Priority Service** |  | 584d? | 2006-03-13 A | 2008-06-05 A | 100% |  | 2006-03-13 | 2008-06-05 | 584d? |  |  | S1 | 4672h | 4672h | ePRIOR | PCG-21 | Telcordia | Rel-9 | SP-39 | Alain |  |  |
| 168 | 86.1 | Stage 1 for ePRIOR |  | 584d? | 2006-03-13 A | 2008-06-05 A | 100% |  | 2006-03-13 | 2008-06-05 | 584d? |  | start no earlier than 2006-03-12 | S1 | 4672h | 4672h | ePRIOR | PCG-21 | Telcordia | Rel-9 | SP-39 | Alain | 22.153, 22.278 |  |
| 169 | 87 | **Support of Personal Area Networks and Enhancements to Personal Network Management** |  | 468d? | 2008-06-05 A | 2010-03-19 | 83% | 81.47d? | 2008-06-05 | 2010-03-19 | 468d? | 390d |  | S1,C1 | 7480h | 6177.81h | PAN_EPNM | PCG-21 | Vodafone | Rel-9 | SP-40 | Alain |  |  |
| 170 | 87.1 | Stage 1 for PAN_EPNM | milestone | 0d? | 2008-06-05 A | 2008-06-05 A | 100% |  | 2008-06-05 | 2008-06-05 | 0d? |  | finish no earlier than 2008-06-05 | S1 |  |  | PAN_EPNM | PCG-21 | Vodafone | Rel-9 | SP-40 | Alain | 22.259 |  |
| 171 | 87.2 | Stage 2 for PAN_EPNM |  | 196d? | 2009-03-06 A | 2009-12-04 A | 100% |  | 2009-03-06 | 2009-12-04 | 196d? |  | finish no earlier than 2009-12-04 | C1 | 1568h | 1568h | PAN_EPNM | PCG-22 | Huawei | Rel-9 | CP-43 | Frederic | 23.259 |  |
| 172 | 87.3 | Stage 3 for PAN_EPNM |  | 271d? | 2009-03-09 A | 2010-03-19 | 70% | 81.3d? | 2009-03-09 | 2010-03-19 | 271d? | 390d | finish no earlier than 2010-03-19 | C1 | 2168h | 1517.6h | PAN_EPNM | PCG-22 | Huawei | Rel-9 | CP-43 | Frederic | 24.259 | CP-090879 |
| 173 | 88 | **Multi-Media Telephony Service enhancements** |  | 472d? | 2008-06-05 A | 2010-03-25 | 87% | 62.87d? | 2008-06-05 | 2010-03-25 | 472d? | 386d |  | S1,S5,C1 | 10288h | 8916.67h | eMMTel | PCG-21 | France Telecom | Rel-9 | SP-40 | Alain |  |  |
| 174 | 88.1 | Stage 1 for eMMTel |  | 136d? | 2008-06-05 A | 2008-12-11 A | 100% |  | 2008-06-05 | 2008-12-11 | 136d? |  | start no earlier than 2008-06-05 | S1 | 1088h | 1088h | eMMTel | PCG-21 | France Telecom | Rel-9 | SP-40 | Alain | 22.173 |  |
| 175 | 88.2 | Multimedia Telephony (MMTel) Service and Supplementary Services - Online Charging and completion for Offline Charging (all supplementary services) |  | 272d? | 2009-03-12 A | 2010-03-25 | 85% | 40.8d? | 2009-03-12 | 2010-03-25 | 272d? | 386d | finish no earlier than 2010-03-25 | S5 | 2168h | 1841.6h | eMMTel-SS-CH | PCG-22 | Alcatel-Lucent | Rel-9 | SP-43 | Dionisio | 32.275, 32.298, 32.299 | SP-090753 |
| 176 | 88.3 | Support of Real-time Transfer of Tariff Information (RTTI) in IMS charging |  | 271d? | 2009-03-12 A | 2010-03-25 | 75% | 67.75d? | 2009-03-12 | 2010-03-25 | 271d? | 386d | finish no earlier than 2010-03-25 | S5 | 2168h | 1626h | IMSTSS-RTTI-CH | PCG-22 | Orange | Rel-9 | SP-43 | Dionisio | 32.27x, 32.240, 32.280, 32.298, 32.299 | SP-090754 |
| 177 | 88.4 | Stage 3 - Enhancements for Completion of Communications Supplementary service |  | 136d? | 2009-05-30 A | 2009-12-04 A | 100% |  | 2009-05-30 | 2009-12-04 | 136d? |  | finish no earlier than 2009-12-04 | C1 | 1088h | 1088h | eMMTel-CC | PCG-23 | France Telecom | Rel-9 | CP-44 | Frederic | 24.642 |  |
| 178 | 89 | **User Data Convergence** |  | 472d? | 2008-06-05 A | 2010-03-25 | 60% | 188.65d? | 2008-06-05 | 2010-03-25 | 472d? | 386d |  | S1,S5,C4 | 13136h | 7716.38h | UDC | PCG-21 | China Mobile | Rel-9 | SP-40 | Alain |  |  |
| 179 | 89.1 | Stage 1 for UDC |  | 136d? | 2008-06-05 A | 2008-12-11 A | 100% |  | 2008-06-05 | 2008-12-11 | 136d? |  | start no earlier than 2008-06-05 | S1 | 1088h | 1088h | UDC | PCG-21 | China Mobile | Rel-9 | SP-40 | Alain | 22.985, 22.101 |  |
| 180 | 89.2 | UDC Technical Realization (Stage 2) |  | 271d? | 2009-03-06 A | 2010-03-19 | 70% | 81.3d? | 2009-03-06 | 2010-03-19 | 271d? | 390d | finish no earlier than 2010-03-19 | C4 | 2168h | 1517.6h | UDC-CN | PCG-22 | Ericsson | Rel-9 | CP-43 | Kimmo | new 23.335 | CP-090805 |
| 181 | 89.3 | UDC Protocol Description |  | 130d? | 2009-09-18 A | 2010-03-19 | 30% | 91d? | 2009-09-18 | 2010-03-19 | 130d? | 390d | finish no earlier than 2010-03-19 | C4 | 1040h | 312h | UDC-CN | PCG-23 | China Mobile, Ericsson | Rel-9 | CP-45 | Kimmo | 29.335 | CP-090805 |
| 182 | 89.4 | **User Data Convergence - Modelling and Management** |  | 211d? | 2009-06-04 A | 2010-03-25 | 50% | 105.5d? | 2009-06-04 | 2010-03-25 | 211d? | 386d |  | S5 | 5064h | 2532h | UDC-MMAN | PCG-23 | T-Mobile, China Mobile, Ericsson | Rel-9 | SP-44 | Dionisio |  |  |
| 183 | 89.4.1 | UDC – Framework for Model Handling and Management |  | 211d? | 2009-06-04 A | 2010-03-25 | 30% | 147.7d? | 2009-06-04 | 2010-03-25 | 211d? | 386d | finish no earlier than 2010-03-25 | S5 | 1688h | 506.4h | UDC-MMAN-MFRM | PCG-23 | T-Mobile | Rel-9 | SP-44 | Dionisio | 32.172, new 32.181 | SP-090748 |
| 184 | 89.4.2 | UDC – Common Baseline Information Model |  | 211d? | 2009-06-04 A | 2010-03-25 | 70% | 63.3d? | 2009-06-04 | 2010-03-25 | 211d? | 386d | finish no earlier than 2010-03-25 | S5 | 1688h | 1181.6h | UDC-MMAN-CBIM | PCG-23 | China Mobile, Ericsson | Rel-9 | SP-44 | Dionisio | 32.172, new 32.182 | SP-090747 |

Notes:
- 161: TSG#46 completed. Larger scope than Rel-8 Feature UID_370051 (ETWS). Triggered by TR 22.968 Study UID_320025 (FS_PWS) / Text5: Mark.Younge@t-mobile.com
- 162: SP#42 completed / Text5: Mark.Younge@t-mobile.com
- 163: RP#46 completed / Text5: Ramachandran Subramanian (rsubrama@qualcomm.com)
- 164: CP#46 completed / Text5: Ramachandran Subramanian (rsubrama@qualcomm.com)
- 165: CP#46 completed / Text5: Ramachandran Subramanian (rsubrama@qualcomm.com)
- 166: RP#46 completed / Text5: don.zelmer@att.com
- 167: SP#40 Stage 1 completed. Continuation of Rel-8 Feature PRIOR UID_340044. / Text5: jgarraha@telcordia.com
- 168: SP#40 completed / Text5: jgarraha@telcordia.com
- 169: SP#40 WID approved & Stage 1 completed / Text5: armin.toepfer@vodafone.com
- 170: SP#40 Stage 1 completed / Text5: armin.toepfer@vodafone.com
- 171: CP#46 completed. CP#44 WID updated CP-090113=>CP-090435 Removed: Mechanism for a PNE without a (U)SIM capable of discovering PNEs with a (U)SIM in its proximity / Text5: Lili Yang (kadyyang@huawei.com)
- 172: CP#46 exception to 03/10 in CP-090879 / Text5: Lili Yang (kadyyang@huawei.com)
- 173: SP#42 Stage 1 completed. SP#41 WID updated SP-080324=>SP-080503 / Text5: Philippe Lottin
- 174: SP#42 completed. SP#41 WID updated SP-080324=>SP-080503 / Text5: Philippe Lottin
- 175: SP#46 exception to 03/10 in SP-090753 / Text5: Maryse.Gardella@alcatel-lucent.fr
- 176: SP#46 exception to 03/10 in SP-090754. Linked to SA5 Rel-8 UID_380042 AoC support in IMS Charging (IMSTSS) / Text5: Jean-Luc Garcia (jl.garcia@orange-ftgroup.com)
- 177: CP#46 completed / Text5: Youssef.chadli@orange-ftgroup.com
- 178: SP#42 Stage 1 completed / Text5: lansizhong@chinamobile.com
- 179: SP#42 completed / Text5: lansizhong@chinamobile.com
- 180: CP#46 exception to 03/10 in CP-090805 / Text5: Emiliano Merino (emiliano.merino@ericsson.com)
- 181: CP#46 exception to 03/10 in CP-090805 / Text5: Lan Si Zhong (lansizhong@chinamobile.com), emiliano.merino@ericsson.com
- 182: SP#46 exception to 03/10 / Text5: Istvan Aba, Lan Si Zhong, Miguel Garcia
- 183: SP#46 exception to 03/10 in SP-090748 / Text5: istvan.aba <at> t-mobile.at
- 184: SP#46 exception to 03/10 in SP-090747. 32.182 v100 for Information / Text5: Istvan Aba, Lan Si Zhong, Miguel Garcia

| ID | WBS | Task | Duration | Start | Finish | Complete | Remaining | Baseline start | Baseline finish | Baseline duration | Total slack | Constraint | Resources | Work | Actual work | Text1 | Text2 | Text4 | Text5 | Text6 | Text7 | Text8 | Text11 |
| --- | --- | --- | --- | --- | --- | --- | --- | --- | --- | --- | --- | --- | --- | --- | --- | --- | --- | --- | --- | --- | --- | --- | --- |
| 185 | 90 | **IMS Services Centralization and Continuity** | 393d? | 2008-09-18 A | 2010-03-19 | 91% | 35.13d? | 2008-09-18 | 2010-03-19 | 393d? | 390d |  | S1,S2,C1 | 12160h | 8522.88h | IMS_SCC | PCG-21 | NEC | Joerg Swetina (joerg.swetina@nw.neclab.eu) | Rel-9 | SP-41 | Alain |  |
| 186 | 90.1 | Stage 1 - Inter-Device Transfer – Requirements | 61d? | 2008-09-18 A | 2008-12-11 A | 100% |  | 2008-09-18 | 2008-12-11 | 61d? |  | finish no earlier than 2009-06-18 | S1 | 488h | 488h | IMS_SCC-IDT | PCG-21 | NEC | Joerg Swetina (joerg.swetina@nw.neclab.eu) | Rel-9 | SP-41 | Alain |  |
| 187 | 90.2 | Stage 2 - IMS Service Continuity Enhancements: Service, Policy and Interactions | 186d? | 2008-09-18 A | 2009-06-04 A | 100% |  | 2008-09-18 | 2009-06-04 | 186d? |  | finish no earlier than 2009-06-04 | S2 | 1488h | 1488h | IMS_SCC-SPI | PCG-21 | Huawei | HengLiang Zhang (hl_zhang@huawei.com) | Rel-9 | SP-41 | Maurice |  |
| 188 | 90.3 | Stage 3 - IMS Service Continuity Enhancements: Service, Policy, Interactions and Inter UE Transfer | 212d? | 2009-05-29 A | 2010-03-19 | 80% | 42.4d? | 2009-05-29 | 2010-03-19 | 212d? | 390d | finish no earlier than 2010-03-19 | C1 | 1696h | 1356.8h | IMS_SCC-SPI | PCG-23 | Qualcomm Europe | Roozbeh Atarius (ratarius@qualcomm.com) | Rel-9 | CP-44 | Frederic | CP-090875 |
| 189 | 90.4 | Stage 2 - IMS Centralized Services | 186d? | 2008-09-18 A | 2009-06-04 A | 100% |  | 2008-09-18 | 2009-06-04 | 186d? |  | finish no earlier than 2009-06-04 | S2 | 1488h | 1488h | IMS_SCC-ICS | PCG-21 | Alcatel-Lucent | Andy Bennett (andybennett@alcatel-lucent.com) | Rel-9 | SP-41 | Maurice |  |
| 190 | 90.5 | Stage 3 - Enhancements to IMS Centralized Services | 212d? | 2009-05-29 A | 2010-03-19 | 98% | 4.24d? | 2009-05-29 | 2010-03-19 | 212d? | 390d | finish no earlier than 2010-03-19 | C1 | 1688h | 1654.08h | IMS_SCC-ICS | PCG-23 | Nokia Siemens Networks | Peter.Leis@nsn.com | Rel-9 | CP-44 | Frederic |  |
| 191 | 90.6 | Stage 3 - IMS Centralized Services support via I1 interface | 271d? | 2009-03-06 A | 2010-03-19 | 80% | 54.2d? | 2009-03-06 | 2010-03-19 | 271d? | 390d | finish no earlier than 2010-03-19 | C1 | 2168h | 1734.4h | IMS_SCC-ICS_I1 | PCG-22 | Huawei | Lili Yang(kadyyang@huawei.com) | Rel-9 | CP-43 | Frederic | CP-090874 |
| 192 | 91 | **Service Specific Access Control in EPS** | 333d? | 2008-12-11 A | 2010-03-19 | 85% | 49.72d? | 2008-12-11 | 2010-03-19 | 333d? | 390d |  | S1,C1 | 4368h | 1457.6h | SSAC | PCG-22 | NTT DoCoMo | Frederic Thepot (thepot@docomolab-euro.com) | Rel-9 | SP-42 | Alain |  |
| 193 | 91.1 | Stage 1 for SSAC | 1d? | 2008-12-11 A | 2008-12-11 A | 100% |  | 2008-12-11 | 2008-12-11 | 1d? |  | start no earlier than 2008-12-11 | S1 | 8h | 8h | SSAC | PCG-22 | NTT DoCoMo | Frederic Thepot (thepot@docomolab-euro.com) | Rel-9 | SP-42 | Alain |  |
| 194 | 91.2 | Stage 3 for SSAC | 212d? | 2009-05-29 A | 2010-03-19 | 85% | 31.8d? | 2009-05-29 | 2010-03-19 | 212d? | 390d | finish no earlier than 2010-03-19 | C1 | 1696h | 1441.6h | SSAC | PCG-23 | NTT DoCoMo | Hideyuki Yamashita (yamashitahi@s1.nttdocomo.co.jp) | Rel-9 | CP-44 | Frederic | CP-090880 |
| 195 | 92 | **Support for IMS Emergency Calls over GPRS and EPS** | 575d? | 2008-01-14 A | 2010-03-25 | 96% | 20.59d? | 2008-01-14 | 2010-03-25 | 575d? | 386d |  | S1,S2,S3,C1,C3,C4,R2,R3 | 24771.7h | 19801.5h | IMS_EMER_GPRS_EPS | PCG-21 | Alcatel-Lucent | Deborah Barclay | Rel-9 | SP-38 | Maurice |  |
| 196 | 92.1 | Stage 1 of IMS_EMER_GPRS_EPS | 239d? | 2008-01-14 A | 2008-12-11 A | 100% |  | 2008-01-14 | 2008-12-11 | 239d? |  | finish no earlier than 2008-12-11 | S1 | 1912h | 1912h | IMS_EMER_GPRS_EPS | PCG-21 | Alcatel-Lucent | Deborah Barclay | Rel-9 | SP-38 | Alain |  |
| 197 | 92.2 | Stage 2 of IMS_EMER_GPRS_EPS | 364d? | 2008-01-14 A | 2009-06-04 A | 100% |  | 2008-01-14 | 2009-06-04 | 364d? |  | finish no earlier than 2009-06-04 | S2 | 2912h | 2912h | IMS_EMER_GPRS_EPS | PCG-21 | Alcatel-Lucent | Deborah Barclay | Rel-9 | SP-38 | Maurice |  |
| 198 | 92.3 | Security aspects of IMS_EMER_GPRS_EPS | 336d? | 2008-12-12 A | 2010-03-25 | 80% | 67.2d? | 2008-12-12 | 2010-03-25 | 336d? | 386d | finish no earlier than 2010-03-25 | S3 | 2688h | 2150.4h | IMS_EMER_GPRS_EPS-Sec | PCG-22 | Alcatel-Lucent | Deborah Barclay | Rel-9 | SP-42 | Dionisio |  |
| 199 | 92.4 | **Stage 3 of IMS_EMER_GPRS_EPS** | 212d? | 2009-05-29 A | 2010-03-19 | 98% | 5.21d? | 2009-05-29 | 2010-03-19 | 212d? | 390d |  | C1,C3,C4 | 5139.68h | 3395.15h | IMS_EMER_GPRS_EPS | PCG-23 | Alcatel-Lucent | Frank Alfano (falfano@alcatel-lucent.com) | Rel-9 | CP-44 | Frederic |  |
| 200 | 92.4.1 | CT1 aspects - Stage 3 of IMS_EMER_GPRS_EPS | 212d? | 2009-05-29 A | 2010-03-19 | 95% | 10.6d? | 2009-05-29 | 2010-03-19 | 212d? | 390d | finish no earlier than 2010-03-19 | C1 | 1696h | 1611.2h | IMS_EMER_GPRS_EPS | PCG-23 | Alcatel-Lucent | Frank Alfano (falfano@alcatel-lucent.com) | Rel-9 | CP-44 | Frederic | CP-090873 |
| 201 | 92.4.2 | CT3 aspects - Stage 3 of IMS_EMER_GPRS_EPS | 82d? | 2009-05-29 A | 2009-09-18 A | 100% |  | 2009-05-29 | 2009-09-18 | 82d? |  | start no earlier than 2009-05-29 | C3 | 651.68h | 651.68h | IMS_EMER_GPRS_EPS | PCG-23 | Alcatel-Lucent | Frank Alfano (falfano@alcatel-lucent.com) | Rel-9 | CP-44 | Gwiho |  |
| 202 | 92.4.3 | CT4 aspects - Stage 3 of IMS_EMER_GPRS_EPS | 137d? | 2009-05-29 A | 2009-12-04 A | 100% |  | 2009-05-29 | 2009-12-04 | 137d? |  | finish no earlier than 2009-12-04 | C4 | 1096h | 1096h | IMS_EMER_GPRS_EPS | PCG-23 | Alcatel-Lucent | Frank Alfano (falfano@alcatel-lucent.com) | Rel-9 | CP-44 | Kimmo |  |
| 203 | 92.5 | Support for IMS Emergency Calls over LTE | 206d? | 2008-12-05 A | 2009-09-18 A | 100% |  | 2008-12-05 | 2009-09-18 | 206d? |  |  | R2,R3 | 1648h | 1648h | IMS_EMER_LTE | PCG-22 | Alcatel-Lucent | Sudeep Palat (spalat@alcatel-lucent.com) | Rel-9 | RP-42 | Joern | RP-090698 |
| 204 | 92.6 | **SRVCC support for IMS Emergency Calls** | 322d? | 2008-09-18 A | 2009-12-10 A | 100% |  | 2008-09-18 | 2009-12-10 | 322d? |  |  | S2,C1,C4,C3 | 5872h | 5872h | IMS_EMER_GPRS_EPS-SRVCC | PCG-21 | China Mobile | Yu Qing (Yuqing@chinamobile.com) | Rel-9 | SP-41 | Maurice |  |
| 205 | 92.6.1 | SRVCC support for IMS Emergency Calls | 322d? | 2008-09-18 A | 2009-12-10 A | 100% |  | 2008-09-18 | 2009-12-10 | 322d? |  | finish no earlier than 2009-12-10 | S2 | 2576h | 2576h | IMS_EMER_GPRS_EPS-SRVCC | PCG-21 | China Mobile | Yu Qing (Yuqing@chinamobile.com) | Rel-9 | SP-41 | Maurice |  |
| 206 | 92.6.2 | **CT aspects of SRVCC support for IMS Emergency Calls** | 137d? | 2009-05-29 A | 2009-12-04 A | 100% |  | 2009-05-29 | 2009-12-04 | 137d? |  |  | C1,C4,C3 | 3296h | 3296h | IMS_EMER_GPRS_EPS-SRVCC | PCG-24 | China Mobile | jiangyi@chinamobile.com | Rel-9 | CP-46 | Frederic |  |
| 207 | 92.6.2.1 | CT1 aspects of SRVCC support for IMS Emergency Calls | 137d? | 2009-05-29 A | 2009-12-04 A | 100% |  | 2009-05-29 | 2009-12-04 | 137d? |  | finish no earlier than 2009-12-04 | C1 | 1096h | 1096h | IMS_EMER_GPRS_EPS-SRVCC | PCG-23 | China Mobile | jiangyi@chinamobile.com | Rel-9 | CP-44 | Frederic |  |
| 208 | 92.6.2.2 | CT4 aspects of SRVCC support for IMS Emergency Calls | 137d? | 2009-05-29 A | 2009-12-04 A | 100% |  | 2009-05-29 | 2009-12-04 | 137d? |  | finish no earlier than 2009-12-04 | C4 | 1096h | 1096h | IMS_EMER_GPRS_EPS-SRVCC | PCG-23 | China Mobile | jiangyi@chinamobile.com | Rel-9 | CP-44 | Kimmo |  |
| 209 | 92.6.2.3 | CT3 aspects of SRVCC support for IMS Emergency Calls | 1d? | 2009-12-04 A | 2009-12-04 A | 100% |  | 2009-12-04 | 2009-12-04 | 1d? |  | finish no earlier than 2009-12-04 | C3 | 8h | 8h | IMS_EMER_GPRS_EPS-SRVCC | PCG-24 | China Mobile | jiangyi@chinamobile.com | Rel-9 | CP-46 | Kimmo |  |

Notes:
- 185: SP#42 Stage 1 completed.
- 186: SP#42 completed / Text3: 22.101, 22.228
- 187: SP#44 completed. TR 23.838 for Approval / Text3: 23.838, 23.237, 23.292, 23.216
- 188: CP#46 exception to 03/10 in CP-090875 / Text3: 24.216, 24.229, 24.237
- 189: SP#44 completed. TR 23.883 for Information + Approval / Text3: 23.883, 23.292
- 190: CP#46 completion 12/09=>03/10. WID updated CP-090439=>CP-090883 (added ICS support of video media over CS bearer) / Text3: 24.292, 24.604, 24.607, 24.608, 24.611, 24.623
- 191: CP#46 exception to 03/10 in CP-090874 / Text3: 24.237, 24.292, new 24.294
- 192: SP#42 Stage 1 completed (need for SA2 input). Triggered by Study UID_400036 on Service Specific Access Control in EPS (FS_SSAC)
- 193: SP#42 completed / Text3: 22.011 CR0136
- 194: CP#46 exception to 03/10 in CP-090880. WID updated CP-090443=>CP-090885 / Text3: 24.173, 27.007
- 195: SP#42 Stage 1 completed. WID updated SP-070820=>SP-080352=>SP-080844 (Add SA3 task).
- 196: SP#42 completed / Text3: 22.101
- 197: SP#44 completed / Text3: 23.869, 23.060, 23.167, 23.203, 23.221, 23.228, 23.271, 23.401, 23.402
- 198: SP#46 completion 12/09=>03/10 (no exception requested !?). SP#42 WID updated SP-080352=>SP-080844 (Added SA3 task) / Text3: 33.401, 33.402
- 199: CP#45 WID updated CP-090441=>CP-090564
- 200: CP#46 exception to 03/10 in CP-090873 / Text3: 23.122, 24.008, 24.229, 24.301, 24.302
- 201: CP#45 completed / Text3: 29.212, 29.213, 29.214, 29.215
- 202: CP#46 completed / Text3: 23.003, 23.008, 29.060, 29.272, 29.273, 29.274, 29.275, 29.276
- 203: RP#45 completed / Text3: 36.331, 36.413
- 204: CP/SP#46 completed
- 205: SP#46 completed. SP#43 WID updated SP-080562=>SP-090099 (added location continuity aspects) / Text3: 23.870, 23.216, 23.237
- 206: CP#46 completed. WID updated CP-090436=>CP-090882 (added CT3 part)
- 207: CP#46 completed / Text3: 24.229, 24.237
- 208: CP#46 completed / Text3: 29.205, 29.280
- 209: CP#46 completed / Text3: 29.163

| ID | WBS | Task | Duration | Start | Finish | Complete | Remaining | Baseline start | Baseline finish | Baseline duration | Total slack | Constraint | Resources | Work | Actual work | Text1 | Text2 | Text6 | Text7 | Text8 | Text4 | Text5 | Text11 |
| --- | --- | --- | --- | --- | --- | --- | --- | --- | --- | --- | --- | --- | --- | --- | --- | --- | --- | --- | --- | --- | --- | --- | --- |
| 210 | 93 | **LCS for LTE and EPS** | 468d? | 2008-06-05 A | 2010-03-19 | 73% | 126.9d? | 2008-06-05 | 2010-03-19 | 468d? | 390d |  | S2,C1,C4,R2,R1,R3,R4 | 17832h | 13316.8h | LCS_LTE_EPS | PCG-22 | Rel-9 | SP-43 | Maurice |  |  |  |
| 211 | 93.1 | **LCS Control Plane Solution for EPS** | 468d? | 2008-06-05 A | 2010-03-19 | 81% | 86.9d? | 2008-06-05 | 2010-03-19 | 468d? | 390d |  | S2,C4,C1 | 9224h | 7511.16h | LCS_EPS-CPS | PCG-21 | Rel-9 | SP-40 | Maurice | Polaris Wireless | Robert Gross |  |
| 212 | 93.1.1 | Stage 2 for LCS_CPS_EPS | 261d? | 2008-06-05 A | 2009-06-04 A | 100% |  | 2008-06-05 | 2009-06-04 | 261d? |  | finish no earlier than 2009-06-04 | S2 | 2088h | 2088h | LCS_EPS-CPS | PCG-21 | Rel-9 | SP-40 | Maurice | Polaris Wireless | Robert Gross |  |
| 213 | 93.1.2 | CT4 aspects - Control Plane LCS in the EPC | 212d? | 2009-05-29 A | 2010-03-19 | 80% | 42.4d? | 2009-05-29 | 2010-03-19 | 212d? | 390d | finish no earlier than 2010-03-19 | C4 | 1696h | 1356.8h | LCS_EPS-CPS | PCG-23 | Rel-9 | CP-44 | Kimmo | Polaris Wireless | Robert Gross | CP-090808 |
| 214 | 93.1.3 | CT1 aspects - Control Plane LCS in the EPC | 212d? | 2009-05-29 A | 2010-03-19 | 60% | 84.8d? | 2009-05-29 | 2010-03-19 | 212d? | 390d | finish no earlier than 2010-03-19 | C1 | 1696h | 1017.6h | LCS_EPS-CPS | PCG-23 | Rel-9 | CP-44 | Frederic | Polaris Wireless | Robert Gross | CP-090876 |
| 215 | 93.2 | Positioning Support for LTE | 337d? | 2008-12-05 A | 2010-03-19 | 90% | 33.7d? | 2008-12-05 | 2010-03-19 | 337d? | 390d | finish no earlier than 2010-03-19 | R2,R1,R3,R4 | 2696h | 2426.4h | LCS_LTE | PCG-22 | Rel-9 | RP-42 | Joern | Qualcomm Europe | Nathan Tenny (ntenny@qualcomm.com) | RP-091042 |
| 216 | 93.3 | Network-Based Positioning Support in LTE | 271d? | 2009-03-09 A | 2010-03-19 | 30% | 189.7d? | 2009-03-09 | 2010-03-19 | 271d? | 390d | finish no earlier than 2010-03-19 | R2,R3,R4 | 2168h | 650.4h | LCS_LTE-NBPS | PCG-22 | Rel-9 | RP-43 | Joern | TruePosition | terri.brooks@trueposition.com | RP-091043 |
| 217 | 94 | **MBMS support in EPS** | 468d? | 2008-06-05 A | 2010-03-19 | 99% | 5d? | 2008-06-05 | 2010-03-19 | 468d? | 390d |  | S2,S3,S5,C3,C4,R2,R3,R4 | 13880h | 13731.6h | MBMS_EPS | PCG-21 | Rel-9 | SP-40 | Maurice | China Mobile | Liu Hong (liuhongyfw@chinamobile.com) |  |
| 218 | 94.1 | Stage 2 for MBMS_EPS | 261d? | 2008-06-05 A | 2009-06-04 A | 100% |  | 2008-06-05 | 2009-06-04 | 261d? |  | finish no earlier than 2009-06-04 | S2 | 2088h | 2088h | MBMS_EPS | PCG-21 | Rel-9 | SP-40 | Maurice | China Mobile | Liu Hong (liuhongyfw@chinamobile.com) |  |
| 219 | 94.2 | Security for MBMS_EPS | 261d? | 2008-12-11 A | 2009-12-10 A | 100% |  | 2008-12-11 | 2009-12-10 | 261d? |  | finish no earlier than 2009-12-10 | S3 | 2088h | 2088h | MBMS_EPS | PCG-22 | Rel-9 | SP-42 | Dionisio | China Mobile | Liu Hong (liuhongyfw@chinamobile.com) |  |
| 220 | 94.3 | MBMS Charging in EPS | 201d? | 2009-03-06 A | 2009-12-10 A | 100% |  | 2009-03-06 | 2009-12-10 | 201d? |  | finish no earlier than 2009-12-10 | S5 | 1600h | 1600h | MBMS_EPS | PCG-22 | Rel-9 | SP-43 | Dionisio | ZTE | guo.wenjie1@zte.com.cn |  |
| 221 | 94.4 | CT4 aspects of MBMS support in EPS (Stage 3) | 137d? | 2009-05-29 A | 2009-12-04 A | 100% |  | 2009-05-29 | 2009-12-04 | 137d? |  | finish no earlier than 2009-12-04 | C4 | 1096h | 1096h | MBMS_EPS | PCG-23 | Rel-9 | CP-44 | Kimmo | China Mobile, ZTE | wangjingyf@chinamobile.com, lu.fei1@zte.com.cn |  |
| 222 | 94.5 | CT3 aspects of MBMS support in EPS (Stage 3) | 137d? | 2009-05-29 A | 2009-12-04 A | 100% |  | 2009-05-29 | 2009-12-04 | 137d? |  | start no earlier than 2009-05-29 | C3 | 1096h | 1096h | MBMS_EPS | PCG-23 | Rel-9 | CP-44 | Gwiho | ZTE, China Mobile | zhou.xiaoyun@zte.com.cn, wangjingyf@chinamobile.com |  |
| 223 | 94.6 | MBMS support in LTE | 271d? | 2009-03-06 A | 2010-03-19 | 95% | 13.55d? | 2009-03-06 | 2010-03-19 | 271d? | 390d | finish no earlier than 2010-03-19 | R2,R3,R4 | 2168h | 2059.6h | MBMS_LTE | PCG-22 | Rel-9 | RP-43 | Joern | Huawei | arnaud.meylan@huawei.com | RP-091044 |
| 224 | 95 | **Access Network Discovery and Selection Function enhancements** | 333d? | 2008-12-11 A | 2010-03-19 | 85% | 50.92d? | 2008-12-11 | 2010-03-19 | 333d? | 390d |  | S2,C1 | 4720h | 2757.6h | eANDSF | PCG-22 | Rel-9 | SP-42 | Maurice | Motorola | Apostolis Salkintzis (salki@motorola.com) |  |
| 225 | 95.1 | Stage 2 for eANDSF | 126d? | 2008-12-11 A | 2009-06-04 A | 100% |  | 2008-12-11 | 2009-06-04 | 126d? |  | finish no earlier than 2009-06-04 | S2 | 1008h | 1008h | eANDSF | PCG-22 | Rel-9 | SP-42 | Maurice | Motorola | Apostolis Salkintzis (salki@motorola.com) |  |
| 226 | 95.2 | CT1 aspects - eANDSF | 131d? | 2009-09-18 A | 2010-03-19 | 70% | 39.3d? | 2009-09-18 | 2010-03-19 | 131d? | 390d | finish no earlier than 2010-03-19 | C1 | 1048h | 733.6h | eANDSF | PCG-23 | Rel-9 | CP-45 | Frederic | Panasonic | benjamin.limck@sg.panasonic.com | CP-090869 |
| 227 | 96 | **Multiple PDN Connection to the Same APN for PMIP-based Interfaces** | 267d? | 2009-03-13 A | 2010-03-19 | 95% | 14.1d? | 2009-03-13 | 2010-03-19 | 267d? | 390d |  | S2,C4,C1 | 4120h | 2367.2h | MUPSAP | PCG-22 | Rel-9 | SP-43 | Maurice | Samsung | erik.guttman@partner.samsung.com |  |
| 228 | 96.1 | Stage 2 for MUPSAP | 61d? | 2009-03-13 A | 2009-06-04 A | 100% |  | 2009-03-13 | 2009-06-04 | 61d? |  | finish no earlier than 2009-06-04 | S2 | 488h | 488h | MUPSAP | PCG-22 | Rel-9 | SP-43 | Maurice | Samsung | erik.guttman@partner.samsung.com |  |
| 229 | 96.2 | MUPSAP - CT4 aspects | 56d? | 2009-09-18 A | 2009-12-04 A | 100% |  | 2009-09-18 | 2009-12-04 | 56d? |  | finish no earlier than 2009-12-04 | C4 | 448h | 448h | MUPSAP | PCG-23 | Rel-9 | CP-45 | Kimmo | Samsung | Surjyakanta Mohapatra (surjya.kanta@samsung.com) |  |
| 230 | 96.3 | MUPSAP - CT1 aspects | 131d? | 2009-09-18 A | 2010-03-19 | 90% | 13.1d? | 2009-09-18 | 2010-03-19 | 131d? | 390d | finish no earlier than 2010-03-19 | C1 | 1048h | 943.2h | MUPSAP | PCG-23 | Rel-9 | CP-45 | Frederic | Samsung | Surjyakanta Mohapatra (surjya.kanta@samsung.com) | CP-090878 |
| 231 | 97 | Access Security Enhancements | 505d? | 2007-07-02 A | 2009-06-04 A | 100% |  | 2007-07-02 | 2009-06-04 | 505d? |  | finish no earlier than 2009-06-03 | S3 | 4040h | 4040h | ACCSEC2 |  | Rel-9 | SP-26 | Dionisio | Ericsson | Bengt.Sahlin@ericsson.com |  |
| 232 | 98 | **Protection against Unsolicited Communication for IMS (PUCI)** | 322d? | 2008-09-18 A | 2009-12-10 A | 100% |  | 2008-09-18 | 2009-12-10 | 322d? |  |  | S3,S1 | 5640h | 5640h | PUCI | PCG-21 | Rel-9 | SP-41 | Alain | NEC | Anand R. Prasad (anand@bq.jp.nec.com) |  |
| 233 | 98.1 | Stage 1 for PUCI | 61d? | 2008-09-18 A | 2008-12-11 A | 100% |  | 2008-09-18 | 2008-12-11 | 61d? |  | finish no earlier than 2009-06-18 | S1 | 488h | 488h | PUCI | PCG-21 | Rel-9 | SP-41 | Alain | NEC | Anand R. Prasad (anand@bq.jp.nec.com) |  |
| 234 | 98.2 | SA3 work on PUCI | 322d? | 2008-09-18 A | 2009-12-10 A | 100% |  | 2008-09-18 | 2009-12-10 | 322d? |  | finish no earlier than 2009-12-10 | S3 | 2576h | 2576h | PUCI | PCG-21 | Rel-9 | SP-41 | Dionisio | NEC | Anand R. Prasad (anand@bq.jp.nec.com) |  |

Notes:
- 210: -
- 211: Triggered by abandoned Study UID_380068 (FS_LCS_EPS). Linked to UID_380064 Feature IMS_EMER_GPRS_EPS.
- 212: SP#44 completed (Some alignments might be needed later on based on RAN progress) / Text3: 23.891, 23.271, 23.401, 23.402
- 213: CP#46 exception to 03/10 in CP-090808. WID updated CP-090518=>CP-090811. Stage 3 SLs and SLg interfaces & transport of positioning messages between E-SMLC and MME in the scope of UID_420006 (Positioning Support for LTE) / Text3: 24.080, 29.002 new 24.171, 29.171, 29.172, 29.173
- 214: CP#46 exception to 03/10 in CP-090876 / Text3: 24.301
- 215: RP#46 exception to 03/10 in RP-091390. WID updated RP-080995=>RP-091389. UID_400038 (LCS Control Plane Solution for EPS) depends on this WI / Text3: 34.213, 36.133, 36.171, 36.211, 36.214, 36.300, 36.305, 36.331, 36.355, 36.410, 36.413, 36.455
- 216: RP#46 exception to 03/10 in RP-091391 / Text3: 36.300, 36.331, 36.355, 36.413, new R4 36.xxx (Performance Requirements for LMU)
- 217: SP#42 WID updated SP-080442=>SP-080737 (add SA3 task)
- 218: SP#44 completed / Text3: 23.246
- 219: SP#46 completed / Text3: 33.246
- 220: SP#46 completed / Text3: 32.273, 32.251, 32.298, 32.299
- 221: CP#46 completed / Text3: 29.274, 29.281, 23.007, 23.008
- 222: CP#46 completed / Text3: 29.061
- 223: RP#46 exception to 03/10 in RP-091221. WID updated RP-090619=>RP-091457 / Text3: 25.446, 36.101, 36.104, 36.141, 36.300, 36.304, 36.321, 36.322, 36.323, 36.331, 36.440, 36.441, 36.442, 36.444, 36.445
- 224: SP#44 Stage 2 completed. No new Rel-9 use cases defined. Implement service requirements not covered in Rel-8 / Text3: 22.278, SA3 33.402 CR#0055
- 225: SP#44 completed / Text3: 23.402, 23.002
- 226: CP#46 exception to 03/10 in CP-090869 / Text3: 24.302, 24.312
- 227: SP#44 Stage 2 completed. Continues Rel-8 SAES Stage 2 UID_320005. Stage 1 in 22.278 (EPS Service requirements)
- 228: SP#44 completed / Text3: 23.060, 23.203, 23.401, 23.402
- 229: CP#46 completed / Text3: 29.275, 23.008, 29.282
- 230: CP#46 exception to 03/10 in CP-090878 / Text3: 24.302
- 231: SP#44 completed. Stopped TR 33.801. CRs 33.102,43.020 on A5/2 removal done long time ago. A5/4 introduction CRs will be done under UID_440057 128 bit encryption for GSM and GPRS. SP#26 approved WID (improved GERAN security) / Text3: 33.102, 43.020, Stopped TR 33.801 “Access security review” (Reason: draft contained useful material for planning A5/2 removal and A5/4 introduction. Completion would require significant effort)
- 232: SP#46 TR completed but no specification work done in Rel-9. Related work in OMA Categorization Based Content Screening
- 233: SP#42 completed / Text3: 22.228
- 234: SP#46 completed. TR 33.837 converted to 33.937. No SA3 normative work done in Rel-9 / Text3: new 33.937

| ID | WBS | Task | Duration | Start | Finish | Complete | Remaining | Baseline start | Baseline finish | Baseline duration | Total slack | Constraint | Resources | Work | Actual work | Text1 | Text2 | Text4 | Text5 | Text6 | Text7 | Text8 | Text11 | Text9 | Text12 |
| --- | --- | --- | --- | --- | --- | --- | --- | --- | --- | --- | --- | --- | --- | --- | --- | --- | --- | --- | --- | --- | --- | --- | --- | --- | --- |
| 235 | 99 | **IMS Media Plane Security** | 271d? | 2009-03-13 A | 2010-03-25 | 52% | 130.97d? | 2009-03-13 | 2010-03-25 | 271d? | 386d |  | S3,C1,C4,C3 | 6467.2h | 2118.21h | MEDIASEC | PCG-22 | Vodafone | Peter.Howard@vodafone.com | Rel-9 | SP-43 | Dionisio |  |  |  |
| 236 | 99.1 | SA3 aspects - MEDIASEC | 271d? | 2009-03-13 A | 2010-03-25 | 95% | 13.55d? | 2009-03-13 | 2010-03-25 | 271d? | 386d | finish no earlier than 2010-03-25 | S3 | 2168h | 2059.6h | MEDIASEC | PCG-22 | Vodafone | Peter.Howard@vodafone.com | Rel-9 | SP-43 | Dionisio |  |  |  |
| 237 | 99.2 | **CN aspects of IMS Media Plane Security** | 131d? | 2009-09-18 A | 2010-03-19 | 3% | 127.4d? | 2009-09-18 | 2010-03-19 | 131d? | 390d |  | C1,C4,C3 | 2131.2h | 58.61h | MEDIASEC_CORE | PCG-23 | Vodafone | peter.dawes@vodafone.com | Rel-9 | CP-45 | Frederic | CP-090877 |  |  |
| 238 | 99.2.1 | CT1 aspects - MEDIASEC | 33d? | 2009-09-18 A | 2010-03-19 | 20% | 26.4d? | 2009-09-18 | 2010-03-19 | 33d? | 390d | finish no earlier than 2010-03-19 | C1 | 264h | 52.8h | MEDIASEC_CORE | PCG-23 | Vodafone | peter.dawes@vodafone.com | Rel-9 | CP-45 | Frederic | CP-090877 |  |  |
| 239 | 99.2.2 | CT4 aspects - MEDIASEC | 131d? | 2009-09-18 | 2010-03-19 |  |  | 2009-09-18 | 2010-03-19 | 131d? | 390d | finish no earlier than 2010-03-19 | C4 | 1048h |  | MEDIASEC_CORE | PCG-23 | Vodafone | peter.dawes@vodafone.com | Rel-9 | CP-45 | Kimmo | CP-090809 |  |  |
| 240 | 99.2.3 | CT3 aspects - MEDIASEC | 76d? | 2009-12-04 | 2010-03-19 |  |  | 2009-12-04 | 2010-03-19 | 76d? | 390d | finish no earlier than 2010-03-19 | C3 | 608h |  | MEDIASEC_CORE | PCG-24 | Vodafone | peter.dawes@vodafone.com | Rel-9 | CP-46 |  | CP-091022 |  |  |
| 241 | 100 | **GBAPush enhancements (Generic push layer)** | 533d? | 2008-03-12 A | 2010-03-25 | 85% | 79.95d? | 2008-03-12 | 2010-03-25 | 533d? | 386d |  | S3 | 8528h | 7248.8h | eGBAPush | PCG-23 | Ericsson | Rolf Blom | Rel-9 | SP-44 | Dionisio |  |  |  |
| 242 | 100.1 | SA3 part of eGBAPush (Generic push layer) | 533d? | 2008-03-12 A | 2010-03-25 | 85% | 79.95d? | 2008-03-12 | 2010-03-25 | 533d? | 386d | finish no earlier than 2010-03-25 | S3 | 4264h | 3624.4h | eGBAPush | PCG-21 | Ericsson | Rolf Blom | Rel-9 | SP-39 | Dionisio |  |  |  |
| 243 | 101 | Extended Identity Management | 136d? | 2009-06-04 A | 2009-12-10 A | 100% |  | 2009-06-04 | 2009-12-10 | 136d? |  | finish no earlier than 2009-12-10 | S3 | 1088h | 1088h | GBA-IdM | PCG-23 | Nokia | Silke.Holtmanns at nokia.com | Rel-9 | SP-44 | Dionisio |  |  |  |
| 244 | 102 | **Network Domain Security (NDS) enhancements to support backhaul security** | 211d? | 2009-06-04 A | 2010-03-25 | 57% | 90.86d? | 2009-06-04 | 2010-03-25 | 211d? | 386d |  | S3,C4 | 4432h | 2523.53h | NDS_Backhaul | PCG-23 | Vodafone | Peter Howard | Rel-9 | SP-44 | Dionisio |  |  |  |
| 245 | 102.1 | SA3 part of NDS_Backhaul | 211d? | 2009-06-04 A | 2010-03-25 | 30% | 147.7d? | 2009-06-04 | 2010-03-25 | 211d? | 386d | finish no earlier than 2010-03-25 | S3 | 1688h | 506.4h | NDS_Backhaul | PCG-23 | Vodafone | Peter Howard | Rel-9 | SP-44 | Dionisio | SP-090834 |  |  |
| 246 | 102.2 | CT4 part of NDS_Backhaul | 132d? | 2009-06-04 A | 2009-12-04 A | 100% |  | 2009-06-04 | 2009-12-04 | 132d? |  | finish no earlier than 2009-12-04 | C4 | 1056h | 1056h | NDS_Backhaul | PCG-23 | Vodafone | Peter Howard | Rel-9 | SP-44 | Kimmo |  |  |  |
| 247 | 103 | **128 bit encryption for GSM and GPRS** | 136d? | 2009-06-04 A | 2009-12-10 A | 100% |  | 2009-06-04 | 2009-12-10 | 136d? |  |  | S3,C1,C4,G2,G3new | 6040h | 6040h | A5/4-GEA4 | PCG-23 | Ericsson | Karl Norrman | Rel-9 | SP-44 | Dionisio |  |  |  |
| 248 | 103.1 | SA3 part of A5/4-GEA4 | 136d? | 2009-06-04 A | 2009-12-10 A | 100% |  | 2009-06-04 | 2009-12-10 | 136d? |  | finish no earlier than 2010-01-06 | S3 | 1088h | 1088h | A5/4-GEA4 | PCG-23 | Ericsson | Karl Norrman | Rel-9 | SP-44 | Dionisio |  |  |  |
| 249 | 103.2 | CT1 part of A5/4-GEA4 | 77d? | 2009-06-04 A | 2009-09-18 A | 100% |  | 2009-06-04 | 2009-09-18 | 77d? |  | start no earlier than 2009-06-04 | C1 | 616h | 616h | A5/4-GEA4 | PCG-23 | Ericsson | Karl Norrman | Rel-9 | SP-44 | Frederic |  |  |  |
| 250 | 103.3 | CT4 part of A5/4-GEA4 | 136d? | 2009-06-04 A | 2009-12-10 A | 100% |  | 2009-06-04 | 2009-12-10 | 136d? |  | start no earlier than 2009-06-04 | C4 | 1088h | 1088h | A5/4-GEA4 | PCG-23 | Ericsson | Karl Norrman | Rel-9 | SP-44 | Kimmo |  |  |  |
| 251 | 103.4 | GERAN2 part of A5/4-GEA4 | 67d? | 2009-06-04 A | 2009-09-04 A | 100% |  | 2009-06-04 | 2009-09-04 | 67d? |  | finish no earlier than 2009-09-04 | G2 | 536h | 536h | A5/4-GEA4 | PCG-23 | Ericsson | Karl Norrman | Rel-9 | SP-44 | Gert |  |  |  |
| 252 | 103.5 | GERAN3new (testing) part of A5/4-GEA4 | 122d? | 2009-06-04 A | 2009-11-20 A | 100% |  | 2009-06-04 | 2009-11-20 | 122d? |  | finish no earlier than 2009-11-20 | G3new | 976h | 976h | A5/4-GEA4 | PCG-23 | Ericsson | Karl Norrman | Rel-9 | SP-44 | Ingbert |  |  |  |
| 253 | 103.6 | Deleted - SA2 part of A5/4-GEA4 | 81d? | 2009-06-04 A | 2009-09-24 A | 100% |  | 2009-06-04 | 2009-09-24 | 81d? |  | finish no earlier than 2009-09-24 | S2 | 648h | 648h | A5/4-GEA4 | PCG-23 | Ericsson | Karl Norrman | Rel-9 | SP-44 | Maurice |  | PCG-23 | SP-45 |
| 254 | 104 | Lawful Interception in the 3GPP Rel-9 | 211d? | 2009-06-04 A | 2010-03-25 | 30% | 147.7d? | 2009-06-04 | 2010-03-25 | 211d? | 386d | finish no earlier than 2010-03-25 | S3 | 1688h | 506.4h | LI9 | PCG-23 | PIDS, Nortel | Koen Jaspers, Ronald Ryan | Rel-9 | SP-44 | Dionisio | SP-090833 |  |  |
| 255 | 105 | Timed Graphics | 337d? | 2008-12-11 A | 2010-03-25 A | 100% |  | 2008-12-11 | 2010-03-25 | 337d? |  | finish no earlier than 2010-03-25 | S4 | 2696h | 2696h | TG | PCG-22 | Ericsson | clinton.priddle@ericsson.com | Rel-9 | SP-42 | Paolo |  |  |  |
| 256 | 106 | Managing MTSI Media Adaptation | 272d? | 2009-03-12 A | 2010-03-25 A | 100% |  | 2009-03-12 | 2010-03-25 | 272d? |  | finish no earlier than 2009-12-10 | S4 | 1568h | 1568h | M3A | PCG-22 | Samsung | kyunghun.jung@samsung.com | Rel-9 | SP-43 | Paolo |  |  |  |
| 257 | 107 | **PSS and MBMS Aspects** | 272d? | 2009-03-12 A | 2010-03-25 A | 100% |  | 2009-03-12 | 2010-03-25 | 272d? |  |  | S4 | 6512h | 6512h | PMA | PCG-23 | Ericsson, Nokia | Clinton.Priddle@ericsson.com, imed.bouazizi@nokia.com | Rel-9 | SP-44 | Paolo |  |  |  |
| 258 | 107.1 | PSS and MBMS extensions | 271d? | 2009-03-12 A | 2010-03-25 A | 100% |  | 2009-03-12 | 2010-03-25 | 271d? |  | finish no earlier than 2010-03-25 | S4 | 2168h | 2168h | PMA-MBS_Ext | PCG-22 | Ericsson | Clinton.Priddle@ericsson.com | Rel-9 | SP-43 | Paolo |  |  |  |
| 259 | 107.2 | Improved Video Support for PSS and MBMS | 271d? | 2009-03-12 A | 2010-03-25 A | 100% |  | 2009-03-12 | 2010-03-25 | 271d? |  | finish no earlier than 2010-03-25 | S4 | 2168h | 2168h | PMA-IVS | PCG-22 | Nokia | imed.bouazizi@nokia.com | Rel-9 | SP-43 | Paolo |  |  |  |
| 260 | 108 | IMS based PSS and MBMS User Service extensions | 197d? | 2009-03-12 A | 2009-12-10 A | 100% |  | 2009-03-12 | 2009-12-10 | 197d? |  | finish no earlier than 2009-12-10 | S4 | 1576h | 1576h | IMS_PSS_MBMS_US_EXT | PCG-22 | Ericsson | Markus Kampmann | Rel-9 | SP-43 | Paolo |  |  |  |
| 261 | 109 | Syndicated Feed Reception within 3GPP environments | 136d? | 2009-06-04 A | 2009-12-10 A | 100% |  | 2009-06-04 | 2009-12-10 | 136d? |  | start no earlier than 2009-06-04 | S4 | 1088h | 1088h | SFR | PCG-23 | Ericsson | Thorsten.Lohmar@ericsson.com | Rel-9 | SP-44 | Paolo |  |  |  |
| 262 | 110 | Distortion Measurement Test Methods and Requirements | 131d? | 2009-09-24 A | 2010-03-25 A | 100% |  | 2009-09-24 | 2010-03-25 | 131d? |  | finish no earlier than 2010-03-25 | S4 | 1048h | 1048h | DTMR | PCG-23 | Motorola | Stephen Kendall (wcsk01@motorola.com) | Rel-9 | SP-45 | Paolo |  |  |  |

Notes:
- 235: CP#46 Stage 3 exception to 03/10
- 236: SP#46 completion 12/09=>03/10. TR 33.828 3rd time for Information. TS 33.328 for Approval / Text3: new 33.828, 33.328
- 237: CP#46 exception to 03/10. WID updated CP-090740=>CP-090884
- 238: CP#46 exception to 03/10 in CP-090877 / Text3: 23.218, 24.229
- 239: CP#46 exception to 03/10 in CP-090809 / Text3: 29.238, 23.334, 29.334
- 240: CP#46 exception to 03/10 in CP-091022 / Text3: 29.162
- 241: SP#43 Umbrella Feature created to host 33.224, moved from Rel-8 to Rel-9 (Develop a generic push layer using GAA protection)
- 242: SP#46 completion 12/09=>03/10. SP#45 TS 33.224 for Approval / Text3: 33.224
- 243: SP#46 completed. TR 33.924 (Stage 2) for Approval. Stage 1 not identified: GBA Liberty Interworking has been outlined and GBAOpenID interworking is analogous / Text3: new 33.924, CP#45 CT4 completed (Added service code in 29.109)
- 244: SP#46 further Stage 2 exception to 03/10 (was 12/09). Continuation of Rel-8 UID_390044 SAE security architecture. Covers gaps in backhaul security in SAE (also applicable to UTRAN and GERAN backhaul)
- 245: SP#46 further Stage 2 exception to 03/10 (was 12/09) in SP-090834. [Identity Management and 3GPP Security Interworking (Interworking of GAA and OpenID)] / Text3: 33.102, 33.210, 33.310, 33.401, 33.402
- 246: CP#46 completed. No impact on CT4 specs
- 247: Allow 128 as an alternative to 64 bit keys (Stage 2/3 + Test spec)
- 248: SP#46 completed. SP#45 TS 55.226v100 for Information+Approval / Text3: 33.102,43.020, new 55.226
- 249: CP#45 completed / Text3: 24.008,44.064
- 250: CP#46 completed. Kc128 enhancements are carried as UMTS keys => no CT4 impact / Text3: 29.002, 29.060
- 251: GP#43 WID approved + completed / Text3: 44.018,48.008,48.018,48.058
- 252: GP#44 completed. GP#43 WID approved / Text3: 51.010
- 253: SP#45 work stopped/abandoned / Text3: 23.060
- 254: SP#46 further Stage 2 exception to 03/10 (was 12/09) in SP-090833. WID updated SP-090532=>SP-090831 / Text3: 33.106 (LI requirements), 33.107 (LI architecture and functions), 33.108 (Handover interface for LI)
- 255: SP#47 completed. Provide graphics in parallel to a video stream (without requiring an umbrella scene descriptor such as 3GPP DIMS in TS 26.142) / Text3: 26.114, 26.140, 26.234, 26.244, 26.245, 26.346, new 26.430
- 256: SP#46 completed. Work extending Rel-8 UID_34041 MTSI Video - Dynamic Rate Adaptation/Signalling of Image Size. Update speech/video adaptation algorithms used by network to control MTSI client terminal in congestion or poor transmission conditions. / Text3: 26.114
- 257: Umbrella WI. SP#47 completed
- 258: SP#47 completed. Extends Rel-8 UID_34043 (PSS_MBMS_OMTV) & ensures compatibility with UID_34046 (IMS_PSS_MBMS_US) / Text3: 26.234, 26.346
- 259: SP#47 completed / Text3: 26.234, 26.244, 26.346, new 26.903
- 260: SP#46 completed. Work extending Rel-8 UID_34046 (IMS_PSS_MBMS_US), SA2 UID_410034 IMSSCC-SPI (IMS Service Continuity Enhancements: Service, Policy and Interactions) / Text3: 26.237
- 261: SP#46 completed. TS 26.150v100 for Approval. RSS optimized for mobile use. Reuse/reference OMA's enabler DCD. / Text3: 26.150
- 262: SP#47 completed / Text3: 26.131, 26.132

| ID | WBS | Task | Duration | Start | Finish | Complete | Remaining | Baseline start | Baseline finish | Baseline duration | Total slack | Constraint | Resources | Work | Actual work | Text1 | Text2 | Text6 | Text7 | Text8 | Text4 | Text11 | Text9 | Text12 |
| --- | --- | --- | --- | --- | --- | --- | --- | --- | --- | --- | --- | --- | --- | --- | --- | --- | --- | --- | --- | --- | --- | --- | --- | --- |
| 263 | 111 | **OAM&P 9** | 546d? | 2008-02-22 A | 2010-03-25 | 60% | 216.47d? | 2008-02-22 | 2010-03-25 | 546d? | 386d |  | S5 | 33810.4h | 20486h | OAM9 | PCG-22 | Rel-9 | SP-42 | Dionisio |  |  |  |  |
| 264 | 111.1 | **Network Infrastructure Management** | 337d? | 2008-12-11 A | 2010-03-25 | 44% | 187.44d? | 2008-12-11 | 2010-03-25 | 337d? | 386d |  | S5 | 8760h | 3887.68h | OAM9-NIM | PCG-22 | Rel-9 | SP-42 | Dionisio |  |  |  |  |
| 265 | 111.1.1 | Software Management for Network Elements | 336d? | 2008-12-11 A | 2010-03-25 | 75% | 84d? | 2008-12-11 | 2010-03-25 | 336d? | 386d | finish no earlier than 2010-03-25 | S5 | 2688h | 2016h | OAM9-NE_SWM | PCG-22 | Rel-9 | SP-42 | Dionisio | Huawei, Nokia Siemens Networks | SP-090742 |  |  |
| 266 | 111.1.2 | Service Oriented Architecture (SOA) for IRP | 211d? | 2009-06-04 A | 2010-03-25 | 20% | 168.8d? | 2009-06-04 | 2010-03-25 | 211d? | 386d | finish no earlier than 2010-03-25 | S5 | 1688h | 337.6h | OAM9 | PCG-23 | Rel-9 | SP-44 | Dionisio | Ericsson, Nokia Siemens Networks | SP-090749 |  |  |
| 267 | 111.1.3 | IRP SOAP Solution Sets continuation from Rel-8 | 211d? | 2009-06-04 A | 2010-03-25 | 20% | 168.8d? | 2009-06-04 | 2010-03-25 | 211d? | 386d | finish no earlier than 2010-03-25 | S5 | 1688h | 337.6h | OAM9 | PCG-23 | Rel-9 | SP-44 | Dionisio | Ericsson | SP-090750 |  |  |
| 268 | 111.2 | **Performance Management** | 272d? | 2009-03-12 A | 2010-03-25 | 69% | 85.6d? | 2009-03-12 | 2010-03-25 | 272d? | 386d |  | S5 | 7010.41h | 4802.4h | OAM9-PM | PCG-22 | Rel-9 | SP-42 | Dionisio |  |  |  |  |
| 269 | 111.2.1 | Enhancement of E-UTRAN Performance Measurements | 272d? | 2009-03-12 A | 2010-03-25 | 30% | 190.4d? | 2009-03-12 | 2010-03-25 | 272d? | 386d | finish no earlier than 2010-03-25 | S5 | 2176h | 652.8h | OAM9 | PCG-22 | Rel-9 | SP-43 | Dionisio | Motorola, Huawei | SP-090745 |  |  |
| 270 | 111.2.2 | Enhancement of EPC Performance Measurements | 197d? | 2009-03-12 A | 2009-12-10 A | 100% |  | 2009-03-12 | 2009-12-10 | 197d? |  | finish no earlier than 2010-03-25 | S5 | 1570.41h | 1570.41h | OAM9 | PCG-22 | Rel-9 | SP-43 | Dionisio | China Mobile |  |  |  |
| 271 | 111.2.3 | Enhancement of UTRAN Performance Measurements | 136d? | 2009-06-04 A | 2009-12-10 A | 100% |  | 2009-06-04 | 2009-12-10 | 136d? |  | start no earlier than 2009-06-04 | S5 | 1088h | 1088h | OAM9 | PCG-23 | Rel-9 | SP-44 | Dionisio | China Mobile |  |  |  |
| 272 | 111.3 | Deleted - Trace | 196d? | 2009-03-13 A | 2009-12-10 A | 100% |  | 2009-03-13 | 2009-12-10 | 196d? |  | finish no earlier than 2009-12-10 | S5 | 1568h | 1568h | OAM9-Trace | PCG-22 | Rel-9 | SP-42 | Dionisio |  |  | PCG-24 | SP-46 |
| 273 | 111.4 | **Self-Organizing Networks (SON) - OAM aspects** | 546d? | 2008-02-22 A | 2010-03-25 | 68% | 174.6d? | 2008-02-22 | 2010-03-25 | 546d? | 386d |  | S5 | 10416h | 7085.22h | OAM9-SON | PCG-22 | Rel-9 | SP-43 | Dionisio |  |  |  |  |
| 274 | 111.4.1 | SON self-optimization management | 545d? | 2008-02-22 A | 2010-03-25 | 75% | 136.25d? | 2008-02-22 | 2010-03-25 | 545d? | 386d | finish no earlier than 2010-03-25 | S5 | 4360h | 3270h | LTE_SON-OAM | PCG-21 | Rel-9 | SP-39 | Dionisio | Huawei | SP-090741 |  |  |
| 275 | 111.4.2 | Automatic Radio Network Configuration Data Preparation | 211d? | 2009-06-04 A | 2010-03-25 | 50% | 105.5d? | 2009-06-04 | 2010-03-25 | 211d? | 386d | finish no earlier than 2010-03-25 | S5 | 1688h | 844h | OAM9 | PCG-23 | Rel-9 | SP-44 | Dionisio | Nokia Siemens Networks | SP-090752 |  |  |
| 276 | 111.5 | Subscription Management (SuM) evolution | 211d? | 2009-06-04 A | 2010-03-25 | 30% | 147.7d? | 2009-06-04 | 2010-03-25 | 211d? | 386d | finish no earlier than 2010-03-25 | S5 | 1688h | 506.4h | OAM9-SuM | PCG-23 | Rel-9 | SP-44 | Dionisio | Ericsson | SP-090746 |  |  |
| 277 | 112 | **Charging Management small Enhancements** | 211d? | 2009-06-04 A | 2010-03-25 | 25% | 158.25d? | 2009-06-04 | 2010-03-25 | 211d? | 386d |  | S5 | 3376h | 844h | CH9 | PCG-23 | Rel-9 | SP-44 | Dionisio |  |  |  |  |
| 278 | 112.1 | IWLAN mobility charging | 211d? | 2009-06-04 A | 2010-03-25 | 25% | 158.25d? | 2009-06-04 | 2010-03-25 | 211d? | 386d | finish no earlier than 2010-03-25 | S5 | 1688h | 422h | eIWLAN_Mob | PCG-23 | Rel-9 | SP-44 | Dionisio | Orange | SP-090755 |  |  |
| 279 | 113 | **CS-IBCF and CS-TrGW definition in 3GPP specifications** | 397d? | 2008-05-30 A | 2009-12-04 A | 100% |  | 2008-05-30 | 2009-12-04 | 397d? |  |  | C3,C4 | 9513.27h | 9513.27h | CS-IBCF | PCG-21 | Rel-9 | CP-40 | Gwiho | Telecom Italia |  |  |  |
| 280 | 113.1 | CT3 aspects of CS-IBCF | 397d? | 2008-05-30 A | 2009-12-04 A | 100% |  | 2008-05-30 | 2009-12-04 | 397d? |  | finish no earlier than 2009-12-04 | C3 | 3169.27h | 3169.27h | CS-IBCF | PCG-21 | Rel-9 | CP-40 | Gwiho | Telecom Italia |  |  |  |
| 281 | 113.2 | CT4 aspects of CS-IBCF | 396d? | 2008-05-30 A | 2009-12-04 A | 100% |  | 2008-05-30 | 2009-12-04 | 396d? |  | finish no earlier than 2009-12-04 | C4 | 3168h | 3168h | CS-IBCF | PCG-21 | Rel-9 | CP-40 | Kimmo | Telecom Italia |  |  |  |
| 282 | 114 | **IMS – Interconnection Border Control Function (IBCF) – Transition Gateway (TrGW); Ix Interface; Stage 3** | 322d? | 2008-09-12 A | 2009-12-04 A | 100% |  | 2008-09-12 | 2009-12-04 | 322d? |  |  | C4,C3 | 6858.4h | 6858.4h | IMS_IBCF | PCG-21 | Rel-9 | CP-41 | Kimmo | Alcatel-Lucent |  |  |  |
| 283 | 114.1 | CT4 part of IMS_IBCF | 321d? | 2008-09-12 A | 2009-12-04 A | 100% |  | 2008-09-12 | 2009-12-04 | 321d? |  | finish no earlier than 2009-12-04 | C4 | 2568h | 2568h | IMS_IBCF | PCG-21 | Rel-9 | CP-41 | Kimmo | Alcatel-Lucent |  |  |  |
| 284 | 114.2 | CT3 part of IMS_IBCF | 295.8d? | 2008-09-12 A | 2009-12-04 A | 100% |  | 2008-09-12 | 2009-12-04 | 295.8d? |  | finish no earlier than 2010-03-19 | C3 | 2366.4h | 2366.4h | IMS_IBCF | PCG-21 | Rel-9 | CP-41 | Gwiho | Alcatel-Lucent |  |  |  |
| 285 | 115 | IMS Application Level Gateway Control Function (ALGCF) – IMS Access Media Gateway (IMA-MGW); Iq Interface; Stage 2 and Stage 3 | 321d? | 2008-09-12 A | 2009-12-04 A | 100% |  | 2008-09-12 | 2009-12-04 | 321d? |  | finish no earlier than 2009-12-04 | C4 | 2568h | 2568h | IMS_AGCF | PCG-21 | Rel-9 | CP-41 | Kimmo | Alcatel-Lucent |  |  |  |
| 286 | 116 | **Enhancements of IMS Customized Alerting Tone (CAT) Service** | 337d? | 2008-12-05 A | 2010-03-19 | 95% | 16.85d? | 2008-12-05 | 2010-03-19 | 337d? | 390d |  | C1 | 4966.4h | 4718.08h | eCAT | PCG-22 | Rel-9 | CP-42 | Frederic | China Mobile |  |  |  |
| 287 | 116.1 | Stage 3 Enhancements of IMS CAT Supplementary Service | 336d? | 2008-12-05 A | 2010-03-19 | 95% | 16.8d? | 2008-12-05 | 2010-03-19 | 336d? | 390d | finish no earlier than 2010-03-19 | C1 | 2688h | 2553.6h | eCAT-SS | PCG-22 | Rel-9 | CP-42 | Frederic | China Mobile | CP-090870 |  |  |

Notes:
- 263: SP#42 umbrella Feature created to host OAM WIs
- 264: SP#42 umbrella BB created to host OAM WIs
- 265: SP#46 exception to 03/10 in SP-090742 / Text3: 32.531, 32.532, 32.533, 32.537 / Text5: Bidipta Das (bidipta@huawei.com), Clemens Suerbaum (clemens.suerbaum@nsn.com)
- 266: SP#46 exception to 03/10 in SP-090749. Triggered by UID_400029 Study on Service Oriented Architecture (SOA) for IRP (TR 32.824) / Text3: 32.101, 32.102, 32.150 / Text5: Edwin Tse (Ericsson), Joerg Schmidt (NSN)
- 267: SP#46 exception to 03/10 in SP-090750. Continuation of Rel-8 UID_400030 IRP SOAP Solution Sets / Text3: 32.127, 32.327, 32.337, 32.357, 32.387, 32.397, 32.447, 32.121, 32.122, 32.123, 32.321, 32.322, 32.323, 32.325, 32.331, 32.332, 32.333, 32.335, 32.351, 32.352, 32.353, 32.381, 32.382, 32.383, 32.385, 32.391, 32.392, 32.393, 32.395, 32.441, 32.442, 32.443 / Text5: John Power
- 268: SP#42 umbrella BB created to host OAM WIs
- 269: SP#46 exception to 03/10 in SP-090745 / Text3: 32.425 / Text5: Yizhi Yao (yzyao@motorola.com),Lan Zou (zlan@huawei.com)
- 270: SP#46 completed / Text3: 32.426 / Text5: Li Jian (lijian@chinamobile.com), Liang Shuangchun (liangshuangchun@cmdi.chinamobile.com)
- 271: SP#46 completed / Text3: 32.405 / Text5: Liang Shuangchun, Li Jian, Bao Haitao
- 272: SP#46 stopped (no work in Rel-9)
- 273: SP#43 umbrella BB created to host OAM WIs
- 274: SP#46 exception to 03/10 in SP-090741. WID updated SP-090054=>SP-090762 (removed Self-Healing handling which becomes a Rel-10 dedicated WI SP-090757) / Text3: 32.425, new 32.521, 32.522, 32.523 / Text5: Lan Zou (zlan@huawei.com)
- 275: SP#46 exception to 03/10 in SP-090752. WID updated SP-090317=>SP-090869 / Text3: 32.501, 32.502, 32.503 / Text5: clemens.suerbaum@nsn.com
- 276: SP#46 exception to 03/10 in SP-090746 / Text3: 32.140, 32.141, 32.152, 32.172, 32.175 / Text5: frode.nergard@ericsson.com
- 277: -
- 278: SP#46 exception to 03/10 in SP-090755. RAT differentiation for charging. Completes Rel-8 Feature IWLAN_Mob UID_370049 Mobility between 3GPP-WLAN Interworking and 3GPP Systems / Text3: 32.240, 32.252, 32.298, 32.299 / Text5: Jean-Luc Garcia
- 279: CP#46 completed. Rel-8 UID_380061 (Ipinterc) covers Stage 1 in SA1 22.101, 22.228 / Text5: mauro.ficaccio@telecomitalia.it
- 280: CP#46 completed / Text3: 29.235 / Text5: mauro.ficaccio@telecomitalia.it
- 281: CP#46 completed / Text3: 23.231, 29.232, new 29.238 / Text5: mauro.ficaccio@telecomitalia.it
- 282: CP#46 completed / Text5: Bruno.Landais@alcatel-lucent.fr
- 283: CP#46 completed / Text3: new 29.238 / Text5: Bruno.Landais@alcatel-lucent.fr
- 284: CP#46 completed / Text3: 29.162, 29.235 / Text5: Bruno.Landais@alcatel-lucent.fr
- 285: CP#46 completed / Text3: new (23.334, 29.334) / Text5: bruno.landais@alcatel-lucent.fr
- 286: CP#46 completion 12/09=>03/10. CP#42 umbrella Feature created to host CT1 CAT WI (Stage 1 in 22.182) / Text5: Jiang Yi
- 287: CP#46 exception to 03/10 in CP-090870 / Text3: 24.182 / Text5: Jiang Yi

| ID | WBS | Task | Duration | Start | Finish | Complete | Remaining | Baseline start | Baseline finish | Baseline duration | Total slack | Constraint | Resources | Work | Actual work | Text1 | Text2 | Text4 | Text5 | Text6 | Text7 | Text8 | Text11 |
| --- | --- | --- | --- | --- | --- | --- | --- | --- | --- | --- | --- | --- | --- | --- | --- | --- | --- | --- | --- | --- | --- | --- | --- |
| 288 | 117 | **Completion of IMS Restoration Procedures** | 212d? | 2009-05-29 A | 2010-03-19 | 33% | 141.33d? | 2009-05-29 | 2010-03-19 | 212d? | 390d |  | C3, C4,C1 | 6784h | 1696h | eIMS_RP | PCG-23 | Ericsson | Emiliano Merino (emiliano.merino@ericsson.com) | Rel-9 | CP-44 | Kimmo |  |
| 289 | 117.1 | CT4 aspects of eIMS_RP | 212d? | 2009-05-29 A | 2010-03-19 | 60% | 84.8d? | 2009-05-29 | 2010-03-19 | 212d? | 390d | finish no earlier than 2010-03-19 | C4 | 1696h | 1017.6h | eIMS_RP | PCG-23 | Ericsson | Emiliano Merino (emiliano.merino@ericsson.com) | Rel-9 | CP-44 | Kimmo | CP-090806 |
| 290 | 117.2 | CT1 aspects of eIMS_RP | 212d? | 2009-05-29 | 2010-03-19 |  |  | 2009-05-29 | 2010-03-19 | 212d? | 390d | finish no earlier than 2010-03-19 | C1 | 1696h |  | eIMS_RP | PCG-23 | Ericsson | Emiliano Merino (emiliano.merino@ericsson.com) | Rel-9 | CP-44 | Kimmo | CP-090871 |
| 291 | 117.3 | CT3 aspects of eIMS_RP | 212d? | 2009-05-29 A | 2010-03-19 | 40% | 127.2d? | 2009-05-29 | 2010-03-19 | 212d? | 390d | finish no earlier than 2010-03-19 | C3 | 1696h | 678.4h | eIMS_RP | PCG-24 | Ericsson | Emiliano Merino (emiliano.merino@ericsson.com) | Rel-9 | CP-46 | Kimmo | CP-090863 |
| 292 | 118 | IMS Stage 3 - IETF Protocol Alignment | 212d? | 2009-05-29 A | 2010-03-19 | 95% | 10.6d? | 2009-05-29 | 2010-03-19 | 212d? | 390d | finish no earlier than 2010-03-19 | C1 | 1696h | 1611.2h | IMSProtoc3 | PCG-23 | Alcatel-Lucent | Keith Drage (drage@alcatel-lucent.com) | Rel-9 | CP-44 | Frederic |  |
| 293 | 119 | Operational description of the Inter-IMS Network to Network Interface (II-NNI) | 212d? | 2009-05-29 A | 2010-03-19 | 80% | 42.4d? | 2009-05-29 | 2010-03-19 | 212d? | 390d | finish no earlier than 2010-03-19 | C3 | 1696h | 1356.8h | II-NNI | PCG-23 | Orange | sebastien.daudet@orange-ftgroup.com | Rel-9 | CP-44 | Gwiho | CP-090862 |
| 294 | 120 | Definition of Ml interface for Control Plane LCS (Stage 3) | 131d? | 2009-09-18 A | 2010-03-19 | 75% | 32.75d? | 2009-09-18 | 2010-03-19 | 131d? | 390d | finish no earlier than 2010-03-19 | C1 | 1048h | 786h | EMC2 | PCG-23 | Alcatel-Lucent | Keith Drage (drage@alcatel-lucent.com) | Rel-9 | CP-45 | Frederic | CP-090872 |
| 295 | 121 | PCC enhancements | 56d? | 2009-09-18 A | 2009-12-04 A | 100% |  | 2009-09-18 | 2009-12-04 | 56d? |  | finish no earlier than 2009-12-04 | C3 | 448h | 448h | PCC-Enh | PCG-23 | Huawei | Wei Weihua (weiwh@huawei.com) | Rel-9 | CP-45 | Gwiho |  |
| 296 | 122 | 3GPP IMS Conferencing Management Object (MO) | 2d? | 2009-12-03 A | 2009-12-04 A | 100% |  | 2009-12-03 | 2009-12-04 | 2d? |  | start no earlier than 2009-12-03 | C1 | 16h | 16h | IMS_ConfMO | PCG-24 |  |  | Rel-9 | CP-46 |  |  |
| 297 | 123 | **Rel-9 Improvements of the Radio Interface** | 397d? | 2008-09-12 A | 2010-03-19 | 93% | 26.74d? | 2008-09-12 | 2010-03-19 | 397d? | 390d |  | RP,GP | 19147.6h | 18004.2h | RInImp9 | PCG-21 |  |  | Rel-9 | RP-41 | Issam |  |
| 298 | 123.1 | LCR TDD UE OTA Performance Requirements | 186d? | 2008-09-12 A | 2009-05-29 A | 100% |  | 2008-09-12 | 2009-05-29 | 186d? |  | finish no earlier than 2009-05-29 | R4 | 1488h | 1488h | RInImp9-RFLCROTA | PCG-21 | RITT | Wu Xiang (wuxiang@chinattl.com) | Rel-9 | RP-41 | Issam | RP-090389 |
| 299 | 123.2 | **RF requirements for Multicarrier and Multi-RAT BS** | 347d? | 2008-11-21 A | 2010-03-19 | 99% | 3.91d? | 2008-11-21 | 2010-03-19 | 347d? | 390d |  | R4,G1 | 7403.6h | 7320.15h | RInImp9-RFmulti | PCG-21 | Ericsson | Johan.skold@ericsson.com | Rel-9 | RP-41 | Issam | RP-091033 |
| 300 | 123.2.1 | RAN4 part of RF requirements for Multicarrier and Multi RAT BS | 337d? | 2008-12-05 A | 2010-03-19 | 98% | 6.74d? | 2008-12-05 | 2010-03-19 | 337d? | 390d | finish no earlier than 2010-03-19 | R4 | 2696h | 2642.08h | RInImp9-RFmulti | PCG-22 | Ericsson | Johan.skold@ericsson.com | Rel-9 | RP-42 | Issam | RP-091299 |
| 301 | 123.2.2 | GERAN part of RF requirements for Multicarrier and Multi RAT BS | 261d? | 2008-11-21 A | 2009-11-20 A | 100% |  | 2008-11-21 | 2009-11-20 | 261d? |  | finish no earlier than 2009-11-20 | G1 | 2088h | 2088h | RInImp9-RFmulti-GERAN | PCG-22 | Ericsson | mats.y.samuelsson@ericsson.com | Rel-9 | GP-40 | Paolo |  |
| 302 | 123.3 | Extended UMTS/LTE 800 MHz | 207d? | 2008-12-05 A | 2009-09-18 A | 100% |  | 2008-12-05 | 2009-09-18 | 207d? |  |  | R4,R2,R3 | 1648h | 1648h | RInImp9-UMTSLTE800 | PCG-22 | NTT DoCoMo | Shingo Suwa (suwas@nttdocomo.co.jp) | Rel-9 | RP-42 | Issam | RP-090687 |
| 303 | 123.4 | UMTS/LTE 800 MHz for Europe | 272d? | 2009-03-06 A | 2010-03-19 | 65% | 95.2d? | 2009-03-06 | 2010-03-19 | 272d? | 390d | finish no earlier than 2010-03-19 | R4,R2,R3 | 2176h | 1414.4h | RInImp9-UMTSLTE800EU | PCG-22 | Ericsson | olav.queseth@ericsson.com | Rel-9 | RP-43 | Issam | RP-091034 |
| 304 | 123.5 | Performance requirement for LCR TDD with UE speeds up to 350 km/h | 196d? | 2009-03-06 A | 2009-12-04 A | 100% |  | 2009-03-06 | 2009-12-04 | 196d? |  | finish no earlier than 2009-12-04 | R4 | 1568h | 1568h | RInImp9-LCRTDD350 | PCG-22 | CATT | Yuexia Song (songyuexia@datangmobile.cn) | Rel-9 | RP-43 | Issam | RP-091035 |
| 305 | 123.6 | Extended UMTS/LTE 1500 MHz | 211d? | 2009-05-30 A | 2010-03-19 | 95% | 10.55d? | 2009-05-30 | 2010-03-19 | 211d? | 390d | finish no earlier than 2010-03-19 | R4,R2,R3 | 1688h | 1603.6h | UMTSLTE1500 | PCG-23 | NTT DoCoMo | Shingo Suwa (suwas@nttdocomo.co.jp) | Rel-9 | RP-44 | Issam | RP-091365 |
| 306 | 124 | **Rel-9 Improvements of the Radio Interface - UE Conformance Testing** | 220d? | 2009-05-19 A | 2010-03-19 | 21% | 172.81d? | 2009-05-19 | 2010-03-19 | 220d? | 390d |  | R5 | 5176h | 1110.36h | RInImp-UEConTest | PCG-23 |  |  | Rel-9 | RP-44 | Ingbert |  |
| 307 | 124.1 | Conformance Test Aspects – UMTS/LTE in 800 MHz for Europe | 220d? | 2009-05-19 A | 2010-03-19 | 2% | 215.7d? | 2009-05-19 | 2010-03-19 | 220d? | 390d | finish no earlier than 2010-03-19 | R5 | 1760h | 34.4h | RInImp-UEConTest-UMTSLTE800EU | PCG-23 | Ericsson | fredrik.sundstrom@ericsson.com | Rel-9 | RP-44 | Ingbert | RP-091069 |
| 308 | 124.2 | Conformance Test Aspects – Extended UMTS/LTE 1500 MHz | 126d? | 2009-09-18 A | 2010-03-12 | 5% | 119.7d? | 2009-09-18 | 2010-03-12 | 126d? | 395d | finish no earlier than 2010-03-12 | R5 | 1008h | 50.4h | UMTSLTE1500_UEConTest | PCG-23 | NTT DoCoMo | Nguyen Dung Dao (dao@nttdocomo.co.jp) | Rel-9 | RP-45 | Ingbert | RP-091073 |
| 309 | 124.3 | TDD UE Over The Air (Antenna) conformance testing methodology | 81d? | 2009-05-30 A | 2009-09-18 A | 100% |  | 2009-05-30 | 2009-09-18 | 81d? |  | finish no earlier than 2009-09-18 | R5 | 648h | 648h | UEAnt_TDDTest | PCG-23 | CATR | Qu Yan (quyan@emcite.com) | Rel-9 | RP-44 | Ingbert | RP-090727 |
| 310 | 125 | Conformance Test Aspects – SMS over IMS in E-UTRAN | 196d? | 2009-09-18 A | 2010-06-18 | 5% | 186.2d? | 2009-09-18 | 2010-06-18 | 196d? | 325d | finish no earlier than 2010-06-18 | R5 | 1568h | 78.4h | SMSoverIMS_UEConTest | PCG-23 | Alcatel-Lucent | Nidal Khrais (khrais@alcatel-lucent.com) | Rel-9 | RP-45 | Ingbert | RP-091074 |
| 311 | 126 | **Rel-9 RAN improvements** | 272d? | 2009-03-06 A | 2010-03-19 | 99% | 3.7d? | 2009-03-06 | 2010-03-19 | 272d? | 390d |  | RP | 9536h | 9397.58h | RANimp | PCG-22 |  |  | Rel-9 | RP-43 | Issam |  |
| 312 | 126.1 | Dual-Cell HSUPA | 272d? | 2009-03-06 A | 2010-03-19 | 95% | 13.6d? | 2009-03-06 | 2010-03-19 | 272d? | 390d | finish no earlier than 2010-03-19 | R1,R2,R3,R4 | 1568h | 1459.2h | RANimp-DC_HSUPA | PCG-22 | Nokia Siemens Networks | Karri Ranta-aho (karri.ranta-aho@nsn.com) | Rel-9 | RP-43 | Patrick | RP-091037 |
| 313 | 126.2 | Support for different bands for Dual-Cell HSDPA | 197d? | 2009-03-06 A | 2009-12-04 A | 100% |  | 2009-03-06 | 2009-12-04 | 197d? |  |  | R4,R2,R3 | 1568h | 1568h | RANimp-MultiBand_DC_HSDPA | PCG-22 | Nokia Siemens Networks | Tuomo Säynäjäkangas (tuomo.saynajakangas@nsn.com) | Rel-9 | RP-43 | Issam | RP-091038 |
| 314 | 126.3 | Combination of DC-HSDPA with MIMO | 197d? | 2009-03-06 A | 2009-12-04 A | 100% |  | 2009-03-06 | 2009-12-04 | 197d? |  |  | R1,R2,R3,R4 | 1568h | 1568h | RANimp-DC_MIMO | PCG-22 | Ericsson | johan.bergman@ericsson.com | Rel-9 | RP-43 | Patrick | RP-091039 |
| 315 | 126.4 | Transmit Antenna Array (TxAA) extension for non-MIMO UEs | 197d? | 2009-03-06 A | 2009-12-04 A | 100% |  | 2009-03-06 | 2009-12-04 | 197d? |  |  | R1,R2,R3,R4 | 1568h | 1568h | RANimp-TxAA_nonMIMO | PCG-22 | Nokia | Arto Lehti (arto.lehti@nokia.com) | Rel-9 | RP-43 | Patrick | RP-091040 |
| 316 | 126.5 | Cell Portion for 1.28 Mcps TDD | 136d? | 2009-05-30 A | 2009-12-04 A | 100% |  | 2009-05-30 | 2009-12-04 | 136d? |  |  | R3,R1,R4 | 1088h | 1088h | CP_LCRTDD | PCG-23 | CATT | Ying Zhang (zhangying2@datangmobile.cn) | Rel-9 | RP-44 | Juha | RP-091041 |

Notes:
- 288: CP#46 exception to 03/10. WID updated CP-090316=>CP-091050 (added CT3 part). Continuation of Rel-8 Feature UID_400012 IMS Restoration Procedures
- 289: CP#46 exception to 03/10 in CP-090806 / Text3: 23.380, 23.820
- 290: CP#46 exception to 03/10 in CP-090871 / Text3: 24.229
- 291: CP#46 exception to 03/10 in CP-090863 / Text3: 29.061, 29.212, 29.213, 29.214, 29.215
- 292: CP#46 completion 12/09=>03/10 / Text3: 23.218, 24.229, 24.930
- 293: CP#46 exception to 03/10 in CP-090862 / Text3: 29.165
- 294: CP#46 exception to 03/10 in CP-090872. Stage 3 for Rel-7 Emergency Calls (EMC1). Related to Rel-9 UID_400038 LCS Control Plane Solution for EPS. Stage 2 in Rel-9 UID_400038 (23.271), UID_410037 (23.167) / Text3: 24.229
- 295: CP#46 completed / Text3: 29.212, 29.213, 29.215
- 296: CP#46 TS 24.166 v10x approved in CP-091044. Linked to Rel-6 UID_11051 (IMS Management objects) under the Feature UID_32021 (IMS Phase 2). MO compatible with OMA DM v1.2 & upwards and defined using OMA DM Device Description Framework (OMA-ERELD _DM-V1_2) / Text3: new 24.166
- 297: RP#41 umbrella Feature created to host Rel-9 WIs
- 298: RP#44 completed (Technical work completed, RAN4 internal TR abandoned. / Text3: Produced no TR 25.8xy (LCR TDD UE OTA performance requirements)
- 299: RF requirements specification applicable to Multi-Standard Radio (MSR) Base Station with multiple carriers and/or multiple 3GPP Radio Access Technologies (RAT)
- 300: RP#46 exception to 03/10 in RP-091382. WID updated RP-081098=>RP-091381 / Text3: 25.104, 25.105, 36.104, new 37.104, 37.113, 37.141, 37.900
- 301: GP#44 Core spec completed (ongoing BS conformance spec). GP#40 WID approved / Text3: 45.005, 51.021
- 302: RP#45 completed / Text3: 25.101, 25.104, 25.113, 25.133, 34.124, 36.101, 36.104, 36.113, 36.124, 36.133, 36.141, 25.306, 25.307, 25.331, 36.331, 25.461, 25.466, new 36.800
- 303: RP#46 exception to 03/10 in RP-091383. TR 36.810 v100 for Information / Text3: 25.101, 25.104, 25.113, 25.133, 25.141, 34.124, 36.101, 36.104, 36.113, 36.124, 36.133, 36.141, new 36.810, 25.306, 25.307, 25.331, 36.331, 25.461, 25.466
- 304: RP#46 completed / Text3: 25.102, 25.105, 25.142
- 305: RP#46 exception to 03/10 in RP-091367. For potential deployment in Japan / Text3: 25.101, 25.104, 25.113, 25.133, 25.141, 25.306, 25.307, 25.331, 25.461, 25.466, 34.124, 36.101, 36.104, 36.113, 36.124, 36.133, 36.141, 36.331, new 36.821
- 306: -
- 307: Testing for UID_430009 UMTS/LTE 800 MHz for Europe / Text3: 34.108, 34.121-1, 34.121-2, 36.508, 36.521-1, 36.521-2, 36.521-3
- 308: RP#46 updated WID RP-090748=>RP-091366 / Text3: 34.108, 34.121-1, 34.121-2, 34.123-1, 34.123-2, 34.123-3, 36.508, 36.521-1, 36.521-2, 36.521-3, 36.523-1, 36.523-2, 36.523-3
- 309: RP#45 completed. Finalize TDD UE test methodology based on R4 TR 25.914 (UE and MS antenna performance evaluation method) and TS 25.144 Over the Air (Antenna) minimum performance requirements for the speech mode (terminal close to head) / Text3: 34.114
- 310: - / Text3: 34.229-1, 34.229-2, 34.229-3
- 311: -
- 312: RP#46 exception to 03/10 in RP-091388 / Text3: 25.101, 25.104, 25.133, 25.211, 25.212, 25.213, 25.214, 25.215, 25.319, 25.306, 25.321, 25.331, 25.423, 25.433
- 313: RP#46 completed / Text3: 25.101, 25.104, 25.133, 25.306, 25.308, 25.331, 25.423, 25.433, new 25.317 (Requirements on Ues supporting a release-independent frequency band combination)
- 314: RP#46 completed / Text3: 25.101, 25.104, 25.133, 25.211, 25.212, 25.213, 25.214, 25.215, 25.308, 25.321, 25.331, 26.306, 25.423, 25.433
- 315: RP#46 completed / Text3: 25.101, 25.104, 25.211, 25.212, 25.213, 25.214, 25.215, 25.308, 25.306, 25.321, 25.331, 25.423, 25.433
- 316: RP#46 completed / Text3: 25.102, 25.105, 25.123, 25.225, 25.423, 25.433

| ID | WBS | Task | Duration | Start | Finish | Complete | Remaining | Baseline start | Baseline finish | Baseline duration | Total slack | Constraint | Resources | Work | Actual work | Text1 | Text2 | Text6 | Text7 | Text8 | Text4 | Text5 | Text11 |
| --- | --- | --- | --- | --- | --- | --- | --- | --- | --- | --- | --- | --- | --- | --- | --- | --- | --- | --- | --- | --- | --- | --- | --- |
| 317 | 127 | **LTE improvements** | 272d? | 2009-03-06 A | 2010-03-19 | 88% | 31.62d? | 2009-03-06 | 2010-03-19 | 272d? | 390d |  | RP | 5920h | 5231.86h | LTEimp | PCG-22 | Rel-9 | RP-42 | Issam |  |  |  |
| 318 | 127.1 | LTE Pico NodeB RF Requirements | 196d? | 2009-03-06 A | 2009-12-04 A | 100% |  | 2009-03-06 | 2009-12-04 | 196d? |  | finish no earlier than 2010-03-05 | R4 | 1568h | 1568h | LTEimp-Pico_eNB-RF | PCG-22 | Rel-9 | RP-43 | Issam | Huawei | Liyan Yin (yinliyan@huawei.com) | RP-091045 |
| 319 | 127.2 | Enhanced Dual-Layer transmission for LTE | 272d? | 2009-03-06 A | 2010-03-19 | 80% | 54.4d? | 2009-03-06 | 2010-03-19 | 272d? | 390d | finish no earlier than 2010-03-19 | R1,R2,R4 | 2176h | 1740.8h | LTEimp-eDL | PCG-22 | Rel-9 | RP-43 | Patrick | China Mobile | Xu Xiaodong (xuxiaodong@chinamobile.com) | RP-091046 |
| 320 | 128 | **System aspects of vocoder rate adaptation for LTE** | 140d? | 2009-05-30 A | 2009-12-10 A | 100% |  | 2009-05-30 | 2009-12-10 | 140d? |  |  | S2,S4,R2 | 3504h | 3504h | LTEimp-Vocoder | PCG-23 | Rel-9 | SP-45 | Maurice | Qualcomm Europe | AC Mahendran (ac@qualcomm.com) |  |
| 321 | 128.1 | SA2 system aspects of vocoder rate adaptation for LTE | 81d? | 2009-06-04 A | 2009-09-24 A | 100% |  | 2009-06-04 | 2009-09-24 | 81d? |  | start no earlier than 2009-06-04 | S2 | 648h | 648h | LTEimp-Vocoder | PCG-23 | Rel-9 | SP-45 | Maurice | Qualcomm Europe | AC Mahendran (ac@qualcomm.com) |  |
| 322 | 128.2 | SA4 system aspects of vocoder rate adaptation for LTE | 136d? | 2009-06-04 A | 2009-12-10 A | 100% |  | 2009-06-04 | 2009-12-10 | 136d? |  | finish no earlier than 2009-12-07 | S4 | 1088h | 1088h | LTEimp-Vocoder | PCG-23 | Rel-9 | SP-45 | Paolo | Qualcomm Europe | Nikolai Leung |  |
| 323 | 128.3 | Vocoder rate adaptation for LTE | 81d? | 2009-05-30 A | 2009-09-18 A | 100% |  | 2009-05-30 | 2009-09-18 | 81d? |  | finish no earlier than 2009-09-18 | R2 | 648h | 648h | LTEimp-Vocoder | PCG-23 | Rel-9 | RP-44 | Joern | Alcatel-Lucent | Sudeep Palat (spalat@alcatel-lucent.com) | RP-090704 |
| 324 | 129 | Self-Organizing Networks (SON) | 272d? | 2009-03-06 A | 2010-03-19 | 91% | 24.48d? | 2009-03-06 | 2010-03-19 | 272d? | 390d | finish no earlier than 2010-03-19 | R3,R2 | 2176h | 1980.16h | SON | PCG-22 | Rel-9 | SP-42 | Juha | Nokia Siemens Networks | Krzysztof Kordybach | RP-091051 |
| 325 | 130 | **A-GNSS Performances and Testing Procedures** | 527d? | 2008-05-16 A | 2010-05-21 | 50% | 261.21d? | 2008-05-16 | 2010-05-21 | 527d? | 345d |  | GP | 12208h | 4348.4h | AGNSSPTP |  | Rel-9 |  | Paolo | Thales | Michel.monnerat@thalesaleniaspace.com | GP-092344 |
| 326 | 130.1 | A-GNSS Minimum Performances | 472d? | 2008-05-16 A | 2010-03-05 | 90% | 47.2d? | 2008-05-16 | 2010-03-05 | 472d? | 400d | finish no earlier than 2010-03-05 | G1 | 3776h | 3398.4h | AGNSSPTP- Perfreq |  | Rel-9 |  | Paolo | Thales | Michel.monnerat@thalesaleniaspace.com | GP-092344 |
| 327 | 130.2 | A-GNSS Testing Procedures | 527d? | 2008-05-16 A | 2010-05-21 | 15% | 447.95d? | 2008-05-16 | 2010-05-21 | 527d? | 345d | finish no earlier than 2010-05-21 | G3new | 4216h | 632.4h | AGNSSPTP-MStest |  | Rel-9 |  | Ingbert | Thales | Michel.monnerat@thalesaleniaspace.com | GP-092344 |
| 328 | 131 | **Voice services over Adaptive Multi-user channels on One Slot** | 392d? | 2008-11-21 A | 2010-05-21 | 63% | 143.64d? | 2008-11-21 | 2010-05-21 | 392d? | 345d |  | GP | 12520.7h | 7929.92h | VAMOS | PCG-22 | Rel-9 | SP-42 | Paolo | Nokia Siemens Networks, China Mobile | juergen.hofmann@nsn.com, liuxiaoyu@chinamobile.com | GP-092470 |
| 329 | 131.1 | VAMOS Stage 2 | 392d? | 2008-11-21 A | 2010-05-21 | 90% | 39.2d? | 2008-11-21 | 2010-05-21 | 392d? | 345d | finish no earlier than 2010-05-21 | GP | 3128.68h | 2815.08h | VAMOS | PCG-22 | Rel-9 | GP-40 | Paolo | Nokia Siemens Networks, China Mobile | juergen.hofmann@nsn.com, liuxiaoyu@chinamobile.com | GP-092470 |
| 330 | 131.2 | VAMOS Stage 3 | 391d? | 2008-11-21 A | 2010-05-21 | 60% | 156.4d? | 2008-11-21 | 2010-05-21 | 391d? | 345d | finish no earlier than 2010-05-21 | GP | 3128h | 1876.8h | VAMOS | PCG-22 | Rel-9 | GP-40 | Paolo | Nokia Siemens Networks, China Mobile | juergen.hofmann@nsn.com, liuxiaoyu@chinamobile.com | GP-092470 |
| 331 | 131.3 | VAMOS Radio Performance Requirements | 391d? | 2008-11-24 A | 2010-05-21 | 40% | 234.6d? | 2008-11-24 | 2010-05-21 | 391d? | 345d | finish no earlier than 2010-05-21 | GP | 3128h | 1251.2h | VAMOS | PCG-22 | Rel-9 | GP-40 | Paolo | Nokia Siemens Networks, China Mobile | juergen.hofmann@nsn.com, liuxiaoyu@chinamobile.com | GP-092470 |
| 332 | 132 | **Local Call Local Switch** | 327d? | 2009-02-20 A | 2010-05-21 | 34% | 217.27d? | 2009-02-20 | 2010-05-21 | 327d? | 345d |  | GP,C4,C3,C1 | 12008h | 3460.2h | LCLS | PCG-22 | Rel-9 | GP-41 | Paolo | Huawei | Xing Zhu |  |
| 333 | 132.1 | Local Call Local Switch | 326d? | 2009-02-20 A | 2010-05-21 | 60% | 130.4d? | 2009-02-20 | 2010-05-21 | 326d? | 345d | finish no earlier than 2010-05-21 | GP | 2608h | 1564.8h | LCLS | PCG-22 | Rel-9 | GP-41 | Paolo | Huawei | Xing Zhu | GP-092473 |
| 334 | 132.2 | **CN aspects of Local Call Local Switch** | 212d? | 2009-05-29 A | 2010-03-19 | 20% | 169.6d? | 2009-05-29 | 2010-03-19 | 212d? | 390d |  | C4 | 6784h | 1017.6h | LCLS-CN | PCG-23 | Rel-9 | CP-44 | Kimmo | Vodafone | David Hutton |  |
| 335 | 132.2.1 | CT4 aspects of LCLS | 212d? | 2009-05-29 A | 2010-03-19 | 60% | 84.8d? | 2009-05-29 | 2010-03-19 | 212d? | 390d | finish no earlier than 2010-03-19 | C4 | 1696h | 1017.6h | LCLS-CN | PCG-23 | Rel-9 | CP-44 | Kimmo | Vodafone | David Hutton | CP-090807 |
| 336 | 132.2.2 | CT3 aspects of LCLS | 212d? | 2009-05-29 | 2010-03-19 |  |  | 2009-05-29 | 2010-03-19 | 212d? | 390d | finish no earlier than 2010-03-19 | C3 | 1696h |  | LCLS-CN | PCG-23 | Rel-9 | CP-44 | Gwiho | Vodafone | David Hutton |  |
| 337 | 132.2.3 | CT1 aspects of LCLS | 212d? | 2009-05-29 | 2010-03-19 |  |  | 2009-05-29 | 2010-03-19 | 212d? | 390d | finish no earlier than 2010-03-19 | C1 | 1696h |  | LCLS-CN | PCG-23 | Rel-9 | CP-44 | Frederic | Vodafone | David Hutton |  |
| 338 | 133 | **Cell Broadcast protocol Base Station Controller – Cell Broadcast Centre (BSC-CBC)** | 222d? | 2009-05-15 A | 2010-03-19 | 39% | 135.25d? | 2009-05-15 | 2010-03-19 | 222d? | 390d |  | GP,C1 | 5248h | 2050.83h | CEBRO | PCG-23 | Rel-9 | GP-42 | Paolo | Ericsson | Claes-Göran Persson |  |
| 339 | 133.1 | Cell Broadcast protocol Base Station Controller – Cell Broadcast Centre (BSC-CBC) | 212d? | 2009-05-15 A | 2010-03-05 | 80% | 42.4d? | 2009-05-15 | 2010-03-05 | 212d? | 400d | finish no earlier than 2010-03-05 | GP | 1696h | 1356.8h | CEBRO | PCG-23 | Rel-9 | GP-42 | Paolo | Ericsson | Claes-Göran Persson | GP-092475 |
| 340 | 133.2 | Cell Broadcast protocol Base Station Controller – Cell Broadcast Centre (BSC-CBC) | 222d? | 2009-05-15 | 2010-03-19 |  |  | 2009-05-15 | 2010-03-19 | 222d? | 390d | finish no earlier than 2010-03-19 | C1 | 1776h |  | CEBRO | PCG-23 | Rel-9 | GP-42 | Frederic | Ericsson | Claes-Göran Persson | CP-090867 |
| 341 | 134 | Hybrid Location | 136d? | 2009-05-18 A | 2009-11-20 A | 100% |  | 2009-05-18 | 2009-11-20 | 136d? |  | finish no earlier than 2009-11-20 | GP | 1088h | 1088h | HILT | PCG-23 | Rel-9 | GP-42 | Paolo | TruePosition | Matt Ward (mward@trueposition.com) |  |
| 342 | 135 | (Small) Technical Enhancements and Improvements for Rel-9 | 325d? | 2008-09-15 A | 2009-12-10 A | 100% |  | 2008-09-15 | 2009-12-10 | 325d? |  | finish no earlier than 2009-12-10 | All | 2600h | 2600h | TEI9 | PCG-22 | Rel-9 | SP-42 |  |  |  |  |
| 343 | 136 | Test - (Small) Technical Enhancements and Improvements for Rel-8 | 286d? | 2009-11-20 | 2010-12-24 |  |  | 2009-11-20 | 2010-12-24 | 286d? | 190d | finish no earlier than 2010-12-24 | R5,G3new | 2288h |  | TEI9_Test | PCG-24 | Rel-9 | GP-44 |  |  |  |  |

Notes:
- 317: -
- 318: RP#46 completed. WID updated RP-090096=>RP-091155 / Text3: 36.104, 36.141, new 36.931
- 319: RP#46 exception to 03/10 in RP-091147. WID updated RP-090783=>RP-091385 / Text3: 36.101, 36.211, 36.212, 36.213, 36.331
- 320: SP#46 completed. Triggered by RAN2 UID_440013 Vocoder rate adaptation for LTE
- 321: SP#45 completed (CR adding support for Explicit Congestion Notification) / Text3: 23.401 CR#1103r3
- 322: SP#46 completed / Text3: 26.114
- 323: RP#45 completed / Text3: 36.300 CR#0114
- 324: RP#46 exception to 03/10 in RP-091395 / Text3: 25.413, 36.300, 36.413, 36.423, 36.902, 48.018
- 325: GP#44 moved to Rel-9. Rel-9 exception to 03/10 in GP-092344. Linked to Rel-10 RAN4 UID_450027 (A-GNSS Minimum Performance for UTRAN)
- 326: GP#44 moved to Rel-9. Rel-9 exception to 03/10 in GP-092344 / Text3: 45.005
- 327: GP#44 moved to Rel-9. Rel-9 exception to 03/10 in GP-092344 / Text3: 51.010-1
- 328: GP#44 exception to 05/10 in GP-092470. GP#40 WID approved. Triggered by UID_50590 (MUROS) Study on Multi-User Reusing-One-Slot
- 329: GP#44 exception to 05/10 in GP-092470 / Text3: 45.001 (Overview of VAMOS solution)
- 330: GP#44 exception to 05/10 in GP-092470 / Text3: 24.008, 44.018, 45.002, 45.003, 45.004, 45.008, 48.008, 48.058
- 331: GP#44 exception to 05/10 in GP-092470 / Text3: 45.005 (Test Scenarios for VAMOS Performance requirements)
- 332: GP#44 exception to 05/10 in GP-092473. GP#41 WID approved. CP#46 WID (CP-090519) revised to Study item (CP-090812).
- 333: GP#44 exception to 05/10 in GP-092473. GP#41 WID approved / Text3: 48.008 (MSC-BSS interface; Layer 3 specification)
- 334: CP#46 WID (CP-090519) revised to Study item (CP-090812). Normative work can be done in Rel-9 but then a complete set of CRs and WID must be provided for approval at CP#47 03/10.
- 335: CP#46 exception to 03/10 in CP-090807 to finish TR 23.889. Normative work target: 23.205, 23.153, 23.231, 29.232 / Text3: new 23.889
- 336: - / Text3: 29.007
- 337: - / Text3: 23.009
- 338: GP#42 WID approved
- 339: GP#44 exception to 03/10 in GP-092475. GP#42 WID approved / Text3: new 48.049
- 340: CP#46 exception to 03/10 in CP-090867 / Text3: 23.041
- 341: GP#44 completed. GP#42 WID approved (Hybrid Integrated Location Technology=HILT) / Text3: 43.059, 48.071
- 342: SP#46 completed
- 343: GP#44 created

| ID | WBS | Task | Type | Duration | Start | Finish | Complete | Remaining | Baseline start | Baseline finish | Baseline duration | Total slack | Constraint | Resources | Work | Actual work | Text1 | Text2 | Text4 | Text6 | Text7 | Text8 | Text9 | Text12 | Text5 | Text11 |
| --- | --- | --- | --- | --- | --- | --- | --- | --- | --- | --- | --- | --- | --- | --- | --- | --- | --- | --- | --- | --- | --- | --- | --- | --- | --- | --- |
| 344 | 137 | **Deleted - SAES Enhancements (non RAN aspects)** |  | 381d? | 2007-06-25 A | 2008-12-08 A | 100% |  | 2007-06-25 | 2008-12-08 | 381d? |  |  | S2 | 11664h | 11664h | SAES_Ph2 | PCG-21 | Nokia Siemens Networks | Rel-9 | SP-39 | Maurice | PCG-21 | SP-39 |  |  |
| 345 | 137.1 | Deleted - Functions and procedures for SAE to support LTE MBMS |  | 381d? | 2007-06-25 A | 2008-12-08 A | 100% |  | 2007-06-25 | 2008-12-08 | 381d? |  | finish no earlier than 2008-12-08 | S2 | 3048h | 3048h | SAES_Ph2 |  |  | Rel-9 | SP-35 | Maurice | PCG-21 | SP-39 |  |  |
| 346 | 137.2 | Deleted - CS over EPS |  | 194d? | 2008-03-12 A | 2008-12-08 A | 100% |  | 2008-03-12 | 2008-12-08 | 194d? |  | finish no earlier than 2008-12-08 | S2 | 1552h | 1552h | SAES_Ph2 | PCG-21 |  | Rel-9 | SP-39 | Maurice | PCG-21 | SP-39 |  |  |
| 347 | 137.3 | **Deleted - SAE for generic support for non-3GPP accesses** |  | 251d? | 2007-06-25 A | 2008-06-09 A | 100% |  | 2007-06-25 | 2008-06-09 | 251d? |  |  | S2 | 4016h | 4016h | SAES_Ph2 | PCG-21 |  | Rel-9 | SP-39 | Maurice | PCG-21 | SP-39 |  |  |
| 348 | 137.3.1 | Deleted - Single Radio Aspects of SAE for Optimized Handover with WiMAX |  | 251d? | 2007-06-25 A | 2008-06-09 A | 100% |  | 2007-06-25 | 2008-06-09 | 251d? |  | finish no earlier than 2008-06-09 | S2 | 2008h | 2008h | SAES_Ph2 | PCG-21 |  | Rel-9 | SP-39 | Maurice | PCG-21 | SP-39 |  |  |
| 349 | 138 | Deleted - Harmonization of Gq'/Rx for Common IMS |  | 304d? | 2008-01-14 A | 2009-03-12 A | 100% |  | 2008-01-14 | 2009-03-12 | 304d? |  | finish no earlier than 2009-03-12 | S2 | 2432h | 2432h | IMS_Comm_GqRx_Harm | PCG-21 | Alcatel-Lucent | Rel-9 | SP-38 | Maurice | PCG-22 | SP-43 | geoffrey.cristallo@alcatel-lucent.be |  |
| 350 | 139 | Deleted - Support of WiMAX - LTE Mobility |  | 407d? | 2008-06-06 A | 2009-12-25 A | 100% |  | 2008-06-06 | 2009-12-25 | 407d? |  | start no earlier than 2008-06-06 | R2 | 3248h | 3248h | WiMAX_LTE_Mobility | PCG-21 | Samsung | Rel-9 | RP-38 | Joern | PCG-21 | SP-39 |  |  |
| 351 | 140 | Deleted - Support of WiMAX - UMTS Mobility |  | 407d? | 2008-06-06 A | 2009-12-25 A | 100% |  | 2008-06-06 | 2009-12-25 | 407d? |  | start no earlier than 2008-06-06 | R2 | 3248h | 3248h | WiMAX_UMTS_Mobility | PCG-21 | Intel | Rel-9 | RP-38 | Joern | PCG-21 | SP-39 |  |  |
| 352 | 141 | Release 9 Studies | milestone | 0d? | 2000-01-01 | 2000-01-01 |  |  | 2000-01-01 | 2000-01-01 | 0d? | 3057d |  | CP,RP,SP |  |  |  |  |  | Rel-9 |  |  |  |  |  |  |
| 353 | 142 | Study on Service Specific Access Control in EPS |  | 136d? | 2008-06-05 A | 2008-12-11 A | 100% |  | 2008-06-05 | 2008-12-11 | 136d? |  | start no earlier than 2008-06-05 | S1 | 1088h | 1088h | FS_SSAC | PCG-21 | NTT DoCoMo | Rel-9 | SP-40 | Alain |  |  | Frederic Thepot (thepot@docomolab-euro.com) |  |
| 354 | 143 | Study on CS Domain Services over EPS access |  | 492d? | 2007-04-25 A | 2009-03-12 A | 100% |  | 2007-04-25 | 2009-03-12 | 492d? |  | finish no earlier than 2009-03-12 | S2 | 3936h | 3936h | FS_CSoPS |  | T-Mobile | Rel-9 | SP-35 | Maurice |  |  | Karl-Heinz.Nenner@T-Mobile.net |  |
| 355 | 144 | Study on Extended Support of IMS Emergency Calls |  | 319d? | 2007-09-24 A | 2008-12-11 A | 100% |  | 2007-09-24 | 2008-12-11 | 319d? |  | finish no earlier than 2009-06-18 | S2 | 2552h | 2552h | FS_IMS-eCall |  | Qualcomm Europe | Rel-9 | SP-37 | Maurice |  |  | Stephen Edge |  |
| 356 | 145 | Study on Service Continuity for Emergency Voice Calls |  | 721d? | 2006-06-08 A | 2009-03-12 A | 100% |  | 2006-06-08 | 2009-03-12 | 721d? |  | finish no earlier than 2009-03-12 | S2 | 5768h | 5768h | FS_VCCEm |  | Nortel | Rel-9 | SP-32 | Maurice |  |  | Ricky Kaura (rkaura@nortel.com) |  |
| 357 | 146 | Study on Security Aspects of Remote Provisioning and Change of Subscription for M2M Equipment |  | 582d? | 2004-04-06 A | 2009-12-10 A | 100% |  | 2004-04-06 | 2009-12-10 | 582d? |  | finish no earlier than 2009-12-10 | S3,C6 | 4656h | 4656h | FS_UM2M |  | Ericsson | Rel-9 | SP-37 | Dionisio |  |  | vesa.lehtovirta@ericsson.com |  |
| 358 | 147 | Study on System Maintenance over Itf-N |  | 602d? | 2007-06-07 A | 2009-09-24 A | 100% |  | 2007-06-07 | 2009-09-24 | 602d? |  | finish no earlier than 2009-09-24 | S5 | 4808h | 4808h | FS_OAM-Maint-Itf-N |  | ZTE | Rel-9 | SP-36 | Dionisio |  |  | HUANG, Shuqiang |  |
| 359 | 148 | Study on Self-Organizing Networks (SON) related OAM interfaces for Home NodeB |  | 522d? | 2007-06-07 A | 2009-06-04 A | 100% |  | 2007-06-07 | 2009-06-04 | 522d? |  | finish no earlier than 2009-12-10 | S5 | 4168h | 4168h | FS_OAM-SON-HNB |  | Huawei | Rel-9 | SP-36 | Dionisio |  |  | Zou Lan (zlan@huawei.com) |  |
| 360 | 149 | Study on Self-healing of Self-Organizing Networks (SON) |  | 416d? | 2008-02-22 A | 2009-09-24 A | 100% |  | 2008-02-22 | 2009-09-24 | 416d? |  | finish no earlier than 2009-09-24 | S5 | 3320.15h | 3320.15h | FS_OAM-SON-SH | PCG-21 | ZTE | Rel-9 | SP-39 | Dionisio |  |  | zhu.weihong@zte.com.cn |  |
| 361 | 150 | Study on Service Oriented Architecture (SOA) for IRP |  | 262d? | 2008-06-05 A | 2009-06-04 A | 100% |  | 2008-06-05 | 2009-06-04 | 262d? |  | finish no earlier than 2009-05-20 | S5 | 2088h | 2088h | FS_OAM_SOA_IRP | PCG-21 | Ericsson | Rel-9 | SP-40 | Dionisio |  |  | edwin.tse@ericsson.com |  |
| 362 | 151 | Study on Interworking Proxy between GTP based and PMIP based interfaces |  | 131d? | 2009-09-18 A | 2010-03-19 | 60% | 52.4d? | 2009-09-18 | 2010-03-19 | 131d? | 390d | finish no earlier than 2010-03-19 | C4 | 1048h | 628.8h | FS_GTP-MIP-IW | PCG-23 | NTT DoCoMo | Rel-9 | CP-45 | Kimmo |  |  | takaaki.matsuura.sp@s1.nttdocomo.com | CP-090810 |
| 363 | 152 | Study on Evaluation of the inclusion of Path Loss Based Technology in the UTRAN |  | 516d? | 2007-12-17 A | 2009-12-04 A | 100% |  | 2007-12-17 | 2009-12-04 | 516d? |  | finish no earlier than 2009-09-18 | R4 | 4120h | 4120h | FS_RAN-Pathloss | PCG-21 | Polaris Wireless | Rel-9 | RP-38 | Issam |  |  | Norman Shaw (nshaw@polariswireless.com) | RP-091080 |
| 364 | 153 | Study on LTE-Advanced |  | 461d? | 2007-03-23 A | 2010-03-19 | 80% | 92.8d? | 2007-03-23 | 2010-03-19 | 461d? | 390d | finish no earlier than 2010-03-19 | R1,R2,R3,R4 | 3688h | 2945.6h | FS_RAN_LTEA | PCG-21 | NTT DoCoMo | Rel-9 | RP-39 | Patrick |  |  | Tetsushi Abe | RP-091082 |
| 365 | 154 | Study on 1.28 Mcps TDD Home NodeB |  | 387d? | 2008-02-20 A | 2009-12-04 A | 100% |  | 2008-02-20 | 2009-12-04 | 387d? |  | finish no earlier than 2009-12-04 | R4 | 3096h | 3096h | FS_RAN-HNBLCRTDD | PCG-21 | TD Tech | Rel-9 | RP-41 | Issam |  |  | Li Rong (lirong@td-tech.com) | RP-091081 |
| 366 | 155 | Study on E-UTRAN Mobility Evaluation and Enhancement |  | 126d? | 2008-12-05 A | 2009-05-29 A | 100% |  | 2008-12-05 | 2009-05-29 | 126d? |  | finish no earlier than 2009-05-29 | R1 | 1008h | 1008h | FS_EUTRAN_mob | PCG-22 | Qualcomm Europe | Rel-9 | RP-42 | Patrick |  |  | Rajat Prakash (rprakash@qualcomm.com) | RP-090426 |
| 367 | 156 | Study on Minimization of drive-tests in Next Generation Networks |  | 196d? | 2009-03-06 A | 2009-12-04 A | 100% |  | 2009-03-06 | 2009-12-04 | 196d? |  | finish no earlier than 2009-12-04 | R2 | 1568h | 1568h | FS_NGN_min_drive-tests | PCG-22 | Qualcomm Europe | Rel-9 | RP-43 | Joern |  |  | Masato Kitazoe (mkitazoe@qualcomm.com) | RP-091084 |
| 368 | 157 | Study on Enhanced Interference Management for HNBs |  | 61d? | 2009-03-06 A | 2009-05-29 A | 100% |  | 2009-03-06 | 2009-05-29 | 61d? |  | start no earlier than 2009-03-06 | R4 | 488h | 488h | FS_eInterfMgmt_HNB | PCG-22 | Qualcomm Europe | Rel-9 | RP-43 | Issam |  |  | Farhad Meshkati (fmeshkat@qualcomm.com) | RP-090429 |
| 369 | 158 | Study on Enhanced Interference Management Mechanisms for HNBs |  | 81d? | 2009-05-30 A | 2009-09-18 A | 100% |  | 2009-05-30 | 2009-09-18 | 81d? |  | finish no earlier than 2009-09-18 | R3 | 648h | 648h | FS_eInterfMgmtMchsm_HNB | PCG-23 | Qualcomm Europe | Rel-9 | RP-44 | Juha |  |  | Farhad Meshkati (fmeshkat@qualcomm.com) | RP-090733 |
| 370 | 159 | Deleted - Study on Protection against SMS and MMS spam |  | 862d? | 2006-06-08 A | 2009-09-24 A | 100% |  | 2006-06-08 | 2009-09-24 | 862d? |  | finish no earlier than 2009-09-24 | S3 | 6896h | 6896h | FS_CPSMal |  | Orange | Rel-9 | SP-32 | Dionisio | PCG-23 | SP-45 | eric.gauthier@orange.ch |  |
| 371 | 160 | Release 8 Features | milestone | 0d? | 2000-01-03 | 2000-01-03 |  |  | 2000-01-03 | 2000-01-03 | 0d? | 3056d | start no earlier than 2000-01-03 | CP,GP,RP,SP |  |  |  |  |  | Rel-8 |  |  |  |  |  |  |

Notes:
- 344: SP#39 created to host Rel-9 Wis. BUT no agreed WID
- 345: SP#39 SAE functionality moved to Rel-9. WID returned to SA2 for re-consideration & remove MBMS for EPS from Rel 8
- 346: SP#39 SAE functionality moved to Rel-9. BUT no agreed WID
- 347: SP#39 SAE functionality moved to Rel-9. BUT no agreed WID
- 348: SP#39 SAE functionality moved to Rel-9. BUT no agreed WID
- 349: SP#43 stopped. LS_out to TISPAN informs about stopping this activity / Text3: 23.822, 23.203
- 350: RP#39: No agreed WID / Text3: 36.306, 36.331, 36.413, 36.300, 36.214, 36.133, 36.304
- 351: RP#39: No agreed WID / Text3: 25.306, 25.331, 25.413
- 352: -
- 353: SP#42 completed. Spin-off Feature UID_420020 (SSAC) / Text3: 22.986
- 354: SP#43 completed / Text3: 23.879
- 355: SP#42 completed / Text3: 23.868
- 356: SP#43 completed / Text3: 23.826
- 357: SP#46 completed. Triggered by SA1 Study UID_7027 (FS_M2M) TR 22.868 / Text3: 33.812
- 358: SP#45 completed / Text3: 32.822
- 359: SP#44 completed / Text3: 32.821
- 360: SP#45 completed / Text3: 32.823
- 361: SP#44 completed. Spin-off implementation WI UID_440064 Service Oriented Architecture (SOA) for IRP / Text3: 32.824
- 362: CP#46 exception to 03/10 in CP-090810 / Text3: 29.875
- 363: RP#46 completed / Text3: 25.907
- 364: RP#46 updated WID RP-090735=>RP-091360 / Text3: 36.913 , new 36.814, 36.912, R2 36.806 (Relay architectures for E-UTRA), R4 36.815 (LTE-Advanced feasibility studies in RAN4)
- 365: RP#46 completed / Text3: 25.866
- 366: RP#44 completed (RP-090452 R1 LS to RAN on Conclusions for LTE Mobility Study Item - no further Rel-9 action/TR needed
- 367: RP#46 completed / Text3: 36.805
- 368: RP#44 completed. Spin-off RAN3 UID_440015 Study on Enhanced Interference Management Mechanisms for HNBs / Text3: 25.967
- 369: Triggered by RAN4 UID_430027 Study on Enhanced Interference Management for HNBs. RP#45 completed / Text3: 25.967
- 370: SP#45 work stopped/abandoned / Text3: 33.9xx
- 371: -

| ID | WBS | Task | Duration | Start | Finish | Complete | Remaining | Baseline start | Baseline finish | Baseline duration | Total slack | Constraint | Resources | Work | Actual work | Text1 | Text4 | Text5 | Text6 | Text8 | Text7 | Text2 |
| --- | --- | --- | --- | --- | --- | --- | --- | --- | --- | --- | --- | --- | --- | --- | --- | --- | --- | --- | --- | --- | --- | --- |
| 372 | 161 | **3GPP System Architecture Evolution Specification - Evolved Packet System (non RAN aspects)** | 1024d? | 2006-04-12 A | 2010-03-12 | 99% | 5.09d? | 2006-04-12 | 2010-03-12 | 1024d? | 395d |  | SP,CP | 259980h | 258340h | SAES | T-Mobile | michael.kurz@t-mobile.at | Rel-8 | Alain |  |  |
| 373 | 161.1 | Requirements for evolution of the 3GPP system architecture | 395d? | 2006-06-08 A | 2007-12-12 A | 100% |  | 2006-06-08 | 2007-12-12 | 395d? |  | finish no earlier than 2007-11-30 | S1 | 3160h | 3160h | AIPN-SAE | T-Mobile | michael.kurz@t-mobile.at | Rel-8 | Alain |  |  |
| 374 | 161.2 | **High level and common (for all accesses) functions** | 629d? | 2007-01-02 A | 2009-05-29 A | 100% |  | 2007-01-02 | 2009-05-29 | 629d? |  |  | SP,CP | 42536h | 42536h | EPS-ComF | Nokia Siemens Networks | balazs.bertenyi@nsn.com | Rel-8 | Maurice | SP-37 |  |
| 375 | 161.2.1 | Stage 2 for High level functions | 370d? | 2007-01-02 A | 2008-06-02 A | 100% |  | 2007-01-02 | 2008-06-02 | 370d? |  | finish no earlier than 2008-06-02 | S2 | 2960h | 2960h | SAES-SA-HLF | Motorola | Irfan.Ali@motorola.com | Rel-8 | Maurice |  |  |
| 376 | 161.2.2 | Stage 2 Security Architecture | 197d? | 2008-03-12 A | 2008-12-11 A | 100% |  | 2008-03-12 | 2008-12-11 | 197d? |  | finish no earlier than 2008-12-11 | S3 | 1576h | 1576h | SAES | Nokia Siemens Networks | marc.blommaert.ext@nsn.com | Rel-8 | Dionisio | SP-39 | PCG-21 |
| 377 | 161.2.3 | Stage 3 (CT1) for SAE impact on services, network functions and capabilities | 545d? | 2007-02-05 A | 2009-03-06 A | 100% |  | 2007-02-05 | 2009-03-06 | 545d? |  | finish no earlier than 2009-03-06 | C1 | 4360h | 4360h | SAES | Nokia Siemens Networks | robert.zaus@nsn.com | Rel-8 | Frederic |  |  |
| 378 | 161.2.4 | Stage 3 SAE impact on existing capabilities | 480d? | 2007-02-05 A | 2008-12-05 A | 100% |  | 2007-02-05 | 2008-12-05 | 480d? |  | finish no earlier than 2008-12-12 | C3 | 3840h | 3840h | SAES | Huawei | Wei Weihua (weiwh@huawei.com) | Rel-8 | Gwiho |  |  |
| 379 | 161.2.5 | Stage 3 (CT4) of SAE impact on existing capabilities | 545d? | 2007-02-05 A | 2009-03-06 A | 100% |  | 2007-02-05 | 2009-03-06 | 545d? |  | finish no earlier than 2009-03-06 | C4 | 4360h | 4360h | SAES | Huawei | shahab.lavasani@huawei.com | Rel-8 | Kimmo |  |  |
| 380 | 161.2.6 | Stage 2/3 for Network selection procedures | 480d? | 2007-02-05 A | 2008-12-05 A | 100% |  | 2007-02-05 | 2008-12-05 | 480d? |  | finish no earlier than 2009-03-06 | C1 | 3840h | 3840h | SAES | Nokia Siemens Networks | robert.zaus@nsn.com | Rel-8 | Frederic |  |  |
| 381 | 161.2.7 | Stage 3 EPC interworking with external PDNs (SGi) | 605d? | 2007-02-05 A | 2009-05-29 A | 100% |  | 2007-02-05 | 2009-05-29 | 605d? |  | finish no earlier than 2009-05-29 | C3 | 4840h | 4840h | SAES-St3-intwk | Huawei | Wei Weihua (weiwh@huawei.com) | Rel-8 | Gwiho |  |  |
| 382 | 161.2.8 | Stage 3 PCC within SAE | 605d? | 2007-02-05 A | 2009-05-29 A | 100% |  | 2007-02-05 | 2009-05-29 | 605d? |  | finish no earlier than 2009-05-29 | C3 | 4840h | 4840h | SAES-St3-PCC | Ericsson | j.javier.pastor@ericsson.com | Rel-8 | Gwiho |  |  |
| 383 | 161.2.9 | Stage 3 for SAE / LTE identities | 545d? | 2007-02-05 A | 2009-03-06 A | 100% |  | 2007-02-05 | 2009-03-06 | 545d? |  | finish no earlier than 2009-03-06 | C4 | 4360h | 4360h | SAES | Huawei | shahab.lavasani@huawei.com | Rel-8 | Kimmo |  |  |
| 384 | 161.2.10 | Unified guidelines for Diameter usage within 3GPP | 316d? | 2007-09-21 A | 2008-12-05 A | 100% |  | 2007-09-21 | 2008-12-05 | 316d? |  | finish no earlier than 2008-12-05 | C3 | 2528h | 2528h | SAES-DIAM | Huawei | Javier Gonzalez Gallego | Rel-8 | Gwiho | CP-37 |  |
| 385 | 161.3 | **SAE for LTE access** | 569d? | 2007-01-02 A | 2009-03-06 A | 100% |  | 2007-01-02 | 2009-03-06 | 569d? |  |  | S2,C1,C3,C4 | 57824h | 57824h | SAES-LTE | Motorola | Irfan.Ali@motorola.com | Rel-8 | Maurice |  |  |
| 386 | 161.3.1 | CT4 Stage 3 for protocol between EPCs | 545d? | 2007-02-05 A | 2009-03-06 A | 100% |  | 2007-02-05 | 2009-03-06 | 545d? |  | finish no earlier than 2009-03-06 | C4 | 4360h | 4360h | SAES | Huawei | shahab.lavasani@huawei.com | Rel-8 | Kimmo |  |  |
| 387 | 7.2.2.1 | **SAES-SA-FP_LTE with GTP variant** | 569d? | 2007-01-02 A | 2009-03-06 A | 100% |  | 2007-01-02 | 2009-03-06 | 569d? |  |  | S2,C4 | 11896h | 11896h | SAES-SA-FP_LTE-GTP | Nokia Siemens Networks | balazs.bertenyi@nsn.com | Rel-8 | Maurice |  |  |
| 388 | 161.3.2.1 | Stage 2 for SAES-SA-FP_LTE with GTP variant | 373d? | 2007-01-02 A | 2008-06-05 A | 100% |  | 2007-01-02 | 2008-06-05 | 373d? |  | finish no earlier than 2008-06-02 | S2 | 2984h | 2984h | SAES-SA-FP_LTE-GTP-St2 | Nokia Siemens Networks | balazs.bertenyi@nsn.com | Rel-8 | Maurice |  |  |
| 389 | 161.3.2.2 | CT4 Stage 3 for GTP v2 protocol | 545d? | 2007-02-05 A | 2009-03-06 A | 100% |  | 2007-02-05 | 2009-03-06 | 545d? |  | finish no earlier than 2009-03-06 | C4 | 4360h | 4360h | SAES | Huawei | shahab.lavasani@huawei.com | Rel-8 | Kimmo |  |  |
| 390 | 7.2.2.2 | **SAES-SA-FP_LTE with PMIP variant** | 569d? | 2007-01-02 A | 2009-03-06 A | 100% |  | 2007-01-02 | 2009-03-06 | 569d? |  |  | S2,C4 | 15736h | 15736h | SAES-SA-FP_LTE-IETF | Nokia Siemens Networks | balazs.bertenyi@nsn.com | Rel-8 | Maurice |  |  |
| 391 | 161.3.3.1 | Stage 2 for SAES-SA-FP_LTE with PMIP variant | 373d? | 2007-01-02 A | 2008-06-05 A | 100% |  | 2007-01-02 | 2008-06-05 | 373d? |  | finish no earlier than 2008-06-02 | S2 | 2984h | 2984h | SAES-SA-FP_LTE-IETF-St2 | Nokia Siemens Networks | balazs.bertenyi@nsn.com | Rel-8 | Maurice |  |  |
| 392 | 161.3.3.2 | CT4 Stage 3 for PMIP protocol within EPC | 545d? | 2007-02-05 A | 2009-03-06 A | 100% |  | 2007-02-05 | 2009-03-06 | 545d? |  | finish no earlier than 2009-03-06 | C4 | 4360h | 4360h | SAES | Huawei | shahab.lavasani@huawei.com | Rel-8 | Kimmo | CP-37 |  |
| 393 | 161.3.3.3 | Mobile IPv4 (MIPv4) based Mobility protocols | 480d? | 2007-02-05 A | 2008-12-05 A | 100% |  | 2007-02-05 | 2008-12-05 | 480d? |  | finish no earlier than 2008-12-05 | C4 | 3840h | 3840h | SAES | Motorola | Lewis Milton | Rel-8 | Kimmo | CP-41 |  |
| 394 | 161.3.4 | Stage 3 for UE NAS mobility procedures in idle and active mode | 545d? | 2007-02-05 A | 2009-03-06 A | 100% |  | 2007-02-05 | 2009-03-06 | 545d? |  | finish no earlier than 2009-03-06 | C1 | 4360h | 4360h | SAES | Nokia Siemens Networks | robert.zaus@nsn.com | Rel-8 | Frederic |  |  |
| 395 | 161.3.5 | Stage 3 for Session management, bearer control and QoS aspects | 545d? | 2007-02-05 A | 2009-03-06 A | 100% |  | 2007-02-05 | 2009-03-06 | 545d? |  | finish no earlier than 2009-03-06 | C1 | 4360h | 4360h | SAES | Nokia Siemens Networks | robert.zaus@nsn.com | Rel-8 | Frederic |  |  |
| 396 | 161.3.6 | Stage 3 for security aspects of LTE Access | 545d? | 2007-02-05 A | 2009-03-06 A | 100% |  | 2007-02-05 | 2009-03-06 | 545d? |  | finish no earlier than 2009-03-06 | C1 | 4360h | 4360h | SAES | Nokia Siemens Networks | robert.zaus@nsn.com | Rel-8 | Frederic |  |  |
| 397 | 161.3.7 | Stage 3 for QoS mechanisms | 480d? | 2007-02-05 A | 2008-12-05 A | 100% |  | 2007-02-05 | 2008-12-05 | 480d? |  | finish no earlier than 2008-12-12 | C3 | 3840h | 3840h | SAES | Ericsson | j.javier.pastor@ericsson.com | Rel-8 | Gwiho |  |  |
| 398 | 161.3.8 | Stage 3 for EPC - HSS interface | 545d? | 2007-02-05 A | 2009-03-06 A | 100% |  | 2007-02-05 | 2009-03-06 | 545d? |  | finish no earlier than 2009-03-06 | C4 | 4360h | 4360h | SAES | Huawei | shahab.lavasani@huawei.com | Rel-8 | Kimmo |  |  |

Notes:
- 372: SP#39 WID updated SP-070933=>SP-080132. Role model for SAE/LTE system wide project management by SA2 in SP-060166
- 373: SP#38 completed / Text3: 22.278, 22.011, 22.246
- 374: SP#39 WID updated SP-070933=>SP-080132
- 375: SP#40 completed / Text3: 23.402
- 376: SP#42 completed. SP#39 WID updated SP-070933=>SP-080132 / Text3: 33.401, 33.210, 33.310
- 377: CP#43 completed / Text3: 24.229, 24.305, 27.007
- 378: CP#42 completed. WID updated CP-080056=>CP-080772 / Text3: 29.061
- 379: CP#43 completed. WID updated CP-080724=>CP-090247. Network sharing, etc, MBMS removed / Text3: 29.274, 29.275
- 380: CP#42 completed. CP#41 WID updated CP-080075=>CP-080493. / Text3: 23.122, 24.302
- 381: CP#44 completed / Text3: 29.061
- 382: CP#44 completed / Text3: 29.212, 29.213, 29.214, 29.215
- 383: CP#43 completed. WID updated CP-080724=>CP-090247 / Text3: 23.003
- 384: CP#42 completed / Text3: 29.909
- 385: CP#43 completed. SP#39 WID updated SP-070933=>SP-080132
- 386: CP#43 completed. WID updated CP-080724=>CP-090247. PMIP and GTP based S8 interface (EPC-EPC) / Text3: 29.274, 29.275
- 387: CP#43 completed. SP#39 WID updated SP-070933=>SP-080132
- 388: SP#40 completed / Text3: 23.401, 23.060, 23.002, 23.246, 23.203, 23.107, 23.234, 23.271
- 389: CP#43 completed. WID updated CP-080724=>CP-090247 / Text3: 29.274
- 390: CP#43 completed. SP#39 WID updated SP-070933=>SP-080132
- 391: SP#40 completed. Multiple PDN related alignments, 23.060-derived changes.
- 392: CP#43 completed. WID updated CP-080724=>CP-090247. PMIP based S5 interface / Text3: 29.275, 29.282
- 393: CP#42 completed. CP#43 WID updated CP-080724=>CP-090247 / Text3: 29.279
- 394: CP#43 completed / Text3: 24.007, 24.301
- 395: CP#43 completed / Text3: 24.007, 24.301
- 396: CP#43 completed / Text3: 24.008, 24.301
- 397: CP#42 completed. CP#41 updated WID CP-080057=>CP-080576. / Text3: 29.213
- 398: CP#43 completed. WID updated CP-080724=>CP-090247. S6a, S6d, S13, S13' interface / Text3: 29.272

| ID | WBS | Task | Type | Duration | Start | Finish | Complete | Baseline start | Baseline finish | Baseline duration | Constraint | Resources | Work | Actual work | Text1 | Text4 | Text5 | Text6 | Text8 | Text3 | Text7 | Text2 | Text12 |
| --- | --- | --- | --- | --- | --- | --- | --- | --- | --- | --- | --- | --- | --- | --- | --- | --- | --- | --- | --- | --- | --- | --- | --- |
| 399 | 161.4 | **SAE for Interoperation between LTE and legacy cellular PS accesses** |  | 545d? | 2007-02-05 A | 2009-03-06 A | 100% | 2007-02-05 | 2009-03-06 | 545d? |  | S2,C1,C4 | 40152h | 40152h | SAES-SA-FP_3GPP | Motorola | Irfan.Ali@motorola.com | Rel-8 | Maurice |  |  |  |  |
| 400 | 161.4.1 | Stage 2 for Interoperation between LTE and 2G/3G |  | 424d? | 2007-02-05 A | 2008-09-18 A | 100% | 2007-02-05 | 2008-09-18 | 424d? | finish no earlier than 2008-09-11 | S2 | 3392h | 3392h | EPSto2_3G | Motorola | Irfan.Ali@motorola.com | Rel-8 | Maurice | 23.401, 23.402 | SP-37 |  |  |
| 401 | 161.4.2 | Stage 3 for Inter-system mobility between E-UTRAN and 2G/3G |  | 545d? | 2007-02-05 A | 2009-03-06 A | 100% | 2007-02-05 | 2009-03-06 | 545d? | finish no earlier than 2009-03-06 | C1 | 4360h | 4360h | SAES | Nokia Siemens Networks | robert.zaus@nsn.com | Rel-8 | Frederic | 24.008, 24.301 | CP-38 | PCG-21 |  |
| 402 | 161.4.3 | Stage 2 GPRS enhancements for LTE access |  | 272d? | 2007-09-04 A | 2008-09-18 A | 100% | 2007-09-04 | 2008-09-18 | 272d? | start no earlier than 2007-09-04 | S2 | 2176h | 2176h | SAES-GPRS_LTE | Vodafone | chris.pudney@vodafone.com | Rel-8 | Maurice | 23.401 |  |  |  |
| 403 | 161.4.4 | Stage 2 GPRS for EPC (23.060, etc.) |  | 179d? | 2008-01-14 A | 2008-09-18 A | 100% | 2008-01-14 | 2008-09-18 | 179d? | finish no earlier than 2008-09-18 | S2 | 1432h | 1432h | SAES | Nokia Siemens Networks | balazs.bertenyi@nsn.com | Rel-8 | Maurice | 23.060 | SP-39 | PCG-21 |  |
| 404 | 161.4.5 | Stage 3 for EPC - GPRS |  | 545d? | 2007-02-05 A | 2009-03-06 A | 100% | 2007-02-05 | 2009-03-06 | 545d? | finish no earlier than 2009-03-06 | C4 | 4360h | 4360h | SAES | Huawei | shahab.lavasani@huawei.com | Rel-8 | Kimmo | 29.274, 29.275, 29.281 |  |  |  |
| 405 | 161.4.6 | Stage 3 for EPC to UTRAN |  | 545d? | 2007-02-05 A | 2009-03-06 A | 100% | 2007-02-05 | 2009-03-06 | 545d? | finish no earlier than 2009-03-06 | C4 | 4360h | 4360h | SAES | Huawei | shahab.lavasani@huawei.com | Rel-8 | Kimmo | 29.274, 29.275, 29.281 | CP-38 | PCG-21 |  |
| 406 | 161.4.7 | Stage 3 for EPC to 3GPP2 |  | 545d? | 2007-02-05 A | 2009-03-06 A | 100% | 2007-02-05 | 2009-03-06 | 545d? | finish no earlier than 2009-03-06 | C4 | 4360h | 4360h | SAES | Huawei | shahab.lavasani@huawei.com | Rel-8 | Kimmo | 29.277, 29.276 | CP-38 | PCG-21 |  |
| 407 | 161.4.8 | Stage 2 for Interoperation between LTE and CDMA2000 |  | 329d? | 2007-06-18 A | 2008-09-18 A | 100% | 2007-06-18 | 2008-09-18 | 329d? | finish no earlier than 2008-04-25 | S2 | 2632h | 2632h | EPStoC2k | Motorola, Vodafone | Irfan.Ali@motorola.com, chris.pudney@vodafone.com | Rel-8 | Maurice | 23.401, 23.402 | CP-37 |  |  |
| 408 | 161.4.9 | Stage 3 for Inter-system mobility between E-UTRAN and CDMA2000 |  | 545d? | 2007-02-05 A | 2009-03-06 A | 100% | 2007-02-05 | 2009-03-06 | 545d? | finish no earlier than 2009-03-06 | C1 | 4360h | 4360h | SAES | Nokia Siemens Networks | robert.zaus@nsn.com | Rel-8 | Frederic | 24.301, 24.302 |  |  |  |
| 409 | 161.4.10 | Stage 3 for MME - SGSN "signalling free" protocol |  | 545d? | 2007-02-05 A | 2009-03-06 A | 100% | 2007-02-05 | 2009-03-06 | 545d? | finish no earlier than 2009-03-06 | C4 | 4360h | 4360h | SAES | Huawei | shahab.lavasani@huawei.com | Rel-8 | Kimmo | 29.272, 29.274 |  |  |  |
| 410 | 161.5 | **SAE for support for non-3GPP accesses** |  | 569d? | 2007-01-02 A | 2009-03-06 A | 100% | 2007-01-02 | 2009-03-06 | 569d? |  | S2,S3,C1,C4 | 53872h | 53872h | SAES-SA-FP_n3GPP | Motorola | Irfan.Ali@motorola.com | Rel-8 | Maurice |  |  |  |  |
| 411 | 7.2.4.1 | Stage 2 for Host-based Mobility aspects |  | 373d? | 2007-01-02 A | 2008-06-05 A | 100% | 2007-01-02 | 2008-06-05 | 373d? | finish no earlier than 2008-04-11 | S2 | 2984h | 2984h | SAES-SA-FP_n3GPP-HBMob | Motorola | Irfan.Ali@motorola.com | Rel-8 | Maurice | 23.402 |  |  |  |
| 412 | 7.2.4.2 | Stage 2 for Network-based Mobility aspects |  | 448d? | 2007-01-02 A | 2008-09-18 A | 100% | 2007-01-02 | 2008-09-18 | 448d? | finish no earlier than 2008-09-18 | S2 | 3584h | 3584h | SAES-SA-FP_n3GPP-NBMob | Motorola | Irfan.Ali@motorola.com | Rel-8 | Maurice | 23.402 |  |  |  |
| 413 | 161.5.3 | Stage 3 for Mobility management based on DSMIP v6 |  | 480d? | 2007-02-05 A | 2008-12-05 A | 100% | 2007-02-05 | 2008-12-05 | 480d? | finish no earlier than 2008-12-05 | C1 | 3840h | 3840h | SAES | Nokia Siemens Networks | robert.zaus@nsn.com | Rel-8 | Frederic | 24.303 |  |  |  |
| 414 | 161.5.4 | Stage 3 for Mobility management based on MIP v4 |  | 480d? | 2007-02-05 A | 2008-12-05 A | 100% | 2007-02-05 | 2008-12-05 | 480d? | start no earlier than 2007-02-05 | C1 | 3840h | 3840h | SAES | Nokia Siemens Networks | robert.zaus@nsn.com | Rel-8 | Frederic | 24.304 | CP-39 | PCG-21 |  |
| 415 | 161.5.5 | Stage 3 for Inter-system mobility between E-UTRAN and non 3GPP accesses |  | 545d? | 2007-02-05 A | 2009-03-06 A | 100% | 2007-02-05 | 2009-03-06 | 545d? | finish no earlier than 2009-03-06 | C1 | 4360h | 4360h | SAES | Nokia Siemens Networks | robert.zaus@nsn.com | Rel-8 | Frederic | 24.008, 24.301 | CP-38 | PCG-21 |  |
| 416 | 161.5.6 | Stage 2 for Optimized Dual-Radio Handover with WiMAX |  | 249d? | 2007-06-25 A | 2008-06-05 A | 100% | 2007-06-25 | 2008-06-05 | 249d? | finish no earlier than 2008-06-09 | S2 | 1992h | 1992h | SAES-SA-FP_n3GPP-OptWIMAX | Motorola | Irfan.Ali@motorola.com | Rel-8 | Maurice | 23.402 |  |  |  |
| 417 | 161.5.7 | Stage 2 Security aspects for non-3GPP Access |  | 197d? | 2008-03-12 A | 2008-12-11 A | 100% | 2008-03-12 | 2008-12-11 | 197d? | finish no earlier than 2008-12-11 | S3 | 1576h | 1576h | SAES | Nokia Siemens Networks | marc.blommaert.ext@nsn.com | Rel-8 | Dionisio | 33.402, 33.210, 33.310 | SP-39 | PCG-21 |  |
| 418 | 161.5.8 | Stage 3 security aspects for DSMIP v6 Access |  | 480d? | 2007-02-05 A | 2008-12-05 A | 100% | 2007-02-05 | 2008-12-05 | 480d? | finish no earlier than 2008-12-05 | C1 | 3840h | 3840h | SAES | Nokia Siemens Networks | robert.zaus@nsn.com | Rel-8 | Frederic | 24.303 | CP-37 |  |  |
| 419 | 161.5.9 | Stage 3 security aspects for MIPv4 Access |  | 480d? | 2007-02-05 A | 2008-12-05 A | 100% | 2007-02-05 | 2008-12-05 | 480d? | finish no earlier than 2008-12-05 | C1 | 3840h | 3840h | SAES | Nokia Siemens Networks | robert.zaus@nsn.com | Rel-8 | Frederic | 24.304 | CP-39 | PCG-21 |  |
| 420 | 161.5.10 | Stage 3 for Access to the EPC via non-3GPP access networks |  | 545d? | 2007-02-05 A | 2009-03-06 A | 100% | 2007-02-05 | 2009-03-06 | 545d? | finish no earlier than 2009-03-06 | C1 | 4360h | 4360h | SAES | Nokia Siemens Networks | robert.zaus@nsn.com | Rel-8 | Frederic | 24.302, 24.312 |  |  |  |
| 421 | 161.5.11 | Stage 3 for interfaces within EPC |  | 383d? | 2007-09-19 A | 2009-03-06 A | 100% | 2007-09-19 | 2009-03-06 | 383d? | finish no earlier than 2009-03-06 | C4 | 3064h | 3064h | SAES | Huawei | shahab.lavasani@huawei.com | Rel-8 | Kimmo | 29.274, 29.281 | CP-37 |  |  |
| 422 | 161.5.12 | Stage 3 for Interfaces EPC - non-3GPP IP access |  | 545d? | 2007-02-05 A | 2009-03-06 A | 100% | 2007-02-05 | 2009-03-06 | 545d? | finish no earlier than 2009-03-06 | C4 | 4360h | 4360h | SAES | Huawei | shahab.lavasani@huawei.com | Rel-8 | Kimmo | 29.273, 29.275 |  |  |  |
| 423 | 161.5.13 | Stage 3 for AAA/HSS related |  | 480d? | 2007-02-05 A | 2008-12-05 A | 100% | 2007-02-05 | 2008-12-05 | 480d? | finish no earlier than 2008-12-05 | C4 | 3840h | 3840h | SAES | Huawei | shahab.lavasani@huawei.com | Rel-8 | Kimmo | 29.273 |  |  |  |
| 424 | 161.5.14 | Stage 3 for EPC - AAA interface |  | 480d? | 2007-02-05 A | 2008-12-05 A | 100% | 2007-02-05 | 2008-12-05 | 480d? | finish no earlier than 2008-12-05 | C4 | 3840h | 3840h | SAES | Huawei | shahab.lavasani@huawei.com | Rel-8 | Kimmo | 29.273 |  |  |  |
| 425 | 161.5.15 | Deleted (already covered) SAES-SA-FP_n3GPP Optimized Handover with CDMA | milestone | 0d? | 2007-06-25 A | 2007-06-25 A | 100% | 2007-06-25 | 2007-06-25 | 0d? | finish no earlier than 2007-06-25 | S2 |  |  | SAES-SA-FP_n3GPP-OptCDMA | Nokia Siemens Networks |  | Rel-8 | Maurice |  |  |  | SP-37 |

Notes:
- 399: CP#43 completed. SP#39 WID updated SP-070933=>SP-080132
- 400: SP#41 completed
- 401: CP#43 completed
- 402: SP#41 completed. 25/03/08 claimed as SP#34 stopped. Resurrected. WID updated SP-060926 => SP-080132
- 403: SP#41 completed
- 404: CP#43 completed. WID updated CP-080724=>CP-090247
- 405: CP#43 completed. WID updated CP-080724=>CP-090247
- 406: CP#43 completed. WID updated CP-080724=>CP-090247. S101, S103 Interface MME - HRPD access S102, Interface to CDMA2000 1x RTT
- 407: SP#41 completed (except: Handover of multiple PDNs=>Rel-9)
- 408: CP#43 completed
- 409: CP#43 completed. WID updated CP-080724=>CP-090247
- 410: CP#43 completed. SP#39 retained in Rel-8 (in addition to the essential functionality defined in SP-070699). Replaces UID_340037
- 411: SP#40 completed
- 412: SP#41 completed
- 413: CP#41 WID updated CP-080075=>CP-080493. CP#42 completed
- 414: CP#41 WID updated CP-080075=>CP-080493. CP#42 completed
- 415: CP#43 completed
- 416: SP#40 completed
- 417: SP#42 completed. SP#39 WID updated SP-070933=>SP-080132
- 418: CP#42 completed. post-CP#39: split into DSMIP v6 and MIPv4 Access. CP#41 WID updated CP-080075=>CP-080493
- 419: CP#42 completed. post-CP#39: split into DSMIP v6 and MIPv4 Access. UID_390072->390172. CP#41 WID updated CP-080075=>CP-080493
- 420: CP#43 completed
- 421: CP#43 completed. WID updated CP-080724=>CP-090247. S10, S11. GTP based S5 Interface
- 422: CP#43 completed. WID updated CP-080724=>CP-090247. S2a, S2b, SWa, STa, SWn (Untrusted IP access - ePDG) interface
- 423: CP#42 completd. CP#43 WID updated CP-080724=>CP-090247
- 424: CP#42 completd. CP#43 WID updated CP-080724=>CP-090247
- 425: SP#37 stopped

| ID | WBS | Task | Type | Duration | Start | Finish | Complete | Remaining | Baseline start | Baseline finish | Baseline duration | Total slack | Constraint | Resources | Work | Actual work | Text1 | Text4 | Text5 | Text6 | Text8 | Text2 | Text7 | Text9 | Text12 | Text11 |
| --- | --- | --- | --- | --- | --- | --- | --- | --- | --- | --- | --- | --- | --- | --- | --- | --- | --- | --- | --- | --- | --- | --- | --- | --- | --- | --- |
| 426 | 161.6 | **Single Radio Voice Call Continuity for 3GPP (SRVCC)** |  | 569d? | 2007-01-02 A | 2009-03-06 A | 100% |  | 2007-01-02 | 2009-03-06 | 569d? |  |  | S2,C1,C4 | 10752h | 10752h | SAES-SRVCC | Nokia Siemens Networks | curt.c.wong@nokia.com | Rel-8 | Maurice |  |  |  |  |  |
| 427 | 161.6.1 | Stage 2 for 2G/3G SRVCC |  | 448d? | 2007-01-02 A | 2008-09-18 A | 100% |  | 2007-01-02 | 2008-09-18 | 448d? |  | finish no earlier than 2008-09-15 | S2 | 3584h | 3584h | SAES-SRVCC | Nokia Siemens Networks | curt.c.wong@nokia.com | Rel-8 | Maurice |  |  |  |  |  |
| 428 | 161.6.2 | Stage 3 for SRVCC in EPS |  | 201d? | 2008-05-30 A | 2009-03-06 A | 100% |  | 2008-05-30 | 2009-03-06 | 201d? |  | finish no earlier than 2009-03-06 | C1 | 1608h | 1608h | SAES-SRVCC | Nokia Siemens Networks | robert.zaus@nsn.com | Rel-8 | Frederic | PCG-21 | CP-41 |  |  |  |
| 429 | 161.6.3 | MME to MSC interface for SRVCC |  | 126d? | 2008-09-12 A | 2009-03-06 A | 100% |  | 2008-09-12 | 2009-03-06 | 126d? |  | finish no earlier than 2009-03-06 | C4 | 1008h | 1008h | SAES-SRVCC | Nokia Siemens Networks | Giorgi Gulbani | Rel-8 | Kimmo | PCG-21 | CP-41 |  |  |  |
| 430 | 161.7 | Voice Call Continuity for CDMA2000 1X |  | 249d? | 2007-06-25 A | 2008-06-05 A | 100% |  | 2007-06-25 | 2008-06-05 | 249d? |  | finish no earlier than 2008-06-13 | S2 | 1992h | 1992h | SAES-VCC_1X | Nokia Siemens Networks | balazs.bertenyi@nsn.com | Rel-8 | Maurice |  |  |  |  |  |
| 431 | 161.8 | SAE impacts on IMS |  | 373d? | 2007-01-02 A | 2008-06-05 A | 100% |  | 2007-01-02 | 2008-06-05 | 373d? |  | finish no earlier than 2008-06-13 | S2 | 2984h | 2984h | SAES-SA_IMS | Nokia Siemens Networks | balazs.bertenyi@nsn.com | Rel-8 | Maurice |  |  |  |  |  |
| 432 | 161.9 | **CS Fallback in EPS** |  | 258d? | 2008-03-12 A | 2009-03-06 A | 100% |  | 2008-03-12 | 2009-03-06 | 258d? |  |  | S2,C1,C4 | 4800h | 4800h | SAES-CSFB | T-Mobile, Vodafone | sabine.demel@t-mobile.at, chris.pudney@vodafone.com | Rel-8 | Maurice | PCG-21 | SP-39 |  |  |  |
| 433 | 161.9.1 | Stage 2 for CS Fallback in EPS |  | 62d? | 2008-03-12 A | 2008-06-05 A | 100% |  | 2008-03-12 | 2008-06-05 | 62d? |  | finish no earlier than 2008-12-05 | S2 | 496h | 496h | SAES-CSFB | T-Mobile, Vodafone | sabine.demel@t-mobile.at, chris.pudney@vodafone.com | Rel-8 | Maurice | PCG-21 | SP-40 |  |  |  |
| 434 | 161.9.2 | Stage 3 for CS Fallback in EPS |  | 201d? | 2008-05-30 A | 2009-03-06 A | 100% |  | 2008-05-30 | 2009-03-06 | 201d? |  | finish no earlier than 2009-03-06 | C1 | 1608h | 1608h | SAES-CSFB | NEC | yannick.lair@nectech.fr | Rel-8 | Frederic | PCG-21 | CP-40 |  |  |  |
| 435 | 161.9.3 | Stage 3 for CS Fallback in EPS |  | 136d? | 2008-05-30 A | 2008-12-05 A | 100% |  | 2008-05-30 | 2008-12-05 | 136d? |  | finish no earlier than 2008-12-05 | C4 | 1088h | 1088h | SAES-CSFB | NEC | yannick.lair@nectech.fr | Rel-8 | Kimmo | PCG-21 | CP-40 |  |  |  |
| 436 | 161.10 | System enhancements for the use of IMS services in local breakout |  | 62d? | 2008-03-12 A | 2008-06-05 A | 100% |  | 2008-03-12 | 2008-06-05 | 62d? |  | finish no earlier than 2008-06-05 | S2 | 496h | 496h | SAES-IMS_LBO | Telecom Italia | mario.madella@telecomitalia.it | Rel-8 | Maurice | PCG-21 | SP-39 |  |  |  |
| 437 | 161.11 | **EPC Data Definitions** |  | 309d? | 2008-01-07 A | 2009-03-12 A | 100% |  | 2008-01-07 | 2009-03-12 | 309d? |  |  | S5 | 7144h | 7144h | EPC-OAM |  |  | Rel-8 | Dionisio | PCG-21 | SP-39 |  |  |  |
| 438 | 161.11.1 | EPC Network Resource Model (NRM) Integration Reference Point (IRP) |  | 309d? | 2008-01-07 A | 2009-03-12 A | 100% |  | 2008-01-07 | 2009-03-12 | 309d? |  | finish no earlier than 2009-03-12 | S5 | 2472h | 2472h | EPC-OAM | Huawei | WANG, Xuelong | Rel-8 | Dionisio | PCG-21 | SP-38 |  |  |  |
| 439 | 161.11.2 | Performance measurements for EPC |  | 275d? | 2008-02-22 A | 2009-03-12 A | 100% |  | 2008-02-22 | 2009-03-12 | 275d? |  | finish no earlier than 2009-03-12 | S5 | 2200h | 2200h | EPC-OAM | China Mobile | Li Jian, Liang Shuangchun | Rel-8 | Dionisio | PCG-21 | SP-39 |  |  |  |
| 440 | 161.12 | EPC Charging |  | 309d? | 2008-01-07 A | 2009-03-12 A | 100% |  | 2008-01-07 | 2009-03-12 | 309d? |  | finish no earlier than 2009-03-12 | S5 | 2472h | 2472h | EPC-CH | Nokia Siemens Networks | GÖRMER, Gerald | Rel-8 | Dionisio | PCG-21 | SP-38 |  |  |  |
| 441 | 161.13 | Issues for CT1 TR 24.801 |  | 420d? | 2007-01-04 A | 2008-12-05 A | 100% |  | 2007-01-04 | 2008-12-05 | 420d? |  | finish no earlier than 2008-12-05 | C1 | 3360h | 3360h | SAES | Nokia Siemens Networks | robert.zaus@nsn.com | Rel-8 | Frederic | PCG-21 | CP-39 |  |  |  |
| 442 | 161.14 | Issues for CT3 TR 29.804 |  | 420d? | 2007-02-05 A | 2008-09-12 A | 100% |  | 2007-02-05 | 2008-09-12 | 420d? |  | finish no earlier than 2008-12-12 | C3 | 3360h | 3360h | SAES | Ericsson | j.javier.pastor@ericsson.com | Rel-8 | Gwiho | PCG-21 | CP-39 |  |  |  |
| 443 | 161.15 | Deleted - Issues for CT4 TR 29.803 |  | 420d? | 2007-01-04 A | 2008-09-12 A | 100% |  | 2007-01-04 | 2008-09-12 | 420d? |  | finish no earlier than 2008-12-11 | C4 | 3360h | 3360h | SAES | Huawei |  | Rel-8 | Kimmo | PCG-21 | CP-39 | PCG-21 | CP-41 |  |
| 444 | 161.16 | Domain Name System Procedures for Evolved Packet System (DEPS) |  | 179.75d? | 2008-05-30 A | 2009-03-06 A | 100% |  | 2008-05-30 | 2009-03-06 | 179.75d? |  | finish no earlier than 2009-03-06 | C4 | 1438h | 1438h | SAES-DEPS | TeliaSonera | jouni.korhonen@teliasonera.com | Rel-8 | Kimmo | PCG-21 | CP-40 |  |  |  |
| 445 | 161.17 | InterWorking Function (IWF) between MAP based and Diameter based interfaces |  | 126d? | 2008-09-12 A | 2009-03-06 A | 100% |  | 2008-09-12 | 2009-03-06 | 126d? |  | finish no earlier than 2009-03-06 | C4 | 1008h | 1008h | SAES-MAP2Diam | Huawei | liming49985@huawei.com | Rel-8 | Kimmo | PCG-21 | CP-41 |  |  |  |
| 446 | 161.18 | **CT6 aspects of SAE** |  | 527d? | 2008-03-07 A | 2010-03-12 | 80% | 107.02d? | 2008-03-07 | 2010-03-12 | 527d? | 395d |  | C6 | 7872h | 6273.45h | SAES | Nokia | Rune Lindholm | Rel-8 | Xavier | PCG-21 | SP-39 |  |  |  |
| 447 | 161.18.1 | CT6 aspects of SAE |  | 321d? | 2008-03-07 A | 2009-05-29 A | 100% |  | 2008-03-07 | 2009-05-29 | 321d? |  | finish no earlier than 2009-05-29 | C6 | 2568h | 2568h | SAES | Nokia | Rune Lindholm | Rel-8 | Xavier | PCG-21 | CP-39 |  |  |  |
| 448 | 161.18.2 | Test interworking of LTE Terminals with the USIM |  | 331d? | 2008-12-05 A | 2010-03-12 | 60% | 132.4d? | 2008-12-05 | 2010-03-12 | 331d? | 395d | finish no earlier than 2010-03-12 | C6 | 2648h | 1588.8h | SAES-USIM_LTE-Test | Comprion | Udo Willenbrink | Rel-8 | Xavier | PCG-22 | CP-42 |  |  |  |
| 449 | 161.19 | Deleted (covered by 380068): Functions and procedures for SAE to support LCS | milestone | 0d? | 2008-03-03 A | 2008-03-03 A | 100% |  | 2008-03-03 | 2008-03-03 | 0d? |  | finish no earlier than 2008-03-03 | S2 |  |  | SAES-SA-FP_LCS | Nokia Siemens Networks |  | Rel-8 | Maurice |  |  |  | SP-37 |  |
| 450 | 161.20 | Deleted (covered by 380064): SAE aspects of Emergency Calls | milestone | 0d? | 2008-03-03 A | 2008-03-03 A | 100% |  | 2008-03-03 | 2008-03-03 | 0d? |  | start no earlier than 2008-03-03 | S2 |  |  | SAES-SA-EmCall | Nokia Siemens Networks |  | Rel-8 | Maurice |  |  |  | SP-37 |  |
| 451 | 161.21 | Deleted - CT1 aspects of SAES |  | 16.7d? | 2007-09-04 A | 2007-09-27 A | 100% |  | 2007-09-04 | 2007-09-27 | 16.7d? |  | start no earlier than 2007-09-04 | CP,C1 | 133.62h | 133.62h | SAES-St3 |  |  | Rel-8 | Frederic |  |  |  | SP-37 |  |
| 452 | 161.22 | Deleted - CT1 aspects of SAES | milestone | 0d? | 2007-09-04 A | 2007-09-04 A | 100% |  | 2007-09-04 | 2007-09-04 | 0d? |  | start no earlier than 2007-09-04 | C1 |  |  | SAES-St3 |  |  | Rel-8 | Frederic |  |  |  | SP-37 |  |
| 453 | 161.23 | Deleted - Interoperability | milestone | 0d? | 2008-03-14 A | 2008-03-14 A | 100% |  | 2008-03-14 | 2008-03-14 | 0d? |  | start no earlier than 2008-03-14 | C1 |  |  | SAES-St3-interop |  |  | Rel-8 | Frederic |  |  |  | SP-37 |  |
| 454 | 161.24 | Deleted - CT3 aspects of SAES | milestone | 0d? | 2007-09-04 A | 2007-09-04 A | 100% |  | 2007-09-04 | 2007-09-04 | 0d? |  | start no earlier than 2007-09-04 | C3 |  |  | SAES-St3 |  |  | Rel-8 | Gwiho |  |  |  | SP-37 |  |
| 455 | 161.25 | Deleted - CT4 aspects of SAES | milestone | 0d? | 2007-09-04 A | 2007-09-04 A | 100% |  | 2007-09-04 | 2007-09-04 | 0d? |  | start no earlier than 2007-09-04 | C4 |  |  | SAES-St3 |  |  | Rel-8 | Kimmo |  |  |  | SP-37 |  |
| 456 | 161.26 | Deleted - UE to EPC NAS signalling (incl. MBMS and QoS aspects) | milestone | 0d? | 2008-03-14 A | 2008-03-14 A | 100% |  | 2008-03-14 | 2008-03-14 | 0d? |  | start no earlier than 2008-03-14 | C1 |  |  | SAES-St3-sig |  |  | Rel-8 | Frederic |  |  |  | SP-37 |  |
| 457 | 161.27 | Deleted - User and Control plane protocols | milestone | 0d? | 2007-09-21 A | 2007-09-21 A | 100% |  | 2007-09-21 | 2007-09-21 | 0d? |  | start no earlier than 2007-09-21 | C4 |  |  | SAES-St3-prot |  |  | Rel-8 | Kimmo |  |  |  | SP-37 |  |
| 458 | 161.28 | Deleted - Architecture enhancements for non-3GPP accesses | milestone | 0d? | 2007-09-04 A | 2007-09-04 A | 100% |  | 2007-09-04 | 2007-09-04 | 0d? |  | start no earlier than 2007-09-04 | S2 |  |  | SAES-non_3GPP | Motorola | Irfan.Ali@motorola.com | Rel-8 | Maurice |  |  |  | SP-34 |  |
| 459 | 161.29 | Deleted - Stage 2 of architecture for the 3GPP System Architecture Evolution | milestone | 0d? | 2007-10-02 A | 2007-10-02 A | 100% |  | 2007-10-02 | 2007-10-02 | 0d? |  | start no earlier than 2007-10-02 | S2 |  |  | SAES-St2 | Vodafone | chris.pudney@vodafone.com | Rel-8 | Maurice |  |  |  | SP-34 |  |
| 460 | 161.30 | Deleted - SA aspects of System Architecture Evolution |  | 384d? | 2006-04-12 A | 2007-10-01 A | 100% |  | 2006-04-12 | 2007-10-01 | 384d? |  | finish no earlier than 2007-10-02 | S2 | 3072h | 3072h | SAES-SA |  |  | Rel-8 | Maurice |  |  |  | SP-34 |  |
| 461 | 162 | Conformance Test Aspects – Mobility management based on DSMIPv6 (Dual-Stack Mobile IPv6) |  | 196d? | 2009-09-18 A | 2010-06-18 | 20% | 156.8d? | 2009-09-18 | 2010-06-18 | 196d? | 325d | finish no earlier than 2010-06-18 | R5 | 1568h | 313.6h | DSMIPv6_UEConTest | Qualcomm Europe | Lena Chaponniere (lchaponn@qualcomm.com) | Rel-8 | Ingbert | PCG-23 | RP-45 |  |  | RP-091075 |

Notes:
- 426: CP#43 completed. SP#41 Stage 2 completed. SP#38 WID approved (extract from SAE WID SP-070817).
- 427: SP#41 completed. SP#38 WID approved / Text3: 23.216
- 428: CP#43 completed / Text3: 23.009, 24.008, 24.301
- 429: CP#43 completed / Text3: 29.274, 29.277, 23.003, 23.008, 29.280
- 430: SP#40 completed
- 431: SP#40 completed
- 432: CP#43 completed. SP#40 Stage 2 completed.
- 433: SP#40 completed / Text3: 23.272, 23.401
- 434: CP#43 completed / Text3: 24.301, 24.801, 24.007, 24.008, 24.011, 29.018, 29.118 [Mobility Management Entity (MME) – Visitor Location Register (VLR) SGs interface specification]
- 435: CP#42 completed. WID updated CP-080321=>CP-080495=>CP-080791 / Text3: 23.007, 23.008, 29.274, 29.277
- 436: SP#40 completed / Text3: 23.228, 23.221, 23.203
- 437: SP#43 completed
- 438: SP#43 completed / Text3: 32.751, 32.752, 32.753, 32.755
- 439: SP#43 completed / Text3: 32.426
- 440: SP#43 completed / Text3: 32.240/296/251/252/298/299
- 441: CP#43 completed / Text3: 24.801
- 442: CP#41 completed / Text3: 29.804
- 443: CP#41 Work stopped and continued in Normative specifications / Text3: 29.803
- 444: CP#43 completed / Text3: 23.003, 29.303
- 445: CP#43 completed. Triggered by UID_380023 (FS_MAP2Diam) / Text3: 29.305
- 446: CP#44 completed core specification. Testing ongoing
- 447: CP#44 completed (Network Measurement Results collection via USAT are now specified) / Text3: 31.102, 31.111
- 448: CP#45 WID updated CP-080899=>CP-090711. Completion 09/09=>03/10. Testing for UID_390021 (BB: Rel-8 CT6 aspects of SAE) / Text3: 31.121, 31.124
- 449: SP#37 stopped
- 450: SP#37 stopped
- 451: SP#37 stopped
- 452: SP#37 stopped
- 453: SP#37 stopped
- 454: SP#37 stopped
- 455: SP#37 stopped / Text3: 29.803
- 456: SP#37 stopped
- 457: SP#37 stopped
- 458: SP#34 stopped. Replaced by UID_350027 and its children / Text3: 23.402
- 459: SP#34 stopped. Replaced by UIDs 340018 and 340037. (SP#34 report discussion of SP-060917.) / Text3: 23.002, 23.060, 23.107, 23.203, 23.228, 23.234, 23.246, 23.271, 23.279
- 460: SP#34 stopped
- 461: Testing for CT1's UID_360022 (24.303) under Rel-8 Feature SAES / Text3: 36.508, 36.523-1, 36.523-2, 36.523-3

| ID | WBS | Task | Duration | Start | Finish | Complete | Baseline start | Baseline finish | Baseline duration | Constraint | Resources | Work | Actual work | Text1 | Text4 | Text5 | Text6 | Text7 | Text8 | Text2 | Text9 | Text12 |
| --- | --- | --- | --- | --- | --- | --- | --- | --- | --- | --- | --- | --- | --- | --- | --- | --- | --- | --- | --- | --- | --- | --- |
| 462 | 163 | **IMS Centralized Service Control (ICSRA)** | 395d? | 2007-09-03 A | 2009-03-06 A | 100% | 2007-09-03 | 2009-03-06 | 395d? |  | S1,S2,C1,C3,C4 | 10680h | 10680h | ICSRA | AT&T | Randolph Wohlert (rwohlert@tri.sbc.com) | Rel-8 | SP-37 | Alain |  |  |  |
| 463 | 163.1 | Stage 1 for ICSRA | 138d? | 2007-09-03 A | 2008-03-12 A | 100% | 2007-09-03 | 2008-03-12 | 138d? | finish no earlier than 2007-12-14 | S1 | 1104h | 1104h | ICSRA | AT&T | Randolph Wohlert (rwohlert@tri.sbc.com) | Rel-8 | SP-38 | Alain | PCG-21 |  |  |
| 464 | 163.2 | Stage 2 for ICSRA | 125d? | 2007-12-14 A | 2008-06-05 A | 100% | 2007-12-14 | 2008-06-05 | 125d? | start no earlier than 2007-12-14 | S2 | 1000h | 1000h | ICSRA-St2 | Alcatel-Lucent |  | Rel-8 | SP-38 | Maurice | PCG-21 |  |  |
| 465 | 163.3 | **Stage 3 for ICSRA – Protocol, Addressing, Subscriber Data** | 201d? | 2008-05-30 A | 2009-03-06 A | 100% | 2008-05-30 | 2009-03-06 | 201d? |  | C1,C3,C4 | 6520h | 6520h | ICSRA | Ericsson | Sean Schneyer | Rel-8 |  |  |  |  |  |
| 466 | 163.3.1 | CT1 aspects - Stage 3 for ICSRA | 201d? | 2008-05-30 A | 2009-03-06 A | 100% | 2008-05-30 | 2009-03-06 | 201d? | finish no earlier than 2009-03-06 | C1 | 1608h | 1608h | ICSRA | Ericsson | Sean Schneyer | Rel-8 | CP-40 | Frederic | PCG-21 |  |  |
| 467 | 163.3.2 | CT3 aspects - Stage 3 for ICSRA | 201d? | 2008-05-30 A | 2009-03-06 A | 100% | 2008-05-30 | 2009-03-06 | 201d? | finish no earlier than 2009-03-06 | C3 | 1608h | 1608h | ICSRA | Mavenir | Brett Wallis | Rel-8 | CP-40 | Gwiho | PCG-21 |  |  |
| 468 | 163.3.3 | CT4 aspects - Stage 3 for ICSRA | 136d? | 2008-05-30 A | 2008-12-05 A | 100% | 2008-05-30 | 2008-12-05 | 136d? | start no earlier than 2008-05-30 | C4 | 1088h | 1088h | ICSRA | Ericsson | Sean Schneyer | Rel-8 | CP-40 | Kimmo | PCG-21 |  |  |
| 469 | 163.3.4 | Deleted - Stage 3 for ICSRA – I1 interface | 76d? | 2008-05-30 A | 2008-09-12 A | 100% | 2008-05-30 | 2008-09-12 | 76d? | finish no earlier than 2008-09-12 | C1 | 608h | 608h | ICSRA | Huawei | xupeili@huawei.com | Rel-8 | CP-40 | Frederic | PCG-21 | PCG-21 | CP-41 |
| 470 | 164 | **IMS Multimedia Telephony and Supplementary Services** | 487d? | 2007-05-02 A | 2009-03-12 A | 100% | 2007-05-02 | 2009-03-12 | 487d? |  | S1,S5,C1,C3,C4 | 46006.4h | 46006.4h | IMSTSS |  |  | Rel-8 | SP-37 | Alain |  |  |  |
| 471 | 164.1 | **General aspects of IMS Sup Services** | 395d? | 2007-09-03 A | 2009-03-06 A | 100% | 2007-09-03 | 2009-03-06 | 395d? |  | S1,C1,C3,C4 | 9752h | 9752h | IMSSS-Gal | Ericsson | Susana Sabater | Rel-8 | SP-37 | Alain |  |  |  |
| 472 | 164.1.1 | Service and Capability for Core IMS - inclusion of TISPAN requirements | 75d? | 2007-09-03 A | 2007-12-14 A | 100% | 2007-09-03 | 2007-12-14 | 75d? | finish no earlier than 2007-12-14 | S1 | 600h | 600h | TISCAPR8 | Ericsson | Susana Sabater | Rel-8 | SP-37 | Alain |  |  |  |
| 473 | 164.1.2 | Documentation of TISPAN R1 and R2 in CT1 | 208d? | 2007-11-28 A | 2008-09-12 A | 100% | 2007-11-28 | 2008-09-12 | 208d? | finish no earlier than 2008-09-12 | C1 | 1664h | 1664h | REDOC_TIS-C1 | Nokia Siemens Networks | peter.leis@nsn.com | Rel-8 | CP-38 | Frederic | PCG-21 |  |  |
| 474 | 164.1.3 | Documentation of TISPAN R1 and R2 in CT3 | 333d? | 2007-11-28 A | 2009-03-06 A | 100% | 2007-11-28 | 2009-03-06 | 333d? | finish no earlier than 2009-03-06 | C3 | 2664h | 2664h | REDOC_TIS-C3 | Nokia Siemens Networks | peter.leis@nsn.com | Rel-8 | CP-38 | Gwiho | PCG-21 |  |  |
| 475 | 164.1.4 | Documentation of TISPAN R1 and R2 in CT4 | 208d? | 2007-11-28 A | 2008-09-12 A | 100% | 2007-11-28 | 2008-09-12 | 208d? | finish no earlier than 2008-09-12 | C4 | 1664h | 1664h | REDOC_TIS-C4 | Nokia Siemens Networks | peter.leis@nsn.com | Rel-8 | CP-38 | Kimmo | PCG-21 |  |  |
| 476 | 164.2 | **IMS Multimedia Telephony Service** | 394d? | 2007-09-10 A | 2009-03-12 A | 100% | 2007-09-10 | 2009-03-12 | 394d? |  | S1,S5 | 5096h | 5096h | IMS-MMTel |  |  | Rel-8 | SP-37 | Alain |  |  |  |
| 477 | 164.2.1 | Merging TISPAN MMTel [requirements] for Common IMS | 65d? | 2007-09-10 A | 2007-12-07 A | 100% | 2007-09-10 | 2007-12-07 | 65d? | finish no earlier than 2007-12-07 | S1 | 520h | 520h | TMMTEL | Nokia Siemens Networks |  | Rel-8 | SP-37 | Alain |  |  |  |
| 478 | 164.2.2 | Multimedia Telephony Service and Supplementary Services (MMTel) offline Charging | 309d? | 2008-01-07 A | 2009-03-12 A | 100% | 2008-01-07 | 2009-03-12 | 309d? | finish no earlier than 2009-03-12 | S5 | 2472h | 2472h | MMTel-CH | Alcatel-Lucent | GARDELLA, Maryse | Rel-8 | SP-38 | Dionisio | PCG-21 |  |  |
| 479 | 164.3 | **Call Completion on Busy Subscriber (CCBS)/Call Completion on Non-Reachable (CCNR) on IMS** | 483d? | 2007-05-02 A | 2009-03-06 A | 100% | 2007-05-02 | 2009-03-06 | 483d? |  | C1,C3 | 11072h | 11072h | CCBS_CCNR | Deutsche Telekom | martin.huelsemann@telekom.de | Rel-8 | SP-38 | Frederic | PCG-21 |  |  |
| 480 | 164.3.1 | Stage 3 CCBS_CCNR | 483d? | 2007-05-02 A | 2009-03-06 A | 100% | 2007-05-02 | 2009-03-06 | 483d? | finish no earlier than 2009-03-06 | C1 | 3864h | 3864h | CCBS_CCNR | Deutsche Telekom | martin.huelsemann@telekom.de | Rel-8 | CP-38 | Frederic | PCG-21 |  |  |
| 481 | 164.3.2 | Stage 3 CCBS_CCNR | 418d? | 2007-05-02 A | 2008-12-05 A | 100% | 2007-05-02 | 2008-12-05 | 418d? | finish no earlier than 2008-12-05 | C3 | 3344h | 3344h | CCBS_CCNR | Deutsche Telekom | martin.huelsemann@telekom.de | Rel-8 | CP-38 | Gwiho | PCG-21 |  |  |
| 482 | 164.4 | **Flexible Alerting** | 288d? | 2008-01-30 A | 2009-03-06 A | 100% | 2008-01-30 | 2009-03-06 | 288d? |  | S1,C1 | 5278.4h | 5278.4h | FA | Nortel | milanpa@nortel.com | Rel-8 | SP-39 | Alain | PCG-21 |  |  |
| 483 | 164.4.1 | Stage 1 FA | 92d? | 2008-01-30 A | 2008-06-05 A | 100% | 2008-01-30 | 2008-06-05 | 92d? |  | S1 | 670.4h | 670.4h | FA | Telecom Italia |  | Rel-8 | SP-39 | Alain | PCG-21 |  |  |
| 484 | 164.4.2 | Stage 3 FA | 288d? | 2008-01-30 A | 2009-03-06 A | 100% | 2008-01-30 | 2009-03-06 | 288d? | finish no earlier than 2009-03-06 | C1 | 2304h | 2304h | FA | Nortel | milanpa@nortel.com | Rel-8 | CP-39 | Frederic | PCG-21 |  |  |
| 485 | 164.5 | **Communication Wait on IMS** | 331d? | 2007-11-30 A | 2009-03-06 A | 100% | 2007-11-30 | 2009-03-06 | 331d? |  | C1,C3 | 7416h | 7416h | CW_IMS | Deutsche Telekom | martin.huelsemann@telekom.de | Rel-8 | SP-38 | Frederic | PCG-21 |  |  |
| 486 | 164.5.1 | Stage 3 CW-IMS | 331d? | 2007-11-30 A | 2009-03-06 A | 100% | 2007-11-30 | 2009-03-06 | 331d? | finish no earlier than 2009-03-06 | C1 | 2648h | 2648h | CW_IMS | Deutsche Telekom | martin.huelsemann@telekom.de | Rel-8 | CP-38 | Frederic | PCG-21 |  |  |
| 487 | 164.5.2 | Stage 3 CW-IMS | 265d? | 2007-11-30 A | 2008-12-04 A | 100% | 2007-11-30 | 2008-12-04 | 265d? | finish no earlier than 2008-12-05 | C3 | 2120h | 2120h | CW_IMS | Deutsche Telekom | martin.huelsemann@telekom.de | Rel-8 | CP-38 | Gwiho | PCG-21 |  |  |
| 488 | 164.6 | Advice of Charge (AoC) support in IMS Charging | 309d? | 2008-01-07 A | 2009-03-12 A | 100% | 2008-01-07 | 2009-03-12 | 309d? | finish no earlier than 2009-03-12 | S5 | 2472h | 2472h | IMSTSS | Nokia Siemens Networks | GÖRMER, Gerald | Rel-8 | SP-38 | Dionisio | PCG-21 |  |  |
| 489 | 164.7 | Add Interconnection Border Control Function (IBCF) to IMS Charging | 128d? | 2007-09-17 A | 2008-03-12 A | 100% | 2007-09-17 | 2008-03-12 | 128d? | finish no earlier than 2008-03-12 | S5 | 1024h | 1024h | IMSTSS | Alcatel-Lucent | GARDELLA, Maryse | Rel-8 | SP-37 | Dionisio |  |  |  |

Notes:
- 462: CP#46 WID updated CP-080492=>CP-091046. Approved new TS 24.286. SP#40 SA1/2 completed
- 463: SP#38 WID approved. SP#39 completed / Text3: 22.101
- 464: SP#38 WID approved. SP#40 completed / Text3: 23.292, 23.206
- 465: CP#46 WID updated CP-080492=>CP-091046. Approved new TS 24.286
- 466: CP#46 WID updated CP-080492=>CP-091046. Approved new TS 24.286 / Text3: 24.229, new (24.292, 24.286)
- 467: CP#43 completed / Text3: new 29.292
- 468: CP#42 completed / Text3: 23.003, 29.232, 23.018, 29.002
- 469: 23/07/08 Line created at CT1 Zagreb request. CP#41 WID updated CP-080319=>CP-080492. CP#41 work stopped / Text3: 24.293
- 470: SP#43 completed
- 471: CP#43 completed
- 472: SP#39 completed / Text3: 22.228, 22.115, 22.101
- 473: CP#41 completed / Text3: 24.141, 24.147, 24.173, 24.229, 24.247, 24.341, 24.604, 24.605, 24.606, 24.607, 24.608, 24.610, 24.611, 24.616, 24.623, 24.628, 24.629, 24.647, 24.654
- 474: CP#43 completed. CP#46 withdrawn 29.612 from Rel-9 onwards / Text3: 29.162, 29.163, 29.658
- 475: CP#41 completed / Text3: 29.228, 29.229
- 476: SP#43 completed
- 477: SP#38 completed / Text3: 22.173
- 478: CP#43 completed / Text3: 32.275, 32.298/299
- 479: CP#43 completed
- 480: CP#43 completed / Text3: 24.642, 24.229, 24.173
- 481: CP#42 completed / Text3: 29.163
- 482: CP#43 completed
- 483: SP#40 completed / Text3: 22.173
- 484: CP#43 completed / Text3: 24.239, 24.173
- 485: CP#43 completed
- 486: CP#43 completed / Text3: 24.615, 24.229, 24.173
- 487: CP#42 completed / Text3: 29.163
- 488: SP#43 completed / Text3: 32.280, 32.240/260/296/298/299
- 489: SP#39 completed / Text3: 32.260, 32.298

| ID | WBS | Task | Duration | Start | Finish | Complete | Remaining | Baseline start | Baseline finish | Baseline duration | Total slack | Constraint | Resources | Work | Actual work | Text1 | Text2 | Text4 | Text5 | Text6 | Text7 | Text8 |
| --- | --- | --- | --- | --- | --- | --- | --- | --- | --- | --- | --- | --- | --- | --- | --- | --- | --- | --- | --- | --- | --- | --- |
| 490 | 165 | **3GPP2 Input to Common IMS** | 200d? | 2008-03-07 A | 2008-12-11 A | 100% |  | 2008-03-07 | 2008-12-11 | 200d? |  |  | S1,S2,S3,C1,C3,C4 | 8653.2h | 8653.2h | CIMS_3GPP2 | PCG-21 | Nortel | Amar Deol (deola@nortelnetworks.com) | Rel-8 | SP-39 | Alain |
| 491 | 165.1 | Stage 1 CIMS_3GPP2 (SA1) | 30.65d? | 2008-03-12 A | 2008-06-05 A | 100% |  | 2008-03-12 | 2008-06-05 | 30.65d? |  | finish no earlier than 2008-06-12 | S1 | 245.2h | 245.2h | CIMS_3GPP2 | PCG-21 | Nortel | Amar Deol (deola@nortelnetworks.com) | Rel-8 | SP-39 | Alain |
| 492 | 165.2 | Stage 2 CIMS_3GPP2 (SA2) | 62d? | 2008-03-12 A | 2008-06-05 A | 100% |  | 2008-03-12 | 2008-06-05 | 62d? |  | finish no earlier than 2008-09-11 | S2 | 496h | 496h | IMS_Common | PCG-21 | Nortel | Amar Deol (deola@nortelnetworks.com) | Rel-8 | SP-39 | Maurice |
| 493 | 165.3 | Security CIMS_3GPP2 (SA3) | 197d? | 2008-03-12 A | 2008-12-11 A | 100% |  | 2008-03-12 | 2008-12-11 | 197d? |  | finish no earlier than 2008-12-11 | S3 | 1576h | 1576h | IMS_Common | PCG-21 | Nortel | Amar Deol (deola@nortelnetworks.com) | Rel-8 | SP-39 | Dionisio |
| 494 | 165.4 | Stage 3 CIMS_3GPP2 (CT1) | 196d? | 2008-03-07 A | 2008-12-05 A | 100% |  | 2008-03-07 | 2008-12-05 | 196d? |  | finish no earlier than 2008-12-11 | C1 | 1568h | 1568h | REDOC_3GPP2 | PCG-21 | Alcatel-Lucent | orsic@alcatel-lucent.com | Rel-8 | CP-39 | Frederic |
| 495 | 165.5 | Stage 3 CIMS_3GPP2 (CT3) | 196d? | 2008-03-07 A | 2008-12-05 A | 100% |  | 2008-03-07 | 2008-12-05 | 196d? |  | finish no earlier than 2008-12-05 | C3 | 1568h | 1568h | REDOC_3GPP2 | PCG-21 | Alcatel-Lucent | orsic@alcatel-lucent.com | Rel-8 | CP-39 | Gwiho |
| 496 | 165.6 | Stage 3 CIMS_3GPP2 (CT4) | 200d? | 2008-03-07 A | 2008-12-11 A | 100% |  | 2008-03-07 | 2008-12-11 | 200d? |  | finish no earlier than 2008-12-11 | C4 | 1600h | 1600h | REDOC_3GPP2 | PCG-21 | Alcatel-Lucent | orsic@alcatel-lucent.com | Rel-8 | CP-39 | Kimmo |
| 497 | 166 | **IMS Enhancements for support of Packet Cable access** | 388d? | 2006-12-06 A | 2008-05-30 A | 100% |  | 2006-12-06 | 2008-05-30 | 388d? |  |  | S2,S3,C1,C3,C4 | 27448h | 27448h | PktCbl |  | Cablelabs | Bernie McKibben | Rel-8 |  | Maurice |
| 498 | 166.1 | **IMS Enhancements for Cable Client Types and Deployment Models** | 345d? | 2007-02-05 A | 2008-05-30 A | 100% |  | 2007-02-05 | 2008-05-30 | 345d? |  |  | S2,C1 | 6992h | 6992h | PktCbl-Deploy |  | Cablelabs | Bernie McKibben | Rel-8 |  | Maurice |
| 499 | 166.1.1 | Architecture aspects of PktCbl-Deploy | 219d? | 2007-02-05 A | 2007-12-06 A | 100% |  | 2007-02-05 | 2007-12-06 | 219d? |  | finish no earlier than 2007-12-03 | S2 | 1752h | 1752h | PktCbl-Deploy |  | Cablelabs | Bernie McKibben | Rel-8 |  | Maurice |
| 500 | 166.1.2 | CT1 aspects of PktCbl-Deploy | 310d? | 2007-03-26 A | 2008-05-30 A | 100% |  | 2007-03-26 | 2008-05-30 | 310d? |  | finish no earlier than 2008-06-15 | C1 | 2480h | 2480h | PktCbl-Deploy |  | Cablelabs | D.Hancock@ CableLabs.com | Rel-8 |  | Frederic |
| 501 | 166.2 | **IMS Inter-working aspects in Support of Cable Regulatory requirements** | 290d? | 2007-02-05 A | 2008-03-14 A | 100% |  | 2007-02-05 | 2008-03-14 | 290d? |  |  | S2,C1,C3 | 5640h | 5640h | PktCbl-Intw |  | Cablelabs | B.McKibben@CableLabs.com | Rel-8 |  | Maurice |
| 502 | 166.2.1 | Architecture PktCbl-Interwork | 160d? | 2007-02-05 A | 2007-09-14 A | 100% |  | 2007-02-05 | 2007-09-14 | 160d? |  | start no earlier than 2007-02-05 | S2 | 1280h | 1280h | PktCbl-Intw |  | Cablelabs | B.McKibben@CableLabs.com | Rel-8 |  | Maurice |
| 503 | 166.2.2 | CT1,CT3 PktCbl-Interwork | 255d? | 2007-03-26 A | 2008-03-14 A | 100% |  | 2007-03-26 | 2008-03-14 | 255d? |  | finish no earlier than 2008-03-15 | C1,C3 | 2040h | 2040h | PktCbl-Intw |  | Cablelabs | D.Hancock@ CableLabs.com | Rel-8 |  | Frederic |
| 504 | 166.3 | **IMS Enhancements for Security Requirements in Support of Cable Deployments** | 388d? | 2006-12-06 A | 2008-05-30 A | 100% |  | 2006-12-06 | 2008-05-30 | 388d? |  |  | S3,C1,C3,C4 | 11712h | 11712h | PktCbl-Sec |  | Cablelabs | s.dotson@cablelabs.com | Rel-8 |  | Dionisio |
| 505 | 166.3.1 | SA3 Aspects of PktCbl-Sec | 331d? | 2006-12-06 A | 2008-03-12 A | 100% |  | 2006-12-06 | 2008-03-12 | 331d? |  | finish no earlier than 2007-12-20 | S3 | 2648h | 2648h | PktCbl-Sec |  | Cablelabs | s.dotson@cablelabs.com | Rel-8 |  | Dionisio |
| 506 | 166.3.2 | CT1 Aspects of PktCbl-Sec | 310d? | 2007-03-26 A | 2008-05-30 A | 100% |  | 2007-03-26 | 2008-05-30 | 310d? |  | finish no earlier than 2008-06-06 | C1 | 2480h | 2480h | PktCbl-Sec |  | Cablelabs | D.Hancock@ CableLabs.com | Rel-8 |  | Frederic |
| 507 | 166.3.3 | CT3 Aspects of PktCbl-Sec | 180d? | 2007-03-26 A | 2007-11-30 A | 100% |  | 2007-03-26 | 2007-11-30 | 180d? |  | finish no earlier than 2008-03-15 | C3 | 1440h | 1440h | PktCbl-Intw | PCG-21 | Cablelabs | D.Hancock@ CableLabs.com | Rel-8 | CP-38 | Gwiho |
| 508 | 166.3.4 | CT4 Aspects of PktCbl-Sec | 255d? | 2007-03-26 A | 2008-03-14 A | 100% |  | 2007-03-26 | 2008-03-14 | 255d? |  | finish no earlier than 2008-03-14 | C4 | 2040h | 2040h | PktCbl-Sec |  | Cablelabs | D.Hancock@ CableLabs.com | Rel-8 |  | Kimmo |
| 509 | 167 | **IMS System enhancements for corporate network access** | 717d? | 2007-06-22 A | 2010-03-19 | 99% | 7.09d? | 2007-06-22 | 2010-03-19 | 717d? | 390d |  | S2,S1,C1,C4 | 14336.9h | 14195.3h | IMS_Corp |  | Orange | Delphin Barankanira | Rel-8 |  | Maurice |
| 510 | 167.1 | SA1 aspects of IMS_Corp | 23.6d? | 2008-03-12 A | 2008-06-05 A | 100% |  | 2008-03-12 | 2008-06-05 | 23.6d? |  | finish no earlier than 2008-06-05 | S1 | 188.8h | 188.8h | IMS_Corp | PCG-21 | Telecom Italia |  | Rel-8 | SP-39 | Alain |
| 511 | 167.2 | SA2 aspects of IMS_Corp | 325d? | 2007-06-22 A | 2008-09-18 A | 100% |  | 2007-06-22 | 2008-09-18 | 325d? |  | finish no earlier than 2008-12-25 | S2 | 2600h | 2600h | IMS_Corp |  | Orange | Delphin Barankanira | Rel-8 |  | Maurice |
| 512 | 167.3 | CT1 aspects of IMS_Corp | 532d? | 2008-03-07 A | 2010-03-19 | 98% | 10.64d? | 2008-03-07 | 2010-03-19 | 532d? | 390d | finish no earlier than 2010-03-19 | C1 | 4244.09h | 4159.21h | IMS_Corp | PCG-21 | Alcatel-Lucent | Keith Drage (drage@alcatel-lucent.com) | Rel-8 | CP-39 | Frederic |
| 513 | 167.4 | CT4 aspects of IMS_Corp | 196d? | 2008-02-26 A | 2008-12-05 A | 100% |  | 2008-02-26 | 2008-12-05 | 196d? |  | finish no earlier than 2008-12-11 | C4 | 1568h | 1568h | IMS_Corp | PCG-21 | Alcatel-Lucent | Keith Drage (drage@alcatel-lucent.com) | Rel-8 | CP-39 | Kimmo |

Notes:
- 490: TSG#42 completed
- 491: SP#40 completed / Text3: 22.228, 22.173, 22.101, 22.153
- 492: SP#40 completed / Text3: 23.002, 23.141, 23.203, 23.167, 23.228
- 493: SP#42 completed [issues addressed under UID_370078 (IMS-Sec)] / Text3: 33.141, 33.203, 33.210
- 494: CP#42 completed. WID updated CP-080218=>CP-080494=>CP-080795 / Text3: 23.218, 24.141, 24.147, 24.173, 24.229, 24.238, 24.247, 24.604, 24.605, 24.606, 24.607, 24.608, 24.610, 24.611, 24.629, 24.930
- 495: CP#42 completed. WID updated CP-080218=>CP-080494=>CP-080795 / Text3: 29.163, 29.212, 29.213, 29.214
- 496: CP#42 completed. WID updated CP-080218=>CP-080494=>CP-080795 / Text3: 29.228, 29.229, 29.328, 29.329
- 497: CP#40 completed
- 498: CP#40 completed
- 499: SP#38 completed / Text3: 23.228
- 500: CP#40 completed
- 501: CP#39 completed
- 502: SP#37 completed / Text3: 23.228
- 503: CP#39 completed / Text3: 24.229
- 504: CP#40 completed
- 505: SP#39 completed / Text3: 33.203, 33.210, 33.220
- 506: CP#40 completed / Text3: 24.229
- 507: CP#38 completed / Text3: 29.163
- 508: CP#39 completed / Text3: 29.228, 29.229, 23.008
- 509: CP#45 still some unresolved issue. SP#41 no Stage 2 impacts identified by Joint Workshop
- 510: SP#40 completed
- 511: SP#41 completed / Text3: 23.228
- 512: CP#46 still some unresolved issue / Text3: 24.229, 24.503
- 513: CP#42 completed / Text3: 29.228, 29.229, 23.003, 23.008, 29.433

| ID | WBS | Task | Duration | Start | Finish | Complete | Baseline start | Baseline finish | Baseline duration | Constraint | Resources | Work | Actual work | Text1 | Text2 | Text6 | Text7 | Text8 | Text4 | Text5 |
| --- | --- | --- | --- | --- | --- | --- | --- | --- | --- | --- | --- | --- | --- | --- | --- | --- | --- | --- | --- | --- |
| 514 | 168 | **Maintenance of TISPAN documentation** | 244d? | 2007-07-02 A | 2008-06-05 A | 100% | 2007-07-02 | 2008-06-05 | 244d? |  | S2,C1,C3,C4 | 5984h | 5984h | MAINTISP | PCG-21 | Rel-8 | SP-38 | Maurice |  |  |
| 515 | 168.1 | Maintenance of TISPAN R1 | 86d? | 2007-11-09 A | 2008-03-07 A | 100% | 2007-11-09 | 2008-03-07 | 86d? | start no earlier than 2007-11-09 | C1,C3,C4 | 688h | 688h | MAINT_R1 | PCG-21 | Rel-7 | CP-38 | Frederic | Alcatel-Lucent | Keith Drage (drage@alcatel-lucent.com) |
| 516 | 168.2 | Maintenance of TISPAN R2 | 86d? | 2007-11-09 A | 2008-03-07 A | 100% | 2007-11-09 | 2008-03-07 | 86d? | start no earlier than 2007-11-09 | C1,C3,C4 | 688h | 688h | MAINT_R2 | PCG-21 | Rel-8 | CP-38 | Frederic | Alcatel-Lucent | Keith Drage (drage@alcatel-lucent.com) |
| 517 | 168.3 | Documentation of TISPAN NGN R1 and R2 in 3GPP SA2 | 104d? | 2008-01-14 A | 2008-06-05 A | 100% | 2008-01-14 | 2008-06-05 | 104d? | finish no earlier than 2008-06-20 | S2 | 832h | 832h | IMS_Comm_Doc | PCG-21 | Rel-8 | SP-38 | Maurice | Nokia Siemens Networks | jozsef.varga@nsn.com |
| 518 | 168.4 | Maintenance of TISPAN release 1 common IMS | 114d? | 2007-07-02 A | 2007-12-06 A | 100% | 2007-07-02 | 2007-12-06 | 114d? | finish no earlier than 2007-12-06 | S2,S1 | 912h | 912h | IMS_Comm_Mtce7 | PCG-21 | Rel-7 | SP-38 | Maurice | BT, Ericsson | Dick Knight, Raymond Forbes |
| 519 | 168.5 | Maintenance of TISPAN release 2 common IMS | 114d? | 2007-07-02 A | 2007-12-06 A | 100% | 2007-07-02 | 2007-12-06 | 114d? | finish no earlier than 2007-12-06 | S2 | 912h | 912h | IMS_Comm_Mtce8 | PCG-21 | Rel-8 | SP-38 | Maurice | Telecom Italia | antonio.ascolese@telecomitalia.it |
| 520 | 169 | **IMS Service Continuity** | 318d? | 2008-03-12 A | 2009-05-29 A | 100% | 2008-03-12 | 2009-05-29 | 318d? |  | S2,S1,C1 | 5624h | 5624h | IMS-Cont | PCG-21 | Rel-8 | SP-39 | Maurice | LG Electronics | JaeSeung SONG (anthonys@lge.com) |
| 521 | 169.1 | Stage 1 IMS Service Continuity | 62d? | 2008-03-12 A | 2008-06-05 A | 100% | 2008-03-12 | 2008-06-05 | 62d? | start no earlier than 2008-03-12 | S1 | 496h | 496h | IMS-Cont | PCG-21 | Rel-8 | SP-39 | Alain | LG Electronics | JaeSeung SONG (anthonys@lge.com) |
| 522 | 169.2 | Stage 2 IMS Service Continuity | 62d? | 2008-03-12 A | 2008-06-05 A | 100% | 2008-03-12 | 2008-06-05 | 62d? | finish no earlier than 2008-06-05 | S2 | 496h | 496h | IMS-Cont | PCG-21 | Rel-8 | SP-39 | Maurice | LG Electronics | JaeSeung SONG (anthonys@lge.com) |
| 523 | 169.3 | Stage 3 IMS Service Continuity | 261d? | 2008-05-30 A | 2009-05-29 A | 100% | 2008-05-30 | 2009-05-29 | 261d? | finish no earlier than 2009-05-29 | C1 | 2088h | 2088h | IMS-Cont | PCG-21 | Rel-8 | CP-40 | Frederic | Huawei | Lili Yang (kadyyang@huawei.com) |
| 524 | 170 | **Security Enhancements for IMS** | 643.3d? | 2006-09-19 A | 2009-03-06 A | 100% | 2006-09-19 | 2009-03-06 | 643.3d? |  | S3,C1,C4 | 18624h | 18624h | IMS-Sec |  | Rel-8 | SP-37 | Dionisio | Ericsson | Bengt.Sahlin@ericsson.com |
| 525 | 170.1 | Stage 2 for IMS-Sec | 466d? | 2007-03-01 A | 2008-12-11 A | 100% | 2007-03-01 | 2008-12-11 | 466d? | finish no earlier than 2008-12-11 | S3 | 3728h | 3728h | IMS-Sec |  | Rel-8 |  | Dionisio | Ericsson | Bengt.Sahlin@ericsson.com |
| 526 | 170.2 | CT1 part of Stage 3 for IMS-Sec | 392d? | 2006-09-19 A | 2008-12-05 A | 100% | 2006-09-19 | 2008-12-05 | 392d? | finish no earlier than 2008-12-05 | C1 | 3136h | 3136h | IMS-Sec | PCG-21 | Rel-8 | CP-39 | Frederic | Ericsson |  |
| 527 | 170.3 | CT4 part of Stage 3 for IMS-Sec | 457d? | 2007-06-07 A | 2009-03-06 A | 100% | 2007-06-07 | 2009-03-06 | 457d? | finish no earlier than 2009-03-06 | C4 | 3656h | 3656h | IMS-Sec | PCG-21 | Rel-8 | CP-39 | Kimmo | Ericsson |  |
| 528 | 170.4 | CT1 part of NASS Bundled Authentication | 343d? | 2007-11-14 A | 2009-03-06 A | 100% | 2007-11-14 | 2009-03-06 | 343d? | finish no earlier than 2009-03-06 | C1 | 2744h | 2744h | NBA | PCG-21 | Rel-8 | CP-39 | Frederic | Alcatel-Lucent | Keith Drage (drage@alcatel-lucent.com) |
| 529 | 170.5 | CT4 part of NASS Bundled Authentication | 143d? | 2007-11-14 A | 2008-05-30 A | 100% | 2007-11-14 | 2008-05-30 | 143d? | start no earlier than 2007-11-14 | C4 | 1144h | 1144h | NBA-CT4 | PCG-21 | Rel-8 | CP-39 | Kimmo | Alcatel-Lucent |  |
| 530 | 171 | IMS initiated and controlled PSS and MBMS User Service | 262d? | 2008-03-12 A | 2009-03-12 A | 100% | 2008-03-12 | 2009-03-12 | 262d? | finish no earlier than 2009-03-12 | S4,S3 | 1003.2h | 1003.2h | IMS_PSS_MBMS_US |  | Rel-8 |  | Paolo | FT, Ericsson | olle.franceschi@ericsson.com |
| 531 | 172 | **Multimedia interworking between IMS and CS networks** | 836d? | 2005-09-23 A | 2008-12-05 A | 100% | 2005-09-23 | 2008-12-05 | 836d? |  | C3,C4 | 16112h | 16112h | MIW-IMS |  | Rel-8 |  | Gwiho | Vodafone | nico.gabriele@vodafone.com |
| 532 | 172.1 | Note: Stages 1 and 2 defined in earlier Release | 49d? | 2005-09-23 A | 2005-11-30 A | 100% | 2005-09-23 | 2005-11-30 | 49d? | start no earlier than 2005-09-23 | S2 | 392h | 392h | MIW-IMS |  | Rel-8 |  | Maurice | Vodafone | nico.gabriele@vodafone.com |
| 533 | 172.2 | Stage 3 of MW-IMS | 571d? | 2005-09-23 A | 2007-11-30 A | 100% | 2005-09-23 | 2007-11-30 | 571d? | finish no earlier than 2007-09-14 | C3 | 4568h | 4568h | MIW-IMS-St3 |  | Rel-8 |  | Gwiho | Vodafone | nico.gabriele@vodafone.com |
| 534 | 172.3 | Stage 3 for MW-IMS, MONA extension | 285d? | 2007-11-05 A | 2008-12-05 A | 100% | 2007-11-05 | 2008-12-05 | 285d? | finish no earlier than 2008-12-05 | C3 | 2280h | 2280h | MIW-IMS | PCG-21 | Rel-8 | CP-38 | Gwiho | Vodafone | Christer.Holmberg@ericsson.com |
| 535 | 172.4 | Mn interface (MGCF – IM MGW) | 273d? | 2007-11-21 A | 2008-12-05 A | 100% | 2007-11-21 | 2008-12-05 | 273d? | finish no earlier than 2008-12-19 | C4 | 2184h | 2184h | MIW-IMS | PCG-21 | Rel-8 | CP-38 | Kimmo | Vodafone | Christer.Holmberg@ericsson.com |
| 536 | 173 | IMS Stage 3 IETF Protocol Alignment | 446d? | 2007-06-22 A | 2009-03-06 A | 100% | 2007-06-22 | 2009-03-06 | 446d? | finish no earlier than 2009-03-06 | C1 | 3568h | 3568h | IMSProtoc2 |  | Rel-8 |  | Frederic | Alcatel-Lucent | Keith Drage (drage@alcatel-lucent.com) |
| 537 | 174 | **Interworking between User-to-User Signalling (UUS) and SIP** | 335d? | 2007-11-30 A | 2009-03-12 A | 100% | 2007-11-30 | 2009-03-12 | 335d? |  | C1,C3 | 7488h | 7488h | UUSIW | PCG-21 | Rel-8 | CP-38 | Kimmo | Huawei | Lili Yang (kadyyang@huawei.com) |
| 538 | 174.1 | Stage 3 MGCF UUSIW | 266d? | 2007-11-30 A | 2008-12-05 A | 100% | 2007-11-30 | 2008-12-05 | 266d? | finish no earlier than 2008-12-05 | C1 | 2128h | 2128h | UUSIW | PCG-21 | Rel-8 | CP-38 | Frederic | Huawei | Lili Yang (kadyyang@huawei.com) |
| 539 | 174.2 | Stage 3 MGCF UUSIW | 335d? | 2007-11-30 A | 2009-03-12 A | 100% | 2007-11-30 | 2009-03-12 | 335d? | finish no earlier than 2009-03-12 | C3 | 2680h | 2680h | UUSIW | PCG-21 | Rel-8 | CP-38 | Gwiho | Huawei | Lili Yang (kadyyang@huawei.com) |

Notes:
- 514: SP#40 completed
- 515: CP#39 completed / Text3: 24.404, 24.405, 24.406, 24.407, 24.408, 24.410, 24.411, 24.416, 29.421, 24.423, 24.428, 24.429, 29.433, 24.441, 24.403, 29.427, 24.430, 29.412
- 516: CP#39 completed. CP#46 withdrawn 29.624 from Rel-9 onwards / Text3: 24.406, 24.407, 24.410, 24.411, 24.423, 24.430, 24.447, 24.451, 24.454, 24.503, 24.505, 24.508, 24.516, 24.528, 24.529, 29.412, 29.421, 29.433, 29.458, 29.527, 29.624
- 517: WID approved SP#38. per OPs & ETSI GA 39. This is a joint effort of SA WG2 and TISPAN WG2. SP#40 completed / Text3: 23.228, 23.204, 23.167
- 518: SP#38 WID and TSs approved. SP#40 WID updated SP-070915=>SP-080315. SP#41 WID updated SP-080315=>SP-080501 / Text3: 22.273, 22.401, 23.406, 23.417, 23.508, 23.509, 23.511, 22.401, 22.173
- 519: SP#38 approved WID and TSs / Text3: 23.506, 23.507,23.517, 23.521
- 520: CP#44 completed. SP#40 Stage 1/2 completed
- 521: SP#40 completed
- 522: SP#40 completed / Text3: 23.237, 23.292
- 523: CP#44 completed / Text3: 24.237, 24.229, 24.216
- 524: CP#43 completed. SP#36 WID approved
- 525: SP#42 completed. SP#46 withdrawn draft 33.178-100 and 33.978 from Rel-8 onwards / Text3: 33.203, 33.141, 33.803
- 526: CP#42 completed
- 527: CP#43 completed
- 528: CP#43 completed / Text3: 24.229
- 529: CP#40 completed / Text3: 29.229, 29.228, 23.008
- 530: SP#43 completed. SP#39 WID approved / Text3: 26.237, 26.234, 26.346, 33.246
- 531: CP#42 completed
- 532: SP#31 Moved from FS section Feb 2006
- 533: Moved from R7 WP because it is part of Feature UID_713024. This feature was extended to R8 by the inclusion (at Nov 2007 CT3 meeting) of Stage 3 covering MONA (WI 380021) / Text3: 29.863, 29.163
- 534: CP#42 completed / Text3: 29.863, 29.163
- 535: CP#42 completed / Text3: 29.332
- 536: CP#43 completed / Text3: 23.218, 24.229, 24.930
- 537: CP#43 completed
- 538: CP#42 completed / Text3: 24.279, 24.229
- 539: Depending on IETF draft. CP#43 completed / Text3: 29.163

| ID | WBS | Task | Type | Duration | Start | Finish | Complete | Baseline start | Baseline finish | Baseline duration | Total slack | Constraint | Resources | Work | Actual work | Text1 | Text2 | Text4 | Text5 | Text6 | Text7 | Text8 | Text3 |
| --- | --- | --- | --- | --- | --- | --- | --- | --- | --- | --- | --- | --- | --- | --- | --- | --- | --- | --- | --- | --- | --- | --- | --- |
| 540 | 175 | **Support of Overlap signalling** |  | 331d? | 2007-11-30 A | 2009-03-06 A | 100% | 2007-11-30 | 2009-03-06 | 331d? |  |  | C3,C1,C4 | 10008.2h | 10008.2h | Overlap | PCG-21 | Deutsche Telekom | r.jesske@telekom.de | Rel-8 | CP-38 | Gwiho |  |
| 541 | 175.1 | Stage 3 Overlap (CT1) |  | 331d? | 2007-11-30 A | 2009-03-06 A | 100% | 2007-11-30 | 2009-03-06 | 331d? |  | finish no earlier than 2009-03-06 | C1 | 2648h | 2648h | Overlap | PCG-21 | Deutsche Telekom | r.jesske@telekom.de | Rel-8 | CP-38 | Frederic | 24.229 |
| 542 | 175.2 | Stage 3 Overlap (CT3) |  | 331d? | 2007-11-30 A | 2009-03-06 A | 100% | 2007-11-30 | 2009-03-06 | 331d? |  | finish no earlier than 2009-03-06 | C3 | 2648h | 2648h | Overlap | PCG-21 | Deutsche Telekom | r.jesske@telekom.de | Rel-8 | CP-38 | Gwiho | 29.163 |
| 543 | 175.3 | Stage 3 Overlap (CT4) |  | 258.02d? | 2007-11-30 A | 2008-12-05 A | 100% | 2007-11-30 | 2008-12-05 | 258.02d? |  | start no earlier than 2007-11-30 | C4 | 2064.16h | 2064.16h | Overlap | PCG-21 | Deutsche Telekom | r.jesske@telekom.de | Rel-8 | CP-38 | Kimmo | 29.228, 29.229 |
| 544 | 176 | AS/MRFC Stage 2 and 3 |  | 278d? | 2007-11-14 A | 2008-12-05 A | 100% | 2007-11-14 | 2008-12-05 | 278d? |  | finish no earlier than 2008-12-05 | C1 | 2224h | 2224h | MRFC_TS | PCG-21 | HP | mark.syrett@hp.com | Rel-8 | CP-38 | Frederic | 23.218, 24.229, 24.147, 24.247 |
| 545 | 177 | **IMS Restoration Procedures** |  | 201d? | 2008-05-30 A | 2009-03-06 A | 100% | 2008-05-30 | 2009-03-06 | 201d? |  |  | C4,C1 | 4824h | 4824h | IMS_RP | PCG-21 | Ericsson | german.blanco@ericsson.com | Rel-8 | SP-40 | Kimmo |  |
| 546 | 177.1 | IMS Restoration Procedures |  | 201d? | 2008-05-30 A | 2009-03-06 A | 100% | 2008-05-30 | 2009-03-06 | 201d? |  | finish no earlier than 2009-03-06 | C4 | 1608h | 1608h | IMS_RP | PCG-21 | Ericsson | german.blanco@ericsson.com | Rel-8 | SP-40 | Kimmo | 23.380, 29.228, 29.229, 29.230, 23.008 |
| 547 | 177.2 | IMS Restoration Procedures |  | 201d? | 2008-05-30 A | 2009-03-06 A | 100% | 2008-05-30 | 2009-03-06 | 201d? |  | finish no earlier than 2009-03-06 | C1 | 1608h | 1608h | IMS_RP | PCG-21 | Ericsson | german.blanco@ericsson.com | Rel-8 | SP-40 | Frederic | 24.229 |
| 548 | 178 | IMS Application Server Service Data Descriptions for AS interoperability |  | 125d? | 2008-09-12 A | 2009-03-06 A | 100% | 2008-09-12 | 2009-03-06 | 125d? |  | finish no earlier than 2009-03-06 | C4 | 1000h | 1000h | IMS_ASIO | PCG-21 | Alcatel-Lucent | nhberry@alcatel-lucent.com | Rel-8 | CP-41 | Kimmo | 29.328, 29.329, 29.364 |
| 549 | 179 | **I-WLAN Network Selection Principle (NSP)** |  | 451d? | 2007-06-14 A | 2009-03-06 A | 100% | 2007-06-14 | 2009-03-06 | 451d? |  |  | S1,C1,C6 | 6643.2h | 6643.2h | IWLANNSP |  | Telefonica O2 | chris.friel@o2.com | Rel-8 |  | Alain |  |
| 550 | 179.1 | Stage 1 for I-WLAN NSP | milestone | 0d? | 2007-06-14 A | 2007-06-14 A | 100% | 2007-06-14 | 2007-06-14 | 0d? |  |  | S1 |  |  | IWLANNSP | PCG-21 | Telefonica O2 | chris.friel@o2.com | Rel-8 | SP-39 | Alain | 22.234 |
| 551 | 179.2 | Stage 3 for I-WLAN NSP |  | 261d? | 2008-03-07 A | 2009-03-06 A | 100% | 2008-03-07 | 2009-03-06 | 261d? |  | finish no earlier than 2008-12-05 | C1 | 2088h | 2088h | IWLANNSP | PCG-21 | RIM | Adrian Buckley (abuckley@rim.com) | Rel-8 | CP-39 | Frederic | 24.234 |
| 552 | 179.3 | Stage 3 for I-WLAN NSP |  | 118.4d? | 2008-03-07 A | 2008-12-11 A | 100% | 2008-03-07 | 2008-12-11 | 118.4d? |  | finish no earlier than 2008-12-11 | C6 | 947.2h | 947.2h | IWLANNSP | PCG-21 | RIM | Adrian Buckley (abuckley@rim.com) | Rel-8 | CP-39 | Xavier | 31.102, 31.111 |
| 553 | 180 | **Mobility between 3GPP-WLAN Interworking and 3GPP Systems** |  | 386d? | 2007-09-14 A | 2009-03-06 A | 100% | 2007-09-14 | 2009-03-06 | 386d? |  |  | S2,C1 | 6216h | 6216h | IWLAN_Mob |  | Orange | xiaobao.chen@orange-ftgroup.com | Rel-8 | SP-37 | Maurice |  |
| 554 | 180.1 | Stage 2: I-WLAN Mobility |  | 190d? | 2007-09-14 A | 2008-06-05 A | 100% | 2007-09-14 | 2008-06-05 | 190d? |  | finish no earlier than 2008-09-08 | S2 | 1520h | 1520h | IWLAN_Mob | PCG-21 | Orange | xiaobao.chen@orange-ftgroup.com | Rel-8 | SP-38 | Maurice | 23.327 |
| 555 | 180.2 | CT1 aspects of I-WLAN Mobility |  | 201d? | 2008-05-30 A | 2009-03-06 A | 100% | 2008-05-30 | 2009-03-06 | 201d? |  | finish no earlier than 2009-03-06 | C1 | 1608h | 1608h | IWLAN_Mob | PCG-21 | Orange | reina.nader@orange-ftgroup.com | Rel-8 | CP-40 | Frederic | 24.327, 24.303 |
| 556 | 181 | Conformance Test Aspects – Mobility between 3GPP WLAN Interworking and 3GPP Systems |  | 131d? | 2009-12-04 | 2010-06-04 |  | 2009-12-04 | 2010-06-04 | 131d? | 335d | finish no earlier than 2010-06-04 | R5 | 1048h |  | IWLAN_Mob_UEConfTest | PCG-24 | Qualcomm Europe | Patrick Stupar (pstupar@qualcomm.com) | Rel-8 | RP-46 |  | 34.108, 34.123-1, 34.123-2, 34.123-3 |
| 557 | 182 | **Enhancements for VGCS Applications (EVA)** |  | 919d? | 2006-03-15 A | 2009-09-18 A | 100% | 2006-03-15 | 2009-09-18 | 919d? |  |  | S1,C1,C4,G2 | 23503.5h | 23503.5h | EVA |  | Nortel | Amar Deol (deola@nortelnetworks.com) | Rel-8 |  | Alain |  |
| 558 | 182.1 | SA1 aspects of EVA |  | 191d? | 2006-03-15 A | 2006-12-06 A | 100% | 2006-03-15 | 2006-12-06 | 191d? |  | finish no earlier than 2006-12-06 | S1 | 1528h | 1528h | EVA |  | Nortel | Amar Deol (deola@nortelnetworks.com) | Rel-8 |  | Alain | 42.068 |
| 559 | 182.2 | VGCS/VBS and GPRS Interactions |  | 145d? | 2007-09-03 A | 2008-03-21 A | 100% | 2007-09-03 | 2008-03-21 | 145d? |  | finish no earlier than 2008-03-21 | S1 | 1160h | 1160h | EVA |  | Huawei | Ling Liu | Rel-8 | SP-37 | Alain | 42.068, 42.069 |
| 560 | 182.3 | CT1 aspects of EVA |  | 862d? | 2006-06-02 A | 2009-09-18 A | 100% | 2006-06-02 | 2009-09-18 | 862d? |  | finish no earlier than 2009-12-04 | C1 | 6887.53h | 6887.53h | EVA |  | Nortel | milanpa@nortel.com | Rel-8 |  | Frederic | 43.068, 44.068 |
| 561 | 182.4 | CT4 aspects of EVA |  | 391d? | 2006-06-02 A | 2007-11-30 A | 100% | 2006-06-02 | 2007-11-30 | 391d? |  | finish no earlier than 2007-06-01 | C4 | 3128h | 3128h | EVA |  | Nortel |  | Rel-8 |  | Kimmo | 29.002 |
| 562 | 182.5 | GERAN2 aspects of EVA |  | 431d? | 2006-06-30 A | 2008-02-22 A | 100% | 2006-06-30 | 2008-02-22 | 431d? |  | finish no earlier than 2008-02-22 | G2 | 3448h | 3448h | EVA |  | Nortel | frank.billenkamp@nortel.com | Rel-8 |  | Gert | 44.018, 48.008 |
| 563 | 183 | **Personal Network Management** |  | 955d? | 2005-07-11 A | 2009-03-06 A | 100% | 2005-07-11 | 2009-03-06 | 955d? |  |  | S1,C1,S3 | 27008h | 27008h | PNM |  | Vodafone | armin.toepfer@vodafone.com | Rel-8 |  | Alain |  |
| 564 | 183.1 | Stage 1 for PNM |  | 276d? | 2005-07-11 A | 2006-07-31 A | 100% | 2005-07-11 | 2006-07-31 | 276d? |  | start no earlier than 2005-07-11 | S1 | 2208h | 2208h | PNM |  | Vodafone | armin.toepfer@vodafone.com | Rel-8 |  | Alain | 22.259 |
| 565 | 183.2 | Stage 2 for PNM |  | 445d? | 2007-03-26 A | 2008-12-05 A | 100% | 2007-03-26 | 2008-12-05 | 445d? |  | finish no earlier than 2008-12-05 | C1 | 3560h | 3560h | PNM |  | Vodafone | yang.lu@vodafone.com | Rel-8 |  | Frederic | 23.259 |

Notes:
- 540: CP#43 completed
- 541: CP#43 completed
- 542: CP#43 completed
- 543: CP#42 completed
- 544: CP#42 completed. Triggered by Study UID_7048 (MRFC)
- 545: CP#43 completed. CP#41 WID updated CP-080281=>CP-080447. Triggered by Study TR 23.820 (FS_IMS_RP) UID_350018
- 546: CP#43 completed
- 547: CP#43 completed
- 548: CP#43 completed. Triggered by UID_360030 (FS_IMS_ASIO)
- 549: CP#43 completed. SP#36 Stage 1 completed
- 550: SP#36 completed
- 551: CP#43 completed
- 552: CP#42 completed
- 553: CP#43 completed. SP#40 Stage 2 completed
- 554: SP#40 completed
- 555: CP#43 completed
- 556: Testing for Rel-8 UID_400013 CT1 aspects of mobility between 3GPP WLAN Interworking and 3GPP Systems (24.327)
- 557: CP#45 completed (Voice Group Call Service)
- 558: SP#38 completed
- 559: SP#39 completed
- 560: CP#45 completed. CT1 will not do more but SA1 may remove the requirement not solved by CT1
- 561: CP#38 completed
- 562: GP#37 completed
- 563: CP#43 completed. Feb 06 moved FS=>Feature. SP#31 Stage 1 completed. SP#40 WID updated with reduced scope SP-060574=>SP-080327
- 564: SP#31 completed. SP#40 WID updated SP-060574=>SP-080327
- 565: CP#42 completed

| ID | WBS | Task | Type | Duration | Start | Finish | Complete | Remaining | Baseline start | Baseline finish | Baseline duration | Total slack | Constraint | Resources | Work | Actual work | Text1 | Text4 | Text5 | Text6 | Text8 | Text3 | Text12 | Text7 | Text2 | Text11 |
| --- | --- | --- | --- | --- | --- | --- | --- | --- | --- | --- | --- | --- | --- | --- | --- | --- | --- | --- | --- | --- | --- | --- | --- | --- | --- | --- |
| 566 | 183.3 | **Stage 3 for PNM** |  | 510d? | 2007-03-26 A | 2009-03-06 A | 100% |  | 2007-03-26 | 2009-03-06 | 510d? |  |  | C1,C4 | 11720h | 11720h | PNM | Vodafone | yang.lu@vodafone.com | Rel-8 | Frederic |  |  |  |  |  |
| 567 | 183.3.1 | CT1 aspects of Stage 3 PNM |  | 510d? | 2007-03-26 A | 2009-03-06 A | 100% |  | 2007-03-26 | 2009-03-06 | 510d? |  | finish no earlier than 2008-12-05 | C1 | 4080h | 4080h | PNM | Vodafone | yang.lu@vodafone.com | Rel-8 | Frederic | 24.259, 24.229 |  |  |  |  |
| 568 | 183.3.2 | CT4 aspects of Stage 3 PNM |  | 445d? | 2007-03-26 A | 2008-12-05 A | 100% |  | 2007-03-26 | 2008-12-05 | 445d? |  | finish no earlier than 2008-12-11 | C4 | 3560h | 3560h | PNM | Vodafone | yang.lu@vodafone.com | Rel-8 | Kimmo |  |  |  |  |  |
| 569 | 183.4 | Key establishment between a UICC hosting device and a remote device |  | 235d? | 2006-12-06 A | 2007-10-30 A | 100% |  | 2006-12-06 | 2007-10-30 | 235d? |  | finish no earlier than 2007-10-30 | S3 | 1880h | 1880h | PNM | Ericsson | Vesa.Lehtovirta@ericsson.com | Rel-8 | Dionisio | 33.259 |  |  |  |  |
| 570 | 183.5 | Deleted - Actual Requirements of PNM | milestone | 0d? | 2007-03-26 A | 2007-03-26 A | 100% |  | 2007-03-26 | 2007-03-26 | 0d? |  | finish no earlier than 2007-03-26 | C1 |  |  | PNM | Ericsson |  | Rel-8 | Frederic |  | SP-37 |  |  |  |
| 571 | 184 | **eCall Data Transfer** |  | 637d? | 2006-09-28 A | 2009-03-06 A | 100% |  | 2006-09-28 | 2009-03-06 | 637d? |  |  | S1,C1 | 9744h | 9744h | EData | Airbiquity | rrobinson@airbiquity.com | Rel-8 | Alain |  |  |  |  |  |
| 572 | 184.1 | eData Requirements |  | 380d? | 2006-09-28 A | 2008-03-12 A | 100% |  | 2006-09-28 | 2008-03-12 | 380d? |  | finish no earlier than 2006-12-07 | S1 | 3040h | 3040h | EData | Airbiquity | rrobinson@airbiquity.com | Rel-8 | Alain | 22.101, 22.105 |  | SP-37 |  |  |
| 573 | 184.2 | Transfer of data during an emergency call |  | 201d? | 2008-05-30 A | 2009-03-06 A | 100% |  | 2008-05-30 | 2009-03-06 | 201d? |  | finish no earlier than 2009-03-06 | C1 | 1608h | 1608h | EData | T-Mobile | Dieter Jacobsohn | Rel-8 | Frederic | 24.008 |  | SP-40 | PCG-21 |  |
| 574 | 185 | eCall data transfer Phase 2: Comparison of alternative in-band modem solutions and standardization of one in-band modem solution |  | 472d? | 2007-12-06 A | 2009-09-24 A | 100% |  | 2007-12-06 | 2009-09-24 | 472d? |  | finish no earlier than 2009-09-24 | S4 | 3768.09h | 3768.09h | eCall_Phase2 | Airbiquity | lhong@airbiquity.com & rrobinson@airbiquity.com | Rel-8 | Paolo | 26.267, 26.268, 26.269, 26.967, 26.969 |  |  |  |  |
| 575 | 186 | eCall Conformance Testing |  | 181d? | 2009-09-04 A | 2010-05-14 | 45% | 99.55d? | 2009-09-04 | 2010-05-14 | 181d? | 350d | finish no earlier than 2010-05-14 | G3new | 1448h | 651.6h | eCall_MSTest | Ericsson, Qualcomm Europe | Vikrant Jain (vikrantj@qualcomm.com) | Rel-8 | Ingbert | 51.010-1, 51.010-2 |  | GP-45 | PCG-23 |  |
| 576 | 187 | Conformance Test Aspects – non-modem procedures of eCall sessions in UTRA |  | 126d? | 2009-09-18 A | 2010-03-12 | 15% | 107.1d? | 2009-09-18 | 2010-03-12 | 126d? | 395d | finish no earlier than 2010-03-12 | R5 | 1008h | 151.2h | UMTS_eCall_UEConTest | Ericsson, Qualcomm Europe | Shubhang Vora (svora@qualcomm.com) | Rel-8 | Ingbert | 34.108, 34.123-1, 34.123-2, 34.123-3 |  | RP-45 | PCG-23 | RP-091076 |
| 577 | 188 | **IP Interconnection of Services** |  | 668d? | 2006-08-16 A | 2009-03-06 A | 100% |  | 2006-08-16 | 2009-03-06 | 668d? |  |  | S1,S2,S5,C3 | 17520h | 17520h | IPinterc | Telefonica O2 | chris.friel@O2.com | Rel-8 | Alain |  |  | SP-38 | PCG-21 |  |
| 578 | 188.1 | Stage 1 for IPinterc |  | 70d? | 2007-12-06 A | 2008-03-12 A | 100% |  | 2007-12-06 | 2008-03-12 | 70d? |  | start no earlier than 2007-12-06 | S1 | 560h | 560h | IPinterc | Telefonica O2 | chris.friel@O2.com | Rel-8 | Alain | 22.101, 22.228 |  | SP-38 | PCG-21 |  |
| 579 | 188.2 | **System enhancements for interconnection interfaces between two IMSs** |  | 668d? | 2006-08-16 A | 2009-03-06 A | 100% |  | 2006-08-16 | 2009-03-06 | 668d? |  |  | S2,S5,C3 | 11616h | 11616h | IMS_NNI | Telecom Italia | Mario Madella (mario.madella@telecomitalia.it) | Rel-8 | Maurice |  |  |  |  |  |
| 580 | 188.2.1 | Stage 2 for IMS_NNI |  | 120d? | 2007-06-22 A | 2007-12-06 A | 100% |  | 2007-06-22 | 2007-12-06 | 120d? |  | finish no earlier than 2007-12-21 | S2 | 960h | 960h | IMS_NNI | Telecom Italia | Mario Madella (mario.madella@telecomitalia.it) | Rel-8 | Maurice | 23.002, 23.228 |  |  |  |  |
| 581 | 188.2.2 | IMS inter-operator service interconnection interface |  | 461d? | 2007-06-01 A | 2009-03-06 A | 100% |  | 2007-06-01 | 2009-03-06 | 461d? |  | finish no earlier than 2009-03-06 | C3 | 3688h | 3688h | FBI2-IOPSI | Telecom Italia | antonio.ascolese@telecomitalia.it | Rel-8 | Gwiho | 29.865, 29.165 |  |  |  |  |
| 582 | 188.2.3 | Charging harmonization for NGN between 3GPP and ATIS-TMOC |  | 51d? | 2006-09-28 A | 2006-12-07 A | 100% |  | 2006-09-28 | 2006-12-07 | 51d? |  | finish no earlier than 2006-12-07 | S5 | 408h | 408h | FBI2-TISP2-CH | Amdocs | Brown, Yishai | Rel-8 | Dionisio | 32.297 |  |  |  |  |
| 583 | 188.2.4 | Deleted - Protocol impact of FBI for TISPAN R2 |  | 152d? | 2006-08-16 A | 2007-03-15 A | 100% |  | 2006-08-16 | 2007-03-15 | 152d? |  | finish no earlier than 2007-03-15 | C1 | 1216h | 1216h | FBI2-TISP2-c1 | Ericsson |  | Rel-8 | Frederic |  | SP-38 |  |  |  |
| 584 | 188.2.5 | Deleted (never approved) - Stage 2 of FBI for TISPAN R2 - Rel 8 | milestone | 0d? | 2007-11-30 A | 2007-11-30 A | 100% |  | 2007-11-30 | 2007-11-30 | 0d? |  | finish no earlier than 2007-11-30 | S2 |  |  | FBI2-TISP2-s2 | Nokia Siemens Networks |  | Rel-8 | Maurice |  | SP-36 |  |  |  |
| 585 | 189 | **Support of (G)MSC-S – (G)MSC-S Nc Interface based on the SIP-I protocol** |  | 386d? | 2007-09-14 A | 2009-03-06 A | 100% |  | 2007-09-14 | 2009-03-06 | 386d? |  |  | C4,C3 | 11872h | 11872h | SIP_Nc | Vodafone | David.Hutton@vodafone.com | Rel-8 | Kimmo |  |  |  |  |  |
| 586 | 189.1 | Stage 1 for SIP_Nc (covered by Feature IPinterc) |  | 70d? | 2007-12-06 A | 2008-03-12 A | 100% |  | 2007-12-06 | 2008-03-12 | 70d? |  | start no earlier than 2007-12-06 | S1 | 560h | 560h | IPinterc | Telefonica O2 | chris.friel@O2.com | Rel-8 | Alain | 22.101, 22.228 |  | CP-41 | PCG-21 |  |
| 587 | 189.2 | SIP-I based circuit-switched core network; Stage 2 |  | 321d? | 2007-09-14 A | 2008-12-05 A | 100% |  | 2007-09-14 | 2008-12-05 | 321d? |  | finish no earlier than 2008-12-11 | C4 | 2568h | 2568h | SIP_Nc-St2 | Vodafone | David.Hutton@vodafone.com | Rel-8 | Kimmo | 23.231, 23.153, 23.205 |  |  |  |  |
| 588 | 189.3 | Application of SIP-I Protocols to Circuit Switched (CS) core network architecture; Stage 3 |  | 321d? | 2007-09-14 A | 2008-12-05 A | 100% |  | 2007-09-14 | 2008-12-05 | 321d? |  | finish no earlier than 2008-12-11 | C4 | 2568h | 2568h | SIP_Nc-St3 | Vodafone | David.Hutton@vodafone.com | Rel-8 | Kimmo | 29.231, 29.232, 29.332 |  |  |  |  |
| 589 | 189.4 | Interworking between the 3GPP CS domain with SIP-I as signalling protocol and other networks |  | 386d? | 2007-09-14 A | 2009-03-06 A | 100% |  | 2007-09-14 | 2009-03-06 | 386d? |  | finish no earlier than 2009-03-06 | C3 | 3088h | 3088h | SIP_Nc | Nokia Siemens Networks | Thomas.Belling@nsn.com | Rel-8 | Gwiho | 29.235, 23.172, 23.202, 29.007, 29.163, 29.414 |  |  |  |  |

Notes:
- 566: CP#43 completed. Moved from FS section Feb 06: SP-33: Create new section to capture the PNM stage 2 aspects and identify any impacts to existing stage 2 specifications.
- 567: CP#43 completed
- 568: CP#42 No impact to CT4 specifications
- 569: 07/08: Moved from Rel-7 to Rel-8 WP; Feature=>BB as per SA3/SA WID in SP-060839, keeping the same UID
- 570: SP#37 stopped
- 571: SP#39 completed. Linked to SA4 Feature UID_34042 (eCall_Phase2). CP#40 approved Stage 3 WID.
- 572: SA4 to select a suitable in-band modem. SP#39 completed
- 573: CP#43 completed
- 574: SP#45 completed. TR 26.969 for Approval. Triggered by Study UID_360015 (eCALLIBMS). Linked to SA1 Feature UID_330005 (EData)
- 575: GP#43 WID approved. Testing for Rel-8 eCall_Phase2 (UID_34042) and EData (UID_330005)
- 576: RP#45 testing for Rel-8 eCall_Phase2 (UID_34042) and Edata (UID_330005)
- 577: SP#43 completed. Covers Stage 1 for IMS_NNI (UID_360024),SIP_Nc (UID_360026),CS-IBCF (UID_400008). SP#41 WID updated SP-070871=>SP-080565 [Moved under it as BBs 2 existing Features: CS-IBCF, IMS_NNI]
- 578: SP#39 completed.
- 579: CP#43 completed. SP#36 Name changed from "System enhancements for TISPAN Rel2". Stage 1 in Feature UID_380060 (IPinterc). CP#41 updated WID CP-080054=>CP-080578 (Feature IMS_NNI=>BB under Ipinterc)
- 580: SP#38 completed. SP#41 WID updated SP-070490=>SP-080554
- 581: CP#43 completed
- 582: SP#34 completed
- 583: SP#38 stopped
- 584: SP#36 stopped
- 585: CP#43 completed. Stage 1 in Feature UID_380060 (IPinterc). CP#40 updated WID CP-070517=>CP-080282
- 586: 22/07/08 Created. Stage 1 for SIP_Nc (covered by SA1 Feature UID_380060 Ipinterc)
- 587: CP#42 completed
- 588: CP#42 completed
- 589: CP#43 completed. CP#42 target 12/08=>03/09

| ID | WBS | Task | Type | Duration | Start | Finish | Complete | Remaining | Baseline start | Baseline finish | Baseline duration | Total slack | Constraint | Resources | Work | Actual work | Text1 | Text4 | Text5 | Text6 | Text7 | Text8 | Text3 | Text2 | Text11 | Text9 | Text12 |
| --- | --- | --- | --- | --- | --- | --- | --- | --- | --- | --- | --- | --- | --- | --- | --- | --- | --- | --- | --- | --- | --- | --- | --- | --- | --- | --- | --- |
| 590 | 190 | **Earthquake and Tsunami Warning System** |  | 440d? | 2007-09-10 A | 2009-05-15 A | 100% |  | 2007-09-10 | 2009-05-15 | 440d? |  |  | S1,S2,CP,G2 | 6136h | 6136h | ETWS | NTT DoCoMo | kitaharar@nttdocomo.co.jp | Rel-8 | SP-37 | Alain |  |  |  |  |  |
| 591 | 190.1 | Stage 1 for ETWS |  | 133d? | 2007-09-10 A | 2008-03-12 A | 100% |  | 2007-09-10 | 2008-03-12 | 133d? |  | finish no earlier than 2008-03-12 | S1 | 1064h | 1064h | ETWS | NTT DoCoMo | kitaharar@nttdocomo.co.jp | Rel-8 | SP-37 | Alain | 22.168 |  |  |  |  |
| 592 | 190.2 | SA2 aspects of ETWS |  | 179d? | 2008-01-14 A | 2008-09-18 A | 100% |  | 2008-01-14 | 2008-09-18 | 179d? |  | finish no earlier than 2008-09-08 | S2 | 1432h | 1432h | ETWS | NTT DoCoMo | tanakai@nttdocomo.co.jp | Rel-8 | SP-38 | Maurice | 23.828, 23.401 | PCG-21 |  |  |  |
| 593 | 190.3 | CT1 aspects of ETWS |  | 50.5d? | 2008-05-30 A | 2008-12-05 A | 100% |  | 2008-05-30 | 2008-12-05 | 50.5d? |  | finish no earlier than 2008-12-05 | C1 | 404h | 404h | ETWS | NTT DoCoMo | yamashitahi@s1.nttdocomo.co.jp | Rel-8 | CP-40 | Frederic | 23.041 | PCG-21 |  |  |  |
| 594 | 190.4 | CT4 aspects of ETWS |  | 50.5d? | 2008-09-26 A | 2008-12-05 A | 100% |  | 2008-09-26 | 2008-12-05 | 50.5d? |  | finish no earlier than 2008-12-05 | C4 | 404h | 404h | ETWS | NTT DoCoMo | yamashitahi@s1.nttdocomo.co.jp | Rel-8 | CP-40 | Kimmo | 29.168 | PCG-21 |  |  |  |
| 595 | 190.5 | ETWS primary notification message definition in GERAN |  | 47d? | 2009-03-12 A | 2009-05-15 A | 100% |  | 2009-03-12 | 2009-05-15 | 47d? |  | finish no earlier than 2009-05-15 | G2 | 376h | 376h | ETWS | Ericsson | claes-goran.persson@ericsson.com | Rel-8 | SP-43 | Gert | 44.018, 44.060 | PCG-22 |  |  |  |
| 596 | 191 | Conformance Test Aspects – UMTS Earthquake and Tsunami Warning System (ETWS) FDD |  | 207d? | 2009-05-29 A | 2010-03-12 | 8% | 190.44d? | 2009-05-29 | 2010-03-12 | 207d? | 395d | finish no earlier than 2010-03-12 | R5 | 1656h | 132.48h | ETWS_UMTS_UEConTestFDD | NTT DoCoMo | Makoto Ito (itohm@nttdocomo.co.jp) | Rel-8 | RP-44 | Ingo | 34.108, 34.123-1, 34.123-2, 34.123-3 | PCG-23 | RP-091070 |  |  |
| 597 | 192 | **In Case of Emergency numbers storage and easy access on UICC** |  | 519d? | 2007-03-13 A | 2009-03-06 A | 100% |  | 2007-03-13 | 2009-03-06 | 519d? |  |  | S1,C6 | 8864h | 8864h | ICE | Vodafone | armin.toepfer@vodafone.com | Rel-8 | SP-38 | Alain |  | PCG-21 |  |  |  |
| 598 | 192.1 | Stage 1 for ICE |  | 262d? | 2007-03-13 A | 2008-03-12 A | 100% |  | 2007-03-13 | 2008-03-12 | 262d? |  | finish no earlier than 2008-03-12 | S1 | 2096h | 2096h | ICE | Vodafone | armin.toepfer@vodafone.com | Rel-8 | SP-38 | Alain | 22.030, 22.101 | PCG-21 |  |  |  |
| 599 | 192.2 | CT6 aspects of ICE |  | 519d? | 2007-03-13 A | 2009-03-06 A | 100% |  | 2007-03-13 | 2009-03-06 | 519d? |  | finish no earlier than 2009-03-06 | C6 | 4152h | 4152h | ICE | Vodafone | armin.toepfer@vodafone.com | Rel-8 | SP-38 | Xavier | 31.102 | PCG-21 |  |  |  |
| 600 | 193 | Local Charging Zone Requirements |  | 380d? | 2006-09-28 A | 2008-03-12 A | 100% |  | 2006-09-28 | 2008-03-12 | 380d? |  | finish no earlier than 2006-12-07 | S1 | 3040h | 3040h | LCZR | China Mobile | liuhongyfw@chinamobile.com | Rel-8 |  | Alain | 22.115 |  |  |  |  |
| 601 | 194 | **Customized Alerting Tone (CAT) Service** |  | 729d? | 2006-12-06 A | 2009-09-18 A | 100% |  | 2006-12-06 | 2009-09-18 | 729d? |  |  | S1,C1,C3,C4 | 12302h | 12302h | CAT | China Mobile | fenglingjuan@chinamobile.com | Rel-8 |  | Alain |  |  |  |  |  |
| 602 | 194.1 | Stage 1 for CAT |  | 207d? | 2006-12-06 A | 2007-09-20 A | 100% |  | 2006-12-06 | 2007-09-20 | 207d? |  | start no earlier than 2006-12-06 | S1 | 1656h | 1656h | CAT | China Mobile | fenglingjuan@chinamobile.com | Rel-8 | SP-37 | Alain | 22.182 |  |  |  |  |
| 603 | 194.2 | TISPAN requirements for customized multimedia information services |  | 71d? | 2007-09-03 A | 2007-12-10 A | 100% |  | 2007-09-03 | 2007-12-10 | 71d? |  | finish no earlier than 2007-12-10 | S1 | 568h | 568h | TISCMI | China Mobile | fenglingjuan@chinamobile.com | Rel-8 | SP-37 | Alain | 22.182 |  |  |  |  |
| 604 | 194.3 | IMS CAT Supplementary Service |  | 164d? | 2008-04-21 A | 2008-12-04 A | 100% |  | 2008-04-21 | 2008-12-04 | 164d? |  | finish no earlier than 2008-12-05 | C1 | 1312h | 1312h | CAT-SS | Nortel | milanpa@nortel.com | Rel-8 | CP-39 | Frederic | 24.182 | PCG-21 |  |  |  |
| 605 | 194.4 | CAT solution for voice and video call in CS domain |  | 389.8d? | 2008-03-12 A | 2009-09-18 A | 100% |  | 2008-03-12 | 2009-09-18 | 389.8d? |  | finish no earlier than 2009-09-11 | C3 | 3118.4h | 3118.4h | CAT-SS | Nortel | milanpa@nortel.com | Rel-8 | CP-39 | Gwiho | 29.163 | PCG-21 |  |  |  |
| 606 | 194.5 | CAT Service in 3GPP CS domain |  | 126d? | 2008-09-12 A | 2009-03-06 A | 100% |  | 2008-09-12 | 2009-03-06 | 126d? |  | finish no earlier than 2009-03-06 | C4 | 1008h | 1008h | CAT-3G_CS | China Mobile | zhaoyuyi@chinamobile.com | Rel-8 | CP-41 | Kimmo | 23.205, 23.231, 29.002 | PCG-21 |  |  |  |
| 607 | 194.6 | CAT Service in 3GPP CS domain |  | 57.95d? | 2008-09-12 A | 2008-12-05 A | 100% |  | 2008-09-12 | 2008-12-05 | 57.95d? |  | start no earlier than 2008-09-12 | C1 | 463.6h | 463.6h | CAT-3G_CS | China Mobile | zhaoyuyi@chinamobile.com | Rel-8 | CP-41 | Frederic | 24.008, 23.014 | PCG-21 |  |  |  |
| 608 | 195 | **Service-Level Interworking for Messaging Services** |  | 509d? | 2007-03-26 A | 2009-03-06 A | 100% |  | 2007-03-26 | 2009-03-06 | 509d? |  |  | S1,S2,C3,C1 | 8584h | 8584h | MESSIW | Huawei | ling.liu@huawei.com; duanxiaoqin@huawei.com | Rel-8 |  | Alain |  |  |  |  |  |
| 609 | 195.1 | Stage 1 for MESSIW | milestone | 0d? | 2007-03-26 A | 2007-03-26 A | 100% |  | 2007-03-26 | 2007-03-26 | 0d? |  | finish no earlier than 2007-12-01 | S1 |  |  | MESSIW | Huawei | ling.liu@huawei.com | Rel-8 |  | Alain | 22.105, 22.340 |  |  |  |  |
| 610 | 195.2 | Stage 2 for MESSIW |  | 227d? | 2007-04-26 A | 2008-03-07 A | 100% |  | 2007-04-26 | 2008-03-07 | 227d? |  | finish no earlier than 2008-03-07 | S2 | 1816h | 1816h | MESSIW | Huawei | patrice.hede@huawei.com | Rel-8 |  | Maurice | 23.811, 23.204 |  |  |  |  |
| 611 | 195.3 | Stage 3 for MESSIW |  | 201d? | 2008-05-30 A | 2009-03-06 A | 100% |  | 2008-05-30 | 2009-03-06 | 201d? |  | finish no earlier than 2008-12-05 | C3 | 1608h | 1608h | MESSIW | Huawei | xupeili@huawei.com | Rel-8 | CP-40 | Gwiho | 29.311 | PCG-21 |  |  |  |
| 612 | 195.4 | Stage 3 for MESSIW |  | 136d? | 2008-05-30 A | 2008-12-05 A | 100% |  | 2008-05-30 | 2008-12-05 | 136d? |  | finish no earlier than 2008-12-12 | C1 | 1088h | 1088h | MESSIW | Huawei | xupeili@huawei.com | Rel-8 | CP-40 | Frederic | 24.229 | PCG-21 |  |  |  |
| 613 | 196 | **Multimedia Priority Service** |  | 858d? | 2006-06-08 A | 2009-09-18 A | 100% |  | 2006-06-08 | 2009-09-18 | 858d? |  |  | S1,C1,C3,C4 | 22424h | 22424h | PRIOR | Telcordia | jgarraha@telcordia.com | Rel-8 | SP-34 | Alain |  |  |  |  |  |
| 614 | 196.1 | Service Requirements for PRIOR |  | 391d? | 2006-06-08 A | 2007-12-06 A | 100% |  | 2006-06-08 | 2007-12-06 | 391d? |  | finish no earlier than 2007-11-30 | S1 | 3128h | 3128h | PRIOR-EMR | Telcordia | jgarraha@telcordia.com | Rel-8 | SP-32 | Alain | 22.153 |  |  |  |  |
| 615 | 196.2 | Stage 3 for PRIOR |  | 732d? | 2006-12-01 A | 2009-09-18 A | 100% |  | 2006-12-01 | 2009-09-18 | 732d? |  | finish no earlier than 2009-09-18 | C1 | 5856h | 5856h | PRIOR | Alcatel-Lucent | Keith Drage (drage@alcatel-lucent.com) | Rel-8 | CP-34 | Frederic | 24.229 |  |  |  |  |
| 616 | 196.3 | Deleted - Stage 3 for PRIOR |  | 441d? | 2007-09-21 A | 2009-05-29 A | 100% |  | 2007-09-21 | 2009-05-29 | 441d? |  | finish no earlier than 2009-05-29 | C3 | 3528h | 3528h | PRIOR | Alcatel-Lucent | Keith Drage (drage@alcatel-lucent.com) | Rel-8 | CP-37 | Gwiho | 29.212, 29.213, 29.214, 29.163 |  |  | PCG-23 | CP-44 |
| 617 | 196.4 | Stage 3 for PRIOR |  | 381d? | 2007-09-21 A | 2009-03-06 A | 100% |  | 2007-09-21 | 2009-03-06 | 381d? |  | finish no earlier than 2009-03-06 | C4 | 3048h | 3048h | PRIOR | Alcatel-Lucent | Keith Drage (drage@alcatel-lucent.com) | Rel-8 | CP-37 | Kimmo | 23.008, 29.228, 29.229 |  |  |  |  |

Notes:
- 590: SP#43 GERAN task included. Larger scope Feature UID_380057 (PWS) moved to Rel-9
- 591: SP#39 completed
- 592: SP#41 completed
- 593: CP#42 completed. WID updated CP-080318=>CP-080659=>CP-080951
- 594: CP#42 completed. WID updated CP-080318=>CP-080659=>CP-080951
- 595: SP#44 completed with CT1 help (GERAN2 LS_in SP-090154)
- 596: Testing for Rel-8 ETWS UID_370051
- 597: CP#43 completed (ICE Graphics not included in Rel-8)
- 598: SP#39 Stage 1 completed
- 599: CP#43 completed (ICE Graphics not in Rel-8 / not explicitly in SA1 WID either)
- 600: SP#39 Stage 1 completed
- 601: CP#45 completed
- 602: -
- 603: SP#38 completed
- 604: CP#42 completed. CP#41 WID updated CP-080074=>CP-080496.
- 605: CP#45 completed. CP#44 sent LS to ITU-T (CP-090501) request to specify explicit parameter for CAT signalling and APM container for 3GPP to define the contents. Triggered by Study UID_360031 (FS_CAT_VVC_CS) TR 29.882
- 606: CP#43 completed. Triggered by Study UID_360031 (FS_CAT_VVC_CS) TR 29.882.
- 607: Triggered by Study UID_360031 (FS_CAT_VVC_CS) TR 29.882. CP#42 completed
- 608: CP#43 completed. SP#39 Stage 2 completed
- 609: SP#35 completed
- 610: SP#39 completed
- 611: CP#43 completed
- 612: CP#42 completed. WID updated CP-080391=>CP-080575=>CP-080773
- 613: CP#45 completed. SP#38 Stage 1 completed. No Stage 2 identified
- 614: SP#38 completed
- 615: CP#45 completed
- 616: CP#44 closed (Reason: No Rel-8 solution expected (LS sent to SA2, but not prioritized in SA2)
- 617: CP#43 completed

| ID | WBS | Task | Duration | Start | Finish | Complete | Baseline start | Baseline finish | Baseline duration | Constraint | Resources | Work | Actual work | Text1 | Text4 | Text5 | Text6 | Text8 | Text3 | Text7 | Text2 | Text9 | Text12 |
| --- | --- | --- | --- | --- | --- | --- | --- | --- | --- | --- | --- | --- | --- | --- | --- | --- | --- | --- | --- | --- | --- | --- | --- |
| 618 | 197 | **OSA Rel-8** | 202d? | 2007-08-23 A | 2008-05-30 A | 100% | 2007-08-23 | 2008-05-30 | 202d? |  | S1,C5 | 23552h | 23552h | OSA8 | Orange | Song Dong | Rel-8 | Alain |  |  |  |  |  |
| 619 | 197.1 | OSA Stage 1 - Service Requirements | 145d? | 2007-08-23 A | 2008-03-12 A | 100% | 2007-08-23 | 2008-03-12 | 145d? | finish no earlier than 2007-12-04 | S1 | 1160h | 1160h | OSA8 | Orange, AePONA | Song Dong | Rel-8 | Alain | 22.127 |  |  |  |  |
| 620 | 197.2 | OSA Stage 1 - NGN Service Requirement | 140d? | 2007-09-03 A | 2008-03-14 A | 100% | 2007-09-03 | 2008-03-14 | 140d? | finish no earlier than 2008-03-14 | S1 | 1120h | 1120h | OSA8-IMS | Orange | Song Dong | Rel-8 | Alain | 22.127 | SP-37 |  |  |  |
| 621 | 197.3 | **OSA Stage 2/3 enhancements** | 157d? | 2007-10-25 A | 2008-05-30 A | 100% | 2007-10-25 | 2008-05-30 | 157d? |  | C5 | 20016h | 20016h | OSA8 | Alcatel-Lucent | unmehopa@alcatel-lucent.com | Rel-8 | Kimmo | 23.198, 29.198, 29.199 |  |  |  |  |
| 622 | 197.3.1 | Deleted - Ensure Parlay-X composable with identity management frameworks, in particular Liberty Alliance | 157d? | 2007-10-25 A | 2008-05-30 A | 100% | 2007-10-25 | 2008-05-30 | 157d? | finish no earlier than 2008-12-25 | C5 | 1256h | 1256h | OSA8 | Ericsson, FT/Orange, Sprint, Telecom Italia | catherine.mulligan@ericsson.com | Rel-8 | Kimmo | existing 29.199-xy | CP-37 | PCG-21 | PCG-21 | CP-40 |
| 623 | 197.3.2 | Parlay-X Content Management web service (store/manage meta-data) | 157d? | 2007-10-25 A | 2008-05-30 A | 100% | 2007-10-25 | 2008-05-30 | 157d? | finish no earlier than 2008-12-04 | C5 | 1256h | 1256h | OSA8 | Alcatel-Lucent | unmehopa@alcatel-lucent.com | Rel-8 | Kimmo | 29.199-21 | CP-37 |  |  |  |
| 624 | 197.3.3 | Parlay-X Policy web service | 157d? | 2007-10-25 A | 2008-05-30 A | 100% | 2007-10-25 | 2008-05-30 | 157d? | finish no earlier than 2008-12-04 | C5 | 1256h | 1256h | OSA8 | Alcatel-Lucent | unmehopa@alcatel-lucent.com | Rel-8 | Kimmo | 29.199-22 | CP-37 |  |  |  |
| 625 | 197.3.4 | Parlay-X Terminal status web service | 157d? | 2007-10-25 A | 2008-05-30 A | 100% | 2007-10-25 | 2008-05-30 | 157d? | finish no earlier than 2008-05-30 | C5 | 1256h | 1256h | OSA8 | Alcatel-Lucent | unmehopa@alcatel-lucent.com | Rel-8 | Kimmo | 29.199-08 | CP-37 |  |  |  |
| 626 | 197.3.5 | Deleted - Identify communication format used by a particular application | 157d? | 2007-10-25 A | 2008-05-30 A | 100% | 2007-10-25 | 2008-05-30 | 157d? | finish no earlier than 2008-05-30 | C5 | 1256h | 1256h | OSA8 | Ericsson | catherine.mulligan@ericsson.com | Rel-8 | Kimmo | existing 29.199-xy | CP-37 | PCG-21 | PCG-21 | CP-40 |
| 627 | 197.3.6 | Deleted - Security on User Profile Management - reuse GUP API (22.127 CR 0084 S1-071794) | 128d? | 2007-12-05 A | 2008-05-30 A | 100% | 2007-12-05 | 2008-05-30 | 128d? | finish no earlier than 2008-12-25 | C5 | 1024h | 1024h | OSA8 | Telecom Italia | vincenzo.amorino@telecomitalia.it | Rel-8 | Kimmo | PXWS Framework | CP-38 | PCG-21 | PCG-21 | CP-40 |
| 628 | 197.3.7 | Deleted - Privacy on Subscriber Identity (Liberty Alliance, OASIS) (22.127 CR 0085 S1-071835) | 128d? | 2007-12-05 A | 2008-05-30 A | 100% | 2007-12-05 | 2008-05-30 | 128d? | finish no earlier than 2008-12-25 | C5 | 1024h | 1024h | OSA8 | Telecom Italia | vincenzo.amorino@telecomitalia.it | Rel-8 | Kimmo | PXWS Framework | CP-38 | PCG-21 | PCG-21 | CP-40 |
| 629 | 197.3.8 | Deleted - Topology Hiding (22.127 CR 0086 S1-071838) | 128d? | 2007-12-05 A | 2008-05-30 A | 100% | 2007-12-05 | 2008-05-30 | 128d? | finish no earlier than 2008-12-25 | C5 | 1024h | 1024h | OSA8 | Telecom Italia | vincenzo.amorino@telecomitalia.it | Rel-8 | Kimmo | PXWS Framework | CP-38 | PCG-21 | PCG-21 | CP-40 |
| 630 | 197.3.9 | Deleted - Subscriber event notification (22.127 CR 0087 S1-071836) | 128d? | 2007-12-05 A | 2008-05-30 A | 100% | 2007-12-05 | 2008-05-30 | 128d? | finish no earlier than 2008-12-25 | C5 | 1024h | 1024h | OSA8 | Telecom Italia | vincenzo.amorino@telecomitalia.it | Rel-8 | Kimmo | PXWS Framework | CP-38 | PCG-21 | PCG-21 | CP-40 |
| 631 | 197.3.10 | Deleted - Event notification (22.127 CR 0088 S1-071762) | 128d? | 2007-12-05 A | 2008-05-30 A | 100% | 2007-12-05 | 2008-05-30 | 128d? | finish no earlier than 2008-12-25 | C5 | 1024h | 1024h | OSA8 | Telecom Italia | vincenzo.amorino@telecomitalia.it | Rel-8 | Kimmo | PXWS Framework | CP-38 | PCG-21 | PCG-21 | CP-40 |
| 632 | 197.3.11 | Deleted - Access policy (22.127 CR 0089 S1-071763) | 128d? | 2007-12-05 A | 2008-05-30 A | 100% | 2007-12-05 | 2008-05-30 | 128d? | finish no earlier than 2008-12-25 | C5 | 1024h | 1024h | OSA8 | Telecom Italia | vincenzo.amorino@telecomitalia.it | Rel-8 | Kimmo | PXWS Framework | CP-38 | PCG-21 | PCG-21 | CP-40 |
| 633 | 197.3.12 | Deleted - API usage accounting (22.127 CR 0090 S1-071792) | 128d? | 2007-12-05 A | 2008-05-30 A | 100% | 2007-12-05 | 2008-05-30 | 128d? | finish no earlier than 2008-12-25 | C5 | 1024h | 1024h | OSA8 | Telecom Italia | vincenzo.amorino@telecomitalia.it | Rel-8 | Kimmo | PXWS Framework | CP-38 | PCG-21 | PCG-21 | CP-40 |
| 634 | 197.3.13 | Presence alignment with OMA and IETF (22.127 CR 0092 S1-071764) | 128d? | 2007-12-05 A | 2008-05-30 A | 100% | 2007-12-05 | 2008-05-30 | 128d? | finish no earlier than 2008-05-30 | C5 | 1024h | 1024h | OSA8 | Alcatel-Lucent | unmehopa@alcatel-lucent.com | Rel-8 | Kimmo | 29.199-14/13 | CP-38 | PCG-21 |  |  |
| 635 | 197.3.14 | Deleted - Service identification (22.127 CR 0095 S1-071837) | 128d? | 2007-12-05 A | 2008-05-30 A | 100% | 2007-12-05 | 2008-05-30 | 128d? | finish no earlier than 2008-05-30 | C5 | 1024h | 1024h | OSA8 | Ericsson | catherine.mulligan@ericsson.com | Rel-8 | Kimmo | existing 29.199-xy | CP-38 | PCG-21 | PCG-21 | CP-40 |
| 636 | 197.3.15 | Framework Enterprise Operator (Service Subscription function) | 102d? | 2008-01-10 A | 2008-05-30 A | 100% | 2008-01-10 | 2008-05-30 | 102d? | finish no earlier than 2008-05-30 | C5 | 816h | 816h | OSA8 | Alcatel-Lucent | unmehopa@alcatel-lucent.com | Rel-8 | Kimmo | 29.198-03 | CP-39 | PCG-21 |  |  |
| 637 | 197.3.16 | Mobility Emergency Location | 102d? | 2008-01-10 A | 2008-05-30 A | 100% | 2008-01-10 | 2008-05-30 | 102d? | finish no earlier than 2008-05-30 | C5 | 816h | 816h | OSA8 | Alcatel-Lucent | unmehopa@alcatel-lucent.com | Rel-8 | Kimmo | 29.198-06 | CP-39 | PCG-21 |  |  |
| 638 | 197.3.17 | Connectivity Manager SCF | 102d? | 2008-01-10 A | 2008-05-30 A | 100% | 2008-01-10 | 2008-05-30 | 102d? |  | C5 | 816h | 816h | OSA8 | Alcatel-Lucent | unmehopa@alcatel-lucent.com | Rel-8 | Kimmo | 29.198-10 | CP-39 | PCG-21 |  |  |
| 639 | 197.3.18 | PAM Presence Agent | 102d? | 2008-01-10 A | 2008-05-30 A | 100% | 2008-01-10 | 2008-05-30 | 102d? | finish no earlier than 2008-05-30 | C5 | 816h | 816h | OSA8 | Alcatel-Lucent | unmehopa@alcatel-lucent.com | Rel-8 | Kimmo | 29.198-14 | CP-39 | PCG-21 |  |  |
| 640 | 198 | **Paging Permission with Access Control (PPACR)** | 389d? | 2007-06-12 A | 2008-12-05 A | 100% | 2007-06-12 | 2008-12-05 | 389d? |  | S1,C1 | 5888h | 5888h | PPACR | NTT DoCoMo | Morita Takashi | Rel-8 | Alain |  |  |  |  |  |
| 641 | 198.1 | Stage 1 for PPACR | 69d? | 2007-06-12 A | 2007-09-14 A | 100% | 2007-06-12 | 2007-09-14 | 69d? | finish no earlier than 2007-09-14 | S1 | 552h | 552h | PPACR-S1 | NTT DoCoMo | Morita Takashi | Rel-8 | Alain | 22.011 | SP-37 |  |  |  |
| 642 | 198.2 | Stage 3 for PPACR (CT1) | 278d? | 2007-11-14 A | 2008-12-05 A | 100% | 2007-11-14 | 2008-12-05 | 278d? | finish no earlier than 2008-12-05 | C1 | 2224h | 2224h | PPACR-CT1 | NTT DoCoMo |  | Rel-8 | Frederic | 24.008, 23.122, 24.301 | CP-38 | PCG-21 |  |  |

Notes:
- 618: TSG#40 completed. New OSA work in OMA. SA1 need to remove unfulfilled Requirements to align with CT5 Stage 2/3 reality.
- 619: TSG#40 New OSA work in OMA. SA1 to remove non-fulfilled Requirements.
- 620: TSG#40 New OSA work in OMA. SA1 to remove non-fulfilled Requirements.
- 621: CP#40 WID updated CP-070349=>CP-080252. Started work completed. Unfulfilled Rel-8 Stage 1 and New OSA work to be done in OMA. SA1 needs to remove non-fulfilled requirements in 22.127
- 622: CP#40: Work moved to OMA
- 623: CP#40 completed
- 624: CP#40 completed
- 625: CP#40 completed
- 626: CP#40: Work moved to OMA
- 627: SP#38 SP-070853 R8 CRs 22.127 OSA Stage 1. CP#40: Work moved to OMA
- 628: SP#38 SP-070853 R8 CRs 22.127 OSA Stage 1. CP#40: Work moved to OMA
- 629: SP#38 SP-070853 R8 CRs 22.127 OSA Stage 1. CP#40: Work moved to OMA
- 630: SP#38 SP-070853 R8 CRs 22.127 OSA Stage 1. CP#40: Work moved to OMA
- 631: SP#38 SP-070853 R8 CRs 22.127 OSA Stage 1. CP#40: Work moved to OMA
- 632: SP#38 SP-070853 R8 CRs 22.127 OSA Stage 1. CP#40: Work moved to OMA
- 633: SP#38 SP-070853 R8 CRs 22.127 OSA Stage 1. CP#40: Work moved to OMA
- 634: CP#40 completed
- 635: SP#38 SP-070853 R8 CRs 22.127 OSA Stage 1. CP#40: Work moved to OMA
- 636: CP#40 completed
- 637: CP#40 completed
- 638: CP#40 completed
- 639: CP#40 completed
- 640: CP#42 completed. Triggered by Study UID_330016 (PPAC).
- 641: SP#37 completed
- 642: CP#42 completed

| ID | WBS | Task | Duration | Start | Finish | Complete | Remaining | Baseline start | Baseline finish | Baseline duration | Total slack | Constraint | Resources | Work | Actual work | Text1 | Text2 | Text4 | Text6 | Text7 | Text8 | Text11 |
| --- | --- | --- | --- | --- | --- | --- | --- | --- | --- | --- | --- | --- | --- | --- | --- | --- | --- | --- | --- | --- | --- | --- |
| 643 | 199 | **Charging for multi-phases services** | 70d? | 2007-12-06 A | 2008-03-12 A | 100% |  | 2007-12-06 | 2008-03-12 | 70d? |  |  | S1 | 560h | 560h | CHRGMPH | PCG-21 | Telecom Italia | Rel-8 | SP-38 | Alain |  |
| 644 | 199.1 | Stage 1 for CHRGMPH | 70d? | 2007-12-06 A | 2008-03-12 A | 100% |  | 2007-12-06 | 2008-03-12 | 70d? |  | start no earlier than 2007-12-06 | S1 | 560h | 560h | CHRGMPH-s1 | PCG-21 | Telecom Italia | Rel-8 | SP-38 | Alain |  |
| 645 | 200 | **Home NodeB / eNodeB** | 327d? | 2007-12-06 A | 2009-03-06 A | 100% |  | 2007-12-06 | 2009-03-06 | 327d? |  |  | S1,C1,C4 | 5720h | 5720h | HomeNB | PCG-21 | Vodafone | Rel-8 | SP-38 | Alain |  |
| 646 | 200.1 | Stage 1 for HNB_eHNB | 70d? | 2007-12-06 A | 2008-03-12 A | 100% |  | 2007-12-06 | 2008-03-12 | 70d? |  | start no earlier than 2007-12-06 | S1 | 560h | 560h | HomeNB-S1 | PCG-21 | Vodafone | Rel-8 | SP-38 | Alain |  |
| 647 | 200.2 | CSG and Idle Mode Mobility for LTE Home eNodeB | 126d? | 2008-09-12 A | 2009-03-06 A | 100% |  | 2008-09-12 | 2009-03-06 | 126d? |  | finish no earlier than 2009-03-06 | C1 | 1008h | 1008h | HomeNB-LTE | PCG-21 | Huawei | Rel-8 | CP-41 | Frederic |  |
| 648 | 200.3 | CSG and Idle Mode Mobility for 3G Home NodeB | 126d? | 2008-09-12 A | 2009-03-06 A | 100% |  | 2008-09-12 | 2009-03-06 | 126d? |  | finish no earlier than 2009-03-06 | C1 | 1008h | 1008h | HomeNB-3G | PCG-21 | Qualcomm Europe | Rel-8 | CP-41 | Frederic |  |
| 649 | 200.4 | Support of Closed Subscriber Group (CSG) | 66d? | 2008-12-05 A | 2009-03-06 A | 100% |  | 2008-12-05 | 2009-03-06 | 66d? |  | finish no earlier than 2009-03-06 | C4 | 528h | 528h | HomeNB | PCG-22 | CT#42 | Rel-8 | CP-42 | Kimmo | CT#42 report |
| 650 | 201 | **UTRA HNB** | 326d? | 2008-03-07 A | 2009-06-04 A | 100% |  | 2008-03-07 | 2009-06-04 | 326d? |  |  | RP,S5 | 6832h | 6832h | HNB | PCG-21 |  | Rel-8 | SP-39 | Issam |  |
| 651 | 201.1 | Support of UTRA HNB | 201d? | 2008-05-30 A | 2009-03-06 A | 100% |  | 2008-05-30 | 2009-03-06 | 201d? |  | finish no earlier than 2009-03-06 | R2 | 1608h | 1608h | HNB-supp | PCG-21 | Huawei | Rel-8 | SP-40 | Joern | RP-090040 |
| 652 | 201.2 | FDD Home NodeB RF requirements | 261d? | 2008-03-07 A | 2009-03-06 A | 100% |  | 2008-03-07 | 2009-03-06 | 261d? |  | finish no earlier than 2009-03-06 | R4 | 2088h | 2088h | HNB-RF | PCG-21 | Motorola | Rel-8 | SP-39 | Issam | RP-090041 |
| 653 | 201.3 | UTRAN Architecture for 3G HNB | 136d? | 2008-05-30 A | 2008-12-05 A | 100% |  | 2008-05-30 | 2008-12-05 | 136d? |  | finish no earlier than 2008-12-05 | R3 | 1088h | 1088h | HNB-arch | PCG-21 | Alcatel-Lucent | Rel-8 | SP-40 | Juha | RP-090042 |
| 654 | 201.4 | 3G Home NodeB OAM&P Type 1 Management Interface | 127d? | 2008-12-11 A | 2009-06-04 A | 100% |  | 2008-12-11 | 2009-06-04 | 127d? |  | finish no earlier than 2009-06-04 | S5 | 1008h | 1008h | HNB-3G_OAM | PCG-22 | Huawei | Rel-8 | SP-42 | Dionisio |  |
| 655 | 202 | **UTRA HNB – UE Conformance Testing** | 327d? | 2009-03-06 A | 2010-06-04 | 60% | 130.8d? | 2009-03-06 | 2010-06-04 | 327d? | 335d |  | R5 | 5224h | 3134.4h | HNB-UEConTest | PCG-22 |  | Rel-8 | RP-43 | Ingbert |  |
| 656 | 202.1 | Conformance Test Aspects – UTRA HNB (FDD) | 326d? | 2009-03-06 A | 2010-06-04 | 60% | 130.4d? | 2009-03-06 | 2010-06-04 | 326d? | 335d | finish no earlier than 2010-06-04 | R5 | 2608h | 1564.8h | HNB-UEConTestFDD | PCG-22 | Huawei | Rel-8 | RP-43 | Ingbert | RP-091065 |
| 657 | 203 | Lawful Interception in the 3GPP Rel-8 | 524d? | 2007-03-12 A | 2009-03-12 A | 100% |  | 2007-03-12 | 2009-03-12 | 524d? |  | finish no earlier than 2009-03-12 | S3 | 4192h | 4192h | LI8 |  | BMWI, Verizon | Rel-8 |  | Dionisio |  |
| 658 | 204 | **Generic Bootstrapping Architecture Push Function** | 258d? | 2008-03-12 A | 2009-03-06 A | 100% |  | 2008-03-12 | 2009-03-06 | 258d? |  |  | S3,C1,C4 | 6468.8h | 6468.8h | GBAPush | PCG-21 | Ericsson | Rel-8 | SP-39 | Dionisio |  |
| 659 | 204.1 | SA3 part of GBAPush (33.223) | 193d? | 2008-03-12 A | 2008-12-05 A | 100% |  | 2008-03-12 | 2008-12-05 | 193d? |  | finish no earlier than 2008-12-05 | S3 | 1544h | 1544h | GBAPush | PCG-21 | Ericsson | Rel-8 | SP-39 | Dionisio |  |
| 660 | 204.2 | CT1 part of GBAPush | 178.8d? | 2008-03-12 A | 2009-03-06 A | 100% |  | 2008-03-12 | 2009-03-06 | 178.8d? |  | finish no earlier than 2009-03-06 | C1 | 1430.4h | 1430.4h | GBAPush | PCG-21 | Ericsson | Rel-8 | SP-39 | Frederic |  |
| 661 | 204.3 | CT4 part of GBAPush | 178.8d? | 2008-03-12 A | 2009-03-06 A | 100% |  | 2008-03-12 | 2009-03-06 | 178.8d? |  | finish no earlier than 2009-03-06 | C4 | 1430.4h | 1430.4h | GBAPush | PCG-21 | Ericsson | Rel-8 | SP-39 | Kimmo |  |
| 662 | 205 | Requirements and Test methods for Wideband Terminals | 197d? | 2008-03-12 A | 2008-12-11 A | 100% |  | 2008-03-12 | 2008-12-11 | 197d? |  | start no earlier than 2008-03-12 | S4 | 1576h | 1576h | RETEM_WB_T |  | FT, Ericsson | Rel-8 |  | Paolo |  |
| 663 | 206 | Extending PSS and MBMS User Services for optimized Mobile TV | 266d? | 2007-12-06 A | 2008-12-11 A | 100% |  | 2007-12-06 | 2008-12-11 | 266d? |  | finish no earlier than 2008-12-11 | S4 | 2128h | 2128h | PSS_MBMS_OMTV |  | Ericsson | Rel-8 |  | Paolo |  |
| 664 | 207 | **Encoding formats, transport formats and media description signalling for interworking, QoE, and other enhancements to MTSI-MHI** | 331d? | 2007-12-06 A | 2009-03-12 A | 100% |  | 2007-12-06 | 2009-03-12 | 331d? |  |  | S4,C3,C1,C4 | 9640h | 9640h | MTSI_eMHI | PCG-21 | Ericsson, Qualcomm Europe | Rel-8 | SP-40 | Paolo |  |
| 665 | 207.1 | MTSI Video - Dynamic Rate Adaptation/Signalling of Image Size | 331d? | 2007-12-06 A | 2009-03-12 A | 100% |  | 2007-12-06 | 2009-03-12 | 331d? |  | finish no earlier than 2009-03-12 | S4 | 2648h | 2648h | MTSI_eMHI-DRASIS |  | Qualcomm Europe, Samsung | Rel-8 |  | Paolo |  |
| 666 | 207.2 | CT3 part of Enhancement of interworking between MTSI and CS networks | 201d? | 2008-05-30 A | 2009-03-06 A | 100% |  | 2008-05-30 | 2009-03-06 | 201d? |  | finish no earlier than 2009-03-06 | C3 | 1608h | 1608h | MTSI_eMHI | PCG-21 | Huawei | Rel-8 | CP-40 | Gwiho |  |
| 667 | 207.3 | CT1 part of Enhancement of interworking between MTSI and CS networks | 141d? | 2008-05-30 A | 2008-12-12 A | 100% |  | 2008-05-30 | 2008-12-12 | 141d? |  | start no earlier than 2008-05-30 | C1 | 1128h | 1128h | MTSI_eMHI | PCG-21 | Huawei | Rel-8 | CP-40 | Frederic |  |
| 668 | 207.4 | CT4 part of Enhancement of interworking between MTSI and CS networks | 201d? | 2008-05-30 A | 2009-03-06 A | 100% |  | 2008-05-30 | 2009-03-06 | 201d? |  | finish no earlier than 2009-03-06 | C4 | 1608h | 1608h | MTSI_eMHI | PCG-21 | Huawei | Rel-8 | CP-40 | Kimmo |  |

Notes:
- 643: SP#39 Stage 1 completed / Text3: 22.115 / Text5: Marco.DeLuca1@telecomitalia.it
- 644: SP#39 completed / Text3: 22.115 / Text5: Marco.DeLuca1@telecomitalia.it
- 645: CP#43 completed. SP#39 Stage 1 completed / Text5: John Watson
- 646: SP#39 completed / Text3: 22.011, 22.115 / Text5: John Watson
- 647: CP#43 completed / Text3: 23.122, 24.301, 24.801, 24.285 / Text5: zhang.peng@huawei.com
- 648: CP#43 completed / Text3: 23.122, 24.008, 24.285 / Text5: Osok Song
- 649: CP#43 completed. SP#42 SP-080874 22.011CR0141 confirmed Requirement to support roaming subscribers with CSG home network subscription but did NOT confirmed requirement for home network independent support of roamers in CSG / Text3: 29.002, 29.272, 23.008, 23.003 / Text5: Hannu Hietalahti
- 650: RP#43 completed. SP#44 completed
- 651: RP#43 completed. RP#41 WID updated RP-080483=>RP-080752. / Text3: 25.304, 25.306, 25.331, 25.367 / Text5: Yang Xudong (yangxudong@huawei.com)
- 652: RP#43 completed / Text3: 25.104, 25.141, 25.967 / Text5: Ying Cai (yingcai@motorola.com)
- 653: RP#42 completed / Text3: 25.401, 25.410, 25.412, 25.413, 25.414, 25.415, 25.467, 25.468, 25.469 / Text5: Martin Warner (mw15@alcatel-lucent.com)
- 654: SP#44 completed. Complements work in BroadBand Forum / Text3: 32.581, 32.582, 32.583, 32.584 / Text5: Zou Lan (zlan@huawei.com)
- 655: Testing for Feature UID_390033 UTRA HNB
- 656: RP#46 completion 12/09=>06/10 / Text3: 34.108, 34.123-1, 34.123-2, 34.123-3 / Text5: Trica Li (trica_li@huawei.com)
- 657: SP#43 completed / Text3: 33.106, 33.107, 33.108 / Text5: berthold.wilhelm@bnetza.de, ron_ryan@verizon.net
- 658: CP#43 completed / Text5: Rolf Blom
- 659: SP#42 completed 33.223 as Rel-8. TS 33.224 moved to Rel-9 under new UID_420039 / Text3: 33.223 / Text5: Rolf Blom
- 660: CP#43 completed / Text3: 24.109 / Text5: Rolf Blom
- 661: CP#43 completed / Text3: 29.109 / Text5: Rolf Blom
- 662: SP#42 completed. SP#39 WID approved. / Text3: 26.131, 26.132 / Text5: stephane.ragot@orange-ftgroup.com, wanqing.shi@sonyericsson.com
- 663: SP#42 completed. SP#38 WID approved. / Text3: 26.234, 26.346, 26.946 / Text5: thorsten.lohmar@ericsson.com
- 664: TSG#43 completed / Text5: olle.franceschi@ericsson.com, nleung@qualcomm.com
- 665: SP#43 completed. SP#40 WID updated SP-070755=>SP-080246. [Feature=>BB under new Feature UID_400028 (MTSI)] / Text3: 26.114 / Text5: nleung@qualcomm.com & kyunghun.jung@samsung.com
- 666: CP#43 completed / Text3: 29.163 / Text5: Tingfang Tang (tagna_online@huawei.com)
- 667: CP#42 completed (No CT1-impact). WID updated CP-080422=>CP-080774 / Text5: Tingfang Tang (tagna_online@huawei.com)
- 668: CP#43 completed / Text3: 29.332 / Text5: Tingfang Tang (tagna_online@huawei.com)

| ID | WBS | Task | Duration | Start | Finish | Complete | Baseline start | Baseline finish | Baseline duration | Constraint | Resources | Work | Actual work | Text1 | Text6 | Text8 | Text4 | Text5 | Text2 | Text7 | Text9 | Text12 |
| --- | --- | --- | --- | --- | --- | --- | --- | --- | --- | --- | --- | --- | --- | --- | --- | --- | --- | --- | --- | --- | --- | --- |
| 669 | 208 | **OAM&P 8** | 653d? | 2007-06-07 A | 2009-12-04 A | 100% | 2007-06-07 | 2009-12-04 | 653d? |  | S5,C1 | 43227.2h | 43227.2h | OAM8 | Rel-8 | Dionisio |  |  |  |  |  |  |
| 670 | 208.1 | **Network Infrastructure Management** | 653d? | 2007-06-07 A | 2009-12-04 A | 100% | 2007-06-07 | 2009-12-04 | 653d? |  | S5 | 19464h | 19464h | OAM8-NIM | Rel-8 | Dionisio |  |  |  |  |  |  |
| 671 | 208.1.1 | Telecom Management Methodology | 461d? | 2007-06-07 A | 2009-03-12 A | 100% | 2007-06-07 | 2009-03-12 | 461d? | finish no earlier than 2009-03-12 | S5 | 3688h | 3688h | OAM8 | Rel-8 | Dionisio | Ericsson | thomas.tovinger@ericsson.com |  |  |  |  |
| 672 | 208.1.2 | Advanced Alarming on Itf-N | 266d? | 2007-06-07 A | 2008-06-12 A | 100% | 2007-06-07 | 2008-06-12 | 266d? | finish no earlier than 2008-12-11 | S5 | 2128h | 2128h | OAM8 | Rel-8 | Dionisio | Nokia Siemens Networks | SUERBAUM, Clemens |  |  |  |  |
| 673 | 208.1.3 | CN CS Bearer Transport Network (BTN) relative NRM | 266d? | 2007-06-07 A | 2008-06-12 A | 100% | 2007-06-07 | 2008-06-12 | 266d? | finish no earlier than 2008-12-11 | S5 | 2128h | 2128h | OAM8 | Rel-8 | Dionisio | China Mobile | LI, Jian |  |  |  |  |
| 674 | 208.1.4 | Alignment with eTOM and M.3060 architectural concepts | 210d? | 2008-02-22 A | 2008-12-11 A | 100% | 2008-02-22 | 2008-12-11 | 210d? | start no earlier than 2008-02-22 | S5 | 1680h | 1680h | OAM8 | Rel-8 | Dionisio | TeliaSonera | Berggren, Tommy | PCG-21 | SP-39 |  |  |
| 675 | 208.1.5 | IRP SOAP Solution Sets | 201d? | 2008-06-05 A | 2009-03-12 A | 100% | 2008-06-05 | 2009-03-12 | 201d? | finish no earlier than 2009-03-12 | S5 | 1608h | 1608h | OAM8 | Rel-8 | Dionisio | Ericsson | edwin.tse@ericsson.com | PCG-21 | SP-40 |  |  |
| 676 | 208.1.6 | Create missing specifications for IRP XML definitions | 52d? | 2009-09-24 A | 2009-12-04 A | 100% | 2009-09-24 | 2009-12-04 | 52d? | finish no earlier than 2010-03-12 | S5 | 416h | 416h | OAM8 | Rel-8 | Dionisio | ZTE | Shuqiang Huang (huangsq@zte.com.cn) | PCG-23 | SP-45 |  |  |
| 677 | 208.1.7 | Deleted - End point modelling for reference point | 324d? | 2007-09-17 A | 2008-12-11 A | 100% | 2007-09-17 | 2008-12-11 | 324d? | finish no earlier than 2008-12-11 | S5 | 2592h | 2592h | OAM8 | Rel-8 | Dionisio | Motorola | YAO, Yizhi |  | SP-37 | PCG-21 | SP-41 |
| 678 | 208.2 | **Performance Management** | 461d? | 2007-06-07 A | 2009-03-12 A | 100% | 2007-06-07 | 2009-03-12 | 461d? |  | S5 | 13712h | 13712h | OAM8-PM | Rel-8 | Dionisio |  |  |  |  |  |  |
| 679 | 208.2.1 | IP bearer network Performance measurement definitions | 396d? | 2007-06-07 A | 2008-12-11 A | 100% | 2007-06-07 | 2008-12-11 | 396d? | finish no earlier than 2008-12-11 | S5 | 3168h | 3168h | OAM8 | Rel-8 | Dionisio | China Mobile | lilianyuan@chinamobile.com |  |  |  |  |
| 680 | 208.2.2 | HSUPA performance measurements | 396d? | 2007-06-07 A | 2008-12-11 A | 100% | 2007-06-07 | 2008-12-11 | 396d? | finish no earlier than 2008-12-11 | S5 | 3168h | 3168h | OAM8 | Rel-8 | Dionisio | China Mobile | LI, Jian |  |  |  |  |
| 681 | 208.2.3 | Key Performance Indicators (KPIs) for UMTS and GSM | 461d? | 2007-06-07 A | 2009-03-12 A | 100% | 2007-06-07 | 2009-03-12 | 461d? | finish no earlier than 2009-03-12 | S5 | 3688h | 3688h | OAM8 | Rel-8 | Dionisio | China Mobile | Liang Shuangchun |  |  |  |  |
| 682 | 208.3 | **Trace Management** | 196d? | 2008-03-07 A | 2008-12-05 A | 100% | 2008-03-07 | 2008-12-05 | 196d? |  | S5,C1,C3,C4 | 5777.6h | 5777.6h | OAM8-Trace | Rel-8 | Dionisio |  |  |  |  |  |  |
| 683 | 208.3.1 | Service Level Tracing in IMS | 196d? | 2008-03-07 A | 2008-12-05 A | 100% | 2008-03-07 | 2008-12-05 | 196d? | finish no earlier than 2008-12-05 | C1 | 1568h | 1568h | OAM8-Trace | Rel-8 | Frederic | Vodafone | peter.dawes@vodafone.com |  |  |  |  |
| 684 | 208.3.2 | Service Level Tracing in IMS | 175.4d? | 2008-03-07 A | 2008-12-05 A | 100% | 2008-03-07 | 2008-12-05 | 175.4d? | finish no earlier than 2008-12-05 | C3 | 1403.2h | 1403.2h | OAM8-Trace | Rel-8 | Gwiho | Vodafone | peter.dawes@vodafone.com | PCG-21 | CP-40 |  |  |
| 685 | 208.3.3 | Service Level Tracing in IMS | 175.4d? | 2008-03-07 A | 2008-12-05 A | 100% | 2008-03-07 | 2008-12-05 | 175.4d? | finish no earlier than 2008-12-05 | C4 | 1403.2h | 1403.2h | OAM8-Trace | Rel-8 | Frederic | Vodafone | peter.dawes@vodafone.com | PCG-21 | CP-40 |  |  |
| 686 | 209 | **Charging Management small Enhancements** | 716d? | 2006-03-16 A | 2008-12-11 A | 100% | 2006-03-16 | 2008-12-11 | 716d? |  | S5 | 12544h | 12544h | CH8 | Rel-8 | Dionisio |  |  |  |  |  |  |
| 687 | 209.1 | Online charging correlation | 457d? | 2006-03-16 A | 2007-12-14 A | 100% | 2006-03-16 | 2007-12-14 | 457d? | start no earlier than 2006-03-16 | S5 | 3656h | 3656h | CH8 | Rel-8 | Dionisio | Orange | Chahine, Rony |  |  |  |  |
| 688 | 209.2 | SMS online charging | 137d? | 2007-06-07 A | 2007-12-14 A | 100% | 2007-06-07 | 2007-12-14 | 137d? | finish no earlier than 2007-12-14 | S5 | 1096h | 1096h | CH8 | Rel-8 | Dionisio | Vodafone | WONG, Gavin |  |  |  |  |
| 689 | 209.3 | Introduce Online Charging from SMS-SC into the SMS Charging Specifications | 61d? | 2008-09-18 A | 2008-12-11 A | 100% | 2008-09-18 | 2008-12-11 | 61d? | finish no earlier than 2008-12-11 | S5 | 488h | 488h | CH8 | Rel-8 | Dionisio | Acision | Gebler, Erik - Acision [erik.gebler (at) acision.com] | PCG-21 | SP-41 |  |  |
| 690 | 209.4 | Deleted - WLAN Offline Charging | 244d? | 2008-01-07 A | 2008-12-11 A | 100% | 2008-01-07 | 2008-12-11 | 244d? | finish no earlier than 2008-12-11 | S5 | 1952h | 1952h | CH8 | Rel-8 | Dionisio | Alcatel-Lucent | GARDELLA, Maryse | PCG-21 | SP-38 | PCG-22 | SP-42 |
| 691 | 210 | **Conferencing enhancements for Mp interface** | 266d? | 2007-11-30 A | 2008-12-05 A | 100% | 2007-11-30 | 2008-12-05 | 266d? |  | C4 | 6384h | 6384h | eMp | Rel-8 | Kimmo | Huawei | Chencheng@huawei.com | PCG-21 |  |  |  |
| 692 | 210.1 | Stage 2 for eMp | 266d? | 2007-11-30 A | 2008-12-05 A | 100% | 2007-11-30 | 2008-12-05 | 266d? | finish no earlier than 2008-12-11 | C4 | 2128h | 2128h | eMp | Rel-8 | Kimmo | Huawei | Chencheng@huawei.com | PCG-21 | CP-38 |  |  |
| 693 | 210.2 | Stage 3 for eMp | 266d? | 2007-11-30 A | 2008-12-05 A | 100% | 2007-11-30 | 2008-12-05 | 266d? | finish no earlier than 2008-12-05 | C4 | 2128h | 2128h | eMp | Rel-8 | Kimmo | Huawei | Chencheng@huawei.com | PCG-21 | CP-38 |  |  |

Notes:
- 669: -
- 670: -
- 671: SP#43 completed / Text3: 32.155, 32.153
- 672: SP#40 completed / Text3: 32.121, 32.122, 32.123
- 673: SP#40 completed / Text3: 32.632/3/5
- 674: SP#42 completed / Text3: 32.101/2, 32-series
- 675: SP#43 completed. WID updated SP-080276=>SP-090148 (removed the planned but not delivered new TSs 32.127, 32.327, 32.337, 32.357, 32.387, 32.397, 32.447) / Text3: 32.111-7, 32.617, 32.417, 32.367, 32.347, 32.111-1, 32.111-2, 32.111-3, 32.111-5, 32.307, 32.317, 32.341, 32.342, 32.343, 32.345, 32.361, 32.362, 32.363, 32.365, 32.411, 32.412, 32.413, 32.415, 32.611, 32.612, 32.613, 32.615, 32.625
- 676: SP#46 completed. Create missing XML definitions specs for IRPs (Advanced Alarm Management, Communication Surveillance, Self-Configuration of Network Elements, Software Management) needed for implementation of Rel-8 Notification Log IRP (TS 32.33x) / Text3: new TS (32.125, 32.355, 32.505, 32.535), 32.150, 32.153, 32.335
- 677: SP#41 Work stopped. Contributions related to E-UTRAN/EPC to be submitted to UID_380036 E-UTRAN NRM IRP/ UID_380037 EPC NRM IRP / Text3: 32.152, 32.62/3/4x, 32.73x
- 678: -
- 679: SP#42 completed. SP#36 WID updated SP-050319=>SP-070301 / Text3: 32.321/2/3/5
- 680: SP#42 completed / Text3: 32.405
- 681: SP#43 completed / Text3: 32.410
- 682: -
- 683: CP#42 completed. CP#40 WID updated CP-060521=>CP-080315. / Text3: 24.323, 24.229
- 684: CP#42 completed (No CT3-impact). CP#40 WID updated CP-060521=>CP-080315
- 685: CP#42 completed. CP#40 WID updated CP-060521=>CP-080315. / Text3: 29.228, 29.229
- 686: SP#42 completed.
- 687: SP#38 completed / Text3: 32.296
- 688: SP#38 completed / Text3: 32.274, 32.240/299
- 689: SP#42 completed. Linked to SA2 UID 32081 (Support of SMS over IP networks) and CT4 UID 340016 (Routeing of MT-SMS via the HPLMN). / Text3: 32.274, 32.299
- 690: SP#42 stopped / Text3: 32.252, 32.298, 32.299
- 691: CP#42 completed. WID updated CP-070868=>CP-080725
- 692: CP#42 completed. WID updated CP-070868=>CP-080725 / Text3: 23.333
- 693: CP#42 completed. WID updated CP-070868=>CP-080725 / Text3: 29.333

| ID | WBS | Task | Type | Duration | Start | Finish | Complete | Baseline start | Baseline finish | Baseline duration | Total slack | Constraint | Resources | Work | Actual work | Text1 | Text4 | Text5 | Text6 | Text8 | Text7 | Text12 | Text2 | Text11 |
| --- | --- | --- | --- | --- | --- | --- | --- | --- | --- | --- | --- | --- | --- | --- | --- | --- | --- | --- | --- | --- | --- | --- | --- | --- |
| 694 | 211 | **Contact Manager for 3GPP UICC applications** |  | 642d? | 2006-06-22 A | 2008-12-05 A | 100% | 2006-06-22 | 2008-12-05 | 642d? |  |  | C6 | 13352h | 13352h | eUPHBOOK | Gemalto | Jacques.seif@gemalto.com | Rel-8 | Xavier |  |  |  |  |
| 695 | 211.1 | Requirements for Contact Manager |  | 392d? | 2006-06-22 A | 2007-12-21 A | 100% | 2006-06-22 | 2007-12-21 | 392d? |  | finish no earlier than 2007-12-21 | C6 | 3136h | 3136h | eUPHBOOK-St1 | Gemalto | Jacques.seif@gemalto.com | Rel-8 | Xavier |  |  |  |  |
| 696 | 211.2 | External interface for eUPHBOOK |  | 220d? | 2007-05-07 A | 2008-03-07 A | 100% | 2007-05-07 | 2008-03-07 | 220d? |  | finish no earlier than 2008-03-07 | C6 | 1760h | 1760h | eUPHBOOK-Ext_Spec | Gemalto | Jacques.seif@gemalto.com | Rel-8 | Xavier |  |  |  |  |
| 697 | 211.3 | Internal interface for eUPHBOOK |  | 415d? | 2007-05-07 A | 2008-12-05 A | 100% | 2007-05-07 | 2008-12-05 | 415d? |  | finish no earlier than 2008-12-05 | C6 | 3320h | 3320h | eUPHBOOK-Int_Spec | Gemalto | Jacques.seif@gemalto.com | Rel-8 | Xavier | CP-37 |  |  |  |
| 698 | 211.4 | Deleted - Implementation of eUPHBOOK | milestone | 0d? | 2007-06-21 A | 2007-06-21 A | 100% | 2007-06-21 | 2007-06-21 | 0d? |  | start no earlier than 2007-06-21 | C6 |  |  | eUPHBOOK-St23 | Giesecke & Devrient | Claus Dietze | Rel-8 | Xavier |  | SP-33 |  |  |
| 699 | 212 | **Contact Manager Conformance Test specifications** |  | 471d? | 2008-06-02 | 2010-03-19 |  | 2008-06-02 | 2010-03-19 | 471d? | 390d |  | C6 | 11304h |  | eUPHBOOK-Test | Comprion, Gemalto | Udo Willenbrink, Jacques Seif | Rel-8 | Xavier | CP-40 |  | PCG-21 |  |
| 700 | 212.1 | Contact Manager for 3GPP UICC applications test specifications |  | 471d? | 2008-06-02 | 2010-03-19 |  | 2008-06-02 | 2010-03-19 | 471d? | 390d | finish no earlier than 2010-03-19 | C6 | 3768h |  | eUPHBOOK-Test | Comprion | Udo Willenbrink | Rel-8 | Xavier | CP-40 |  | PCG-21 |  |
| 701 | 212.2 | Contact Manager API for Java™ Card test specification |  | 471d? | 2008-06-02 | 2010-03-19 |  | 2008-06-02 | 2010-03-19 | 471d? | 390d | finish no earlier than 2010-03-19 | C6 | 3768h |  | eUPHBOOK-Test | Gemalto | jacques.seif@gemalto.com | Rel-8 | Xavier | CP-40 |  | PCG-21 |  |
| 702 | 213 | **Rel-8 LTE – 3G Long Term Evolution - Evolved Packet System RAN part** |  | 644d? | 2006-09-25 A | 2009-03-12 A | 100% | 2006-09-25 | 2009-03-12 | 644d? |  |  | RP,S5 | 44896h | 44896h | LTE | NTT DoCoMo | Takehiro Nakamura (nakamurata@nttdocomo.co.jp) | Rel-8 |  |  |  |  | RP-080741 |
| 703 | 213.1 | LTE – Physical Layer |  | 380d? | 2006-09-25 A | 2008-03-07 A | 100% | 2006-09-25 | 2008-03-07 | 380d? |  | finish no earlier than 2007-09-14 | R1 | 3040h | 3040h | LTE-Phys | NTT DoCoMo | Sadayuki Abeta | Rel-8 | Patrick |  |  |  | RP-080741 |
| 704 | 213.2 | LTE – Radio Interface Layer 2 and 3 Protocol Aspect |  | 575d? | 2006-09-25 A | 2008-12-05 A | 100% | 2006-09-25 | 2008-12-05 | 575d? |  | finish no earlier than 2008-12-11 | R2 | 4600h | 4600h | LTE-L23 | Nokia Siemens Networks | benoist.sebire@nokia.com | Rel-8 | Joern |  |  |  | RP-080741 |
| 705 | 213.3 | LTE – eUTRAN Interfaces |  | 575d? | 2006-09-25 A | 2008-12-05 A | 100% | 2006-09-25 | 2008-12-05 | 575d? |  | finish no earlier than 2008-12-11 | R3 | 4600h | 4600h | LTE-interfaces | Ericsson | Martin Israelsson | Rel-8 | Juha |  |  |  | RP-080741 |
| 706 | 213.4 | LTE – Evolved UTRA and UTRAN RF Radio Transmission/Reception, System Performance Requirements and Conformance Testing |  | 575d? | 2006-09-25 A | 2008-12-05 A | 100% | 2006-09-25 | 2008-12-05 | 575d? |  | finish no earlier than 2008-12-11 | R4 | 4600h | 4600h | LTE-RF | Nokia Siemens Networks | Tuomo Saynajakangas | Rel-8 | Issam |  |  |  | RP-080741 |
| 707 | 213.5 | LTE – FDD repeaters |  | 386d? | 2007-09-14 A | 2009-03-06 A | 100% | 2007-09-14 | 2009-03-06 | 386d? |  | finish no earlier than 2009-03-06 | R4 | 3088h | 3088h | LTE-Repeaters | Powerwave Technologies, Andrew Wireless | ralf.michanikl@andrew.com, Alf.Ahlstrom@pwav.com | Rel-8 | Issam | RP-37 |  |  | RP-090037 |
| 708 | 213.6 | **E-UTRAN Data Definitions** |  | 389d? | 2007-09-17 A | 2009-03-12 A | 100% | 2007-09-17 | 2009-03-12 | 389d? |  |  | S5 | 13096h | 13096h | E-UTRAN-OAM |  |  | Rel-8 | Dionisio | SP-39 |  | PCG-21 |  |
| 709 | 213.6.1 | Subscriber and Equipment Trace for E-UTRAN and EPC |  | 389d? | 2007-09-17 A | 2009-03-12 A | 100% | 2007-09-17 | 2009-03-12 | 389d? |  | finish no earlier than 2009-03-12 | S5 | 3112h | 3112h | E-UTRAN-OAM | Ericsson | PETERSEN, Robert | Rel-8 | Dionisio | SP-37 |  |  |  |
| 710 | 213.6.2 | E-UTRAN Network Resource Model (NRM) Integration Reference Point (IRP) |  | 309d? | 2008-01-07 A | 2009-03-12 A | 100% | 2008-01-07 | 2009-03-12 | 309d? |  | finish no earlier than 2009-03-12 | S5 | 2472h | 2472h | E-UTRAN-OAM | Ericsson | ELMDAHL, Per | Rel-8 | Dionisio | SP-38 |  | PCG-21 |  |
| 711 | 213.6.3 | Performance measurements for E-UTRAN |  | 275d? | 2008-02-22 A | 2009-03-12 A | 100% | 2008-02-22 | 2009-03-12 | 275d? |  | finish no earlier than 2009-03-12 | S5 | 2200h | 2200h | E-UTRAN-OAM | Motorola, Huawei | YAO, Yizhi | Rel-8 | Dionisio | SP-39 |  | PCG-21 |  |
| 712 | 213.6.4 | Key Performance Indicators (KPIs) for E-UTRAN |  | 275d? | 2008-02-22 A | 2009-03-12 A | 100% | 2008-02-22 | 2009-03-12 | 275d? |  | finish no earlier than 2009-03-12 | S5 | 2200h | 2200h | E-UTRAN-OAM | Ericsson | HÜBINETTE, Ulf | Rel-8 | Dionisio | SP-39 |  | PCG-21 |  |
| 713 | 213.7 | **Self-Organizing Networks (SON)** |  | 210d? | 2008-02-22 A | 2008-12-11 A | 100% | 2008-02-22 | 2008-12-11 | 210d? |  |  | S5 | 6720h | 6720h | LTE_SON-OAM | Vodafone | GOMPAKIS, Panagiotis | Rel-8 | Dionisio | SP-39 |  | PCG-21 |  |
| 714 | 213.7.1 | SON Concepts and requirements |  | 210d? | 2008-02-22 A | 2008-12-11 A | 100% | 2008-02-22 | 2008-12-11 | 210d? |  |  | S5 | 1680h | 1680h | LTE_SON-OAM | Vodafone | GOMPAKIS, Panagiotis | Rel-8 | Dionisio | SP-39 |  | PCG-21 |  |
| 715 | 213.7.2 | Self-Establishment of eNBs, including automated Software Management |  | 210d? | 2008-02-22 A | 2008-12-11 A | 100% | 2008-02-22 | 2008-12-11 | 210d? |  | start no earlier than 2008-02-22 | S5 | 1680h | 1680h | LTE_SON-OAM | Nokia Siemens Networks | SUERBAUM, Clemens | Rel-8 | Dionisio | SP-39 |  | PCG-21 |  |
| 716 | 213.7.3 | SON Automatic Neighbour Relations (ANR) List Management |  | 210d? | 2008-02-22 A | 2008-12-11 A | 100% | 2008-02-22 | 2008-12-11 | 210d? |  | finish no earlier than 2008-12-11 | S5 | 1680h | 1680h | LTE_SON-OAM | Ericsson | edwin.tse@ericsson.com | Rel-8 | Dionisio | SP-39 |  | PCG-21 |  |
| 717 | 214 | **Rel-8 LTE – Terminal Conformance Test Specification** |  | 657d? | 2007-06-01 A | 2009-12-04 A | 100% | 2007-06-01 | 2009-12-04 | 657d? |  |  | R5 | 14336h | 14336h | LTE-UEConTest |  |  | Rel-8 | Ingbert |  |  |  |  |
| 718 | 214.1 | 3G LTE – Terminal Protocol Conformance Test Specifications |  | 657d? | 2007-06-01 A | 2009-12-04 A | 100% | 2007-06-01 | 2009-12-04 | 657d? |  | finish no earlier than 2009-12-04 | R5 | 5256h | 5256h | LTE-UEConTest_SIG | NEC, Motorola | david.lecompte@nectech.fr, Jacob.John@motorola.com | Rel-8 | Ingbert |  |  |  | RP-091060 |
| 719 | 214.2 | LTE – Terminal Radio Transmission and Reception Conformance Test Specifications |  | 657d? | 2007-06-01 A | 2009-12-04 A | 100% | 2007-06-01 | 2009-12-04 | 657d? |  |  | R5 | 5256h | 5256h | LTE-UEConTest_RF | Agilent | andrea_leonardi@agilent.com | Rel-8 | Ingbert |  |  |  | RP-091059 |

Notes:
- 694: CP#42 completed. CP#40: WID updated CP-070622=>CP-080382. aka Enhanced USIM phonebook
- 695: CP#38 completed / Text3: 21.111
- 696: CP#39 completed / Text3: 31.220
- 697: CP#42 completed / Text3: 31.221
- 698: SP#33 stopped / Text3: 31.102
- 699: CP#46 work not started
- 700: CP#46 work not started / Text3: 31.320 (external interface for communication with the ME)
- 701: CP#46 work not started / Text3: 31.321 (internal interface (API))
- 702: RP#43 completed. Role model for SAE/LTE system wide project management by SA2 in SP-060166 / Text3: 36.300, 36.938
- 703: RP#39 completed / Text3: 36.201, 36.211, 36.212, 36.213, 36.214, 25.215, 25.225
- 704: RP#42 completed / Text3: 36.302, 36.304, 36.306, 36.314, 36.321, 36.322, 36.323, 36.331, 25.302, 25.304, 25.331
- 705: RP#42 completed / Text3: 36.401, 36.410, 36.411, 36.412, 36.413, 36.414, 36.420, 36.421, 36.422, 36.423, 36.424, 25.413
- 706: RP#42 completed / Text3: 36.101, 36.104, 36.113, 36.124, 36.133, 36.141, 36.942, 25.123, 25.133
- 707: RP#43 completed / Text3: 36.106, 36.143, 25.113
- 708: SP#43 completed
- 709: SP#43 completed / Text3: 32.42x, 32.44x
- 710: SP#43 completed / Text3: 32.761, 32.762, 32.763, 32.765
- 711: SP#43 completed / Text3: 32.425
- 712: SP#43 completed / Text3: 32.450, 32.451
- 713: SP#42 completed (WT UID_390007 moved to Rel-9). SP#40 updated WID SP-080064=>SP-080275.
- 714: SP#42 completed. SP#40 updated WID SP-080064=>SP-080275. SP#41 UID_390004 split to monitor 32.500 progress. / Text3: 32.500
- 715: SP#42 completed. WID updated SP-080065=>SP-080849 / Text3: 32.501, 32.502, 32.531, 32.532, 32.533
- 716: SP#42 completed / Text3: 32.511, 32.761, 32.762, 32.763, 32.765
- 717: Testing for Feature UID_20068 (LTE)
- 718: RP#46 completed / Text3: 36.521-1, 36.521-2, 36.508, 36.509, 36.523-1, 36.523-2, 36.523-3
- 719: RP#46 completed / Text3: 36.521-1, 36.521-2, 36.521-3

| ID | WBS | Task | Duration | Start | Finish | Complete | Baseline start | Baseline finish | Baseline duration | Constraint | Resources | Work | Actual work | Text1 | Text6 | Text8 | Text4 | Text5 | Text11 | Text2 | Text7 | Text9 | Text12 |
| --- | --- | --- | --- | --- | --- | --- | --- | --- | --- | --- | --- | --- | --- | --- | --- | --- | --- | --- | --- | --- | --- | --- | --- |
| 720 | 215 | **Rel-8 Improvements of the Radio Interface** | 525d? | 2007-03-05 A | 2009-03-06 A | 100% | 2007-03-05 | 2009-03-06 | 525d? |  | RP | 18152h | 18152h | RInImp8 | Rel-8 | Issam |  |  |  |  |  |  |  |
| 721 | 215.1 | UMTS 1500 MHz | 140d? | 2007-03-05 A | 2007-09-14 A | 100% | 2007-03-05 | 2007-09-14 | 140d? | finish no earlier than 2007-09-14 | R4 | 1120h | 1120h | RInImp8-UMTS1500 | Rel-8 | Issam | NTT DoCoMo | Takehiro Nakamura (nakamurata@nttdocomo.co.jp) | RP-070526 |  |  |  |  |
| 722 | 215.2 | UMTS 700 MHz FDD | 325d? | 2007-03-05 A | 2008-05-30 A | 100% | 2007-03-05 | 2008-05-30 | 325d? | finish no earlier than 2008-06-12 | R4 | 2600h | 2600h | RInImp8-UMTS700 | Rel-8 | Issam | Nokia | Tuomo Saynajakangas | RP-080260 |  |  |  |  |
| 723 | 215.3 | UMTS 2300 MHz TDD LCR | 195d? | 2007-12-17 A | 2008-09-12 A | 100% | 2007-12-17 | 2008-09-12 | 195d? | finish no earlier than 2008-09-12 | R4 | 1560h | 1560h | RInImp8-UMTS2300TDD | Rel-8 | Issam | CATT | songyuexia@datangmobile.cn | RP-080517 | PCG-21 | RP-38 |  |  |
| 724 | 215.4 | Further Improved Minimum Performance Requirements for HSDPA UE (FDD) - Two-Branch Interference Cancellation | 265d? | 2007-03-05 A | 2008-03-07 A | 100% | 2007-03-05 | 2008-03-07 | 265d? | finish no earlier than 2008-03-12 | R4 | 2120h | 2120h | RInImp8-2BIC | Rel-8 | Issam | AT&T | Marc Grant | RP-080041 |  |  |  |  |
| 725 | 215.5 | CS Voice Service over HSPA | 167d? | 2007-07-19 A | 2008-03-07 A | 100% | 2007-07-19 | 2008-03-07 | 167d? |  | R2 | 1336h | 1336h | RInImp8-CsHspa | Rel-8 | Joern | Nokia Siemens Networks | woonhee.hwang@nsn.com | RP-080042 |  | RP-37 |  |  |
| 726 | 215.6 | Performance requirements for 15 code reception with 16QAM/QPSK (FDD) | 126d? | 2007-06-11 A | 2008-03-07 A | 100% | 2007-06-11 | 2008-03-07 | 126d? | finish no earlier than 2008-06-12 | R4 | 1008h | 1008h | RInImp8-Hsdpa15codes | Rel-8 | Issam | Vodafone | tim.frost@vodafone.com | RP-080043 |  | RP-37 |  |  |
| 727 | 215.7 | UMTS 1880 MHz TDD | 126d? | 2008-09-12 A | 2009-03-06 A | 100% | 2008-09-12 | 2009-03-06 | 126d? | finish no earlier than 2009-03-09 | R4 | 1008h | 1008h | RInImp9-UMTS1880TDD | Rel-8 | Issam | CATT | Yuexia Song (songyuexia@datangmobile.cn) | RP-090044 | PCG-21 | RP-41 |  |  |
| 728 | 215.8 | Deleted - UMTS 2300 MHz FDD/TDD | 400d? | 2007-03-05 A | 2008-09-12 A | 100% | 2007-03-05 | 2008-09-12 | 400d? | finish no earlier than 2008-12-11 | R4 | 3200h | 3200h | RInImp8-UMTS2300 | Rel-8 | Issam | AT&T | Marc Grant | RP-080515 |  |  | PCG-21 | RP-41 |
| 729 | 216 | **Rel-8 Improvements of the Radio Interface - UE Conformance Testing** | 396d? | 2007-06-01 A | 2008-12-05 A | 100% | 2007-06-01 | 2008-12-05 | 396d? |  | R5 | 6256h | 6256h | RInImp-UEConTest | Rel-8 | Ingbert |  |  |  |  |  |  |  |
| 730 | 216.1 | Conformance Test Aspects – CS Voice Service over HSPA | 336d? | 2007-06-01 A | 2008-09-12 A | 100% | 2007-06-01 | 2008-09-12 | 336d? | finish no earlier than 2008-09-12 | R5 | 2688h | 2688h | RInImp8-CsHspa_UEConTest | Rel-8 | Ingbert | Huawei | baoyi@huawei.com | RP-080542 |  |  |  |  |
| 731 | 216.2 | Conformance Test Aspects – Performance requirements for 15 code reception with 16QAM/QPSK (FDD) | 195d? | 2008-03-07 A | 2008-12-05 A | 100% | 2008-03-07 | 2008-12-05 | 195d? | finish no earlier than 2008-12-05 | R5 | 1560h | 1560h | RInImp8-UEConTest_ Hsdpa15codes | Rel-8 | Ingbert | Ericsson | Mikael.Ziren@Ericsson.com | RP-080818 | PCG-21 | RP-40 |  |  |
| 732 | 217 | **Rel-8 RAN improvements** | 520d? | 2007-06-04 A | 2009-05-29 A | 100% | 2007-06-04 | 2009-05-29 | 520d? |  | RP | 29776h | 29776h | RANimp | Rel-8 |  |  |  |  |  |  |  |  |
| 733 | 217.1 | Combination of 64QAM and MIMO for HSDPA (FDD) | 205d? | 2007-06-04 A | 2008-09-12 A | 100% | 2007-06-04 | 2008-09-12 | 205d? | finish no earlier than 2008-09-12 | R1 | 1640h | 1640h | RANimp-64QamMimoHsdpa | Rel-8 | Patrick | Ericsson | Johan.Bergman@ericsson.com | RP-080518 |  |  |  |  |
| 734 | 217.2 | Improved L2 for uplink | 186d? | 2007-09-14 A | 2008-05-30 A | 100% | 2007-09-14 | 2008-05-30 | 186d? | finish no earlier than 2008-05-30 | R2 | 1488h | 1488h | RANimp-UplinkL2dataRates | Rel-8 | Joern | Ericsson | Janne.Peisa@ericsson.com | RP-080265 |  | RP-37 |  |  |
| 735 | 217.3 | Enhanced Uplink for CELL_FACH State in FDD | 321d? | 2007-09-14 A | 2008-12-05 A | 100% | 2007-09-14 | 2008-12-05 | 321d? | finish no earlier than 2008-12-12 | R2 | 2568h | 2568h | RANimp-UplinkEnhState | Rel-8 | Joern | Nokia Siemens Networks | markus.wimmer@nsn.com | RP-080804 |  | RP-37 |  |  |
| 736 | 217.4 | Enhanced UE DRX for FDD | 261d? | 2007-09-14 A | 2008-09-12 A | 100% | 2007-09-14 | 2008-09-12 | 261d? | finish no earlier than 2008-09-12 | R2 | 2088h | 2088h | RANimp-DRX | Rel-8 | Joern | Nokia | luis.barreto@nokia.com | RP-080520 |  | RP-37 |  |  |
| 737 | 217.5 | Enhancements for SRNS Relocation Procedure | 261d? | 2007-09-14 A | 2008-09-12 A | 100% | 2007-09-14 | 2008-09-12 | 261d? | finish no earlier than 2008-09-12 | R3 | 2088h | 2088h | RANimp-SrnsReloc | Rel-8 | Juha | Nokia Siemens Networks | masatoshi.nakamata@nsn.com | RP-080521 |  | RP-37 |  |  |
| 738 | 217.6 | Enhancements for FDD HSPA Evolution | 321d? | 2007-09-14 A | 2008-12-05 A | 100% | 2007-09-14 | 2008-12-05 | 321d? | finish no earlier than 2008-12-05 | R3,R2 | 2568h | 2568h | RANimp-HSPAEvo | Rel-8 | Juha | Nokia Siemens Networks | masatoshi.nakamata@nsn.com | RP-080805 |  | RP-37 |  |  |
| 739 | 217.7 | 64QAM for 1.28 Mcps TDD HSDPA | 264d? | 2007-12-04 A | 2008-12-05 A | 100% | 2007-12-04 | 2008-12-05 | 264d? | finish no earlier than 2008-12-05 | R1 | 2112h | 2112h | RANimp-64Qam1.28TDD | Rel-8 | Patrick | ZTE | zfmail@zte.com.cn | RP-080806 | PCG-21 | RP-38 |  |  |
| 740 | 217.8 | Enhanced CELL_FACH state in 1.28 Mcps TDD | 264d? | 2007-12-04 A | 2008-12-05 A | 100% | 2007-12-04 | 2008-12-05 | 264d? | finish no earlier than 2008-12-12 | R2 | 2112h | 2112h | RANimp-EnhState1.28TDD | Rel-8 | Joern | ZTE | zhang.yincheng@zte.com.cn | RP-080807 | PCG-21 | RP-38 |  |  |
| 741 | 217.9 | Continuous Connectivity for packet data users for 1.28 Mcps TDD | 321d? | 2008-03-07 A | 2009-05-29 A | 100% | 2008-03-07 | 2009-05-29 | 321d? | finish no earlier than 2009-05-29 | R1 | 2568h | 2568h | RANimp-LCRCPC | Rel-8 | Patrick | TD Tech | chenying@td-tech.com | RP-090394 | PCG-21 | RP-39 |  |  |
| 742 | 217.10 | HSPA VoIP to WCDMA/GSM CS continuity | 261d? | 2008-03-07 A | 2009-03-06 A | 100% | 2008-03-07 | 2009-03-06 | 261d? | finish no earlier than 2009-03-06 | R2 | 2088h | 2088h | RANimp-HSPAVoIP | Rel-8 | Joern | Nokia | Simone.Provvedi@nokia.com | RP-090050 | PCG-21 | RP-39 |  |  |
| 743 | 217.11 | HS-DSCH Serving Cell Change Enhancements | 196d? | 2008-03-07 A | 2008-12-05 A | 100% | 2008-03-07 | 2008-12-05 | 196d? | finish no earlier than 2008-12-12 | R2 | 1568h | 1568h | RANimp-HSDSCH | Rel-8 | Joern | Ericsson | henrik.enbuske@ericsson.com | RP-080811 | PCG-21 | RP-39 |  |  |
| 744 | 217.12 | MIMO for 1.28 Mcps TDD | 201d? | 2007-11-01 A | 2009-03-06 A | 100% | 2007-11-01 | 2009-03-06 | 201d? | finish no earlier than 2009-05-29 | R1,R4 | 1608h | 1608h | RANimp-MIMOLCR | Rel-8 | Patrick | CATT | wangke@datangmobile.cn | RP-090313 | PCG-21 | RP-40 |  |  |
| 745 | 217.13 | Dual-Cell HSDPA operation on adjacent carriers | 140d? | 2008-05-30 A | 2008-12-11 A | 100% | 2008-05-30 | 2008-12-11 | 140d? | finish no earlier than 2009-05-29 | R1,R4 | 1120h | 1120h | RANimp-DCHSDPA | Rel-8 | Patrick | Ericsson | johan.bergman@ericsson.com | RP-080814 | PCG-21 | RP-40 |  |  |

Notes:
- 720: -
- 721: SR in RP-070526. Introduction of Band XI / Text3: 25.101, 25.104, 25.133, 25.141, 25.331, 25.942, 25.306, 25.307, 34.121
- 722: SR in RP-080260. Introduction of UMTS 700 MHz (Bands XII XIV) in 25.307 / Text3: 25.101, 25.104, 25.133, 25.141, 25.331, 25.942, 25.306, 25.307, 34.121
- 723: SR in RP-080517. RP#41 completed / Text3: 25.102, 25.105, 25.113, 25.123, 25.142, 34.124, 25.306, 25.331, 34.122
- 724: SR in RP-080041.
- 725: SR in RP-080042. / Text3: 25.323, 25.331, 25.322
- 726: SR in RP-080043. / Text3: 25.101
- 727: RP#43 completed as Rel-8 / Text3: 25.102, 25.105, 25.113, 25.123, 25.142, 34.124, 25.307
- 728: SR in RP-080515. RP#41 stopped / Text3: 25.101, 25.104, 25.133, 25.141, 25.331, 25.942, 25.306, 25.307, 34.121
- 729: 05/08: Linked to Feature UID_20028 (RInImp)
- 730: SR in RP-080542. RP#41 completed. / Text3: 34.108, 34.123-1, 34.123-2, 34.123-3
- 731: RP#42 completed. SR in RP-080818. Linked to UID_370033. / Text3: 34.121-1, 34.121-2
- 732: -
- 733: SR in RP-080518. RP#41 completed / Text3: 25.308, 25.211, 25.212, 25.213, 25.306, 25.331, 25.433, 25.435, 25.423, 25.425, 25.101, 25.104, 25.141
- 734: SR in RP-080265. RP#40 completed / Text3: 25.319, 25.301, 25.306, 25.321, 25.331, 25.433, 25.435, 25.423, 25.425, 25.427
- 735: SR in RP-080804. RP#42 completed / Text3: 25.309, 25.211, 25.214, 25.321, 25.331, 25.423, 25.433
- 736: SR in RP-080520. RP#41 completed / Text3: 25.306, 25.308, 25.321, 25.331, 25.423
- 737: SR in RP-080521. RP#41 completed / Text3: 25.306, 25.308, 25.321, 25.331, 25.423, 25.433, 25.214, 25.133
- 738: SR in RP-080805. RP#42 completed. WID updated RP-070760=>RP-080830 / Text3: 25.401, 25.413, 25.420, 25.423, 25.427, 25.433, 25.446, 25.301, 25.346
- 739: SR in RP-080806. RP#42 completed / Text3: 25.102, 25.105, 25.123, 25.142, 25.201, 25.221, 25.222, 25.223, 25.224, 25.306, 25.308, 25.321, 25.331, 25.423, 25.433
- 740: SR in RP-080807. RP#42 completed / Text3: 25.123, 25.221, 25.222, 25.224, 25.301, 25.302, 25.304, 25.306, 25.308, 25.319, 25.321, 25.331, 25.401, 25.423, 25.425, 25.433, 25.435
- 741: RP#44 completed / Text3: 25.929, 25.308, 25.319
- 742: RP#43 completed / Text3: 25.331, 25.413
- 743: SR in RP-080811. RP#42 completed / Text3: 25.101, 25.104, 25.133, 25.212, 25.214, 25.308, 25.321, 25.331, 25.423, 25.433
- 744: RP#43 completed (part missing R4 performance part) / Text3: 25.201, 25.221, 25.222, 25.223, 25.224, 25.306, 25.308, 25.321, 25.331, 25.423, 25.433, 25.102, 25.105, 25.142
- 745: RP#42 completed except R4 performance part 05/09. Triggered by FS_RAN-DCHS UID_390032 / Text3: 25.101, 25.104, 25.133, 25.141, 25.211, 25.212, 25.213, 25.214, 25.215, 25.306, 25.308, 25.321, 25.331, 25.423, 25.433

| ID | WBS | Task | Duration | Start | Finish | Complete | Remaining | Baseline start | Baseline finish | Baseline duration | Total slack | Constraint | Resources | Work | Actual work | Text1 | Text6 | Text8 | Text2 | Text4 | Text7 | Text11 |
| --- | --- | --- | --- | --- | --- | --- | --- | --- | --- | --- | --- | --- | --- | --- | --- | --- | --- | --- | --- | --- | --- | --- |
| 746 | 218 | **Rel-8 RAN improvements - UE Conformance Testing** | 602d? | 2008-05-30 A | 2010-09-17 | 57% | 255.96d? | 2008-05-30 | 2010-09-17 | 602d? | 260d |  | R5 | 28391.2h | 13671.6h | RANimp-UEConTest | Rel-8 | Ingbert |  |  |  |  |
| 747 | 218.1 | Conformance Test Aspects – Combination of 64QAM and MIMO for HSDPA (FDD) | 322d? | 2008-09-12 A | 2009-12-04 A | 100% |  | 2008-09-12 | 2009-12-04 | 322d? |  | finish no earlier than 2009-12-04 | R5 | 2576h | 2576h | RANimp-UEConTest_64QamMimoHsdpa | Rel-8 | Ingbert | PCG-21 | Ericsson | RP-41 | RP-091058 |
| 748 | 218.2 | Conformance Test Aspects – Improved L2 for uplink | 341d? | 2008-05-30 A | 2009-09-18 A | 100% |  | 2008-05-30 | 2009-09-18 | 341d? |  | finish no earlier than 2009-09-18 | R5 | 2728h | 2728h | RANimp-UEConTest_UplinkL2dataRates | Rel-8 | Ingbert | PCG-21 | Ericsson | RP-40 | RP-090712 |
| 749 | 218.3 | Conformance Test Aspects – 64QAM for 1.28 Mcps TDD HSDPA | 261d? | 2008-05-30 A | 2009-05-29 A | 100% |  | 2008-05-30 | 2009-05-29 | 261d? |  | finish no earlier than 2009-05-29 | R5 | 2088h | 2088h | RANimp-UEConTest_64Qam1.28TDD | Rel-8 | Ingbert | PCG-21 | ZTE | RP-40 | RP-090415 |
| 750 | 218.4 | Conformance Test Aspects – Dual-Cell HSDPA operation on adjacent carriers | 336d? | 2008-12-05 A | 2010-03-19 | 80% | 67.2d? | 2008-12-05 | 2010-03-19 | 336d? | 390d | finish no earlier than 2010-03-19 | R5 | 2688h | 2150.4h | RANimp-UEConTest_DCHSDPA | Rel-8 | Ingbert | PCG-22 | Qualcomm Europe | RP-42 | RP-091062 |
| 751 | 218.5 | Conformance Test Aspects – Enhanced Uplink for CELL_FACH State in FDD | 266d? | 2009-03-06 A | 2010-03-12 | 40% | 159.6d? | 2009-03-06 | 2010-03-12 | 266d? | 395d | finish no earlier than 2010-03-12 | R5 | 2128h | 851.2h | RANimp-UEConTest_EnhancedRACHCellFACHState | Rel-8 | Ingbert | PCG-22 | Nokia | RP-43 | RP-091067 |
| 752 | 218.6 | Conformance Test Aspects – Receiver Type3i | 196d? | 2009-03-06 A | 2009-12-04 A | 100% |  | 2009-03-06 | 2009-12-04 | 196d? |  | finish no earlier than 2009-12-04 | R5 | 1568h | 1568h | RANimp-UEConTest_ReceiverType3i | Rel-8 | Ingbert | PCG-22 | Qualcomm Europe | RP-43 | RP-091066 |
| 753 | 218.7 | Conformance Test Aspects – Enhanced CELL_FACH State in LCR TDD | 341d? | 2009-05-30 A | 2010-09-17 | 25% | 257d? | 2009-05-30 | 2010-09-17 | 341d? | 260d | finish no earlier than 2010-09-17 | R5 | 2728h | 672h | RANimp-UEConTest_EnhancedCellFACHStateLCRTDD | Rel-8 | Ingbert | PCG-23 | CATT | RP-44 | RP-091068 |
| 754 | 218.8 | Conformance Test Aspects – 1.28 Mcps TDD Improved L2 support for high data rates | 337d? | 2009-05-29 A | 2010-09-10 | 30% | 235.9d? | 2009-05-29 | 2010-09-10 | 337d? | 265d | finish no earlier than 2010-09-10 | R5 | 2696h | 808.8h | RANimp-UEConTest_ImprovedL2LCRTDD | Rel-8 | Ingbert | PCG-23 | CATT | RP-44 | RP-091071 |
| 755 | 218.9 | Conformance Test Aspects – Continuous Connectivity for packet data users for 1.28 Mcps TDD | 261d? | 2009-09-18 A | 2010-09-17 | 5% | 247.95d? | 2009-09-18 | 2010-09-17 | 261d? | 260d | finish no earlier than 2010-09-17 | R5 | 2088h | 104.4h | RANimp-UEConTest_CPCLCRTDD | Rel-8 | Ingbert | PCG-23 | ZTE | RP-45 | RP-091077 |
| 756 | 218.10 | Conformance Test Aspects – MIMO for 1.28 Mcps TDD | 186d? | 2009-09-18 A | 2010-06-04 | 5% | 176.7d? | 2009-09-18 | 2010-06-04 | 186d? | 335d | finish no earlier than 2010-06-04 | R5 | 1488h | 74.4h | RANimp-UEConTest_MIMOLCRTDD | Rel-8 | Ingbert | PCG-23 | ZTE | RP-45 | RP-091078 |
| 757 | 218.11 | Conformance Test Aspects – HS-DSCH Serving Cell Change Enhancements | 126d? | 2009-09-18 A | 2010-03-12 | 5% | 119.7d? | 2009-09-18 | 2010-03-12 | 126d? | 395d | finish no earlier than 2010-03-12 | R5 | 1008h | 50.4h | HSDSCH_UEConTest | Rel-8 | Ingbert | PCG-23 | Qualcomm Europe | RP-45 | RP-091079 |
| 758 | 219 | 3.84 Mcps TDD MBSFN Integrated Mobile Broadcast | 395d? | 2007-06-04 A | 2008-12-05 A | 100% |  | 2007-06-04 | 2008-12-05 | 395d? |  |  | R1 | 3160h | 3160h | MBSFN-DOB | Rel-8 | Patrick |  | Ericsson |  | RP-080218 |
| 759 | 220 | Conformance Test Aspects – 3.84 Mcps TDD MBSFN Integrated Mobile Broadcast | 211d? | 2009-05-30 A | 2010-03-19 | 95% | 10.55d? | 2009-05-30 | 2010-03-19 | 211d? | 390d | finish no earlier than 2010-03-19 | R5 | 1688h | 1603.6h | MBSFN_IMB_UEConTest | Rel-8 | Ingbert | PCG-23 | IPwireless | RP-44 | RP-091072 |
| 760 | 221 | GERAN support for GERAN - 3G Long Term Evolution interworking | 641d? | 2006-09-08 A | 2009-02-20 A | 100% |  | 2006-09-08 | 2009-02-20 | 641d? |  | finish no earlier than 2009-02-20 | GP | 5128h | 5128h | GELTE | Rel-8 | Paolo |  | Nokia, Nokia Siemens Networks |  |  |
| 761 | 222 | U-TDOA Enhancement | 131d? | 2007-05-18 A | 2007-11-16 A | 100% |  | 2007-05-18 | 2007-11-16 | 131d? |  | finish no earlier than 2007-05-18 | GP | 1048h | 1048h | GUTEN | Rel-8 | Paolo |  | TruePosition |  |  |
| 762 | 223 | **GAN Enhancements** | 604.2d? | 2007-05-15 A | 2009-09-04 A | 100% |  | 2007-05-15 | 2009-09-04 | 604.2d? |  |  | GP | 9432h | 9432h | GANENH | Rel-8 | Paolo |  | T-Mobile |  |  |
| 763 | 223.1 | Update to GAN specifications | 126d? | 2007-08-31 A | 2008-02-22 A | 100% |  | 2007-08-31 | 2008-02-22 | 126d? |  | finish no earlier than 2008-02-22 | GP | 1008h | 1008h | GANENH-SPEC | Rel-8 | Paolo |  | T-Mobile |  |  |
| 764 | 223.2 | Update TS 51.010 Mobile Station (MS) Conformance Specification for GAN Enhancements | 526d? | 2007-05-15 A | 2009-09-04 A | 100% |  | 2007-05-15 | 2009-09-04 | 526d? |  | finish no earlier than 2009-09-04 | G3new | 4208h | 4208h | GANENH-MStest | Rel-8 | Ingbert |  | T-Mobile |  |  |
| 765 | 224 | **AoIP (A-interface over IP)** | 2335d? | 2000-01-03 A | 2008-12-11 A | 100% |  | 2000-01-03 | 2008-12-11 | 2335d? |  |  | GP,S4,C4,C1,C3 | 41412.1h | 41412.1h | AoIP | Rel-8 | Paolo | PCG-21 | China Mobile, Ericsson |  |  |
| 766 | 224.1 | GERAN aspects of AoIP | 2321d? | 2000-01-03 A | 2008-11-21 A | 100% |  | 2000-01-03 | 2008-11-21 | 2321d? |  | finish no earlier than 2008-11-21 | GP | 18560h | 18560h | AoIP | Rel-8 | Paolo | PCG-21 | China Mobile, Ericsson | SP-40 |  |
| 767 | 224.2 | Media Requirements for CS over IP based User Plane | 267d? | 2007-12-05 A | 2008-12-11 A | 100% |  | 2007-12-05 | 2008-12-11 | 267d? |  | finish no earlier than 2008-12-11 | S4 | 1996.09h | 1996.09h | AoIP-CSoIP | Rel-8 | Paolo | PCG-21 | China Mobile, Ericsson | SP-40 |  |
| 768 | 224.3 | Core Network Impacts for A-Interface User Plane over IP | 136d? | 2008-05-30 A | 2008-12-05 A | 100% |  | 2008-05-30 | 2008-12-05 | 136d? |  | start no earlier than 2008-05-30 | C4 | 1088h | 1088h | AoIP-CN | Rel-8 | Kimmo | PCG-21 | Ericsson | CP-40 |  |
| 769 | 224.4 | Core Network Impacts for A-Interface User Plane over IP | 68d? | 2008-05-30 A | 2008-12-05 A | 100% |  | 2008-05-30 | 2008-12-05 | 68d? |  | finish no earlier than 2008-12-05 | C1 | 544h | 544h | AoIP-CN | Rel-8 | Frederic | PCG-21 | Ericsson | CP-40 |  |
| 770 | 224.5 | Core Network Impacts for A-Interface User Plane over IP | 68d? | 2008-05-30 A | 2008-12-05 A | 100% |  | 2008-05-30 | 2008-12-05 | 68d? |  | finish no earlier than 2008-12-05 | C3 | 544h | 544h | AoIP-CN | Rel-8 | Gwiho | PCG-21 | Ericsson | CP-40 |  |
| 771 | 225 | New multicarrier BTS class | 261d? | 2007-08-31 A | 2008-08-29 A | 100% |  | 2007-08-31 | 2008-08-29 | 261d? |  | finish no earlier than 2008-08-29 | G1 | 2088h | 2088h | MCBTS | Rel-8 | Paolo |  | Alcatel-Lucent |  |  |

Notes:
- 746: Linked to Feature UID_20029 (RANimp)
- 747: RP#46 completed / Text3: 34.108, 34.121-1, 34.121-2, 34.123-1, 34.123-2 / Text5: leif.mattisson@ericsson.com
- 748: RP#45 completed. Testing for UID_370036 / Text3: 34.108, 34.123-1, 34.123-2, 34.123-3 / Text5: leif.mattisson@ericsson.com
- 749: RP#44 completed. Testing for UID_380075 / Text3: 34.108, 34.122, 34.123-1, 34.123-2, 34.123-3 / Text5: ma.zijiang@zte.com.cn
- 750: RP#46 completion 12/09 (was 09/09)=>03/10. Testing for UID_400052 / Text3: 34.108, 34.121-1, 34.121-2, 34.123-1, 34.123-2, 34.123-3 / Text5: Shubhang Vora (svora@qualcomm.com)
- 751: Testing for UID_370037 / Text3: 34.108, 34.121-1, 34.121-2, 34.123-1, 34.123-2, 34.123-3 / Text5: jarkko.hellsten@nokia.com
- 752: RP#46 completed. Testing for Receiver Type3i in 25.101 UE radio Tx and Rx FDD / Text3: 34.108, 34.121-1, 34.121-2 / Text5: Ashok Kumar Narayanaswamy (anarayan@qualcomm.com)
- 753: Testing for UID_380076 / Text3: 34.108, 34.123-1, 34.123-2, 34.123-3 / Text5: Xiaozhong Chen (chenxiaozhong@datangmobile.cn)
- 754: Testing for Rel-7 UID_340039 Improved L2 support for high data rates and Rel-8 UID_370036 Improved L2 for uplink / Text3: 34.108, 34.123-1, 34.123-2, 34.123-3 / Text5: Xiaozhong Chen (chenxiaozhong@datangmobile.cn)
- 755: Testing for UID_390028 / Text3: 34.108, 34.123-1, 34.123-2, 34.123-3 / Text5: He Huang (huang.he4@zte.com.cn)
- 756: Testing for UID_400050 / Text3: 34.108, 34.123-1, 34.123-2, 34.123-3 / Text5: He Huang (huang.he4@zte.com.cn)
- 757: Testing for UID_390030 / Text3: 34.108, 34.121-1, 34.121-2, 34.123-1, 34.123-2, 34.123-3 / Text5: Shubhang Vora (svora@qualcomm.com)
- 758: RP#42 completed. WID updated RP-070493=>RP-081124 (changed WI title "MBSFN Downlink Optimized Broadcast (DOB) 3.84 Mcps TDD" => "3.84Mcps TDD MBSFN Integrated Mobile Broadcast"). RP#39 SR in RP-080218. / Text3: 25.102, 25.105, 25.123, 25.201, 25.221, 25.222, 25.223, 25.224, 25.304, 25.306, 25.331, 25.346, 25.402, 25.433 / Text5: Lars.Lindbom@ericsson.com
- 759: RP#46 completion 12/09=>03/10. Testing for Rel-8 MBSFN-DOB UID_360008 / Text3: 34.108, 34.122, 34.123-1, 34.123-2, 34.123-3 / Text5: Phil Young (pyoung@ipwireless.com)
- 760: GP#41 completed (MS conformance testing open) / Text3: 24.008, 43.055, 43.129, 43.246, 44.018, 44.060, 45.002, 45.008, 45.010, 48.008, 48.018, 51.010 / Text5: sergio.parolari@nsn.com, vlora.rexhepi@nokia.com
- 761: GP#36 completed U-TDOA (Uplink Time Difference of Arrival) / Text3: 43.059, 45.008, 48.071 / Text5: Terry Brooks (terri.brooks@trueposition.com)
- 762: GP#37 completed. GP#43 completed Testing / Text5: mohammed.versi@t-mobile.com
- 763: GP#37 completed / Text3: 43.318, 44.318 / Text5: mohammed.versi@t-mobile.com
- 764: GP#43 completed / Text3: 51.010 / Text5: mohammed.versi@t-mobile.com
- 765: GP#40/TSG#42 completed . Triggered by TR 43.903 Study on A-interface over IP (AINTIP) UID_50589. / Text5: wangshuaiyu@chinamobile.com, paul.schliwa-bertling@ericsson.com
- 766: GP#40 completed. GP#39 updated WID GP-080901=>GP-081362. / Text3: 48.001, 48.002, 48.008, 48.020, 49.008, 48.103 / Text5: wangshuaiyu@chinamobile.com, paul.schliwa-bertling@ericsson.com
- 767: SP#42 completed / Text3: 26.102, 26.103, 26.202 / Text5: Karl.Hellwig@Ericsson.com
- 768: CP#42 completed. Updated WID CP-080278=>CP-080722 / Text3: 23.205, 23.153, 23.231, 29.232 / Text5: philip.hodges@ericsson.com
- 769: CP#42 completed. Updated WID CP-080278=>CP-080722 / Text3: 23.009 / Text5: philip.hodges@ericsson.com
- 770: CP#42 completed. Updated WID CP-080278=>CP-080722 / Text3: 29.007 / Text5: philip.hodges@ericsson.com
- 771: GP#39 completed / Text3: 45.005, 45.050, 51.021 / Text5: thomas.bitzer@alcatel-lucent.de

| ID | WBS | Task | Type | Duration | Start | Finish | Complete | Remaining | Baseline start | Baseline finish | Baseline duration | Total slack | Constraint | Resources | Work | Actual work | Text1 | Text4 | Text6 | Text8 | Text11 | Text2 | Text3 | Text7 | Text12 | Text9 |
| --- | --- | --- | --- | --- | --- | --- | --- | --- | --- | --- | --- | --- | --- | --- | --- | --- | --- | --- | --- | --- | --- | --- | --- | --- | --- | --- |
| 772 | 226 | **Support for Additional Navigation Satellite Systems (ANSS) for LCS** |  | 150d? | 2008-05-16 A | 2008-12-11 A | 100% |  | 2008-05-16 | 2008-12-11 | 150d? |  |  | S1,G2 | 3384h | 3384h | ANSS | Qualcomm Europe | Rel-8 | Paolo | RP-080813 |  |  |  |  |  |
| 773 | 226.1 | Stage 1 for ANSS for LCS |  | 1d? | 2008-12-11 A | 2008-12-11 A | 100% |  | 2008-12-11 | 2008-12-11 | 1d? |  | start no earlier than 2008-12-11 | S1 | 8h | 8h | ANSS |  | Rel-8 | Alain |  | PCG-22 | 22.071 | SP-42 |  |  |
| 774 | 226.2 | Support for Additional Navigation Satellite Systems (ANSS) for LCS |  | 136d? | 2008-05-16 A | 2008-11-21 A | 100% |  | 2008-05-16 | 2008-11-21 | 136d? |  | start no earlier than 2008-05-16 | G2 | 1088h | 1088h | ANSS | Qualcomm Europe | Rel-8 | Paolo |  |  | 43.059, 44.031, 49.031, 44.071, 48.031, 51.010 |  |  |  |
| 775 | 226.3 | Support for Additional Navigation Satellite Systems (ANSS) for LCS |  | 136d? | 2008-05-30 A | 2008-12-05 A | 100% |  | 2008-05-30 | 2008-12-05 | 136d? |  | finish no earlier than 2008-12-08 | R2 | 1088h | 1088h | RANimp-ANSS | Qualcomm Europe | Rel-8 | Joern | RP-080813 | PCG-21 | 25.305, 25.306, 25.331, 25.413, 25.423, 25.433, 25.453 | RP-40 |  |  |
| 776 | 227 | **Conformance testing for the Latency Reductions feature** |  | 532d? | 2008-02-22 A | 2010-03-05 | 97% | 17.84d? | 2008-02-22 | 2010-03-05 | 532d? | 400d |  | G1, G3new | 10592h | 10236.4h | CTLATRED | Ericsson | Rel-8 | Paolo |  | PCG-21 |  |  |  |  |
| 777 | 227.1 | MS conformance testing for the Latency Reductions feature |  | 532d? | 2008-02-22 A | 2010-03-05 | 95% | 26.6d? | 2008-02-22 | 2010-03-05 | 532d? | 400d | finish no earlier than 2010-03-05 | G3new | 4248h | 4035.2h | CTLATRED-MStest | Ericsson | Rel-8 | Ingbert |  | PCG-21 | 51.010 |  |  |  |
| 778 | 227.2 | BTS conformance testing for the Latency Reductions feature |  | 261d? | 2008-02-22 A | 2009-02-20 A | 100% |  | 2008-02-22 | 2009-02-20 | 261d? |  | finish no earlier than 2009-02-20 | G1 | 2088h | 2088h | CTLATRED-BTStest | Ericsson | Rel-8 | Paolo |  | PCG-21 | 51.021 |  |  |  |
| 779 | 228 | MS conformance testing of changes introduced by WI “Support of Packet-switched Handover for GERAN A/Gb mode” |  | 196d? | 2008-02-22 A | 2008-11-21 A | 100% |  | 2008-02-22 | 2008-11-21 | 196d? |  | finish no earlier than 2008-11-21 | G3new | 1568h | 1568h | PSHCT-MStest | Rohde & Schwarz | Rel-8 | Ingbert |  | PCG-21 | 51.010 |  |  |  |
| 780 | 229 | (Small) Technical Enhancements and Improvements for Rel-8 |  | 509d? | 2007-01-01 A | 2008-12-11 A | 100% |  | 2007-01-01 | 2008-12-11 | 509d? |  | finish no earlier than 2008-12-11 | All | 4072h | 4072h | TEI8 | ALL | Rel-8 |  |  |  |  |  |  |  |
| 781 | 230 | Test - (Small) Technical Enhancements and Improvements for Rel-8 |  | 672d? | 2007-03-07 A | 2010-12-24 | 60% | 268.8d? | 2007-03-07 | 2010-12-24 | 672d? | 190d | finish no earlier than 2010-12-24 | R5,G3new | 5376h | 3225.6h | TEI8_Test | ALL | Rel-8 | Ingbert |  | PCG-21 |  | RP-40 |  |  |
| 782 | 231 | **Deleted - All-IP Network** |  | 448d? | 2004-06-28 A | 2006-03-15 A | 100% |  | 2004-06-28 | 2006-03-15 | 448d? |  |  | S1 | 7168h | 7168h | AIPN | NTT DoCoMo | Rel-8 | Alain |  |  |  |  | SP-38 |  |
| 783 | 231.1 | Deleted - Stage 1 |  | 448d? | 2004-06-28 A | 2006-03-15 A | 100% |  | 2004-06-28 | 2006-03-15 | 448d? |  | finish no earlier than 2006-03-15 | S1 | 3584h | 3584h | AIPN | NTT DoCoMo | Rel-8 | Alain |  |  | 22.258 |  | SP-38 |  |
| 784 | 232 | Deleted - was Rel7 - LCS for 3GPP Interworking WLAN | milestone | 0d? | 2007-09-28 A | 2007-09-28 A | 100% |  | 2007-09-28 | 2007-09-28 | 0d? |  | start no earlier than 2007-09-28 | S2 |  |  | LCS4_IWLAN | LG Electronics | Rel-8 | Maurice |  |  | 23.234, 23.271, 23.167 |  | SP-35 |  |
| 785 | 233 | Deleted - never approved- FBI Phase 2 | milestone | 0d | 2007-09-28 A | 2007-09-28 A | 100% |  | 2007-09-28 | 2007-09-28 | 0d |  | start no earlier than 2007-09-28 | S2 |  |  | FBI2 | Nokia Siemens Networks | Rel-8 | Maurice |  |  |  |  | SP-38 |  |
| 786 | 234 | Deleted -Enhancements to BS30 Bearer service for Videotelephony | milestone | 0d? | 2007-03-15 A | 2007-03-15 A | 100% |  | 2007-03-15 | 2007-03-15 | 0d? |  | finish no earlier than 2007-03-15 | S1 |  |  | BS30 |  | Rel-8 | Alain |  |  | 22.002, 22.004, 22.101, 22.105, 24.008 |  | SP-38 |  |
| 787 | 235 | Deleted - IMS Enhancements Rel-8 |  | 75d? | 2007-09-03 A | 2007-12-14 A | 100% |  | 2007-09-03 | 2007-12-14 | 75d? |  |  | S1 | 600h | 600h | IMS8 | Telecom Italia | Rel-8 | Alain |  |  |  | SP-37 | SP-38 |  |
| 788 | 236 | Deleted - MS conformance testing of Support of Conversational Services in A/Gb mode via the PS domain |  | 401d? | 2008-02-25 A | 2009-09-04 A | 100% |  | 2008-02-25 | 2009-09-04 | 401d? |  | finish no earlier than 2009-09-04 | G3new | 3208h | 3208h | SCSAGBCT-MStest | Nokia | Rel-8 | Ingbert |  | PCG-21 | 51.010 |  | GP-43 | PCG-23 |
| 789 | 237 | Release 8 Studies | milestone | 0d? | 2008-03-20 | 2008-03-20 |  |  | 2008-03-20 | 2008-03-20 | 0d? | 912d | finish no earlier than 2008-03-20 | CP,GP,RP,SP |  |  |  |  | Rel-8 |  |  |  |  |  |  |  |
| 790 | 238 | Study on Customised Alerting Tone (CAT) Requirements |  | 245d? | 2005-10-07 A | 2006-09-14 A | 100% |  | 2005-10-07 | 2006-09-14 | 245d? |  | start no earlier than 2005-10-07 | S1 | 1960h | 1960h | FS_CAT | China Mobile | Rel-8 | Alain |  |  | 22.982 |  |  |  |
| 791 | 239 | Study on Facilitating Machine to Machine Communication in GSM and UMTS (M2M) |  | 350d? | 2005-11-04 A | 2007-03-08 A | 100% |  | 2005-11-04 | 2007-03-08 | 350d? |  | finish no earlier than 2006-06-16 | S1 | 2800h | 2800h | FS_M2M | Siemens | Rel-8 | Alain |  |  | 22.868 |  |  |  |
| 792 | 240 | Study on Network Composition |  | 526d? | 2005-12-07 A | 2007-12-12 A | 100% |  | 2005-12-07 | 2007-12-12 | 526d? |  | finish no earlier than 2006-09-27 | S1 | 4208h | 4208h | FS_NetComp | Nokia Siemens Networks | Rel-8 | Alain |  |  | 22.980 |  |  |  |
| 793 | 241 | Study on Requirements of IMS Multimedia Conferencing |  | 330d? | 2006-06-08 A | 2007-09-12 A | 100% |  | 2006-06-08 | 2007-09-12 | 330d? |  | finish no earlier than 2007-03-21 | S1 | 2640h | 2640h | FS_IMSconf | China Mobile | Rel-8 | Alain |  |  | 22.948 |  |  |  |
| 794 | 242 | Study on support of a Public Warning System |  | 140d? | 2007-09-03 A | 2008-03-14 A | 100% |  | 2007-09-03 | 2008-03-14 | 140d? |  |  | S1 | 1120h | 1120h | FS_PWS | T-Mobile | Rel-8 | Alain |  |  | 22.968 |  |  |  |
| 795 | 243 | Study on Paging Permission with Access Control |  | 256d? | 2006-09-28 A | 2007-09-20 A | 100% |  | 2006-09-28 | 2007-09-20 | 256d? |  | finish no earlier than 2007-09-20 | S1 | 2048h | 2048h | FS_PPAC | NTT DoCoMo | Rel-8 | Alain |  |  | 22.908 |  |  |  |
| 796 | 244 | Study on Non 3GPP access NSP |  | 392d? | 2006-12-06 A | 2008-06-05 A | 100% |  | 2006-12-06 | 2008-06-05 | 392d? |  | finish no earlier than 2007-11-19 | S1 | 3136h | 3136h | FS_N3GtoNSP | Telefonica O2 | Rel-8 | Alain |  |  | 22.912 |  |  |  |
| 797 | 245 | Study on Value Added Services for Short Message Service |  | 263d? | 2006-12-06 A | 2007-12-07 A | 100% |  | 2006-12-06 | 2007-12-07 | 263d? |  | finish no earlier than 2007-12-07 | S1 | 2104h | 2104h | FS_VAS4SMS | China Mobile | Rel-8 | Alain |  |  | 22.942 |  |  |  |
| 798 | 246 | Study on Service continuity between mobile and WLAN networks |  | 262d? | 2006-12-06 A | 2007-12-06 A | 100% |  | 2006-12-06 | 2007-12-06 | 262d? |  | finish no earlier than 2008-12-25 | S1 | 2096h | 2096h | FS_SMLSWLAN | BT | Rel-8 | Alain |  |  | 22.937 |  |  |  |
| 799 | 247 | Study on Services Alignment and Migration |  | 331d? | 2006-12-06 A | 2008-03-12 A | 100% |  | 2006-12-06 | 2008-03-12 | 331d? |  | finish no earlier than 2007-09-20 | S1 | 2648h | 2648h | FS_ServAl | China Mobile | Rel-8 | Alain |  |  | 22.983 | SP-37 |  |  |

Notes:
- 772: GP#40 completed. Align with RANimp-ANSS ongoing work item. GP#40 WID updated GP-080776=>GP-081784 (Conformance testing moved to A-GNSS WID) / Text5: Mungal Dhanda
- 773: SP#42 completed by 22.071 CR0077
- 774: GP#40 completed. Align with RANimp-ANSS ongoing work item. GP#40 WID updated GP-080776=>GP-081784 (Conformance testing moved to A-GNSS WID) / Text5: Mungal Dhanda
- 775: SR in RP-080813. RP#42 WI closed at 95%. GERAN leading the work / considers performance requirements for Rel-9 / Text5: Etienne Chaponniere (echaponn@qualcomm.com)
- 776: GP#41 completion 09/09=>11/09 / Text5: mats.y.samuelsson@ericsson.com, hakan.e.grunditz@ericsson.com
- 777: GP#44 completion 11/09=>03/10 / Text5: hakan.e.grunditz@ericsson.com
- 778: GP#41 completed / Text5: mats.y.samuelsson@ericsson.com
- 779: GP#40 completed / Text5: Franz.Segerer@ROHDE-SCHWARZ.COM
- 780: SP#42 completed
- 781: -
- 782: SP#38 stopped. 25/07/08 Moved UID_31059 Study on All-IP Network (FS_AIPN/was AIPFS ) to Rel-7 out of the stopped Rel-8 Feature UID_31067 Deleted - All-IP Network (AIPN) / Text5: c.masyu@nttdocomo.co.jp
- 783: 22.258 withdrawn, superseded by 22.278 (UID 320022). SP#38 stopped / Text5: c.masyu@nttdocomo.co.jp
- 784: SP-35 stopped / Text5: dhshim@lge.com
- 785: SP#38 stopped
- 786: SP#38 stopped (no support) / Text5: andre.jarvis@three.co.uk
- 787: SP#38 stopped
- 788: GP#43 work stopped/abandoned (completion 0%) / Text5: arsi.heino@nokia.com
- 789: -
- 790: Spin-off WID UID_370028 under Feature CAT UID_340029 / Text5: fenglingjuan@chinamobile.com
- 791: SP#35 completed. Spin-off SA3 SID UID_370053. SP#40 Spin-off new Feature UID_410030 (NIMTC) / Text5: Juergen Merkel
- 792: SP#38 completed / Text5: Joerg Swetina (joerg.swetina@nw.neclab.eu)
- 793: SP#37 completed. Spin-off New Feature UID_370026 (VAS4SM) / Text5: zhengjianping@chinamobile.com
- 794: SP#39 completed. Spin-off Rel-9 Feature UID_380057 (PWS) / Text5: mark.younge@t-mobile.com
- 795: SP#37 completed. Spin-off new Feature UID_370084 (PPACR) / Text5: noguchi@nttdocomo.co.jp
- 796: SP#38 completed. Spin-off New Feature UID_380062 (N3GTONSP). SP#40 WID updated SP-060930=>SP-080318. TR re-approved with new # 22.812=>22.912 / Text5: chris.friel@o2.com
- 797: SP#38 completed. Spin-off New Feature UID_370026 (VAS4SM) / Text5: wubin@chinamobile.com
- 798: SP#38 completed / Text5: mike.meyerstein@bt.com
- 799: SP#39 completed. Spin-off Feature UID_330017 (ServAl) / Text5: fenglingjuan@chinamobile.com

| ID | WBS | Task | Duration | Start | Finish | Complete | Remaining | Baseline start | Baseline finish | Baseline duration | Total slack | Constraint | Resources | Work | Actual work | Text1 | Text4 | Text5 | Text6 | Text8 | Text3 | Text2 | Text7 | Text11 | Text9 | Text12 |
| --- | --- | --- | --- | --- | --- | --- | --- | --- | --- | --- | --- | --- | --- | --- | --- | --- | --- | --- | --- | --- | --- | --- | --- | --- | --- | --- |
| 800 | 248 | **Study on 3GPP System Architecture Evolution** | 1115d? | 2004-12-03 A | 2009-03-12 A | 100% |  | 2004-12-03 | 2009-03-12 | 1115d? |  |  | S2,S3 | 23456h | 23456h | FS_SAE | Vodafone | Chris Pudney | Rel-8 | Maurice |  |  |  |  |  |  |
| 801 | 248.1 | Stage 2 Interim conclusion for RAN Work to start | 990d? | 2004-12-03 A | 2008-09-18 A | 100% |  | 2004-12-03 | 2008-09-18 | 990d? |  | finish no earlier than 2005-09-23 | S2 | 7920h | 7920h | FS_SAE | Vodafone | Chris Pudney | Rel-8 | Maurice | 23.882 |  |  |  |  |  |
| 802 | 248.2 | Stage 2 study on 3GPP architectural development | 704d? | 2006-01-09 A | 2008-09-18 A | 100% |  | 2006-01-09 | 2008-09-18 | 704d? |  | finish no earlier than 2007-09-28 | S2 | 5632h | 5632h | FS_SAE | Vodafone | Chris Pudney | Rel-8 | Maurice | 23.882 |  |  |  |  |  |
| 803 | 248.3 | Security study for Inter-access mobility between non-3GPP and 3GPP system | 334d? | 2007-09-03 A | 2009-03-12 A | 100% |  | 2007-09-03 | 2009-03-12 | 334d? |  | finish no earlier than 2009-03-12 | S3 | 2672h | 2672h | FS_SAE | Nokia | dajiang.zhang@nokia.com | Rel-8 | Dionisio | 33.821, 33.822 |  |  |  |  |  |
| 804 | 249 | Study on Stage 2 aspects of IMS Service Brokering | 589d? | 2006-06-19 A | 2008-09-18 A | 100% |  | 2006-06-19 | 2008-09-18 | 589d? |  | finish no earlier than 2008-09-18 | S2 | 4712h | 4712h | FS_ISB_ST2 | Telcordia | raquel@research.telcordia.com | Rel-8 | Maurice | 23.810 |  |  |  |  |  |
| 805 | 250 | Study on IMS utilizing multicast bearer services | 447d? | 2006-03-22 A | 2007-12-06 A | 100% |  | 2006-03-22 | 2007-12-06 | 447d? |  | finish no earlier than 2007-12-03 | S2 | 3576h | 3576h | FS_MLTICAST-IMS | Nokia Siemens Networks |  | Rel-8 | Maurice | 23.847 |  |  |  |  |  |
| 806 | 251 | Study on Mobility between 3GPP-WLAN Interworking and 3GPP Systems | 393d? | 2007-03-20 A | 2008-09-18 A | 100% |  | 2007-03-20 | 2008-09-18 | 393d? |  | finish no earlier than 2008-09-18 | S2 | 3144h | 3144h | FS_SM3GWLAN | Orange |  | Rel-8 | Maurice | 23.827 withdrawn |  |  |  |  |  |
| 807 | 252 | Study on Multimedia Session Continuity | 291d? | 2007-04-26 A | 2008-06-05 A | 100% |  | 2007-04-26 | 2008-06-05 | 291d? |  | finish no earlier than 2008-06-05 | S2 | 2328h | 2328h | FS_MMSC | LG Electronics |  | Rel-8 | Maurice | 23.893 |  |  |  |  |  |
| 808 | 253 | **Study on centralized IMS service control** | 363d? | 2006-10-23 A | 2008-03-12 A | 100% |  | 2006-10-23 | 2008-03-12 | 363d? |  |  | S2,S1 | 7952h | 7952h | FS_ICS | Ericsson | peter.bleckert@ericsson.com | Rel-8 | Alain |  | PCG-21 | SP-38 |  |  |  |
| 809 | 253.1 | Study on centralized IMS services requirements | 268d? | 2007-03-05 A | 2008-03-12 A | 100% |  | 2007-03-05 | 2008-03-12 | 268d? |  | start no earlier than 2007-03-05 | S1 | 2144h | 2144h | FS_ICS-S1 | Ericsson | peter.bleckert@ericsson.com | Rel-8 | Alain | 22.892 |  | SP-37 |  |  |  |
| 810 | 253.2 | Study on centralized IMS services control | 363d? | 2006-10-23 A | 2008-03-12 A | 100% |  | 2006-10-23 | 2008-03-12 | 363d? |  | finish no earlier than 2008-02-21 | S2 | 2904h | 2904h | FS_IMS_CSC | Alcatel-Lucent | Andy Bennett (andybennett@alcatel-lucent.com) | Rel-8 | Maurice | 23.892 |  |  |  |  |  |
| 811 | 254 | Study on Architecture of IMS based Customized Alerting Tone (CAT) | 208d? | 2007-12-04 A | 2008-09-18 A | 100% |  | 2007-12-04 | 2008-09-18 | 208d? |  | finish no earlier than 2008-09-08 | S2 | 1664h | 1664h | FS_CAT-St2 | China Mobile | WANG, Jing (wangjing@chinamobilecom) | Rel-8 | Maurice | 23.872 | PCG-21 | SP-38 |  |  |  |
| 812 | 255 | Study on Home (e)NodeB Security | 321d? | 2007-12-20 A | 2009-03-12 A | 100% |  | 2007-12-20 | 2009-03-12 | 321d? |  | finish no earlier than 2009-03-10 | S3 | 2568h | 2568h | FS_HNB_Sec | Huawei | yangyanmei@huawei.com | Rel-8 | Dionisio | 33.820 | PCG-21 | SP-38 |  |  |  |
| 813 | 256 | Study on Transferring of emergency call data – in-band modem solution | 265d? | 2006-12-07 A | 2007-12-12 A | 100% |  | 2006-12-07 | 2007-12-12 | 265d? |  | finish no earlier than 2008-09-18 | S4 | 2120h | 2120h | eCALLIBMS | Airbiquity | lhong@airbiquity.com | Rel-8 | Paolo | 26.967 |  |  |  |  |  |
| 814 | 257 | Study on Element Operations Systems Function (EOSF) definition | 266d? | 2007-06-07 A | 2008-06-12 A | 100% |  | 2007-06-07 | 2008-06-12 | 266d? |  | finish no earlier than 2008-12-11 | S5 | 2128h | 2128h | OAM7-NIM- EOSF | China Mobile | LI, Jian | Rel-8 | Dionisio | 32.819 |  |  |  |  |  |
| 815 | 258 | Study on SA5 MTOSI XML Harmonization | 351d? | 2006-05-10 A | 2007-09-12 A | 100% |  | 2006-05-10 | 2007-09-12 | 351d? |  | finish no earlier than 2007-12-14 | S5 | 2808h | 2808h | OAM8-NIM-XML | Nortel | jduguay@nortel.com | Rel-8 | Dionisio | 32.818 |  |  |  |  |  |
| 816 | 259 | Study on Common Profile Storage (CPS) Framework of User Data for network services and management | 244d? | 2006-07-03 A | 2007-06-07 A | 100% |  | 2006-07-03 | 2007-06-07 | 244d? |  | finish no earlier than 2007-06-07 | S5 | 1952h | 1952h | OAM7-CPS | T-Mobile | istvan.aba@t-mobile.at | Rel-8 | Dionisio | 32.808 |  |  |  |  |  |
| 817 | 260 | Study on Management for LTE and SAE | 526d? | 2006-12-07 A | 2008-12-11 A | 100% |  | 2006-12-07 | 2008-12-11 | 526d? |  | finish no earlier than 2008-12-11 | S5 | 4208h | 4208h | FS_OAM_LTE_SAE | Ericsson | PETERSEN, Robert | Rel-8 | Dionisio | 32.816 |  |  |  |  |  |
| 818 | 261 | Study on Charging Aspects of 3GPP System Evolution | 179d? | 2007-04-02 A | 2007-12-06 A | 100% |  | 2007-04-02 | 2007-12-06 | 179d? |  | finish no earlier than 2007-12-06 | S5 | 1432h | 1432h | FS_SAEcharg | Nokia Siemens Networks | GÖRMER, Gerald | Rel-8 | Dionisio | 32.820 |  |  |  |  |  |
| 819 | 262 | Study on AS-MRFC media server control protocol | 583d? | 2006-03-22 A | 2008-06-13 A | 100% |  | 2006-03-22 | 2008-06-13 | 583d? |  | finish no earlier than 2008-06-13 | C1 | 4664h | 4664h | MRFC | HP | mark.syrett@hp.com | Rel-8 | Frederic | 24.880 |  |  |  |  |  |
| 820 | 263 | Study on IMS Restoration Procedures | 310d? | 2007-03-26 A | 2008-05-30 A | 100% |  | 2007-03-26 | 2008-05-30 | 310d? |  | finish no earlier than 2008-05-30 | C4 | 2480h | 2480h | FS_IMS_RP | Ericsson | german.blanco@ericsson.com | Rel-8 | Kimmo | 23.820 |  |  |  |  |  |
| 821 | 264 | Study on IMS Application Server Service Data Descriptions for AS interoperability | 261d? | 2007-09-14 A | 2008-09-12 A | 100% |  | 2007-09-14 | 2008-09-12 | 261d? |  | finish no earlier than 2008-09-12 | C4 | 2088h | 2088h | FS_IMS_ASIO | Alcatel-Lucent | Jean-Jacques Trottin | Rel-8 | Kimmo | 29.864 |  |  |  |  |  |
| 822 | 265 | Study on Customized Alerting Tone (CAT) solution for voice and video call in CS domain | 261d? | 2007-09-14 A | 2008-09-12 A | 100% |  | 2007-09-14 | 2008-09-12 | 261d? |  |  | C4 | 626.4h | 626.4h | FS_CAT_VVC_CS | China Mobile | zhanghao@chinamobile.com | Rel-8 | Kimmo | 29.882 |  |  |  |  |  |
| 823 | 266 | Study on InterWorking Function between MAP based and Diameter based interfaces | 266d? | 2007-11-30 A | 2008-12-05 A | 100% |  | 2007-11-30 | 2008-12-05 | 266d? |  | finish no earlier than 2008-12-05 | C4 | 2128h | 2128h | FS_MAP2Diam | Huawei | liming49985@huawei.com | Rel-8 | Kimmo | 29.805 | PCG-21 | CP-38 |  |  |  |
| 824 | 267 | Study on Scope of future HSPA Evolution for 1.28 Mcps TDD | 186d? | 2007-09-14 A | 2008-05-30 A | 100% |  | 2007-09-14 | 2008-05-30 | 186d? |  | finish no earlier than 2008-05-30 | R1 | 1488h | 1488h | FS_RAN-LCRTDDHSPAEvo | RITT | Xu Fei | Rel-8 | Patrick | 25.824 |  | RP-37 | RP-080290 |  |  |
| 825 | 268 | Study on Synchronized E-DCH for UTRA FDD | 126d? | 2007-09-14 A | 2008-03-07 A | 100% |  | 2007-09-14 | 2008-03-07 | 126d? |  | finish no earlier than 2008-03-14 | R1 | 1008h | 1008h | FS_RAN-UplinkSync | Nokia Siemens Networks | Karri.Ranta-aho@nsn.com | Rel-8 | Patrick | 25.823 |  | RP-37 | RP-080068 |  |  |
| 826 | 269 | Study on Improved network controlled mobility between LTE and 3GPP2/mobile WiMAX radio technologies | 131d? | 2007-06-04 A | 2007-12-03 A | 100% |  | 2007-06-04 | 2007-12-03 | 131d? |  | finish no earlier than 2007-12-03 | R4 | 1048h | 1048h | FS_RAN-LTEmob | Motorola | hao.bi@Motorola.com | Rel-8 | Issam | 36.938 |  |  | RP-070827 |  |  |
| 827 | 270 | Study on 3G Home NodeB/eNodeB | 325d? | 2007-03-05 A | 2008-05-30 A | 100% |  | 2007-03-05 | 2008-05-30 | 325d? |  | finish no earlier than 2008-05-30 | R4 | 2600h | 2600h | FS_RAN-HNBeNB | Motorola | howard.thomas@motorola.com | Rel-8 | Issam | 25.820 |  |  | RP-080289 |  |  |
| 828 | 271 | Study on HS-PDSCH serving cell change enhancements | 60d? | 2007-12-17 A | 2008-03-07 A | 100% |  | 2007-12-17 | 2008-03-07 | 60d? |  | finish no earlier than 2008-06-12 | R4 | 480h | 480h | FS_RAN-HSPDSCH | Qualcomm Europe |  | Rel-8 | Issam | none | PCG-21 | RP-38 | RP-080070 |  |  |
| 829 | 272 | Study on Dual-Cell HSDPA operation | 261d? | 2007-08-15 A | 2009-03-06 A | 100% |  | 2007-08-15 | 2009-03-06 | 261d? |  | finish no earlier than 2009-03-06 | R1 | 2088h | 2088h | FS_RAN-DCHS | Qualcomm Europe | Josef Blanz | Rel-8 | Patrick | withdrawn 25.825 v100 | PCG-21 | RP-39 | RP-090066 |  |  |
| 830 | 273 | Study on A-interface over IP | 126d? | 2007-08-31 A | 2008-02-22 A | 100% |  | 2007-08-31 | 2008-02-22 | 126d? |  | finish no earlier than 2008-02-22 | GP | 1008h | 1008h | AINTIP | China Mobile, Ericsson | paul.schliwa-bertling@ericsson.com | Rel-8 | Paolo | 43.903 |  |  |  |  |  |
| 831 | 274 | Study on Multi-User Reusing-One-Slot | 602d? | 2007-11-16 A | 2010-03-05 | 98% | 12.04d? | 2007-11-16 | 2010-03-05 | 602d? | 400d | finish no earlier than 2010-03-05 | GP | 4808h | 4711.68h | MUROS | Nokia Siemens Networks | juergen.hofmann@nsn.com | Rel-8 | Paolo | 45.914 |  |  | GP-092021 |  |  |
| 832 | 275 | Study on Optimized Transmit Pulse Shape for Downlink EGPRS2-B | 602d? | 2007-11-16 A | 2010-03-05 | 95% | 30.1d? | 2007-11-16 | 2010-03-05 | 602d? | 400d | finish no earlier than 2010-03-05 | G1 | 4808h | 4567.2h | WIDER | RIM, Nokia Siemens Networks | jdwyer@RIM.COM and eddie.riddington@nsn.com | Rel-8 | Paolo | 45.913 |  |  | GP-092126 |  |  |
| 833 | 276 | Deleted - equals 340035 -FS on Service continuity between mobile and WLAN networks | 75d? | 2007-09-03 A | 2007-12-14 A | 100% |  | 2007-09-03 | 2007-12-14 | 75d? |  | finish no earlier than 2007-12-14 | S1 | 600h | 600h | FSSCMobToW | BT | mike.meyerstein@bt.com | Rel-8 | Alain | 22.937 |  | SP-37 |  | PCG-21 | SP-39 |
| 834 | 277 | Deleted - Study on Evaluation of LCS Control Plane Solution for EPS | 100d? | 2008-01-14 A | 2008-05-30 A | 100% |  | 2008-01-14 | 2008-05-30 | 100d? |  | finish no earlier than 2009-03-20 | S2 | 800h | 800h | FS_LCS_EPS | SiRF |  | Rel-8 | Maurice | 23.891 |  | SP-38 |  | PCG-21 | SP-40 |
| 835 | 278 | Release 7 Features | 1d? | 2000-01-03 | 2000-01-03 |  |  | 2000-01-03 | 2000-01-03 | 1d? | 3056d | start no earlier than 2000-01-01 | CP,GP,RP,SP | 8h |  |  |  |  | Rel-7 |  |  |  |  |  |  |  |

Notes:
- 800: SP#43 completed
- 801: SP#41 completed
- 802: SP#41 completed
- 803: SP#43 completed
- 804: SP#41 completed. No spin-off activity proposed. [Note: IMS Service Brokering enhancements UID_31088 moved back from R8 to R7 to give a home to 22228CR0036_(Rel-7)_S1-051232. Hence, Rel-7 ISB has Stage 1 only (and is misaligned with Rel-7 Stages 2/3.]
- 805: SP#38 completed
- 806: 08/08/08 TR 23.827 v 0.4.0 no progress for 1 year. MCC recommended FS be completed and 23.827 brought under CR. SP#41 completed (draft TR 23.827 not SA approved/published; TR content implemented in TSs)
- 807: SP#40 completed
- 808: SP#39 completed
- 809: SP#39 completed
- 810: SP#39 completed
- 811: SP#41 completed as Rel-8
- 812: SP#43 completed
- 813: SP#38 completed. Spin-off WID UID_34042 (eCall_Phase2)
- 814: SP#40 completed. SID updated SP-050608=>SP-070307
- 815: SP#37 completed. SID updated SP-050295=>SP-070305
- 816: SP#36 completed. Spin-off New Feature UID_400034 (UDC)
- 817: SP#42 completed
- 818: SP#38 completed
- 819: CP#40 completed. Spin-off New Feature UID_380035 (MRFC_TS)
- 820: CP#40 completed. Spin-off WID UID_400012 (IMS_RP)
- 821: CP#41 completed. Linked to SA5 Study on Common Profile Storage framework UID_320006. Spin-off WID UID_410003 (IMS_ASIO)
- 822: CP#41 completed. Spin-off WID under Feature CAT UID_340029
- 823: CP#41 Spin-off WID UID_410007 (MAP2Diam). CP#42 completed
- 824: RP#40 completed. SR in RP-080290
- 825: SID in RP-070678. RP#39 completed. SR in RP-080068
- 826: RP#38 completed. SR in RP-070827
- 827: RP#40 completed. SR in RP-080289
- 828: SID in RP-071044. SR in RP-080070. The study produced no TR. RP#39 completed. Spin-off New implementation WID in RP-080227
- 829: RP#43 closed. TR 25.825 v100 withdrawn. Conclusions in RP-090318 RAN1 findings of the UTRA Multi-Carrier Evolution study). RP#42 New WID RP-080490 (RANimp-DCHSDPA) UID_400052 approved
- 830: GP#37 completed. Spin-off implementation Feature AoIP (A-interface over IP) UID_50591
- 831: GP#44 completion 11/09=>03/10 (was 11/08=>02/09=>05/09=>11/09). Spin-off implementation WI UID_420002 VAMOS (Voice services over Adaptive Multi-user channels on One Slot)
- 832: GP#44 completion 11/09=>03/10 (was 11/08=>02/09=>05/09=>11/09). Needs some more work to define possible Rel-9 or Rel-10 implementation work
- 833: SP#39 stopped
- 834: SP#40 spin-off Feature UID_400038 (LCS_CPS_EPS). SP#40 FS stopped
- 835: -

| ID | WBS | Task | Type | Duration | Start | Finish | Complete | Baseline start | Baseline finish | Baseline duration | Constraint | Resources | Work | Actual work | Text1 | Text4 | Text5 | Text6 | Text8 | Text12 | Text11 | Text7 | Text2 |
| --- | --- | --- | --- | --- | --- | --- | --- | --- | --- | --- | --- | --- | --- | --- | --- | --- | --- | --- | --- | --- | --- | --- | --- |
| 836 | 279 | **Identification of Communication Services in IMS** |  | 620d? | 2005-05-02 A | 2007-09-14 A | 100% | 2005-05-02 | 2007-09-14 | 620d? |  | S2,S1,C1,S5 | 13016h | 13016h | ServID | Ericsson | stephen.terrill@ericsson.com | Rel-7 | Maurice |  |  |  |  |
| 837 | 279.1 | TR on ServID |  | 232d? | 2005-05-02 A | 2006-03-21 A | 100% | 2005-05-02 | 2006-03-21 | 232d? | finish no earlier than 2006-03-20 | S2 | 1856h | 1856h | ServID | Ericsson | stephen.terrill@ericsson.com | Rel-7 | Maurice |  |  |  |  |
| 838 | 279.2 | Stage 1,2 of ServID |  | 144d? | 2005-11-11 A | 2006-05-31 A | 100% | 2005-11-11 | 2006-05-31 | 144d? | start no earlier than 2005-11-11 | S1,S2 | 1152h | 1152h | ServID | Ericsson | stephen.terrill@ericsson.com | Rel-7 | Maurice |  |  |  |  |
| 839 | 279.3 | Stage 3 of ServID |  | 250d? | 2006-03-31 A | 2007-03-15 A | 100% | 2006-03-31 | 2007-03-15 | 250d? | finish no earlier than 2007-03-15 | C1 | 2000h | 2000h | ServID | Ericsson | christer.holmberg@ericsson.com | Rel-7 | Frederic |  |  |  |  |
| 840 | 279.4 | Charging of ServID |  | 381d? | 2006-03-31 A | 2007-09-14 A | 100% | 2006-03-31 | 2007-09-14 | 381d? | finish no earlier than 2007-09-14 | S5 | 3048h | 3048h | ServID | Orange | alain.bibas@orange-ft.com | Rel-7 | Dionisio |  |  |  |  |
| 841 | 280 | **Supporting Globally Routable User Agent URIs in IMS** |  | 415d? | 2005-11-14 A | 2007-06-15 A | 100% | 2005-11-14 | 2007-06-15 | 415d? |  | S2,S1,C1 | 7760h | 7760h | GRUU | RIM | Adrian Buckley (abuckley@rim.com) | Rel-7 | Maurice |  |  |  |  |
| 842 | 280.1 | Deleted - TR on GRUU |  | 219d? | 2005-11-14 A | 2006-09-14 A | 100% | 2005-11-14 | 2006-09-14 | 219d? | finish no earlier than 2006-09-14 | S2 | 1752h | 1752h | GRUU | RIM | Adrian Buckley (abuckley@rim.com) | Rel-7 | Maurice | SP-32 |  |  |  |
| 843 | 280.2 | Stage 1,2 of GRUU |  | 65d? | 2006-07-03 A | 2006-09-29 A | 100% | 2006-07-03 | 2006-09-29 | 65d? | start no earlier than 2006-07-03 | S1,S2 | 520h | 520h | GRUU | RIM | Adrian Buckley (abuckley@rim.com) | Rel-7 | Maurice |  |  |  |  |
| 844 | 280.3 | Stage 3 of GRUU |  | 271d? | 2006-06-02 A | 2007-06-15 A | 100% | 2006-06-02 | 2007-06-15 | 271d? | finish no earlier than 2007-06-15 | C1 | 2168h | 2168h | GRUU | CableLabs | Bernie McKibben | Rel-7 | Frederic |  |  |  |  |
| 845 | 281 | **Multimedia Telephony Service for IMS** |  | 357d? | 2006-02-01 A | 2007-06-15 A | 100% | 2006-02-01 | 2007-06-15 | 357d? |  | S1,C1,S4 | 8976h | 8976h | MTSI | Ericsson | peter.bleckert@ericsson.com | Rel-7 | Alain |  |  |  |  |
| 846 | 281.1 | Stage 1 of MTSI |  | 173d? | 2006-02-01 A | 2006-09-29 A | 100% | 2006-02-01 | 2006-09-29 | 173d? | start no earlier than 2006-02-01 | S1 | 1384h | 1384h | MTSI-REQ | Ericsson | peter.bleckert@ericsson.com | Rel-7 | Alain |  |  |  |  |
| 847 | 281.2 | Stage 3 of MTSI |  | 330d? | 2006-03-10 A | 2007-06-14 A | 100% | 2006-03-10 | 2007-06-14 | 330d? | finish no earlier than 2007-06-15 | C1 | 2640h | 2640h | MTSI | Ericsson | christer.holmberg@ericsson.com | Rel-7 | Frederic |  |  |  |  |
| 848 | 281.3 | Media handling and interaction in MTSI |  | 262d? | 2006-03-15 A | 2007-03-15 A | 100% | 2006-03-15 | 2007-03-15 | 262d? | finish no earlier than 2007-03-15 | S4 | 2096h | 2096h | MTSI-MHI | Ericsson | olle.franceschi@ericsson.com | Rel-7 | Paolo |  |  |  |  |
| 849 | 281.4 | Deleted - duplicates UID7039 - IMS Multimedia Telephony Service | milestone | 0d? | 2007-06-15 A | 2007-06-15 A | 100% | 2007-06-15 | 2007-06-15 | 0d? | start no earlier than 2007-06-15 | S1 |  |  | MMTEL | Ericsson | peter.bleckert@ericsson.com | Rel-7 | Alain | SP-32 |  |  |  |
| 850 | 282 | Multimedia Telephony Service for IMS (MTSI) - UE Conformance Testing |  | 387d | 2007-09-19 A | 2009-03-12 A | 100% | 2007-09-19 | 2009-03-12 | 387d | finish no earlier than 2009-03-13 | R5 | 1664h | 1664h | MTSI-UEConfTest | Ericsson, Motorola | Leif.Mattisson@ericsson.com, Jacob.John@motorola.com | Rel-7 | Ingbert |  | RP-090056 |  |  |
| 851 | 283 | TISPAN requirements for Multimedia Telephony with PSTN/ISDN simulation services |  | 58d? | 2007-09-18 A | 2007-12-06 A | 100% | 2007-09-18 | 2007-12-06 | 58d? | start no earlier than 2007-09-18 | S1 | 464h | 464h | TMMTEL7 |  |  | Rel-7 | Alain |  |  | SP-37 |  |
| 852 | 284 | **Maintenance of TISPAN release 1 common IMS** |  | 58d? | 2007-09-18 A | 2007-12-06 A | 100% | 2007-09-18 | 2007-12-06 | 58d? |  | S2 | 1392h | 1392h | MCIMSTR1 | Ericsson | Raymond Forbes | Rel-7 | Maurice |  |  | SP-38 | PCG-21 |
| 853 | 284.1 | SA1 aspects of MCIMSTR1 |  | 58d? | 2007-09-18 A | 2007-12-06 A | 100% | 2007-09-18 | 2007-12-06 | 58d? | finish no earlier than 2007-12-06 | S1 | 464h | 464h | MCIMSTR1-S1 | Telecom Italia | Marco.DeLuca1@telecomitalia.it | Rel-7 | Alain |  |  | SP-38 | PCG-21 |
| 854 | 284.2 | SA2 aspects of MCIMSTR1 |  | 58d? | 2007-09-18 A | 2007-12-06 A | 100% | 2007-09-18 | 2007-12-06 | 58d? | finish no earlier than 2007-12-06 | S2 | 464h | 464h | MCIMSTR1-S2 | Ericsson | Raymond Forbes | Rel-7 | Maurice |  |  | SP-38 | PCG-21 |
| 855 | 285 | **PS domain and IMS impacts for supporting IMS Emergency calls** |  | 1760d? | 2000-09-18 A | 2007-06-15 A | 100% | 2000-09-18 | 2007-06-15 | 1760d? |  | S2,S1 | 44157h | 44157h | EMC1 | Siemens | Rainer Liebhart | Rel-7 | Maurice |  |  |  |  |
| 856 | 10.1.1 | Service Requirements for IP-based emergency calls |  | 985d | 2000-09-18 A | 2004-06-25 A | 100% | 2000-09-18 | 2004-06-25 | 985d | finish no earlier than 2004-06-25 | S1 | 7880h | 7880h | EMC1 | Siemens | Rainer Liebhart | Rel-7 | Alain |  |  |  |  |
| 857 | 285.2 | Study on Stage 2 for IMS-level solution |  | 668d? | 2003-02-26 A | 2005-09-16 A | 100% | 2003-02-26 | 2005-09-16 | 668d? | finish no earlier than 2005-09-16 | S2 | 5344h | 5344h | EMC1 | Siemens | Rainer Liebhart | Rel-7 | Maurice |  |  |  |  |
| 858 | 285.3 | Study on Stage 2 for GPRS-level solution |  | 301d? | 2004-10-14 A | 2005-12-08 A | 100% | 2004-10-14 | 2005-12-08 | 301d? | finish no earlier than 2005-12-08 | S2 | 2408h | 2408h | EMC1 | Siemens | Rainer Liebhart | Rel-7 | Maurice |  |  |  |  |
| 859 | 285.4 | Stage 2 Specification Phase - IMS-level |  | 200d? | 2005-09-05 A | 2006-06-09 A | 100% | 2005-09-05 | 2006-06-09 | 200d? | finish no earlier than 2006-06-09 | S2 | 1600h | 1600h | EMC1 | Siemens | Rainer Liebhart | Rel-7 | Maurice |  |  |  |  |
| 860 | 285.5 | Deleted - Stage 2 Specification Phase - GPRS-level | milestone | 0d? | 2007-03-02 A | 2007-03-02 A | 100% | 2007-03-02 | 2007-03-02 | 0d? | start no earlier than 2007-03-02 | S2 |  |  | EMC1 | Siemens | Rainer Liebhart | Rel-7 | Maurice | SP-32 |  |  |  |

Notes:
- 836: WID approved SP#28. WID updated SP#32
- 837: - / Text3: 23.816
- 838: - / Text3: 22.228, 23.228, 23.203
- 839: CP#32 approved WID / Text3: 23.218, 24.229
- 840: - / Text3: 32.260, 32.298, 32.299
- 841: SP#29 approved WID
- 842: Abandoned
- 843: SP#29 approved WID / Text3: 22.228, 23.228, 23.218, 24.229
- 844: CP#32 approved WID / Text3: 24.229
- 845: -
- 846: - / Text3: 22.173
- 847: - / Text3: 24.173
- 848: - / Text3: 26.114
- 849: - / Text3: 22.173
- 850: RP#43 completed. Linked UID_7038 (MTSI) / Text3: 34.123-1, 34.123-2, 34.123-3, 34.229-1, 34.229-2
- 851: - / Text3: 22.273 (EI 181 002 maintenance)
- 852: - / Text3: http://www.3gpp.org/specs/TISPAN-IMS-ansfer.htm
- 853: - / Text3: 22.173, 22.273
- 854: - / Text3: 23.406, 23.417, 23.508,23.509, 23.511
- 855: -
- 856: - / Text3: 22.976 (DB shows 04/2003 withdrawn Study on PS domain services and capabilities (az: belongs this really here ?!)
- 857: - / Text3: 23.867
- 858: - / Text3: 23.867
- 859: - / Text3: 23.167, 23.228, 23.060, 23.002, 23.271
- 860: -

| ID | WBS | Task | Type | Duration | Start | Finish | Complete | Baseline start | Baseline finish | Baseline duration | Constraint | Resources | Work | Actual work | Text1 | Text4 | Text5 | Text6 | Text8 | Text3 | Text12 | Text10 | Text11 |
| --- | --- | --- | --- | --- | --- | --- | --- | --- | --- | --- | --- | --- | --- | --- | --- | --- | --- | --- | --- | --- | --- | --- | --- |
| 861 | 10.1 | **Emergency Call Enhancements for IP& PS Based Calls – stage 3** |  | 375d | 2006-01-09 A | 2007-06-15 A | 100% | 2006-01-09 | 2007-06-15 | 375d |  | C1 | 12845h | 12845h | EMC1 | Ericsson | alf.heidermark@ericsson.com | Rel-7 | Frederic |  |  |  |  |
| 862 | 10.1.2 | CT1 IMS aspects to support IMS Emergency sessions |  | 350.82d | 2006-01-09 A | 2007-06-15 A | 100% | 2006-01-09 | 2007-06-15 | 350.82d | finish no earlier than 2007-06-15 | C1 | 2806.57h | 2806.57h | EMC1 | Ericsson | alf.heidermark@ericsson.com | Rel-7 | Frederic | 24.229 |  |  |  |
| 863 | 10.1.2 | Deleted - CT3 IMS aspects to support IMS Emergency sessions |  | 95d | 2006-05-08 A | 2006-09-15 A | 100% | 2006-05-08 | 2006-09-15 | 95d | finish no earlier than 2006-09-15 | C3 | 760h | 760h | EMC1 | Ericsson | alf.heidermark@ericsson.com | Rel-7 | Gwiho | 29.163 | CP-33 |  |  |
| 864 | 10.1.5 | Deleted - CT3 PS domain aspects to support IMS Emergency sessions |  | 95d | 2006-05-08 A | 2006-09-15 A | 100% | 2006-05-08 | 2006-09-15 | 95d | start no earlier than 2006-05-08 | C3 | 760h | 760h | EMC1 | Ericsson | alf.heidermark@ericsson.com | Rel-7 | Gwiho | 29.061 | CP-33 |  |  |
| 865 | 10.1.5 | CT1 PS domain aspects to support IMS Emergency sessions |  | 349.9d | 2006-01-09 A | 2007-06-15 A | 100% | 2006-01-09 | 2007-06-15 | 349.9d | finish no earlier than 2007-06-15 | C1 | 2799.2h | 2799.2h | EMC1 | Ericsson | alf.heidermark@ericsson.com | Rel-7 | Frederic | 24.008, 24.234 |  |  |  |
| 866 | 10.1.5 | CT4 PS domain aspects to support IMS Emergency sessions |  | 365d | 2006-01-09 A | 2007-06-01 A | 100% | 2006-01-09 | 2007-06-01 | 365d | finish no earlier than 2007-06-01 | C4 | 2920h | 2920h | EMC1-GPRSc4 | Ericsson | alf.heidermark@ericsson.com | Rel-7 | Kimmo | 29.060 |  |  |  |
| 867 | 286 | IMS Support of Conferencing |  | 355d? | 2005-11-04 A | 2007-03-15 A | 100% | 2005-11-04 | 2007-03-15 | 355d? | finish no earlier than 2007-03-15 | C1 | 2840h | 2840h | IMSconf | Alcatel-Lucent | Keith Drage (drage@alcatel-lucent.com) | Rel-7 | Frederic | 24.147, 24.229 |  |  |  |
| 868 | 287 | Performance Characterization of VoIMS over HSDPA\EUL channels |  | 713d? | 2005-03-15 A | 2007-12-06 A | 100% | 2005-03-15 | 2007-12-06 | 713d? | finish no earlier than 2007-12-06 | S4 | 5704h | 5704h | VoIMS-PCVoIMS | Alcatel-Lucent | mcgowan@alcatel-lucent.com | Rel-7 | Paolo | 26.935 |  |  |  |
| 869 | 288 | **WLAN-UMTS Interworking Phase 2** |  | 371d? | 2004-01-05 A | 2005-06-07 A | 100% | 2004-01-05 | 2005-06-07 | 371d? |  | S1 | 3888h | 3888h | WLAN2 | Telenor | frederic.paint@telenor.com | Rel-7 | Alain | 33.234 (SP-36 SA3 CRs approved) |  |  |  |
| 870 | 288.1 | Stage 1 on Session Continuity |  | 115d? | 2004-01-05 A | 2004-06-11 A | 100% | 2004-01-05 | 2004-06-11 | 115d? | start no earlier than 2004-01-05 | S1 | 920h | 920h | WLAN-SC |  |  | Rel-7 | Alain | 22.234 |  | SP-24 |  |
| 871 | 288.2 | Stage 2 on Session Continuity: covered by SAE | milestone | 0d? | 2005-06-07 A | 2005-06-07 A | 100% | 2005-06-07 | 2005-06-07 | 0d? | finish no earlier than 2005-06-07 | S2 |  |  | WLAN-SC |  |  | Rel-7 | Maurice |  |  |  |  |
| 872 | 289 | **WLAN Interworking – Private Network access from WLAN 3GPP IP Access** |  | 252d? | 2005-10-10 A | 2006-09-26 A | 100% | 2005-10-10 | 2006-09-26 | 252d? |  | S2,C1,C3,C4 | 8936h | 8936h | WLANPNA | NEC | Toshiyuki Tamura (tamurato@aj.jp.nec.com) | Rel-7 | Maurice |  |  |  |  |
| 873 | 289.1 | WLAN-PNA - Stage 2 |  | 185d? | 2005-10-10 A | 2006-06-23 A | 100% | 2005-10-10 | 2006-06-23 | 185d? | start no earlier than 2005-10-10 | S2 | 1480h | 1480h | WLANPNA-st2 | NEC | Toshiyuki Tamura (tamurato@aj.jp.nec.com) | Rel-7 | Maurice | 23.234, 33.234 |  |  |  |
| 874 | 289.2 | **WLAN-PNA - Stage 3** |  | 170d? | 2006-02-01 A | 2006-09-26 A | 100% | 2006-02-01 | 2006-09-26 | 170d? |  | C1,C3,C4 | 5440h | 5440h | WLANPNA-st3 | NEC |  | Rel-7 | Frederic |  |  |  |  |
| 875 | 289.2.1 | CT1 aspets for WLAN-PNA |  | 170d? | 2006-02-01 A | 2006-09-26 A | 100% | 2006-02-01 | 2006-09-26 | 170d? | start no earlier than 2006-02-01 | C1 | 1360h | 1360h | WLANPNA-st3 | NEC |  | Rel-7 | Frederic | 24.234 |  |  |  |
| 876 | 289.2.2 | CT3 aspets for WLAN-PNA |  | 170d? | 2006-02-01 A | 2006-09-26 A | 100% | 2006-02-01 | 2006-09-26 | 170d? | start no earlier than 2006-02-01 | C3 | 1360h | 1360h | WLANPNA-st3 | NEC |  | Rel-7 | Gwiho | 29.161 |  |  |  |
| 877 | 289.2.3 | Deleted - CT4 aspets for WLAN-PNA |  | 170d? | 2006-02-01 A | 2006-09-26 A | 100% | 2006-02-01 | 2006-09-26 | 170d? | start no earlier than 2006-02-01 | C4 | 1360h | 1360h | WLANPNA-st3 | NEC |  | Rel-7 | Kimmo | 29.234 | CP-32 |  |  |
| 878 | 290 | **Enhancements to support QoS provisioning over 3GPP/WLAN Interworking** |  | 520d? | 2005-03-14 A | 2007-03-09 A | 100% | 2005-03-14 | 2007-03-09 | 520d? |  | S2,C4,C1 | 8360h | 8360h | WLANQOS | Samsung |  | Rel-7 | Maurice |  |  |  |  |
| 879 | 290.1 | Deleted - TR on support of QoS on WLAN |  | 232d? | 2005-03-14 A | 2006-01-31 A | 100% | 2005-03-14 | 2006-01-31 | 232d? | start no earlier than 2005-03-14 | S2 | 1856h | 1856h | WLANQOS | Samsung |  | Rel-7 | Maurice | 23.836 | SP-32 |  |  |
| 880 | 290.2 | Stage 2 on support of QoS over 3GPP/WLAN interworking |  | 108d? | 2006-02-01 A | 2006-06-30 A | 100% | 2006-02-01 | 2006-06-30 | 108d? | start no earlier than 2006-02-01 | S2 | 864h | 864h | WLANQOS | Samsung |  | Rel-7 | Maurice | 23.234 |  |  |  |
| 881 | 290.3 | Stage 3 CT4 on support of QoS over 3GPP/WLAN Interworking |  | 121d? | 2006-09-22 A | 2007-03-09 A | 100% | 2006-09-22 | 2007-03-09 | 121d? | finish no earlier than 2007-03-09 | C4 | 968h | 968h | WLANQOS | Huawei | zhang.peng@huawei.com | Rel-7 | Kimmo | 29.234, 23.008 |  |  |  |
| 882 | 290.4 | Stage 3 CT1 on support of QoS over 3GPP/WLAN Interworking |  | 64d? | 2006-09-04 A | 2006-11-30 A | 100% | 2006-09-04 | 2006-11-30 | 64d? | finish no earlier than 2006-11-30 | C1 | 512h | 512h | WLANQOS | Huawei | zhang.peng@huawei.com | Rel-7 | Frederic | 24.234 |  |  |  |
| 883 | 291 | **Location Services enhancements** |  | 906d? | 2004-06-28 A | 2007-12-17 A | 100% | 2004-06-28 | 2007-12-17 | 906d? |  | S1,S2,GP,C4,R2 | 46933.6h | 46933.6h | LCS3 |  |  | Rel-7 | Alain |  |  |  |  |
| 884 | 291.1 | Stage 2 for LCS3 (including IMS emergency location aspects) |  | 446d? | 2004-12-31 A | 2006-09-15 A | 100% | 2004-12-31 | 2006-09-15 | 446d? | finish no earlier than 2006-09-15 | S2 | 3568h | 3568h | LCS3 | SiRF | brodilitz@sirf.com | Rel-7 | Maurice | 23.271 |  |  |  |
| 885 | 291.2 | LCS Enhancements related to Location-Based Services |  | 695d? | 2005-01-03 A | 2007-08-31 A | 100% | 2005-01-03 | 2007-08-31 | 695d? | finish no earlier than 2007-08-31 | GP | 5560h | 5560h | LCS3-LBS | SiRF | kjudge@sirf.com | Rel-7 | Paolo | 43.059, 44.031, 48.008, 49.031 |  |  |  |
| 886 | 291.3 | CT4 aspects for LCS UEPos-LBS |  | 240d? | 2006-01-02 A | 2006-12-01 A | 100% | 2006-01-02 | 2006-12-01 | 240d? | finish no earlier than 2006-12-01 | C4 | 1920h | 1920h | LCS3-UEPos-LBS | SiRF | brodilitz@sirf.com | Rel-7 | Kimmo | 24.030, 24.080, 29.002 |  |  |  |
| 887 | 291.4 | UE positioning - Velocity |  | 394d? | 2005-03-15 A | 2006-09-15 A | 100% | 2005-03-15 | 2006-09-15 | 394d? | finish no earlier than 2006-09-15 | R2 | 3152h | 3152h | LCS3-UEPos-Velocity | SiRF | BRodilitz@SiRF.com | Rel-7 | Joern | 25.305, 25.331, 25.410, 25.413, 25.453 |  |  | RP-060459 |
| 888 | 291.5 | Inclusion of Uplink TDOA UE positioning method in the UTRAN specifications |  | 849d? | 2004-09-15 A | 2007-12-17 A | 100% | 2004-09-15 | 2007-12-17 | 849d? | finish no earlier than 2007-12-17 | R2 | 6792h | 6792h | LCS3-UEPos-UTDOA | TruePosition | Robert Gross | Rel-7 | Joern | 25.305, 25.453 |  |  | RP-070797 |

Notes:
- 861: -
- 862: -
- 863: Cancelled for Rel-7 and there is now corresponding Rel-8 WI
- 864: Cancelled for Rel-7 and there is now corresponding Rel-8 WI
- 865: -
- 866: -
- 867: CP#35 revised WID
- 868: -
- 869: Created at TSG#27 because of WLAN items belonging to Rel-7
- 870: -
- 871: -
- 872: -
- 873: Approved at SP#29
- 874: Approved at CP#29
- 875: Approved at CP#29
- 876: Approved at CP#29
- 877: CT4#31; no impacts identified, therefore completed. CP-32 stopped
- 878: Moved from FS section Feb 06. SP-30 updated WID
- 879: SP-32 stopped
- 880: SP-30 updated WID
- 881: CP-32 approved WID
- 882: CP-32 approved WID
- 883: -
- 884: SP#27 approved WID.
- 885: -
- 886: -
- 887: Completed Sept 2006; SR in RP-060459
- 888: Completed Nov 2007; SR in RP-070797

| ID | WBS | Task | Type | Duration | Start | Finish | Complete | Baseline start | Baseline finish | Baseline duration | Constraint | Resources | Work | Actual work | Text1 | Text4 | Text5 | Text6 | Text8 | Text12 | Text11 | Text2 | Text7 |
| --- | --- | --- | --- | --- | --- | --- | --- | --- | --- | --- | --- | --- | --- | --- | --- | --- | --- | --- | --- | --- | --- | --- | --- |
| 889 | 291.6 | **LCS for 3GPP Interworking WLAN** |  | 700d? | 2004-06-28 A | 2007-03-02 A | 100% | 2004-06-28 | 2007-03-02 | 700d? |  | S1 | 11901.6h | 11901.6h | LCS3-IWLAN | Telcordia | Mike Loushine | Rel-7 | Alain |  |  |  |  |
| 890 | 291.6.1 | FS on 3GPP system to WLAN Interworking with LCS |  | 512.7d? | 2004-06-28 A | 2006-06-30 A | 100% | 2004-06-28 | 2006-06-30 | 512.7d? | finish no earlier than 2005-09-29 | S1 | 4101.6h | 4101.6h | LCS3-IWLAN-FSs1 | Telcordia | Mike Loushine, Vijay Varma | Rel-7 | Alain |  |  |  |  |
| 891 | 291.6.2 | Deleted - Study of work on an LCS architecture for I-WLAN. |  | 180d? | 2006-06-26 A | 2007-03-02 A | 100% | 2006-06-26 | 2007-03-02 | 180d? | finish no earlier than 2007-03-02 | S2 | 1440h | 1440h | LCS3-IWLAN-FSs2 | LG Electronics | dhshim@lge.com ; phede@lge.com | Rel-7 | Maurice | SP-35 |  |  |  |
| 892 | 291.6.3 | Stage 2 for LCS architecture for I-WLAN |  | 95d? | 2006-10-23 A | 2007-03-02 A | 100% | 2006-10-23 | 2007-03-02 | 95d? | finish no earlier than 2007-03-02 | S2 | 760h | 760h | LCS3-IWLAN | LG Electronics | dhshim@lge.com ; phede@lge.com | Rel-7 | Maurice |  |  |  |  |
| 893 | 291.7 | Deleted - UE positioning Rel-7 |  | 849d? | 2004-09-15 A | 2007-12-17 A | 100% | 2004-09-15 | 2007-12-17 | 849d? |  | RP | 6792h | 6792h | LCS3-UEpos |  |  | Rel-7 |  | RP-38 |  |  |  |
| 894 | 291.8 | Deleted - RAN2 aspects for LBS | milestone | 0d? | 2005-06-15 A | 2005-06-15 A | 100% | 2005-06-15 | 2005-06-15 | 0d? | start no earlier than 2005-06-15 | R2 |  |  | LCS3-UEPos-LBS | SiRF | BRodilitz@SiRF.com | Rel-7 | Joern | RP-31 |  |  |  |
| 895 | 292 | **MBMS Enhancements** |  | 625d? | 2005-07-11 A | 2007-11-30 A | 100% | 2005-07-11 | 2007-11-30 | 625d? |  | S1 | 10844.6h | 10844.6h | MBMSE | China Mobile | liuhongyfw@chinamobile.com | Rel-7 | Alain |  |  |  |  |
| 896 | 292.1 | Stage 1 of MBMSE |  | 109d? | 2005-07-11 A | 2005-12-08 A | 100% | 2005-07-11 | 2005-12-08 | 109d? | finish no earlier than 2005-12-08 | S1,R1,C3 | 872h | 872h | MBMSE | China Mobile | liuhongyfw@chinamobile.com | Rel-7 | Alain |  |  |  |  |
| 897 | 292.2 | MBMS FDD Physical layer Enhancements |  | 117.29d? | 2006-12-15 A | 2007-06-04 A | 100% | 2006-12-15 | 2007-06-04 | 117.29d? | finish no earlier than 2007-06-04 | R1 | 938.32h | 938.32h | MBMSE-RANPhysFDD | Ericsson | Lars.Lindbom@ericsson.com | Rel-7 | Patrick |  | RP-070290 |  |  |
| 898 | 292.3 | MBMS TDD Physical layer Enhancements |  | 117.29d? | 2006-12-15 A | 2007-06-04 A | 100% | 2006-12-15 | 2007-06-04 | 117.29d? | finish no earlier than 2007-06-04 | R1 | 938.32h | 938.32h | MBMSE-RANPhysTDD | IPWireless | Nicholas Anderson | Rel-7 | Patrick |  | RP-070291 |  |  |
| 899 | 292.4 | MBMS Low Chip Rate TDD Physical Layer Enhancement |  | 127d? | 2007-03-16 A | 2007-09-10 A | 100% | 2007-03-16 | 2007-09-10 | 127d? | finish no earlier than 2007-09-10 | R1 | 1016h | 1016h | MBMSE-RANPhysLCRTDD | RITT | Lin Hui | Rel-7 | Patrick |  | RP-070292 |  |  |
| 900 | 292.5 | MBMS Mz interface |  | 260d? | 2006-12-04 A | 2007-11-30 A | 100% | 2006-12-04 | 2007-11-30 | 260d? | finish no earlier than 2007-05-11 | C3 | 2080h | 2080h | MBMSMz | Huawei | Deng Tingting (ttdeng@huawei.com) | Rel-7 | Gwiho |  |  |  |  |
| 901 | 293 | **MBMS - UE Conformance Testing** |  | 657d? | 2007-06-01 A | 2009-12-04 A | 100% | 2007-06-01 | 2009-12-04 | 657d? |  | R5 | 13848h | 13848h | MBMSE_UEConTest |  |  | Rel-7 | Ingbert |  |  | PCG-21 | SP-40 |
| 902 | 293.1 | Conformance Test Aspects – MBMS TDD Physical layer Enhancements – MBSFN for HCR and VHCR TDD |  | 336d? | 2007-06-01 A | 2008-09-12 A | 100% | 2007-06-01 | 2008-09-12 | 336d? | start no earlier than 2007-06-01 | R5 | 2688h | 2688h | MBMSE-RANPhysTDD_UEConTest | IPWireless | tspeight@ipwireless.com | Rel-7 | Ingbert |  | RP-080541 |  |  |
| 903 | 293.2 | Conformance Test Aspects – MBMS LCR TDD Physical Layer Enhancement |  | 342d? | 2008-05-30 A | 2009-09-18 A | 100% | 2008-05-30 | 2009-09-18 | 342d? | finish no earlier than 2009-09-18 | R5 | 2728h | 2728h | MBMSE-RANPhysLCRTDD_UEConTest | CATT | chenxiaozhong@datangmobile.cn | Rel-7 | Ingbert |  | RP-090715 | PCG-21 | RP-40 |
| 904 | 293.3 | Conformance Test Aspects – MBSFN for FDD |  | 397d? | 2008-05-30 A | 2009-12-04 A | 100% | 2008-05-30 | 2009-12-04 | 397d? | finish no earlier than 2009-12-04 | R5 | 3176h | 3176h | MBMSE-UEConTest_RANPhysFDD | Huawei | Xiang Li (trica_li@huawei.com) | Rel-7 | Ingbert |  | RP-091214 | PCG-21 | RP-40 |
| 905 | 294 | MBMS User Service Extensions |  | 392d? | 2005-12-07 A | 2007-06-07 A | 100% | 2005-12-07 | 2007-06-07 | 392d? | finish no earlier than 2007-06-07 | S4 | 3136h | 3136h | MBMSUSE | Ericsson | Thorsten.Lohmar@ericsson.com | Rel-7 | Paolo |  |  |  |  |
| 906 | 295 | **Advanced Global Navigation Satellite System (A-GNSS) concept** |  | 830d? | 2004-06-28 A | 2007-08-31 A | 100% | 2004-06-28 | 2007-08-31 | 830d? |  | S1,GP,R2 | 9553.6h | 9553.6h | LCS3-AGNSS | Alcatel | Michel.monnerat@thalesaleniaspace.com | Rel-7 | Alain |  |  |  |  |
| 907 | 295.1 | Towards A-GNSS Concept |  | 811.2d? | 2004-06-28 A | 2007-08-31 A | 100% | 2004-06-28 | 2007-08-31 | 811.2d? | finish no earlier than 2007-08-31 | GP | 6489.6h | 6489.6h | AGNSS-GP | Alcatel | richard.couty@space.alcatel.fr | Rel-7 | Paolo |  |  |  |  |
| 908 | 295.2 | Global Navigation Satellite System (GNSS) in UTRAN |  | 383d? | 2005-12-15 A | 2007-06-04 A | 100% | 2005-12-15 | 2007-06-04 | 383d? | finish no earlier than 2007-06-04 | R2 | 3064h | 3064h | LCS3-GNSS-UTRAN | France Telecom | alain.abinakhoul@francetelecom.com | Rel-7 | Joern |  | RP-070482 |  |  |
| 909 | 295.3 | Deleted - Towards A-GNSS Concept | milestone | 0d? | 2007-02-16 A | 2007-02-16 A | 100% | 2007-02-16 | 2007-02-16 | 0d? | start no earlier than 2007-02-16 | S1 |  |  | GNSS | Alcatel | richard.couty@space.alcatel.fr | Rel-7 | Alain | SP-34 |  |  |  |
| 910 | 296 | A-GPS Minimum Performance |  | 351d? | 2006-04-28 A | 2007-08-31 A | 100% | 2006-04-28 | 2007-08-31 | 351d? | finish no earlier than 2007-08-31 | GP | 2808h | 2808h | GAGR | Spirent | richard.catmur@spirentcom.com | Rel-7 | Paolo |  |  |  |  |
| 911 | 297 | **USSD message delivery and transfer to USIM** |  | 376d? | 2004-03-05 A | 2005-08-12 A | 100% | 2004-03-05 | 2005-08-12 | 376d? |  | S1,C6 | 2762.4h | 2762.4h | USSD-USIM | Axalto | Christophe Dubois (cdubois@axalto.com) | Rel-7 | Alain |  |  |  |  |
| 912 | 297.1 | Stage 1 |  | 152d? | 2004-03-18 A | 2004-10-15 A | 100% | 2004-03-18 | 2004-10-15 | 152d? | start no earlier than 2004-03-18 | S1 | 1216h | 1216h | USSD-USIM | Axalto | Christophe Dubois (cdubois@axalto.com) | Rel-7 | Alain |  |  |  |  |
| 913 | 297.2 | Alignment with requirements regarding USSD usage |  | 193.3d? | 2004-03-05 A | 2005-08-12 A | 100% | 2004-03-05 | 2005-08-12 | 193.3d? | finish no earlier than 2005-08-12 | C6 | 1546.4h | 1546.4h | USSD-USIM | Axalto | Christophe Dubois (cdubois@axalto.com) | Rel-7 | Xavier |  |  |  |  |

Notes:
- 889: - / Text3: 22.935
- 890: - / Text3: 22.935
- 891: Updated WID at SP#32 to change "stage 2" to "study" , duplicated UID 320017 deleted. SP#33 TR for Information. Last mention SP-35 Mar 2007 (abandoned ?) / Text3: 23.837
- 892: WID at SP#55 / Text3: 23.234, 23.271, 23.167
- 893: -
- 894: - / Text3: 25.305, 25.331, 25.410, 25.413, 25.453
- 895: -
- 896: Structure created by MCC to include RAN aspects under SA1 Feature / Text3: 22.146, 22.246, 22.228
- 897: Completed May 2007; SR in RP-070290 / Text3: 25.211, 25.212, 25.213, 25.101, 25.104, 25.331, 25.433, 25.346, 25.306
- 898: Completed May 2007; SR in RP-070291 / Text3: 25.346, 25.221, 25.222, 25.223, 25.224, 25.306, 25.331, 25.402, 25.433, 25.102, 25.105, 25.123
- 899: Completed May 2007; SR in RP-070292 / Text3: 25.346, 25.221, 25.222, 25.223, 25.224, 25.306, 25.331, 25.402, 25.433, 25.102, 25.105, 25.123
- 900: - / Text3: 29.061
- 901: Linked to Rel-7 Feature UID_31084 (MBMSE)
- 902: SR in RP-080541. RP#41 completed / Text3: 34.108, 34.122, 34.123-1/2/3
- 903: RP#45 completed / Text3: 34.108, 34.123-1
- 904: RP#46 completed / Text3: 34.108, 34.109, 34.121-1, 34.121-2, 34.123-1, 34.123-2, 34.123-3
- 905: - / Text3: 26.346, 26.946
- 906: -
- 907: GP#36 completed
- 908: Completed Sept 2006; SR in RP-070482 / Text3: 25.305, 25.331, 25.306, 25.413, 25.423, 25.433, 25.453, 25.302, 25.215, 25.401, 25.402, 25.450, 25.452
- 909: -
- 910: - / Text3: 45.005, 51.010
- 911: -
- 912: - / Text3: 22.090
- 913: -

| ID | WBS | Task | Type | Duration | Start | Finish | Complete | Baseline start | Baseline finish | Baseline duration | Constraint | Resources | Work | Actual work | Text1 | Text4 | Text5 | Text6 | Text8 | Text3 | Text12 |
| --- | --- | --- | --- | --- | --- | --- | --- | --- | --- | --- | --- | --- | --- | --- | --- | --- | --- | --- | --- | --- | --- |
| 914 | 298 | **Combinational Services** |  | 296d? | 2005-01-17 A | 2006-03-06 A | 100% | 2005-01-17 | 2006-03-06 | 296d? |  | S1,S2,C1,S4 | 5176h | 5176h | CSICS | TeliaSonera | Robert.Frank@teliasonera.com | Rel-7 | Alain |  |  |
| 915 | 298.1 | Stage 1 for CSICS |  | 104d? | 2005-01-17 A | 2005-06-09 A | 100% | 2005-01-17 | 2005-06-09 | 104d? | start no earlier than 2005-01-17 | S1 | 832h | 832h | CSICS | TeliaSonera | Robert.Frank@teliasonera.com | Rel-7 | Alain | 22.279 |  |
| 916 | 298.2 | Stage 2 for CSICS |  | 130d? | 2005-01-17 A | 2005-07-15 A | 100% | 2005-01-17 | 2005-07-15 | 130d? | start no earlier than 2005-01-17 | S2 | 1040h | 1040h | CSICS | TeliaSonera | Robert.Frank@teliasonera.com | Rel-7 | Maurice | 23.279 |  |
| 917 | 298.3 | Stage 3 for CSICS CN aspects |  | 221d? | 2005-05-02 A | 2006-03-06 A | 100% | 2005-05-02 | 2006-03-06 | 221d? | finish no earlier than 2006-03-06 | C1 | 1768h | 1768h | CSICS | Vodafone | Peter Dawes | Rel-7 | Frederic | 24.879, 24.279, 24.229, 24.008 |  |
| 918 | 298.4 | Stage 3 for codec aspects |  | 192d? | 2005-03-15 A | 2005-12-07 A | 100% | 2005-03-15 | 2005-12-07 | 192d? | finish no earlier than 2005-12-07 | S4 | 1536h | 1536h | CSICS-Codec | Ericsson | Per.Frojdh@ericsson.com | Rel-7 | Paolo | 26.141, 26.235 |  |
| 919 | 299 | **CAMEL Trunk Triggers** |  | 251d? | 2004-12-17 A | 2005-12-05 A | 100% | 2004-12-17 | 2005-12-05 | 251d? |  | S1,C4 | 6024h | 6024h | TTCAMEL | Nortel | Amar Deol (deola@nortelnetworks.com) | Rel-7 | Alain |  |  |
| 920 | 299.1 | Stage 1 for CAMEL Trunk Triggers |  | 251d? | 2004-12-17 A | 2005-12-05 A | 100% | 2004-12-17 | 2005-12-05 | 251d? |  | S1 | 2008h | 2008h | TTCAMEL | Nortel | Amar Deol (deola@nortelnetworks.com) | Rel-7 | Alain | 22.078 |  |
| 921 | 299.2 | CAMEL Trunk Originated Trigger Detection Points |  | 251d? | 2004-12-17 A | 2005-12-05 A | 100% | 2004-12-17 | 2005-12-05 | 251d? | start no earlier than 2004-12-17 | C4 | 2008h | 2008h | CamelR7 | Nortel | David Hutton (dhutton@nortel.com) | Rel-7 | Kimmo |  |  |
| 922 | 300 | **IMS Service Brokering enhancements** |  | 69d? | 2005-12-07 A | 2006-03-13 A | 100% | 2005-12-07 | 2006-03-13 | 69d? |  | S1 | 1104h | 1104h | ISB | Telcordia | jbakker@telcordia.com | Rel-7 | Alain | 22.228 |  |
| 923 | 300.1 | Stage 1 for ISB |  | 69d? | 2005-12-07 A | 2006-03-13 A | 100% | 2005-12-07 | 2006-03-13 | 69d? | finish no earlier than 2006-03-13 | S1 | 552h | 552h | ISB-s1 | Telcordia | jbakker@telcordia.com | Rel-7 | Alain | 22.228 |  |
| 924 | 301 | **Enhancements of VGCS for public authority officials** |  | 731d? | 2004-08-27 A | 2007-06-15 A | 100% | 2004-08-27 | 2007-06-15 | 731d? |  | S1,C1,C4,G2 | 25920h | 25920h | EVGCS |  |  | Rel-7 | Alain | 43.068, 44.068, 24.008, 29.002 |  |
| 925 | 301.1 | Stage 1 | milestone | 0d? | 2004-08-27 A | 2004-08-27 A | 100% | 2004-08-27 | 2004-08-27 | 0d? | finish no earlier than 2004-08-27 | S1 |  |  | EVGCS | Siemens | Joerg Swetina (joerg.swetina@nw.neclab.eu) | Rel-7 | Alain | 42.068, 43.068 |  |
| 926 | 301.2 | **Architecture and protocol aspects** |  | 731d? | 2004-08-27 A | 2007-06-15 A | 100% | 2004-08-27 | 2007-06-15 | 731d? |  | C1,C4 | 14904h | 14904h | EVGCS | Siemens | robert.zaus@nsn.com | Rel-7 | Frederic | 43.068, 44.068 |  |
| 927 | 301.2.1 | CT1 aspects of EVGCS |  | 731d? | 2004-08-27 A | 2007-06-15 A | 100% | 2004-08-27 | 2007-06-15 | 731d? | finish no earlier than 2006-09-15 | C1 | 5848h | 5848h | EVGCS | Siemens | robert.zaus@nsn.com | Rel-7 | Frederic | 43.068, 44.068, 24.008 |  |
| 928 | 301.2.2 | CT4 aspects of EVGCS |  | 401d? | 2004-08-27 A | 2006-03-10 A | 100% | 2004-08-27 | 2006-03-10 | 401d? | finish no earlier than 2006-03-10 | C4 | 3208h | 3208h | EVGCS | Siemens | robert.zaus@nsn.com | Rel-7 | Kimmo | 29.002 |  |
| 929 | 301.3 | GERAN2 aspects |  | 646d? | 2004-08-27 A | 2007-02-16 A | 100% | 2004-08-27 | 2007-02-16 | 646d? | finish no earlier than 2007-02-16 | G2 | 5168h | 5168h | EVGCS | Siemens | kenneth.isaacs@roke.co.uk | Rel-7 | Gert |  |  |
| 930 | 302 | **Improvements of VGCS for parallel use of services** |  | 523d? | 2005-03-15 A | 2007-03-15 A | 100% | 2005-03-15 | 2007-03-15 | 523d? |  | S1 | 12230.2h | 12230.2h | IVGCS |  |  | Rel-7 | Alain |  |  |
| 931 | 302.1 | Service Requirements for VGCS improvements |  | 62d? | 2005-03-15 A | 2005-06-08 A | 100% | 2005-03-15 | 2005-06-08 | 62d? | finish no earlier than 2005-06-08 | S1 | 496h | 496h | IVGCS | T-Mobile | kurt.bischinger@t-mobile.at | Rel-7 | Alain | 42.068 |  |
| 932 | 302.2 | Stage 2 modifications for VGCS improvements |  | 335d? | 2005-12-01 A | 2007-03-14 A | 100% | 2005-12-01 | 2007-03-14 | 335d? | start no earlier than 2005-12-01 | C1 | 2680h | 2680h | IVGCS | T-Mobile | kurt.bischinger@t-mobile.at | Rel-7 | Frederic | 43.068 |  |
| 933 | 302.3 | **Protocol aspects** |  | 336d? | 2005-12-01 A | 2007-03-15 A | 100% | 2005-12-01 | 2007-03-15 | 336d? |  | C1 | 5376h | 5376h | IVGCS | T-Mobile | Dieter Jacobsohn | Rel-7 | Frederic | 44.068 |  |
| 934 | 302.3.1 | CT1 aspects of IVGCS |  | 336d? | 2005-12-01 A | 2007-03-15 A | 100% | 2005-12-01 | 2007-03-15 | 336d? | finish no earlier than 2007-03-15 | C1 | 2688h | 2688h | IVGCS | T-Mobile |  | Rel-7 | Frederic | 43.068, 44.068 |  |
| 935 | 302.3.2 | Deleted - CT4 aspects of IVGCS | milestone | 0d? | 2007-03-09 A | 2007-03-09 A | 100% | 2007-03-09 | 2007-03-09 | 0d? | finish no earlier than 2007-03-09 | C4 |  |  | IVGCS-St3-c4 | T-mobile |  | Rel-7 | Kimmo | 29.002 | CP-35 |
| 936 | 303 | **OSA Rel-7** |  | 584d? | 2005-03-15 A | 2007-06-08 A | 100% | 2005-03-15 | 2007-06-08 | 584d? |  | S1,C5 | 17920h | 17920h | OSA7 | AePONA | eamonn.murray@aepona.com | Rel-7 | Alain |  |  |
| 937 | 303.1 | Service Requirements for OSA Service Broker |  | 62d? | 2005-03-15 A | 2005-06-08 A | 100% | 2005-03-15 | 2005-06-08 | 62d? | finish no earlier than 2005-06-08 | S1 | 496h | 496h | OSA7-SB | AePONA | eamonn.murray@aepona.com | Rel-7 | Alain | 22.127 |  |
| 938 | 303.2 | Stage 2 OSA API Service Brokering |  | 156d? | 2006-04-28 A | 2006-12-01 A | 100% | 2006-04-28 | 2006-12-01 | 156d? |  | C5 | 1248h | 1248h | OSA7-SB | AePONA | damian.oneill@aepona.com | Rel-7 | Kimmo | 23.198 |  |
| 939 | 303.3 | Stage 3 OSA API Service Brokering |  | 156d? | 2006-04-28 A | 2006-12-01 A | 100% | 2006-04-28 | 2006-12-01 | 156d? | finish no earlier than 2006-12-01 | C5 | 1248h | 1248h | OSA7-SB | AePONA | damian.oneill@aepona.com | Rel-7 | Kimmo | 29.198-16 |  |

Notes:
- 914: -
- 915: -
- 916: -
- 917: -
- 918: -
- 919: -
- 920: -
- 921: -
- 922: No CR submitted in rel-8 (according to CR database).
- 923: No Rel-8 changes
- 924: Moved from Rel-6 UID_50563 Enhancements of VGCS in public networks for communication of public authority officials
- 925: Voice Group Call Service
- 926: -
- 927: -
- 928: -
- 929: -
- 930: Voice Group Call Service
- 931: -
- 932: -
- 933: Previous name (before CT32) was Architecture and protocol aspects
- 934: -
- 935: CT4#33 stage 2 solution is still open. ...
- 936: -
- 937: az: WID URL corrected
- 938: -
- 939: -

| ID | WBS | Task | Type | Duration | Start | Finish | Complete | Baseline start | Baseline finish | Baseline duration | Constraint | Resources | Work | Actual work | Text1 | Text3 | Text4 | Text5 | Text6 | Text8 | Text12 | Text11 |
| --- | --- | --- | --- | --- | --- | --- | --- | --- | --- | --- | --- | --- | --- | --- | --- | --- | --- | --- | --- | --- | --- | --- |
| 940 | 303.4 | **OSA Stage 2/3 enhancements** |  | 291d? | 2006-04-28 A | 2007-06-08 A | 100% | 2006-04-28 | 2007-06-08 | 291d? |  | C5 | 10256h | 10256h | OSA7 | 29.198/9, 23.198 | AePONA | damian.oneill@aepona.com | Rel-7 | Kimmo |  |  |
| 941 | 303.4.1 | Parlay X Message Broadcast Web Service |  | 156d? | 2006-04-28 A | 2006-12-01 A | 100% | 2006-04-28 | 2006-12-01 | 156d? | finish no earlier than 2006-12-01 | C5 | 1248h | 1248h | OSA7 | 29.199-15, 23.198 | ETRI |  | Rel-7 | Kimmo |  |  |
| 942 | 303.4.2 | Parlay X Geocoding Web Service |  | 156d? | 2006-04-28 A | 2006-12-01 A | 100% | 2006-04-28 | 2006-12-01 | 156d? | finish no earlier than 2006-12-01 | C5 | 1248h | 1248h | OSA7 | 29.199-16, 23.198 | ETRI |  | Rel-7 | Kimmo |  |  |
| 943 | 303.4.3 | Parlay X Application driven QoS Web Service |  | 226d? | 2006-04-28 A | 2007-03-09 A | 100% | 2006-04-28 | 2007-03-09 | 226d? | finish no earlier than 2007-03-09 | C5 | 1808h | 1808h | OSA7 | 29.199-17, 23.198 | BT |  | Rel-7 | Kimmo |  |  |
| 944 | 303.4.4 | Parlay-X Device Capabilities and Configuration |  | 162d? | 2006-10-26 A | 2007-06-08 A | 100% | 2006-10-26 | 2007-06-08 | 162d? | finish no earlier than 2007-06-09 | C5 | 1296h | 1296h | OSA7 | 29.199-18, 23.198 | Telenor |  | Rel-7 | Kimmo |  |  |
| 945 | 303.4.5 | Parlay-X Multimedia Streaming Session Management Web Service |  | 97d? | 2006-10-26 A | 2007-03-09 A | 100% | 2006-10-26 | 2007-03-09 | 97d? | start no earlier than 2006-10-26 | C5 | 776h | 776h | OSA7 | 29.199-19, 23.198 | Telenor |  | Rel-7 | Kimmo |  |  |
| 946 | 303.4.6 | Parlay-X Multimedia Multicast Control Web Service |  | 97d? | 2006-10-26 A | 2007-03-09 A | 100% | 2006-10-26 | 2007-03-09 | 97d? | start no earlier than 2006-10-26 | C5 | 776h | 776h | OSA7 | 29.199-20, 23.198 | ETRI |  | Rel-7 | Kimmo |  |  |
| 947 | 303.4.7 | OSA API Conference Call Control SCF |  | 97d? | 2006-10-26 A | 2007-03-09 A | 100% | 2006-10-26 | 2007-03-09 | 97d? | start no earlier than 2006-10-26 | C5 | 776h | 776h | OSA7 | 29.198-04-5, 23.198 | Ericsson |  | Rel-7 | Kimmo |  |  |
| 948 | 304 | **Selective Disabling of UE Capabilities** |  | 624.36d? | 2005-01-24 A | 2007-06-15 A | 100% | 2005-01-24 | 2007-06-15 | 624.36d? |  | S1,S2,C1 | 12351.7h | 12351.7h | SDoUE |  | Motorola |  | Rel-7 | Alain |  |  |
| 949 | 304.1 | Stage 1 of SDoUE |  | 393.6d? | 2005-01-24 A | 2006-12-08 A | 100% | 2005-01-24 | 2006-12-08 | 393.6d? | finish no earlier than 2006-12-08 | S1 | 3148.8h | 3148.8h | SDoUE-CR | 22.011 | Motorola |  | Rel-7 | Alain |  |  |
| 950 | 304.2 | Deleted - TR on different possible architectures |  | 195d? | 2005-03-21 A | 2005-12-16 A | 100% | 2005-03-21 | 2005-12-16 | 195d? | finish no earlier than 2005-12-16 | S2 | 1560h | 1560h | SDoUE-FS | 23.805 abandonned at SP-30; descendant C1 24.305 | Vodafone | Gavin.Wong@vodafone.com | Rel-7 | Maurice | SP-30 |  |
| 951 | 304.3 | Stage 3 of SDoUE |  | 331d? | 2006-03-10 A | 2007-06-15 A | 100% | 2006-03-10 | 2007-06-15 | 331d? | finish no earlier than 2007-06-15 | C1 | 2648h | 2648h | SDoUE | 24.305 | Ericsson | christian.herrero@ericsson.com | Rel-7 | Frederic |  |  |
| 952 | 305 | **Network selection enhancements (NSP)** |  | 328d? | 2006-03-15 A | 2007-06-15 A | 100% | 2006-03-15 | 2007-06-15 | 328d? |  | S1 | 6320h | 6320h | NSP-CR | 22.101, 22.011, 23.122, 24.008, 25.304, 31.102, 45.008 | O2 | chris.friel@o2.com | Rel-7 | Alain |  |  |
| 953 | 305.1 | Stage 1 of NSP |  | 191d? | 2006-03-15 A | 2006-12-06 A | 100% | 2006-03-15 | 2006-12-06 | 191d? | start no earlier than 2006-03-15 | S1 | 1528h | 1528h | NSP-TS | 22.101, 22.011, 23.122, 24.008, 25.304, 31.102, 45.008 | O2 | chris.friel@o2.com | Rel-7 | Alain |  |  |
| 954 | 305.2 | Procedural aspects of NSP |  | 271d? | 2006-06-02 A | 2007-06-15 A | 100% | 2006-06-02 | 2007-06-15 | 271d? | finish no earlier than 2007-06-15 | C1 | 2168h | 2168h | NSP-CR | 23.122, 24.008, 31.102 | Motorola | Andrew Howell | Rel-7 | Frederic |  |  |
| 955 | 306 | Network Selection enhancements (NSP) - UE Conformance Testing |  | 396d? | 2007-06-01 A | 2008-12-05 A | 100% | 2007-06-01 | 2008-12-05 | 396d? | finish no earlier than 2008-12-05 | R5 | 3168h | 3168h | NSP-CR_UEConTest | 34.108, 34.123-1, 34.123-2, 34.123-3 | Nokia | jarkko.hellsten@nokia.com | Rel-7 | Ingbert |  | RP-080819 |
| 956 | 307 | **Access Class Barring and Overload Protection** |  | 650d? | 2004-03-15 A | 2006-09-08 A | 100% | 2004-03-15 | 2006-09-08 | 650d? |  | S2,C1 | 3568h | 3568h | ACBOP | 23.898 | Vodafone | Chris Pudney | Rel-7 | Maurice |  |  |
| 957 | 307.1 | TR on Stage 2 |  | 274d? | 2004-03-15 A | 2005-03-31 A | 100% | 2004-03-15 | 2005-03-31 | 274d? | finish no earlier than 2005-03-31 | S2 | 2192h | 2192h | ACBOP | 23.898 | NTT DoCoMo | Jean-Jacques Davidian (davidian@docomo.fr) | Rel-7 | Maurice |  |  |
| 958 | 307.2 | Stage 3 CN aspects of ACBOP |  | 172d? | 2005-06-06 A | 2006-01-31 A | 100% | 2005-06-06 | 2006-01-31 | 172d? | start no earlier than 2005-06-06 | C1 | 1376h | 1376h | ACBOP | 24.008 |  |  | Rel-7 | Frederic |  |  |
| 959 | 307.3 | Deleted - Potential impact on Iu interface Overload functionality | milestone | 0d? | 2004-03-15 A | 2004-03-15 A | 100% | 2004-03-15 | 2004-03-15 | 0d? | finish no earlier than 2004-03-15 | RP |  |  | ACBOP | 25.413 |  |  | Rel-7 | Issam | RP-25 |  |
| 960 | 307.4 | Deleted - Extra ACBOP information in RAN | milestone | 0d? | 2004-03-15 A | 2004-03-15 A | 100% | 2004-03-15 | 2004-03-15 | 0d? | finish no earlier than 2004-03-15 | RP |  |  | ACBOP | 25.331 |  |  | Rel-7 | Issam | RP-25 |  |
| 961 | 307.5 | Deleted - Extra ACBOP information in GERAN | milestone | 0d? | 2006-09-08 A | 2006-09-08 A | 100% | 2006-09-08 | 2006-09-08 | 0d? | start no earlier than 2006-09-08 | GP |  |  | ACBOP | 44.018 |  |  | Rel-7 | Paolo | RP-33 |  |
| 962 | 308 | **System enhancements for fixed broadband access to IMS** |  | 876d? | 2003-11-05 A | 2007-03-14 A | 100% | 2003-11-05 | 2007-03-14 | 876d? |  | S2,S3,S5,C1,C3,C4 | 36656h | 36656h | FBI |  |  |  | Rel-7 | Maurice |  |  |
| 963 | 308.1 | **TISPAN Rel 1 related aspects** |  | 873d? | 2003-11-05 A | 2007-03-09 A | 100% | 2003-11-05 | 2007-03-09 | 873d? |  | S2 | 31568h | 31568h | FBI-TIS1 |  |  |  | Rel-7 | Maurice |  |  |
| 964 | 308.1.1 | Stage 2 of FBI for TISPAN R1 |  | 365d? | 2004-10-14 A | 2006-03-08 A | 100% | 2004-10-14 | 2006-03-08 | 365d? | start no earlier than 2004-10-14 | S2 | 2920h | 2920h | FBI-TIS1 |  |  |  | Rel-7 | Maurice |  |  |

Notes:
- 940: CP#34: WID updated. Completion 12/06 =>03/07
- 941: -
- 942: -
- 943: -
- 944: -
- 945: -
- 946: -
- 947: -
- 948: Moved from FS section Feb 06
- 949: Moved from FS section Feb 06
- 950: Moved from FS section Feb 06. Abandoned at SP-30
- 951: -
- 952: -
- 953: -
- 954: -
- 955: RP#42 completed. SR in RP-080819. Linked to UID_7041 (NSP-CR).
- 956: -
- 957: -
- 958: NEW - inserted on 2/9/2004
- 959: -
- 960: -
- 961: -
- 962: -
- 963: -
- 964: -

| ID | WBS | Task | Duration | Start | Finish | Complete | Baseline start | Baseline finish | Baseline duration | Constraint | Resources | Work | Actual work | Text1 | Text4 | Text5 | Text6 | Text8 | Text3 | Text12 |
| --- | --- | --- | --- | --- | --- | --- | --- | --- | --- | --- | --- | --- | --- | --- | --- | --- | --- | --- | --- | --- |
| 965 | 308.1.2 | **Protocol impact of FBI for TISPAN R1** | 873d? | 2003-11-05 A | 2007-03-09 A | 100% | 2003-11-05 | 2007-03-09 | 873d? |  | C1 | 20720h | 20720h | FBI-TIS1 | Siemens | peter.leis@nsn.com | Rel-7 | Frederic |  |  |
| 966 | 308.1.2.1 | CT1 aspects of FBI for TISPAN R1 | 802d? | 2003-11-05 A | 2006-11-30 A | 100% | 2003-11-05 | 2006-11-30 | 802d? | finish no earlier than 2006-11-30 | C1 | 6416h | 6416h | FBI-TIS1 | Siemens | peter.leis@nsn.com | Rel-7 | Frederic | 24.819, 24.229 |  |
| 967 | 308.1.2.2 | CT3 aspects of FBI for TISPAN R1 | 808d? | 2003-11-05 A | 2006-12-08 A | 100% | 2003-11-05 | 2006-12-08 | 808d? | finish no earlier than 2006-12-08 | C3 | 6464h | 6464h | FBI-TIS1 | Siemens | peter.leis@nsn.com | Rel-7 | Gwiho | 29.163, 29.209 |  |
| 968 | 308.1.2.3 | CT4 aspects of FBI for TISPAN R1 | 301d? | 2006-01-13 A | 2007-03-09 A | 100% | 2006-01-13 | 2007-03-09 | 301d? | finish no earlier than 2007-03-09 | C4 | 2408h | 2408h | FBI-TIS1-st3-c4 | Siemens | peter.leis@nsn.com | Rel-7 | Kimmo | 29.229 |  |
| 969 | 308.1.3 | Security Enhancements for FBI | 118d? | 2005-06-28 A | 2005-12-08 A | 100% | 2005-06-28 | 2005-12-08 | 118d? | start no earlier than 2005-06-28 | S3 | 944h | 944h | FBI-ISE | Ericsson | Bengt.Sahlin@ericsson.com | Rel-7 | Dionisio | 33.203 |  |
| 970 | 308.2 | **PacketCable Related aspects** | 291d? | 2006-02-01 A | 2007-03-14 A | 100% | 2006-02-01 | 2007-03-14 | 291d? |  | S2,S5,C1 | 5088h | 5088h | FBI-PCBL | CableLabs | Bernie McKibben | Rel-7 | Maurice |  |  |
| 971 | 308.2.1 | Stage 1,2 of FBI for PacketCable | 228d? | 2006-02-01 A | 2006-12-15 A | 100% | 2006-02-01 | 2006-12-15 | 228d? | finish no earlier than 2006-12-15 | S2 | 1824h | 1824h | FBI-PCBL | CableLabs | Bernie McKibben | Rel-7 | Maurice | 22.228, 23.228 |  |
| 972 | 308.2.2 | Protocol impact of FBI for PacketCable | 228d? | 2006-05-01 A | 2007-03-14 A | 100% | 2006-05-01 | 2007-03-14 | 228d? | finish no earlier than 2007-03-15 | C1 | 1824h | 1824h | FBI-PCBL |  |  | Rel-7 | Frederic |  |  |
| 973 | 308.2.3 | SA5 Charging aspects of FBI for PacketCable | 180d? | 2006-03-31 A | 2006-12-07 A | 100% | 2006-03-31 | 2006-12-07 | 180d? | finish no earlier than 2006-12-07 | S5 | 1440h | 1440h | FBI-PCBL-CH | CableLabs | Bernie McKibben | Rel-7 | Dionisio | 32.240, 32.260, 32.298, 32.299 |  |
| 974 | 309 | **Support of SMS over generic 3GPP IP access** | 696d? | 2004-10-14 A | 2007-06-14 A | 100% | 2004-10-14 | 2007-06-14 | 696d? |  | S2,C4,C1 | 12408h | 12408h | SMSIP | Huawei | zhangwenlin@huawei.com | Rel-7 | Maurice |  |  |
| 975 | 309.1 | FS on SMSIP | 173d? | 2004-10-14 A | 2005-06-13 A | 100% | 2004-10-14 | 2005-06-13 | 173d? | start no earlier than 2004-10-14 | S2 | 1384h | 1384h | SMSIP | Huawei | zhangwenlin@huawei.com | Rel-7 | Maurice | 23.804 |  |
| 976 | 309.2 | Stage 2 for SMSIP | 333d? | 2005-06-08 A | 2006-09-15 A | 100% | 2005-06-08 | 2006-09-15 | 333d? | finish no earlier than 2006-09-15 | S2 | 2664h | 2664h | SMSIP | Huawei | zhangwenlin@huawei.com | Rel-7 | Maurice | 23.204 |  |
| 977 | 309.3 | **Stage 3 for SMSIP** | 527d? | 2005-06-08 A | 2007-06-14 A | 100% | 2005-06-08 | 2007-06-14 | 527d? |  | C4,C1 | 8360h | 8360h | SMSIP-St3 | Nokia | jari.jansson@nokia.com | Rel-7 | Kimmo |  |  |
| 978 | 309.3.1 | CT1 aspects for SMSIP | 527d? | 2005-06-08 A | 2007-06-14 A | 100% | 2005-06-08 | 2007-06-14 | 527d? | finish no earlier than 2007-06-15 | C1 | 4216h | 4216h | SMSIP | Nokia | jari.jansson@nokia.com | Rel-7 | Frederic | 23.040, 24.229 |  |
| 979 | 309.3.2 | CT4 aspects for SMSIP | 518d? | 2005-06-08 A | 2007-06-01 A | 100% | 2005-06-08 | 2007-06-01 | 518d? | finish no earlier than 2007-06-01 | C4 | 4144h | 4144h | SMSIP-St3-c4 | Nokia | jari.jansson@nokia.com | Rel-7 | Kimmo | 23.008, 29.002 |  |
| 980 | 310 | **Evolution of Policy Control and Charging** | 817d? | 2004-10-14 A | 2007-11-30 A | 100% | 2004-10-14 | 2007-11-30 | 817d? |  | S2,S5,C3,C1 | 30336h | 30336h | PCC | Nokia | balazs.bertenyi@nsn.com | Rel-7 | Maurice |  |  |
| 981 | 310.1 | Deleted - TR for PCC | 315d? | 2004-10-14 A | 2005-12-29 A | 100% | 2004-10-14 | 2005-12-29 | 315d? | finish no earlier than 2005-12-28 | S2 | 2520h | 2520h | PCC | Nokia | balazs.bertenyi@nsn.com | Rel-7 | Maurice | 23.803 | SP-33 |
| 982 | 310.2 | Stage 2 for PCC | 315d? | 2005-07-04 A | 2006-09-15 A | 100% | 2005-07-04 | 2006-09-15 | 315d? | finish no earlier than 2006-09-15 | S2 | 2520h | 2520h | PCC | Nokia | balazs.bertenyi@nsn.com | Rel-7 | Maurice | 23.203 |  |
| 983 | 310.3 | Evolution of policy control and flow based bearer level charging | 109d? | 2006-08-01 A | 2006-12-29 A | 100% | 2006-08-01 | 2006-12-29 | 109d? | start no earlier than 2006-08-01 | S2 | 872h | 872h | PCC | Nokia | balazs.bertenyi@nsn.com | Rel-7 | Maurice | 23.207, 23.002, 23.228 |  |
| 984 | 310.4 | SA5 Charging aspects of PCC | 316d? | 2006-03-31 A | 2007-06-15 A | 100% | 2006-03-31 | 2007-06-15 | 316d? | finish no earlier than 2007-06-15 | S5 | 2528h | 2528h | PCC-CH | Orange | alain.bibas@orange-ft.com | Rel-7 | Dionisio | 32.250, 32.251, 32.298, 32.299 |  |
| 985 | 310.5 | Gx reference point for Policy and Charging Control | 521d? | 2005-12-02 A | 2007-11-30 A | 100% | 2005-12-02 | 2007-11-30 | 521d? | finish no earlier than 2007-09-14 | C3 | 4168h | 4168h | PCC-Gx | Siemens | Thomas.Belling@nsn.com | Rel-7 | Gwiho | 29.212 (not progressed to Rel-7: 29.210, 29.207, 29.208) |  |
| 986 | 310.6 | **Rx reference point for PCC CT3 aspects** | 521d? | 2005-12-02 A | 2007-11-30 A | 100% | 2005-12-02 | 2007-11-30 | 521d? |  | C3,C1 | 11192h | 11192h | PCC-Rx | Ericsson | j.javier.pastor@ericsson.com | Rel-7 | Gwiho |  |  |
| 987 | 310.6.1 | PCC-Rx CT3 aspects | 521d? | 2005-12-02 A | 2007-11-30 A | 100% | 2005-12-02 | 2007-11-30 | 521d? | finish no earlier than 2007-09-14 | C3 | 4168h | 4168h | PCC-Rx-c3 | Ericsson | j.javier.pastor@ericsson.com | Rel-7 | Gwiho | 29.213, 29.214 (not progressed to Rel-7: 29.209, 29.211) |  |
| 988 | 310.6.2 | PCC-Rx CT1 aspects | 357d? | 2005-12-02 A | 2007-06-15 A | 100% | 2005-12-02 | 2007-06-15 | 357d? | finish no earlier than 2007-06-15 | C1 | 2856h | 2856h | PCC-Rx-Gx-c1 | Ericsson | j.javier.pastor@ericsson.com | Rel-7 | Frederic | 24.229 |  |

Notes:
- 965: -
- 966: end date updated by CT1-chairman after CP#33
- 967: -
- 968: CT4#32: a set of CRs on FBI for cable labs
- 969: Duplicated entry ("ACCSEC2", "Access Security Enhancements", SP-040865) deleted by A.Sultan
- 970: -
- 971: -
- 972: -
- 973: 03/2006 SP#31 WID approved
- 974: SP#33 updated WID (removed MMS)
- 975: SP#33 updated WID
- 976: SP#33 updated WID
- 977: CP#34 updated WID
- 978: CP#34 updated WID
- 979: CP#34 updated WID
- 980: SP-29 approved WID. SP-31 updated WID adding SA5 charging. 23.125 will be discontinued from Rel-7.
- 981: SP-30: S2 has no intention for TR completion
- 982: SP-29 approved WID. SP-31 updated WID. 23.125 will be discontinued from Rel-7.
- 983: SP-29 approved WID. SP-31 updated WID. 23.125 will be discontinued from Rel-7.
- 984: SP-31 updated WID with SA5 charging.
- 985: -
- 986: WID approved at CP#30, Revised at CP#31, Revised at CP#33
- 987: -
- 988: -

| ID | WBS | Task | Type | Duration | Start | Finish | Complete | Baseline start | Baseline finish | Baseline duration | Constraint | Resources | Work | Actual work | Text1 | Text4 | Text5 | Text6 | Text8 | Text3 | Text12 |
| --- | --- | --- | --- | --- | --- | --- | --- | --- | --- | --- | --- | --- | --- | --- | --- | --- | --- | --- | --- | --- | --- |
| 989 | 311 | **Voice call continuity between CS and IMS (incl. I-WLAN)** |  | 641d? | 2004-12-31 A | 2007-06-15 A | 100% | 2004-12-31 | 2007-06-15 | 641d? |  | S2,S1,S5,C1,C4 | 12224h | 12224h | VCC | Alcatel-Lucent | Keith Drage (drage@alcatel-lucent.com) | Rel-7 | Maurice |  |  |
| 990 | 311.1 | TR for VCC |  | 245d? | 2004-12-31 A | 2005-12-08 A | 100% | 2004-12-31 | 2005-12-08 | 245d? | finish no earlier than 2005-12-08 | S2 | 1960h | 1960h | VCC | Alcatel-Lucent | Andy Bennett (andybennett@alcatel-lucent.com) | Rel-7 | Maurice | 23.806 |  |
| 991 | 311.2 | Stage 1 for VCC |  | 140d? | 2005-03-17 A | 2005-09-28 A | 100% | 2005-03-17 | 2005-09-28 | 140d? | finish no earlier than 2005-09-28 | S1 | 1120h | 1120h | VCC | Alcatel-Lucent | Andy Bennett (andybennett@alcatel-lucent.com) | Rel-7 | Alain | 22.101 |  |
| 992 | 311.3 | Stage 2 for VCC |  | 264d? | 2005-09-06 A | 2006-09-08 A | 100% | 2005-09-06 | 2006-09-08 | 264d? | finish no earlier than 2006-09-08 | S2 | 2112h | 2112h | VCC | Alcatel-Lucent | Andy Bennett (andybennett@alcatel-lucent.com) | Rel-7 | Maurice | 23.206 |  |
| 993 | 311.4 | SA5 Charging aspects of VCC |  | 325d? | 2006-03-17 A | 2007-06-14 A | 100% | 2006-03-17 | 2007-06-14 | 325d? | finish no earlier than 2007-06-14 | S5 | 2600h | 2600h | VCC-CH | Orange | alain.bibas@orange-ft.com | Rel-7 | Dionisio | 32.250, 32.260 |  |
| 994 | 311.5 | **Stage 3 for VCC** |  | 358d? | 2006-02-01 A | 2007-06-15 A | 100% | 2006-02-01 | 2007-06-15 | 358d? |  | C1,C4 | 4432h | 4432h | VCC | Alcatel-Lucent | Keith Drage (drage@alcatel-lucent.com) | Rel-7 | Frederic |  |  |
| 995 | 311.5.1 | CT1 aspects of VCC |  | 358d? | 2006-02-01 A | 2007-06-15 A | 100% | 2006-02-01 | 2007-06-15 | 358d? | finish no earlier than 2007-06-15 | C1 | 2864h | 2864h | VCC | Alcatel-Lucent | Keith Drage (drage@alcatel-lucent.com) | Rel-7 | Frederic | 24.206, 24.216 |  |
| 996 | 311.5.2 | CT4 aspects of VCC |  | 196d? | 2006-06-09 A | 2007-03-09 A | 100% | 2006-06-09 | 2007-03-09 | 196d? | start no earlier than 2006-06-09 | C4 | 1568h | 1568h | VCC-St3-c4 | Alcatel-Lucent | Keith Drage (drage@alcatel-lucent.com) | Rel-7 | Kimmo | 23.003 |  |
| 997 | 311.5.3 | Deleted - CT3 aspects of VCC | milestone | 0d? | 2006-11-02 A | 2006-11-02 A | 100% | 2006-11-02 | 2006-11-02 | 0d? | finish no earlier than 2006-11-02 | C3 |  |  | VCC | Alcatel-Lucent | Keith Drage (drage@alcatel-lucent.com) | Rel-7 | Gwiho | 29.163 | CP-33 |
| 998 | 312 | **One Tunnel solution for optimization of Packet Data Traffic** |  | 418d? | 2006-03-27 A | 2007-10-31 A | 100% | 2006-03-27 | 2007-10-31 | 418d? |  | S2 | 7048h | 7048h | OPTUNEL | Nokia | antti.j.pasanen@nokia.com | Rel-7 | Maurice |  |  |
| 999 | 312.1 | Deleted - Study on Stage 2 for One Tunnel solution |  | 125d? | 2006-03-27 A | 2006-09-15 A | 100% | 2006-03-27 | 2006-09-15 | 125d? | finish no earlier than 2005-09-12 | S2 | 1000h | 1000h | OPTUNEL-Study | Nokia | antti.j.pasanen@nokia.com | Rel-7 | Maurice | 23.809 | SP-34 |
| 1000 | 312.2 | One Tunnel Deployment Guideline |  | 268d? | 2006-10-23 A | 2007-10-31 A | 100% | 2006-10-23 | 2007-10-31 | 268d? | finish no earlier than 2007-10-31 | S2 | 2144h | 2144h | OPTUNEL-Guide | Huawei | lan.liu@huawei.com | Rel-7 | Maurice | 23.919 |  |
| 1001 | 312.3 | Stage 2 specification for One Tunnel solution |  | 70d? | 2006-09-11 A | 2006-12-15 A | 100% | 2006-09-11 | 2006-12-15 | 70d? | finish no earlier than 2006-12-15 | S2 | 560h | 560h | OPTUNEL-Stage2 | Nokia | antti.j.pasanen@nokia.com | Rel-7 | Maurice | 23.060 |  |
| 1002 | 313 | **CSI Terminating Session handling** |  | 267d? | 2006-06-08 A | 2007-06-15 A | 100% | 2006-06-08 | 2007-06-15 | 267d? |  | S2,C1 | 4728h | 4728h | CSItermS | Samsung | Osok Song | Rel-7 | Maurice |  |  |
| 1003 | 313.1 | Stage 2 of CStermS |  | 192d? | 2006-06-08 A | 2007-03-02 A | 100% | 2006-06-08 | 2007-03-02 | 192d? | start no earlier than 2006-06-08 | S2 | 1536h | 1536h | CSItermS | Samsung | Osok Song | Rel-7 | Maurice | 23.279 |  |
| 1004 | 313.2 | Stage 3 of CStermS |  | 132d? | 2006-12-14 A | 2007-06-15 A | 100% | 2006-12-14 | 2007-06-15 | 132d? | finish no earlier than 2007-06-15 | C1 | 1056h | 1056h | CSItermS | Samsung | chenho.chin@samsung.com | Rel-7 | Frederic | 24.229, 24.279 |  |
| 1005 | 313.3 | Deleted - duplicated with UID 340015 -Stage 3 CSI Terminating Session handling | milestone | 0d? | 2007-03-09 A | 2007-03-09 A | 100% | 2007-03-09 | 2007-03-09 | 0d? | start no earlier than 2007-03-09 | C1 |  |  | CSItermS | Samsung | chenho.chin@samsung.com | Rel-7 | Frederic | 24.229, 24.179, 24.279 | CP-34 |
| 1006 | 314 | Liberty Alliance and 3GPP Security Interworking |  | 451d? | 2005-03-10 A | 2006-11-30 A | 100% | 2005-03-10 | 2006-11-30 | 451d? | finish no earlier than 2006-11-30 | S3 | 3608h | 3608h | LibSec | Nokia | Silke.Holtmanns@NOKIA.COM | Rel-7 | Dionisio | 33.980 |  |
| 1007 | 315 | Trust Requirements for Open Platforms in 3GPP |  | 499d? | 2005-01-03 A | 2006-11-30 A | 100% | 2005-01-03 | 2006-11-30 | 499d? | finish no earlier than 2006-11-30 | S3 | 3992h | 3992h | TrustOP | Nokia | Silke.Holtmanns@NOKIA.COM | Rel-7 | Dionisio | 33.905 |  |
| 1008 | 316 | Development of UEA2 and UIA2 |  | 268d? | 2004-12-01 A | 2005-12-09 A | 100% | 2004-12-01 | 2005-12-09 | 268d? | finish no earlier than 2005-12-09 | S3 | 2144h | 2144h | AlgUEA2 | TeliaSonera | per.christoffersson@teliasonera.com | Rel-7 | Dionisio | 35.919, 35.215, 35.216, 35.217, 35.218 |  |
| 1009 | 317 | Lawful Interception in the 3GPP Rel-7 architecture |  | 118d? | 2005-06-28 A | 2005-12-08 A | 100% | 2005-06-28 | 2005-12-08 | 118d? | start no earlier than 2005-06-28 | S3 | 944h | 944h | LI-7A | BMWI | berthold.wilhelm@regtp.de | Rel-7 | Dionisio | 33.106, 33.107, 33.108 |  |
| 1010 | 318 | Key establishment between a UICC and a terminal |  | 201.45d? | 2005-12-07 A | 2006-09-28 A | 100% | 2005-12-07 | 2006-09-28 | 201.45d? | finish no earlier than 2006-09-28 | S3 | 1611.6h | 1611.6h | KeyEstUTerm | Gemalto | mireille.pauliac@gemplus.com | Rel-7 | Dionisio | 33.110 |  |
| 1011 | 319 | NDS Authentication Framework Extension for Transport Layer Security |  | 50d? | 2006-09-28 A | 2006-12-06 A | 100% | 2006-09-28 | 2006-12-06 | 50d? | finish no earlier than 2006-09-28 | S3 | 400h | 400h | NDSAFTLS | Nokia | tiina.s.koskinen@nokia.com | Rel-7 | Dionisio | 33.310 |  |
| 1012 | 320 | **Security enhancements** |  | 319d? | 2005-09-12 A | 2006-11-30 A | 100% | 2005-09-12 | 2006-11-30 | 319d? |  | S3,C1,C4 | 4856h | 4856h | SEC7 |  |  | Rel-7 | Dionisio |  |  |
| 1013 | 320.1 | HTTPS connection between a UICC and a NAF |  | 1d? | 2005-09-12 A | 2005-09-12 A | 100% | 2005-09-12 | 2005-09-12 | 1d? | start no earlier than 2005-09-12 | S3,C1 | 8h | 8h | SEC7-HSUN | Gemalto | JSeif@axalto.com, mireille.pauliac@gemplus.com | Rel-7 | Dionisio | 33.918, 33.222, 24.109 |  |
| 1014 | 320.2 | 2G GBA: 2G SIM usage in 3GPP GAA framework |  | 61d? | 2005-09-12 A | 2005-12-05 A | 100% | 2005-09-12 | 2005-12-05 | 61d? | finish no earlier than 2005-12-05 | S3 | 488h | 488h | SEC7-2GGBA | Nokia | Silke.Holtmanns@nokia.com | Rel-7 | Dionisio | 33.920, 33.220 |  |
| 1015 | 320.3 | Generic Authentication Architecture usage extensions and optimizations |  | 319d? | 2005-09-12 A | 2006-11-30 A | 100% | 2005-09-12 | 2006-11-30 | 319d? | finish no earlier than 2006-11-30 | S3 | 2552h | 2552h | SEC7-GAA2 | Nokia | Silke.Holtmanns@nokia.com | Rel-7 | Dionisio | 33.220, 29.109, 24.109, (33.223 goes to R8) |  |

Notes:
- 989: WID approved SP#27; updated SP#28; updated SP#32
- 990: -
- 991: -
- 992: -
- 993: 03/2006 SP#31 WID approved
- 994: -
- 995: -
- 996: -
- 997: -
- 998: -
- 999: S2#52 CREATED. TR for Info SP-33. SP-34: S2 Report intention to discontinue TR
- 1000: -
- 1001: S2#52 CREATED
- 1002: Triggered by the abandoned Study UID_32117
- 1003: -
- 1004: CP-34 approved WID. CP-35 updated WID
- 1005: CP-34 approved WID
- 1006: WID approved SP#27.
- 1007: WID approved SP#26.
- 1008: WID approved SP#26, Dependant on Funding Availability.
- 1009: -
- 1010: -
- 1011: TLS profile is moved to Rel-8
- 1012: -
- 1013: -
- 1014: -
- 1015: 33.223 goes to R8

| ID | WBS | Task | Duration | Start | Finish | Complete | Baseline start | Baseline finish | Baseline duration | Total slack | Constraint | Resources | Work | Actual work | Text1 | Text4 | Text5 | Text6 | Text8 | Text3 | Text12 | Text2 | Text7 |
| --- | --- | --- | --- | --- | --- | --- | --- | --- | --- | --- | --- | --- | --- | --- | --- | --- | --- | --- | --- | --- | --- | --- | --- |
| 1016 | 320.4 | **SS7 TCAP security Gateway** | 241d? | 2005-09-12 A | 2006-08-14 A | 100% | 2005-09-12 | 2006-08-14 | 241d? |  |  | S3,C4 | 1808h | 1808h | SEC7-NDS-TCAPsec | Siemens | marc.blommaert.ext@nsn.com | Rel-7 | Dionisio |  |  |  |  |
| 1017 | 320.4.1 | SA3 aspects of SEC7-NDS-TCAPsec | 130d? | 2005-09-12 A | 2006-03-10 A | 100% | 2005-09-12 | 2006-03-10 | 130d? |  | finish no earlier than 2006-03-10 | S3 | 1040h | 1040h | SEC7-NDS-TCAPsec-SA3 | Siemens | marc.blommaert.ext@nsn.com | Rel-7 | Dionisio | 33.204 |  |  |  |
| 1018 | 320.4.2 | TCAPsec Gateway | 96d? | 2006-04-03 A | 2006-08-14 A | 100% | 2006-04-03 | 2006-08-14 | 96d? |  | start no earlier than 2006-04-01 | C4 | 768h | 768h | SEC7-TCAP | Siemens | Ulrich.wiehe@gksag.de | Rel-7 | Kimmo | 29.204, 29.002 |  |  |  |
| 1019 | 321 | IMS Stage 3 IETF Protocol alignment | 589d? | 2004-12-10 A | 2007-03-14 A | 100% | 2004-12-10 | 2007-03-14 | 589d? |  | finish no earlier than 2007-03-15 | C1 | 4712h | 4712h | IMSProtoc |  |  | Rel-7 | Frederic | 24.930 |  |  |  |
| 1020 | 322 | **Interoperability between VGCS/VBS and A/Gb flexibility** | 253d? | 2006-03-22 A | 2007-03-09 A | 100% | 2006-03-22 | 2007-03-09 | 253d? |  |  | C1,C4 | 3296h | 3296h | VGCSFlex | Siemens | robert.zaus@nsn.com | Rel-7 | Frederic |  |  |  |  |
| 1021 | 322.1 | CT1 aspects of VGCSFlex | 159d? | 2006-03-22 A | 2006-10-30 A | 100% | 2006-03-22 | 2006-10-30 | 159d? |  | finish no earlier than 2006-10-30 | C1 | 1272h | 1272h | VGCSFlex | Siemens | robert.zaus@nsn.com | Rel-7 | Frederic | 43.068, 43.069 |  |  |  |
| 1022 | 322.2 | CT4 aspects of VGCSFlex | 253d? | 2006-03-22 A | 2007-03-09 A | 100% | 2006-03-22 | 2007-03-09 | 253d? |  | finish no earlier than 2007-03-09 | C4 | 2024h | 2024h | VGCSFlex-c4 | Siemens | robert.zaus@nsn.com | Rel-7 | Kimmo | 29.002 |  |  |  |
| 1023 | 323 | DIAMETER on the GGSN Gi interface | 586d? | 2004-09-10 A | 2006-12-08 A | 100% | 2004-09-10 | 2006-12-08 | 586d? |  | finish no earlier than 2006-12-08 | C3 | 4688h | 4688h | DIAMGi | Vodafone | Nico.Gabriele@vodafone.com | Rel-7 | Gwiho | 29.061 |  |  |  |
| 1024 | 324 | DIAMETER on the PDG Wi interface | 586d? | 2004-09-10 A | 2006-12-08 A | 100% | 2004-09-10 | 2006-12-08 | 586d? |  | finish no earlier than 2006-12-08 | C3 | 4688h | 4688h | DIAMWi | Vodafone | Nico.Gabriele@vodafone.com | Rel-7 | Gwiho | 29.161 |  |  |  |
| 1025 | 325 | Interworking between the 3GPP CS domain with BICC or ISUP as signalling protocol and external SIP-I networks | 478d? | 2006-09-22 A | 2008-07-22 A | 100% | 2006-09-22 | 2008-07-22 | 478d? |  | finish no earlier than 2007-09-14 | C3 | 3824h | 3824h | ExtSIPI | Siemens | Thomas.Belling@nsn.com | Rel-7 | Gwiho | 29.164 |  |  |  |
| 1026 | 326 | PDU multiplexing at Nb Interface with IP transport | 427d? | 2006-12-04 A | 2008-07-22 A | 100% | 2006-12-04 | 2008-07-22 | 427d? |  | start no earlier than 2006-12-04 | C3 | 3416h | 3416h | NbIPMux | Alcatel-Lucent | Jean.Rzeznik@alcatel-lucent.fr | Rel-7 | Gwiho | 29.414 |  |  |  |
| 1027 | 327 | **Mp (MRFC - MRFP) interface** | 345d? | 2006-02-13 A | 2007-06-08 A | 100% | 2006-02-13 | 2007-06-08 | 345d? |  |  | C4,C1 | 4384h | 4384h | Mp | Ericsson | philip.hodges@ericsson.com | Rel-7 | Kimmo |  |  |  |  |
| 1028 | 327.1 | CT1 aspects of Mp | 1d | 2006-02-13 A | 2006-02-13 A | 100% | 2006-02-13 | 2006-02-13 | 1d |  | finish no earlier than 2006-02-13 | C1 | 8h | 8h | Mp | Ericsson | philip.hodges@ericsson.com | Rel-7 | Frederic | 24.229 |  |  |  |
| 1029 | 327.2 | Deleted - CT3 aspects of Mp | 1d | 2006-09-22 A | 2006-09-22 A | 100% | 2006-09-22 | 2006-09-22 | 1d |  | start no earlier than 2006-09-22 | C3 | 8h | 8h | Mp | Ericsson | philip.hodges@ericsson.com | Rel-7 | Gwiho | 29.162 | CP-33 |  |  |
| 1030 | 327.3 | Procedures description | 201d? | 2006-06-02 A | 2007-03-09 A | 100% | 2006-06-02 | 2007-03-09 | 201d? |  | finish no earlier than 2007-03-09 | C4 | 1608h | 1608h | Mp-PROCc4 | Huawei | Chencheng@huawei.com | Rel-7 | Kimmo | 23.333 |  |  |  |
| 1031 | 327.4 | Stage 3 | 345d | 2006-02-13 A | 2007-06-08 A | 100% | 2006-02-13 | 2007-06-08 | 345d |  | finish no earlier than 2007-06-08 | C4 | 2760h | 2760h | Mp-St3c4 | Ericsson | philip.hodges@ericsson.com | Rel-7 | Kimmo | 29.333 |  |  |  |
| 1032 | 328 | Routeing of MT-SMS via the HPLMN | 71d? | 2006-12-01 A | 2007-03-09 A | 100% | 2006-12-01 | 2007-03-09 | 71d? |  | finish no earlier than 2007-03-09 | C4,C1 | 568h | 568h | SMSviaH | Vodafone | Nick.Russell@vodafone.com | Rel-7 | Kimmo | 23.040, 29.002 |  |  |  |
| 1033 | 329 | Mobile Termination whilst the MS is moving to another MSC | 60d? | 2007-03-09 A | 2007-05-31 A | 100% | 2007-03-09 | 2007-05-31 | 60d? |  | start no earlier than 2007-03-09 | C4 | 480h | 480h | MTmovMS | Alcatel-Lucent | bruno.landais@alcatel-lucent.fr | Rel-7 | Kimmo | 23.008, 23.012, 23.018, 23.078, 23.079, 29.002 |  |  |  |
| 1034 | 330 | ISIM API for Java Card | 620d? | 2005-03-14 A | 2007-07-27 A | 100% | 2005-03-14 | 2007-07-27 | 620d? |  | finish no earlier than 2007-07-27 | C6 | 4960h | 4960h | APIJAVA | Sun | Sebastian Hans | Rel-7 | Xavier | 31.103, 102 241 |  |  |  |
| 1035 | 331 | Rel-7 (U)SIM API Testing (TS 31.213) | 206d? | 2009-05-30 | 2010-03-12 |  | 2009-05-30 | 2010-03-12 | 206d? | 395d | finish no earlier than 2010-03-12 | C6 | 1648h |  | USIM_API_test | Sagem Orga | gerrit.hartbrod@sagem-orga.com | Rel-7 | Xavier | 31.213 |  | PCG-23 | CP-44 |
| 1036 | 332 | High speed interface between the UICC and the ME | 311d? | 2006-09-22 A | 2007-11-30 A | 100% | 2006-09-22 | 2007-11-30 | 311d? |  | finish no earlier than 2007-11-30 | C6 | 2488h | 2488h | HSI | Gemalto | jacques.seif@GEMALTO.COM | Rel-7 | Xavier | 31.101 |  |  |  |
| 1037 | 333 | Video Codec Performance Requirements | 634d? | 2005-01-03 A | 2007-06-07 A | 100% | 2005-01-03 | 2007-06-07 | 634d? |  | finish no earlier than 2007-06-07 | S4 | 5072h | 5072h | VICPer | Siemens | juergen.pandel@siemens.com | Rel-7 | Paolo | 26.234, 26.235, 26.346, 26.140, 26.902 |  |  |  |
| 1038 | 334 | Dynamic and Interactive Multimedia Scenes | 583d? | 2005-03-15 A | 2007-06-07 A | 100% | 2005-03-15 | 2007-06-07 | 583d? |  | finish no earlier than 2007-06-07 | S4 | 4664h | 4664h | DIMS | Streamezzo | gaelle.martin-cocher@streamezzo.com | Rel-7 | Paolo | 26.140, 26.142, 26.234, 26.244, 23.346 |  |  |  |
| 1039 | 335 | 3G-324M Video Telephony Call Setup Times Improvements | 341d? | 2005-06-08 A | 2006-09-27 A | 100% | 2005-06-08 | 2006-09-27 | 341d? |  | finish no earlier than 2006-09-27 | S4 | 2728h | 2728h | VTCSTI | Vodafone | edward.hall@vodafone.co.uk | Rel-7 | Paolo | 26.911 |  |  |  |

Notes:
- 1016: -
- 1017: -
- 1018: -
- 1019: TR 24.930: Signalling flows for the session setup in the IM CN subsystem based on Session Initiation Protocol (SIP)
- 1020: Voice Group Call Service
- 1021: -
- 1022: -
- 1023: -
- 1024: -
- 1025: -
- 1026: -
- 1027: -
- 1028: -
- 1029: CP#34: CT3 not involved in Mp interface definition
- 1030: -
- 1031: -
- 1032: WID approved in CP#34
- 1033: -
- 1034: -
- 1035: Update of Rel-6 (U)SIM API for Java Card Testing UID_43007 under Rel-6 UICC/USIM enhancements and interworking UID_1800
- 1036: Following ETSI publication of TS 102 600, expected to be completed at CT6 meeting 45
- 1037: -
- 1038: -
- 1039: -

| ID | WBS | Task | Type | Duration | Start | Finish | Complete | Baseline start | Baseline finish | Baseline duration | Constraint | Resources | Work | Actual work | Text1 | Text4 | Text5 | Text6 | Text8 | Text12 |
| --- | --- | --- | --- | --- | --- | --- | --- | --- | --- | --- | --- | --- | --- | --- | --- | --- | --- | --- | --- | --- |
| 1040 | 336 | **Optimizations for Multimedia Telephony over IMS** |  | 0d? | 2005-09-28 A | 2005-09-28 A | 100% | 2005-09-28 | 2005-09-28 | 0d? |  | S4 |  |  | OMTIMS | Ericsson | olle.franceschi@ericsson.com | Rel-7 | Paolo |  |
| 1041 | 336.1 | Deleted - Characterisation of Adaptive Jitter Management Performance for VoIP Services | milestone | 0d? | 2005-09-28 A | 2005-09-28 A | 100% | 2005-09-28 | 2005-09-28 | 0d? | start no earlier than 2007-03-15 | S4 |  |  | OMTIMS-CAJMP | Lucent | dhuo@lucent.com | Rel-7 | Paolo | SP-35 |
| 1042 | 337 | End-to-End Multimedia Services Performance Metrics |  | 382d? | 2005-09-28 A | 2007-03-15 A | 100% | 2005-09-28 | 2007-03-15 | 382d? | finish no earlier than 2007-03-15 | S4 | 3056h | 3056h | E2EMSPM | China Mobile | zhangyanyf@chinamobile.com | Rel-7 | Paolo |  |
| 1043 | 338 | Packet Switched Streaming Enhancements |  | 261d? | 2006-06-08 A | 2007-06-07 A | 100% | 2006-06-08 | 2007-06-07 | 261d? | finish no earlier than 2007-06-07 | S4 | 2088h | 2088h | PSSe | Ericsson | olle.franceschi@ericsson.com | Rel-7 | Paolo |  |
| 1044 | 339 | **OAM&P Rel-7** |  | 472.86d? | 2005-09-02 A | 2007-06-26 A | 100% | 2005-09-02 | 2007-06-26 | 472.86d? |  | S5 | 82725.8h | 82725.8h | OAM7 | Huawei | Christian.Toche@huawei.com | Rel-7 | Dionisio |  |
| 1045 | 339.1 | **Network Infrastructure Management** |  | 465d? | 2005-09-02 A | 2007-06-14 A | 100% | 2005-09-02 | 2007-06-14 | 465d? |  | S5 | 41800h | 41800h | OAM7-NIM |  |  | Rel-7 | Dionisio |  |
| 1046 | 339.1.1 | Enhance NRM to accommodate NGN (IMS as basis of the Next Generation Network) |  | 465d? | 2005-09-02 A | 2007-06-14 A | 100% | 2005-09-02 | 2007-06-14 | 465d? | finish no earlier than 2007-06-14 | S5 | 3720h | 3720h | OAM7-NIM | Motorola |  | Rel-7 | Dionisio |  |
| 1047 | 339.1.2 | Co-operative Element Management interface (CO-OP) (Study + Implementation) |  | 400d? | 2005-09-02 A | 2007-03-15 A | 100% | 2005-09-02 | 2007-03-15 | 400d? | finish no earlier than 2007-03-15 | S5 | 3200h | 3200h | OAM7-NIM | Motorola |  | Rel-7 | Dionisio |  |
| 1048 | 339.1.3 | Network Management (NM) Itf-N performance criteria |  | 465d? | 2005-09-02 A | 2007-06-14 A | 100% | 2005-09-02 | 2007-06-14 | 465d? | finish no earlier than 2007-06-14 | S5 | 3720h | 3720h | OAM7-NIM | China Mobile |  | Rel-7 | Dionisio |  |
| 1049 | 339.1.4 | Delta synchronization between IRP Manager and IRP Agent (Study + Implementation) |  | 465d? | 2005-09-02 A | 2007-06-14 A | 100% | 2005-09-02 | 2007-06-14 | 465d? | finish no earlier than 2007-06-14 | S5 | 3720h | 3720h | OAM7-NIM | Siemens |  | Rel-7 | Dionisio |  |
| 1050 | 339.1.5 | Subscription Management (SuM) IRP Solution Sets |  | 330d? | 2005-09-02 A | 2006-12-07 A | 100% | 2005-09-02 | 2006-12-07 | 330d? | finish no earlier than 2006-12-07 | S5 | 2640h | 2640h | OAM7-NIM | Ericsson |  | Rel-7 | Dionisio |  |
| 1051 | 339.1.6 | Integration Reference Point (IRP) Security Management |  | 400d? | 2005-09-02 A | 2007-03-15 A | 100% | 2005-09-02 | 2007-03-15 | 400d? | finish no earlier than 2007-03-15 | S5 | 3200h | 3200h | OAM7-NIM | Huawei | Christian.Toche@huawei.com | Rel-7 | Dionisio |  |
| 1052 | 339.1.7 | Partial suspension of Itf-N during maintenance/testing (Study + Implementation) |  | 465d? | 2005-09-02 A | 2007-06-14 A | 100% | 2005-09-02 | 2007-06-14 | 465d? | finish no earlier than 2007-06-14 | S5 | 3720h | 3720h | OAM7-NIM | Siemens |  | Rel-7 | Dionisio |  |
| 1053 | 339.1.8 | Deleted - Management of Legacy Equipment |  | 336d? | 2005-09-02 A | 2006-12-15 A | 100% | 2005-09-02 | 2006-12-15 | 336d? | finish no earlier than 2006-12-15 | S5 | 2688h | 2688h | OAM7-NIM | Siemens |  | Rel-7 | Dionisio | SP-35 |
| 1054 | 339.1.9 | Deleted - Rules for Vendor Specific Extensions |  | 400d? | 2005-09-02 A | 2007-03-15 A | 100% | 2005-09-02 | 2007-03-15 | 400d? | finish no earlier than 2007-03-15 | S5 | 3200h | 3200h | OAM7-NIM | Siemens |  | Rel-7 | Dionisio | SP-35 |
| 1055 | 339.1.10 | Backward and Forward Compatibility of IRP systems |  | 465d? | 2005-09-02 A | 2007-06-14 A | 100% | 2005-09-02 | 2007-06-14 | 465d? | finish no earlier than 2007-06-14 | S5 | 3720h | 3720h | OAM7-NIM | Ericsson |  | Rel-7 | Dionisio |  |
| 1056 | 339.1.11 | Repeater Network Resource Model (NRM) definition |  | 214d? | 2006-02-13 A | 2006-12-07 A | 100% | 2006-02-13 | 2006-12-07 | 214d? | finish no earlier than 2006-12-07 | S5 | 1712h | 1712h | OAM7-NIM | China Mobile |  | Rel-7 | Dionisio |  |
| 1057 | 339.1.12 | UTRAN radio channel power monitoring |  | 284d? | 2006-02-13 A | 2007-03-15 A | 100% | 2006-02-13 | 2007-03-15 | 284d? | finish no earlier than 2007-03-15 | S5 | 2272h | 2272h | OAM7-NIM | China Mobile |  | Rel-7 | Dionisio |  |
| 1058 | 339.1.13 | Notification XML Schema |  | 71d? | 2006-12-07 A | 2007-03-15 A | 100% | 2006-12-07 | 2007-03-15 | 71d? | finish no earlier than 2007-03-15 | S5 | 568h | 568h | OAM7-NIM | Huawei | Christian.Toche@huawei.com | Rel-7 | Dionisio |  |
| 1059 | 339.2 | **Performance Management** |  | 465d? | 2005-09-02 A | 2007-06-14 A | 100% | 2005-09-02 | 2007-06-14 | 465d? |  | S5 | 22992h | 22992h | OAM7-PM |  |  | Rel-7 | Dionisio |  |
| 1060 | 339.2.1 | Performance measurements definition for CN CS |  | 400d? | 2005-09-02 A | 2007-03-15 A | 100% | 2005-09-02 | 2007-03-15 | 400d? | finish no earlier than 2007-03-15 | S5 | 3200h | 3200h | OAM7-PM | China Mobile |  | Rel-7 | Dionisio |  |
| 1061 | 339.2.2 | Enhancement UTRAN performance measurements definition |  | 465d? | 2005-09-02 A | 2007-06-14 A | 100% | 2005-09-02 | 2007-06-14 | 465d? | finish no earlier than 2007-06-14 | S5 | 3720h | 3720h | OAM7-PM | China Mobile |  | Rel-7 | Dionisio |  |
| 1062 | 339.2.3 | Add TDD specific counters in Performance measurement |  | 330d? | 2005-09-02 A | 2006-12-07 A | 100% | 2005-09-02 | 2006-12-07 | 330d? | finish no earlier than 2006-12-15 | S5 | 2640h | 2640h | OAM7-PM | CATT |  | Rel-7 | Dionisio |  |
| 1063 | 339.2.4 | ATM bearer network Performance measurements |  | 400d? | 2005-09-02 A | 2007-03-15 A | 100% | 2005-09-02 | 2007-03-15 | 400d? | finish no earlier than 2007-03-15 | S5 | 3200h | 3200h | OAM7-PM | ZTE |  | Rel-7 | Dionisio |  |
| 1064 | 339.2.5 | Performance measurements definition for IMS |  | 465d? | 2005-09-02 A | 2007-06-14 A | 100% | 2005-09-02 | 2007-06-14 | 465d? | finish no earlier than 2007-06-14 | S5 | 3720h | 3720h | OAM7-PM | China Mobile |  | Rel-7 | Dionisio |  |
| 1065 | 339.2.6 | HSDPA performance measurements |  | 349d? | 2006-02-13 A | 2007-06-14 A | 100% | 2006-02-13 | 2007-06-14 | 349d? | finish no earlier than 2007-06-14 | S5 | 2792h | 2792h | OAM7-PM | China Mobile |  | Rel-7 | Dionisio |  |

Notes:
- 1040: - / Text3: 26.235, 26.236
- 1041: SP-35 stopped
- 1042: - / Text3: 26.944
- 1043: - / Text3: 26.234, 26.244
- 1044: -
- 1045: -
- 1046: - / Text3: 32.731/2/3/5, 32.631/2/3/5
- 1047: - / Text3: 32.806, 32.814, 32.101
- 1048: - / Text3: 32.811
- 1049: - / Text3: 32.391/2/3/5
- 1050: - / Text3: 32.307/317/607/667/665, 32.101, 32.175
- 1051: - / Text3: 32.372/3/5, 32.111,32.30x,32.32x,32.33x,32.34x,32.35x,32.36x,32.41x,32.60x,32.61x,32.66x
- 1052: - / Text3: 32.381/2/3/5
- 1053: Request to TSG#35 to STOP the WI / Text3: new 32.xxx
- 1054: Request to TSG#35 to STOP the WI / Text3: 32.62n; For n = 1 to 5
- 1055: - / Text3: 32.154
- 1056: - / Text3: 32.721/2/3/5
- 1057: - / Text3: 32.405, 32.64n; For n = 1 to 5
- 1058: 12/2006 SP#34 WID approved / Text3: New 32.325/345/365/415, CR to 32.335/615/665
- 1059: -
- 1060: - / Text3: 32.407, 32.408
- 1061: - / Text3: 32.405
- 1062: - / Text3: 32.405
- 1063: - / Text3: No impact on 32.404, 32.405, 32.406, 32.407
- 1064: - / Text3: 32.404,32.409,32.437, 32.632/3/4/5
- 1065: - / Text3: 32.405

| ID | WBS | Task | Type | Duration | Start | Finish | Complete | Baseline start | Baseline finish | Baseline duration | Constraint | Resources | Work | Actual work | Text1 | Text4 | Text6 | Text8 | Text12 | Text5 | Text11 | Text9 |
| --- | --- | --- | --- | --- | --- | --- | --- | --- | --- | --- | --- | --- | --- | --- | --- | --- | --- | --- | --- | --- | --- | --- |
| 1066 | 44.5 | **Trace Management** |  | 472.86d? | 2005-09-02 A | 2007-06-26 A | 100% | 2005-09-02 | 2007-06-26 | 472.86d? |  | S5 | 14150.9h | 14150.9h | OAM7-Trace | Vodafone | Rel-7 | Dionisio |  |  |  |  |
| 1067 | 339.3.1 | End-to-end Service Level tracing for IMS |  | 350d? | 2005-11-11 A | 2007-03-15 A | 100% | 2005-11-11 | 2007-03-15 | 350d? | finish no earlier than 2007-03-15 | S5 | 2800h | 2800h | OAM7-Trace | Vodafone | Rel-7 | Dionisio | SP-31 |  |  |  |
| 1068 | 339.3.2 | Trace record content for UTRAN TDD |  | 330d? | 2005-09-02 A | 2006-12-07 A | 100% | 2005-09-02 | 2006-12-07 | 330d? | finish no earlier than 2006-12-07 | S5 | 2640h | 2640h | OAM7-Trace | Nokia | Rel-7 | Dionisio |  |  |  |  |
| 1069 | 339.3.3 | IRP for Subscriber and Equipment Trace Management |  | 465d? | 2005-09-02 A | 2007-06-14 A | 100% | 2005-09-02 | 2007-06-14 | 465d? | finish no earlier than 2007-06-14 | S5 | 3720h | 3720h | OAM7-Trace | Nokia | Rel-7 | Dionisio |  |  |  |  |
| 1070 | 339.3.4 | Deleted - SIP enhancements for trace | milestone | 0d? | 2007-06-15 A | 2007-06-26 A | 100% | 2007-06-15 | 2007-06-26 | 0d? | start no earlier than 2007-06-15 | C1 |  |  | OAM7-Trace |  | Rel-7 | Frederic | CP-32 |  |  |  |
| 1071 | 339.3.5 | Deleted - duplicated with UID 35063 - IRP for Subscriber and Equipment Trace Management |  | 336d? | 2005-09-02 A | 2006-12-15 A | 100% | 2005-09-02 | 2006-12-15 | 336d? | finish no earlier than 2006-12-15 | S5 | 2688h | 2688h | OAM7-Trace | Nokia | Rel-7 | Dionisio | SP-33 |  |  |  |
| 1072 | 340 | **Charging Management small Enhancements Rel-7** |  | 279d? | 2006-05-22 A | 2007-06-14 A | 100% | 2006-05-22 | 2007-06-14 | 279d? |  | S5 | 5952h | 5952h | CH7 | Orange | Rel-7 | Dionisio |  | alain.bibas@orange-ft.com |  |  |
| 1073 | 340.1 | Alternate Charged Party (ACP) for IMS |  | 279d? | 2006-05-22 A | 2007-06-14 A | 100% | 2006-05-22 | 2007-06-14 | 279d? | finish no earlier than 2007-06-14 | S5 | 2232h | 2232h | CH7-IMS-ACP | Lucent | Rel-7 | Dionisio |  | njmazzarella@alcatel-lucent.com |  |  |
| 1074 | 340.2 | Align 3GPP Charging with OMA PoC Enabler Release 2.0 |  | 186d? | 2006-09-28 A | 2007-06-14 A | 100% | 2006-09-28 | 2007-06-14 | 186d? | finish no earlier than 2007-06-14 | S5 | 1488h | 1488h | CH7-PoC | Siemens | Rel-7 | Dionisio |  | Gerald GÖRMER |  |  |
| 1075 | 8.5 | **Multiple Input Multiple Output antennas (MIMO)** |  | 1177d? | 2003-03-14 A | 2007-09-17 A | 100% | 2003-03-14 | 2007-09-17 | 1177d? |  | R1 | 40272h | 40272h | MIMO | Alcatel-Lucent | Rel-7 | Patrick |  | hchuang@Alcatel-Lucent.com | RP-070037, RP-070531 |  |
| 1076 | 341.1 | MIMO - Physical layer |  | 915d? | 2003-09-12 A | 2007-03-15 A | 100% | 2003-09-12 | 2007-03-15 | 915d? | finish no earlier than 2007-03-15 | R1 | 7320h | 7320h | MIMO-Phys | Alcatel-Lucent | Rel-7 | Patrick |  | hchuang@Alcatel-Lucent.com | RP-070037 |  |
| 1077 | 341.2 | MIMO - Layer 2,3 aspects |  | 915d? | 2003-09-12 A | 2007-03-15 A | 100% | 2003-09-12 | 2007-03-15 | 915d? | finish no earlier than 2007-03-15 | R2 | 7320h | 7320h | MIMO-L23 | Alcatel-Lucent | Rel-7 | Joern |  | hchuang@Alcatel-Lucent.com | RP-070037 |  |
| 1078 | 341.3 | MIMO - Iub/Iur Protocol Aspects |  | 1045d? | 2003-03-14 A | 2007-03-15 A | 100% | 2003-03-14 | 2007-03-15 | 1045d? | finish no earlier than 2007-03-15 | R3 | 8360h | 8360h | MIMO-IurIub | Alcatel-Lucent | Rel-7 | Juha |  | hchuang@Alcatel-Lucent.com | RP-070037 |  |
| 1079 | 341.4 | MIMO - RF Radio Transmission/Reception, System Performance Requirements and Conformance Testing |  | 982d? | 2003-12-12 A | 2007-09-17 A | 100% | 2003-12-12 | 2007-09-17 | 982d? | finish no earlier than 2007-09-17 | R4 | 7856h | 7856h | MIMO-RF | Alcatel-Lucent | Rel-7 | Issam |  | ngm@Alcatel-Lucent.com | RP-070531 |  |
| 1080 | 342 | **Rel-7 Improvements of the Radio Interface** |  | 709d? | 2004-09-15 A | 2007-06-04 A | 100% | 2004-09-15 | 2007-06-04 | 709d? |  | RP | 29696h | 29696h | RInImp |  | Rel-7 | Issam |  |  |  |  |
| 1081 | 342.1 | Extended UMTS 1.7/2.1 GHz |  | 198d? | 2006-03-15 A | 2006-12-15 A | 100% | 2006-03-15 | 2006-12-15 | 198d? | finish no earlier than 2006-12-15 | R4 | 1584h | 1584h | RInImp-UMTS1721Ext | Ericsson | Rel-7 | Issam |  | Johan Sköld (johan.skold@ericsson.com) | RP-060681 |  |
| 1082 | 342.2 | UMTS 2.6 GHz 7.68 Mcps TDD |  | 67d? | 2006-06-15 A | 2006-09-15 A | 100% | 2006-06-15 | 2006-09-15 | 67d? | finish no earlier than 2006-09-15 | R4 | 536h | 536h | RInImp-UMTS26VHCRTDD | IPWireless | Rel-7 | Issam |  | Shin Horng Wong (shwong@ipwireless.com) | RP-060451 |  |
| 1083 | 342.3 | UMTS 2.6 GHz |  | 195d? | 2004-09-15 A | 2005-06-14 A | 100% | 2004-09-15 | 2005-06-14 | 195d? | finish no earlier than 2005-06-14 | R4 | 1560h | 1560h | RInImp-UMTS2600 | Nokia | Rel-7 | Issam |  | jussi.numminen@nokia.com | RP-050184 |  |
| 1084 | 342.4 | UMTS 2.6 GHz TDD |  | 261d? | 2004-12-15 A | 2005-12-14 A | 100% | 2004-12-15 | 2005-12-14 | 261d? | finish no earlier than 2005-12-15 | R4 | 2088h | 2088h | RInImp-UMTS2600TDD | IPWireless | Rel-7 | Issam |  | Shin Horng Wong (shwong@ipwireless.com) | RP-050661 |  |
| 1085 | 342.5 | UMTS 900 MHz |  | 261d? | 2004-12-15 A | 2005-12-14 A | 100% | 2004-12-15 | 2005-12-14 | 261d? | finish no earlier than 2005-12-15 | R4 | 2088h | 2088h | RInImp-UMTS900 | Nortel | Rel-7 | Issam |  | Yannick Li (yli@nortelnetworks.com) | RP-050662 |  |
| 1086 | 342.6 | UMTS 1700 MHz |  | 197d? | 2005-03-15 A | 2005-12-14 A | 100% | 2005-03-15 | 2005-12-14 | 197d? | finish no earlier than 2005-12-15 | R4 | 1576h | 1576h | RInImp-UMTS1700 | NTT DoCoMo | Rel-7 | Issam |  | Takehiro Nakamura (nakamurata@nttdocomo.co.jp) | RP-050824 |  |
| 1087 | 342.7 | UE Antenna Performance Evaluation Method and Requirements |  | 644d? | 2004-12-15 A | 2007-06-04 A | 100% | 2004-12-15 | 2007-06-04 | 644d? | finish no earlier than 2007-06-04 | R4 | 5152h | 5152h | RInImp-UEAnt | TeliaSonera | Rel-7 | Issam |  | Christian.Bergljung@TeliaSonera.com | RP-070281 |  |
| 1088 | 342.8 | Improved Performance Requirements for HSDPA UE based on Rx Diversity (type 1) & LMMSE equalizer (type 2) | milestone | 0d? | 2005-03-15 A | 2005-03-15 A | 100% | 2005-03-15 | 2005-03-15 | 0d? | finish no earlier than 2005-03-15 | R4 |  |  | RInImp-HSPerf-Type3 | Cingular | Rel-7 | Issam |  | Marc Grant | RP-060015 |  |
| 1089 | 342.9 | **Additional minimum UE performance requirement for non-HSDPA channels based on type 1 enhanced receiver (Rx Diversity)** |  | 327d? | 2005-09-15 A | 2006-12-15 A | 100% | 2005-09-15 | 2006-12-15 | 327d? |  | R4 | 7344h | 7344h | RInImp-RxDiv | Qualcomm Europe | Rel-7 | Issam |  | Serge Willenegger (sergew@qualcomm.com) |  |  |
| 1090 | 342.9.1 | Additional minimum UE performance requirement for DL physical channels in support of DCH/HS-DSCH operation based on type 1 enhanced receiver (RX-Diversity) |  | 195d? | 2005-09-15 A | 2006-06-14 A | 100% | 2005-09-15 | 2006-06-14 | 195d? | finish no earlier than 2006-06-15 | R4 | 1560h | 1560h | RInImp-RxDiv-DCH | Cingular | Rel-7 | Issam |  | Marc Grant | RP-060235 |  |
| 1091 | 342.9.2 | Additional minimum UE performance requirement for downlink physical channels in support of MTCH and MCCH operation based on type 1 enhanced receiver (Rx-Diversity) |  | 198d? | 2006-03-15 A | 2006-12-15 A | 100% | 2006-03-15 | 2006-12-15 | 198d? | finish no earlier than 2006-12-15 | R4 | 1584h | 1584h | RInImp-RxDiv-MBMS | Qualcomm Europe | Rel-7 | Issam |  | Serge Willenegger (sergew@qualcomm.com) | RP-060678 |  |
| 1092 | 342.9.3 | Additional minimum UE performance requirement for downlink physical channels in support of E-DCH operation based on type 1 enhanced receiver (Rx-Diversity) |  | 198d? | 2006-03-15 A | 2006-12-15 A | 100% | 2006-03-15 | 2006-12-15 | 198d? | finish no earlier than 2006-12-15 | R4 | 1584h | 1584h | RInImp-RxDiv-EDCH | Qualcomm Europe | Rel-7 | Issam |  | Serge Willenegger (sergew@qualcomm.com) | RP-060679 |  |
| 1093 | 342.10 | Deleted Improved support of gaming over HSDPA/EDCH |  | 262d? | 2005-12-15 A | 2006-12-15 A | 100% | 2005-12-15 | 2006-12-15 | 262d? | finish no earlier than 2006-12-15 | R2 | 2096h | 2096h | RInImp-Gaming | Cingular | Rel-7 | Joern | RP-34 | Don Zelmer (dz1069@att.com) | RP-060680 |  |
| 1094 | 342.11 | Deleted (not approved at PCG) - UMTS 2.6 GHz FDD DL External | milestone | 0d? | 2005-09-15 A | 2005-09-15 A | 100% | 2005-09-15 | 2005-09-15 | 0d? | finish no earlier than 2005-09-15 | R4 |  |  | RInImp-UMTS2600Ext | T-mobile | Rel-7 | Issam | RP-31 | han.van.bussel@t-mobile.de |  | PCG-16 |

Notes:
- 1066: -
- 1067: 07/2005: OMA (Stage 1), Stage 2/3 SA5, CT1/3/4 / Text3: CR 32.101, 32.421/2/3.
- 1068: - / Text3: CR 32.421/2/3.
- 1069: - / Text3: 32.441/2/3/5, CRs 32.632/3/5
- 1070: combined with UID 11067
- 1071: - / Text3: 32.421,32.422,32.423. 3 new 32.4x1,2,3
- 1072: -
- 1073: - / Text3: 32.240, 32.260, 32.298, 32.299
- 1074: 09/2006 SP#33 WID approved / Text3: 32.240, 32.272, 32.299, 32.298
- 1075: Completed Sep 2007; SR in RP-070037and RP-070531 / Text3: 25.876, 25.996
- 1076: Completed Sep 2007; SR in RP-070037 / Text3: 25.211, 25.212, 25.213, 25.214, 25.215, 25.221
- 1077: Completed Sep 2007; SR in RP-070037 / Text3: 25.876
- 1078: Completed Sep 2007; SR in RP-070037
- 1079: Completed Sep 2007; SR in RP-070531
- 1080: Generic feature
- 1081: SR in RP-060681. Introduction of Band X (Extended UMTS 1.7/2.1 GHz) in 25.307 / Text3: 25.806, 25.101, 25.104, 25.133, 24.141, 25.331, 25.306, 25.307, 25.423, 25.461, 25.463, 34.121
- 1082: Completed Sep 2006; SR in RP-060451 / Text3: 25.102, 25.105, 25.123, 25.113, 25.142, 34.124
- 1083: SR in RP-050184. Introduction of UMTS2600 internal band, Band VII in 25.307 / Text3: 25.101, 25.104, 25.133, 25.141, 25.331, 25.942, 25.306, 25.307, 34.121
- 1084: SR in RP-050661 / Text3: 25.102, 25.105, 25.113, 25.123, 25.142, 25.331, 25.942, 25.306, 25.307, 34.122, 34.124
- 1085: SR in RP-050662. Introduction of UMTS 900 (Band VIII) in 25.307 / Text3: 25.101, 25.104, 25.113, 25.133, 25.141, 25.331, 25.942, 25.306, 25.307, 34.121
- 1086: SR in RP-050824 / Text3: 25.101, 25.104, 25.113, 25.133, 25.141, 25.306, 25.307, 25.331, 34.121
- 1087: RP#36 (May 2007) completed. SR in RP-070281 / Text3: 25.101, 25.963
- 1088: Completed Mar 2006, SR in RP-060015 / Text3: 25.101
- 1089: - / Text3: 25.101
- 1090: Completed Jun 2006, SR in RP-060235 / Text3: 25.101
- 1091: Completed Dec 2006, SR in RP-060678 / Text3: 25.101
- 1092: Completed Dec 2006, SR in RP-060679 / Text3: 25.101
- 1093: RP#34 (Dec 2006) stopped. SR in RP-060680
- 1094: This item was conditionnaly approved pending decision of PCG 16 who decided not to approve it / Text3: 25.101, 25.104, 25.133, 25.141, 25.331, 25.942, 25.306, 25.307, 34.121

| ID | WBS | Task | Duration | Start | Finish | Complete | Baseline start | Baseline finish | Baseline duration | Constraint | Deadline | Resources | Work | Actual work | Text1 | Text6 | Text8 | Text4 | Text5 | Text10 | Text11 |
| --- | --- | --- | --- | --- | --- | --- | --- | --- | --- | --- | --- | --- | --- | --- | --- | --- | --- | --- | --- | --- | --- |
| 1095 | 343 | **Rel-7 Improvements of the Radio Interface - UE Conformance Testing** | 741d? | 2005-11-11 A | 2008-09-12 A | 100% | 2005-11-11 | 2008-09-12 | 741d? |  |  | R5 | 17568h | 17568h | RInImp-UEConTest | Rel-7 | Ingbert |  |  |  |  |
| 1096 | 16.5.1 | UE Conformance Test for UMTS 2600 MHz | 146d | 2005-11-11 A | 2006-06-02 A | 100% | 2005-11-11 | 2006-06-02 | 146d | finish no earlier than 2006-06-02 | 2006-06-02 | R5 | 1168h | 1168h | RInImp-UMTS2600_Test | Rel-7 | Ingbert | Nokia | Aleksi.Heino@nokia.com | Fri 7/11/05 |  |
| 1097 | 16.5.1 | UE Conformance Test for UMTS 900 MHz (band VIII) | 146d | 2005-11-11 A | 2006-06-02 A | 100% | 2005-11-11 | 2006-06-02 | 146d | finish no earlier than 2006-06-02 | 2006-06-02 | R5 | 1168h | 1168h | RInImp-UMTS900_Test | Rel-7 | Ingbert | Qualcomm Europe | hanye@qualcomm.com | Fri 11/03/05 |  |
| 1098 | 343.3 | Conformance Test Aspects – Improved Performance of HSDPA Receiver type 3 | 191d? | 2006-03-10 A | 2006-12-01 A | 100% | 2006-03-10 | 2006-12-01 | 191d? | finish no earlier than 2006-12-01 |  | R5 | 1528h | 1528h | RInImp-HSPerf-Type3_Test | Rel-7 | Ingbert | Motorola | carolyn.taylor@motorola.com |  |  |
| 1099 | 343.4 | UE antenna Over The Air (OTA) conformance testing | 518d? | 2006-09-20 A | 2008-09-12 A | 100% | 2006-09-20 | 2008-09-12 | 518d? | finish no earlier than 2008-09-12 |  | R5 | 4144h | 4144h | RInImp-UEAnt_Test | Rel-7 | Ingbert | Nokia | Aleksi.Heino@nokia.com |  | RP-080535 |
| 1100 | 343.5 | UE conformance testing for FDD Inter-Band Operation | 131d? | 2006-06-02 A | 2006-12-01 A | 100% | 2006-06-02 | 2006-12-01 | 131d? | finish no earlier than 2006-12-01 |  | R5 | 1048h | 1048h | RInImp-InterBand_Test | Rel-7 | Ingbert | NEC, Motorola | Jacob.John@motorola.com |  |  |
| 1101 | 343.6 | Conformance Test Aspects – Extended UMTS 1.7/2.1 GHz | 131d? | 2006-12-01 A | 2007-06-01 A | 100% | 2006-12-01 | 2007-06-01 | 131d? | finish no earlier than 2007-06-01 |  | R5 | 1048h | 1048h | RInImp-UEConTest_UMTS1721Ext | Rel-7 | Ingbert | Motorola | carolyn.taylor@motorola.com |  |  |
| 1102 | 343.7 | Conformance Test Aspects – Minimum UE performance requirement for downlink physical channels in support of E-DCH operation based on type 1 enhanced receiver (Rx-Diversity) | 136d? | 2007-06-01 A | 2007-12-07 A | 100% | 2007-06-01 | 2007-12-07 | 136d? | finish no earlier than 2007-12-07 |  | R5 | 1088h | 1088h | RInImp-UEConTest_RxDivEDCH | Rel-7 | Ingbert | Motorola | carolyn.taylor@motorola.com |  |  |
| 1103 | 343.8 | Conformance Test Aspects – Minimum UE performance requirement for downlink physical channels in support of MTCGH and MCCH operation based on type 1 enhanced receiver (Rx-Diversity) | 201d? | 2007-06-01 A | 2008-03-07 A | 100% | 2007-06-01 | 2008-03-07 | 201d? | finish no earlier than 2008-03-07 |  | R5 | 1608h | 1608h | RInImp-UEConTest_RxDivMBMS | Rel-7 | Ingbert | Ericsson | leif.mattisson@ericsson.com |  | RP-080056 |
| 1104 | 344 | **Rel-7 RAN improvements** | 653d? | 2004-12-15 A | 2007-06-15 A | 100% | 2004-12-15 | 2007-06-15 | 653d? |  |  | RP | 29920h | 29920h | RANimp | Rel-7 |  |  |  |  |  |
| 1105 | 344.1 | Optimization of channelisation code utilisation for 1.28 Mcps TDD | 523d? | 2004-12-15 A | 2006-12-15 A | 100% | 2004-12-15 | 2006-12-15 | 523d? | finish no earlier than 2006-12-15 |  | R1 | 4184h | 4184h | RANimp-RABSE-CodOptLCRTDD | Rel-7 | Patrick | UTStarcom | Ka Leong Lo (kaleong.lo@UTSTAR.COM) |  | RP-060682 |
| 1106 | 344.2 | Delay optimization for procedures applicable to CS and PS Connections | 394d? | 2005-03-15 A | 2006-09-15 A | 100% | 2005-03-15 | 2006-09-15 | 394d? | finish no earlier than 2006-09-15 |  | R2 | 3152h | 3152h | RANimp-DelayOpt | Rel-7 | Joern | Nokia | juho.pirskanen@nokia.com |  | RP-060453 |
| 1107 | 344.3 | Improved support of IMS Realtime Services using HSDPA/HSUPA | 197d? | 2005-03-15 A | 2005-12-14 A | 100% | 2005-03-15 | 2005-12-14 | 197d? | start no earlier than 2005-03-15 |  | R2 | 1576h | 1576h | RANimp-IMSRealTime | Rel-7 | Joern | Cingular | Don Zelmer (dz1069@att.com) |  | RP-050667 |
| 1108 | 344.4 | UE Performance Requirements for MBMS (TDD) | 328d? | 2005-03-15 A | 2006-06-15 A | 100% | 2005-03-15 | 2006-06-15 | 328d? | finish no earlier than 2006-06-15 |  | R4 | 2624h | 2624h | MBMS-RAN-RF-TDD | Rel-7 | Issam | IPwireless | shwong@ipwireless.com |  | RP-060477 |
| 1109 | 344.5 | Continuous connectivity for packet data users | 524d? | 2005-03-14 A | 2007-03-15 A | 100% | 2005-03-14 | 2007-03-15 | 524d? | finish no earlier than 2007-03-15 |  | R1 | 4192h | 4192h | RANimp-CPC | Rel-7 | Patrick | Siemens | Joern.Krause@siemens.com |  | RP-070033 |
| 1110 | 344.6 | Extended WCDMA Cell Range | 198d? | 2006-03-15 A | 2006-12-15 A | 100% | 2006-03-15 | 2006-12-15 | 198d? | finish no earlier than 2006-12-15 |  | R3 | 1584h | 1584h | RANimp-ExtCell | Rel-7 | Juha | Ericsson | Muhammad Kazmi |  | RP-060685 |
| 1111 | 344.7 | 7.68 Mcps TDD Enhanced Uplink | 198d? | 2006-03-15 A | 2006-12-15 A | 100% | 2006-03-15 | 2006-12-15 | 198d? | finish no earlier than 2006-12-15 |  | R1 | 1584h | 1584h | RANimp-VHCRTDD-EDCH | Rel-7 | Patrick | IPwireless | nanderson@ipwireless.com |  | RP-060684 |
| 1112 | 344.8 | Enhanced CELL_FACH State in FDD | 181d? | 2006-09-25 A | 2007-06-04 A | 100% | 2006-09-25 | 2007-06-04 | 181d? | finish no earlier than 2007-06-04 |  | R2 | 1448h | 1448h | RANimp-EnhState | Rel-7 | Joern | Nokia | juho.pirskanen@nokia.com |  | RP-070286 |
| 1113 | 344.9 | 64QAM for HSDPA (FDD) | 110d? | 2006-12-15 A | 2007-06-04 A | 100% | 2006-12-15 | 2007-06-04 | 110d? | finish no earlier than 2007-06-04 |  | R1 | 880h | 880h | RANimp-64QamDownlink | Rel-7 | Patrick | Ericsson | Johan.Bergman@ericsson.com |  | RP-070287 |
| 1114 | 344.10 | Improved L2 support for high data rates | 122d? | 2006-12-15 A | 2007-06-04 A | 100% | 2006-12-15 | 2007-06-04 | 122d? | finish no earlier than 2007-06-04 |  | R2 | 976h | 976h | RANimp-L2DataRates | Rel-7 | Joern | Ericsson | Janne.Peisa@ericsson.com |  | RP-070289 |
| 1115 | 344.11 | Introduction of 16QAM in HSUPA (FDD) | 110d? | 2006-12-15 A | 2007-06-04 A | 100% | 2006-12-15 | 2007-06-04 | 110d? | finish no earlier than 2007-06-04 |  | R1 | 880h | 880h | RANimp-16QamUplink | Rel-7 | Patrick | Nokia | Karri.Ranta-aho@nsn.com |  | RP-070288 |
| 1116 | 344.12 | **Interface to control Tower Mounted Amplifiers (TMAs)** | 101d? | 2007-01-26 A | 2007-06-15 A | 100% | 2007-01-26 | 2007-06-15 | 101d? |  |  | R3 | 1616h | 1616h | RANImp-TMA | Rel-7 | Juha | Vodafone | alexej.kulakov@vodafone.com |  | RP-070140 |
| 1117 | 344.12.1 | OAM aspects to Interface to control TMAs | 101d? | 2007-01-26 A | 2007-06-15 A | 100% | 2007-01-26 | 2007-06-15 | 101d? | finish no earlier than 2007-06-15 |  | S5 | 808h | 808h | RANImp-TMA-OAM | Rel-7 | Dionisio | Vodafone | Adrian.Neal@vodafone.com |  |  |
| 1118 | 345 | **Rel-7 RAN improvements - UE Conformance Testing** | 784d? | 2006-09-20 A | 2009-09-18 A | 100% | 2006-09-20 | 2009-09-18 | 784d? |  |  | R5 | 25472h | 25472h | RANimp-UEConTest | Rel-7 | Ingbert |  |  |  |  |
| 1119 | 345.1 | Conformance Test Aspects - 3.84 Mcps and 7.68 Mcps TDD Enhanced Uplink | 518d? | 2006-09-20 A | 2008-09-12 A | 100% | 2006-09-20 | 2008-09-12 | 518d? | finish no earlier than 2008-09-12 |  | R5 | 4144h | 4144h | RANimp-UEConTest_EDCHTDH | Rel-7 | Ingbert | IPWireless | tspeight@ipwireless.com |  | RP-080536 |
| 1120 | 345.2 | Conformance Test Aspects – 64QAM for HSDPA (FDD) | 257d? | 2007-03-09 A | 2008-03-03 A | 100% | 2007-03-09 | 2008-03-03 | 257d? | finish no earlier than 2008-03-03 |  | R5 | 2056h | 2056h | RANimp-UEConTest_64QamDownlink | Rel-7 | Ingbert | Ericsson | leif.mattisson@ericsson.com |  | RP-080059 |
| 1121 | 345.3 | Conformance Test Aspects – 16QAM for HSUPA (FDD) | 321d? | 2007-03-09 A | 2008-05-30 A | 100% | 2007-03-09 | 2008-05-30 | 321d? | finish no earlier than 2008-05-30 |  | R5 | 2568h | 2568h | RANimp-UEConTest_16QamUplink | Rel-7 | Ingbert | Motorola | carolyn.taylor@motorola.com |  | RP-080281 |
| 1122 | 345.4 | Conformance Test Aspects – Improved L2 support for high data rates | 321d? | 2007-03-09 A | 2008-05-30 A | 100% | 2007-03-09 | 2008-05-30 | 321d? | finish no earlier than 2008-05-30 |  | R5 | 2568h | 2568h | RANimp-UEConTest_L2DataRates | Rel-7 | Ingbert | Ericsson | leif.mattisson@ericsson.com |  | RP-080256 |
| 1123 | 345.5 | Conformance Test Aspects – Continuous connectivity for packet data users | 321d? | 2007-03-09 A | 2008-05-30 A | 100% | 2007-03-09 | 2008-05-30 | 321d? | finish no earlier than 2008-05-30 |  | R5 | 2568h | 2568h | RANimp-UEConTest_CPC | Rel-7 | Ingbert | Nokia | jarkko.hellsten@nokia.com |  | RP-080282 |
| 1124 | 345.6 | Conformance Test Aspects – Enhanced CELL_FACH state in FDD | 662d? | 2007-03-09 A | 2009-09-18 A | 100% | 2007-03-09 | 2009-09-18 | 662d? | finish no earlier than 2009-09-18 |  | R5 | 5296h | 5296h | RANimp-UEConTest_EnhancedCellFACHState | Rel-7 | Ingbert | Nokia | jarkko.hellsten@nokia.com |  | RP-090711 |

Notes:
- 1095: 05/08: Linked to Feature UID_20028 (RInImp)
- 1096: - / Text3: 34.108, 34.121
- 1097: - / Text3: 34.108, 34.121
- 1098: - / Text3: 34.121, 34.108
- 1099: SR in RP-080535. RP#41 completed (GERAN aspects might need to be included later) / Text3: 34.114
- 1100: - / Text3: 34.108, 34.123-1, 34.123-2, 34.123-3
- 1101: - / Text3: 34.108, 34.121-1, 34.121-2
- 1102: -
- 1103: SR in RP-080056
- 1104: Generic feature
- 1105: Completed Dec 2006; SR in RP-060682
- 1106: Completed Sep 2006; SR in RP-060453 / Text3: 25.815, 25.321, 25.322, 25.331
- 1107: Closed Dec 2005; SR in RP-050667
- 1108: Completed Sep 2006; SR in RP-060477 / Text3: 25.102, 25.123
- 1109: Completed at Mar 2007; SR in RP-070033 / Text3: 25.903, 25.201, 25.211, 25.212, 25.214, 25.308, 25.321, 25.331, 25.423, 25.433, 25.101, 25.133
- 1110: Completed Dec 2006; SR in RP-060685 / Text3: 25.133, 25.423, 25.425, 25.433, 25.435, 25.453, 25.331
- 1111: Completed Dec 2006; SR in RP-060684 / Text3: 25.201, 25.202, 25.221, 25.222, 25.223, 25.224, 25.225, 25.331, 23.321, 25.306, 25.302, 25.401, 25.420, 25.423, 25.427, 25.433, 25.102, 25.105, 25.142
- 1112: Completed May 2007; SR in RP-070286 / Text3: 25.308, 25.304, 25.306, 25.321, 25.331, 25.433, 25.435, 25.423, 25.425,
- 1113: Completed May 2007; SR in RP-070287 / Text3: 25.308, 25.211, 25.212, 25.213, 25.306, 25.331, 25.433, 25.435, 25.423, 25.425, 25.101, 25.104, 25.141
- 1114: Completed May 2007; SR in RP-070289 / Text3: 25.301, 25.308,25.306, 25.321, 25.322, 25.331, 25.433, 25.435, 25.423, 25.425, 25.999
- 1115: Completed May 2007; SR in RP-070288 / Text3: 25.319, 25.101, 25.104, 25.133, 25.141, 25.211, 25.212, 25.213, 25.214, 25.306, 25.321, 25.331, 25.423, 25.433
- 1116: Completed Mar 2007; SR in RP-070140
- 1117: SP#36 Jun 2007 completed / Text3: 32.642/3/5 – Align with RAN 25.466
- 1118: 05/08: Linked to Feature UID_20029 (RANimp)
- 1119: SR in RP-080536. RP#41 completed / Text3: 34.108, 34.122, 34.123-1, 34.123-2, 34.123-3
- 1120: SR in RP-080059. RP#39 completed. / Text3: 34.108, 34.121-1, 34.121-2, 34.123-1, 34.123-2, 34.123-3
- 1121: SR in RP-080281. RP#40 completed / Text3: 34.108, 34.121-1, 34.121-2, 34.123-1, 34.123-2, 34.123-3
- 1122: SR in RP-080256. RP#40 completed / Text3: 34.108, 34.123-1, 34.123-2, 34.123-3
- 1123: SR in RP-080282. RP#40 completed / Text3: 34.108, 34.121-1, 34.121-2, 34.123-1, 34.123-2, 34.123-3
- 1124: RP#45 completed / Text3: 34.108, 34.123-1, 34.123-2, 34.123-3

| ID | WBS | Task | Type | Duration | Start | Finish | Complete | Baseline start | Baseline finish | Baseline duration | Constraint | Resources | Work | Actual work | Text1 | Text4 | Text5 | Text6 | Text11 | Text8 | Text12 |
| --- | --- | --- | --- | --- | --- | --- | --- | --- | --- | --- | --- | --- | --- | --- | --- | --- | --- | --- | --- | --- | --- |
| 1125 | 346 | **7.68 Mcps TDD option** |  | 457d? | 2004-09-15 A | 2006-06-15 A | 100% | 2004-09-15 | 2006-06-15 | 457d? |  | RP | 19824h | 19824h | VHCRTDD | IPwireless | Martin Beale (mbeale@ipwireless.com) | Rel-7 | RP-060684 |  |  |
| 1126 | 346.1 | VHCRTDD: Stage 2 |  | 391d? | 2004-09-15 A | 2006-03-15 A | 100% | 2004-09-15 | 2006-03-15 | 391d? | finish no earlier than 2006-03-15 | R1 | 3128h | 3128h | VHCRTDD-Stage2 | IPwireless | Martin Beale (mbeale@ipwireless.com) | Rel-7 |  | Patrick |  |
| 1127 | 346.2 | VHCRTDD: Physical Layer |  | 391d? | 2004-09-15 A | 2006-03-15 A | 100% | 2004-09-15 | 2006-03-15 | 391d? | finish no earlier than 2006-03-15 | R1 | 3128h | 3128h | VHCRTDD-Phys | IPwireless | Martin Beale (mbeale@ipwireless.com) | Rel-7 |  | Patrick |  |
| 1128 | 346.3 | VHCRTDD: Layer 2 and layer 3 protocol aspects |  | 391d? | 2004-09-15 A | 2006-03-15 A | 100% | 2004-09-15 | 2006-03-15 | 391d? | finish no earlier than 2006-03-15 | R2 | 3128h | 3128h | VHCRTDD-L23 | IPwireless | drichards@ipwireless.com | Rel-7 |  | Joern |  |
| 1129 | 346.4 | VHCRTDD: UTRAN Iub/Iur Protocol Aspects |  | 391d? | 2004-09-15 A | 2006-03-15 A | 100% | 2004-09-15 | 2006-03-15 | 391d? | finish no earlier than 2006-03-15 | R3 | 3128h | 3128h | VHCRTDD-IurIub | IPwireless | Peter Legg (plegg@ipwireless.com) | Rel-7 |  | Juha |  |
| 1130 | 346.5 | VHCRTDD: RF Radio Transmission/ Reception, System Performance Requirements and Conformance Testing |  | 457d? | 2004-09-15 A | 2006-06-15 A | 100% | 2004-09-15 | 2006-06-15 | 457d? | finish no earlier than 2006-06-15 | R4 | 3656h | 3656h | VHCRTDD-RF | IPwireless | Shin Horng Wong (shwong@ipwireless.com) | Rel-7 |  | Issam |  |
| 1131 | 347 | **3.84 Mcps TDD Enhanced Uplink** |  | 394d? | 2005-03-15 A | 2006-09-15 A | 100% | 2005-03-15 | 2006-09-15 | 394d? |  | RP | 18384h | 18384h | EDCHTDD | IPwireless | nanderson@ipwireless.com | Rel-7 | RP-060684 |  |  |
| 1132 | 347.1 | EDCHTDD: Stage 2 |  | 328d? | 2005-03-15 A | 2006-06-15 A | 100% | 2005-03-15 | 2006-06-15 | 328d? | finish no earlier than 2006-06-15 | R2 | 2624h | 2624h | EDCHTDD-Stage2 | IPwireless | nanderson@ipwireless.com | Rel-7 |  | Joern |  |
| 1133 | 347.2 | EDCHTDD: Physical Layer |  | 394d? | 2005-03-15 A | 2006-09-15 A | 100% | 2005-03-15 | 2006-09-15 | 394d? | finish no earlier than 2006-09-15 | R1 | 3152h | 3152h | EDCHTDD-Phys | IPwireless | nanderson@ipwireless.com | Rel-7 |  | Patrick |  |
| 1134 | 347.3 | EDCHTDD: Layer 2 and 3 Protocol Aspects |  | 394d? | 2005-03-15 A | 2006-09-15 A | 100% | 2005-03-15 | 2006-09-15 | 394d? | finish no earlier than 2006-09-15 | R2 | 3152h | 3152h | EDCHTDD-L23 | IPwireless | drichards@ipwireless.com | Rel-7 |  | Joern |  |
| 1135 | 347.4 | EDCHTDD: UTRAN Iub/Iur Protocol Aspects |  | 394d? | 2005-03-15 A | 2006-09-15 A | 100% | 2005-03-15 | 2006-09-15 | 394d? | finish no earlier than 2006-09-15 | R3 | 3152h | 3152h | EDCHTDD-IurIub | Interdigital | jim.miller@interdigital.com | Rel-7 |  | Juha |  |
| 1136 | 347.5 | EDCHTDD: RF Radio Transmission/ Reception, System Performance Requirements and Conformance Testing |  | 394d? | 2005-03-15 A | 2006-09-15 A | 100% | 2005-03-15 | 2006-09-15 | 394d? | finish no earlier than 2006-09-15 | R4 | 3152h | 3152h | EDCHTDD-RF | IPwireless | Shin Horng Wong (shwong@ipwireless.com) | Rel-7 |  | Issam |  |
| 1137 | 348 | **1.28 Mcps TDD Enhanced Uplink** |  | 328d? | 2006-03-15 A | 2007-06-15 A | 100% | 2006-03-15 | 2007-06-15 | 328d? |  | RP | 11536h | 11536h | LCRTDD-EDCH | CATT | Haijing Hu | Rel-7 | RP-070296 |  |  |
| 1138 | 348.1 | 1.28 Mcps TDD Enhanced Uplink: Physical Layer |  | 262d? | 2006-03-15 A | 2007-03-15 A | 100% | 2006-03-15 | 2007-03-15 | 262d? | finish no earlier than 2007-03-15 | R1 | 2096h | 2096h | LCRTDD-EDCH-Phys | CATT | Ke Wang | Rel-7 |  | Patrick |  |
| 1139 | 348.2 | 1.28 Mcps TDD Enhanced Uplink: Layer 2 and 3 Protocol Aspects |  | 262d? | 2006-03-15 A | 2007-03-15 A | 100% | 2006-03-15 | 2007-03-15 | 262d? | finish no earlier than 2007-03-15 | R2 | 2096h | 2096h | LCRTDD-EDCH-L23 | CATT | Haiyang Quan | Rel-7 |  | Joern |  |
| 1140 | 348.3 | 1.28 Mcps TDD Enhanced Uplink: UTRAN Iub/Iur Protocol Aspects |  | 262d? | 2006-03-15 A | 2007-03-15 A | 100% | 2006-03-15 | 2007-03-15 | 262d? | finish no earlier than 2007-03-15 | R3 | 2096h | 2096h | LCRTDD-EDCH-IubIur | CATT | Yincheng Zhang | Rel-7 |  | Juha |  |
| 1141 | 348.4 | 1.28 Mcps TDD Enhanced Uplink: RF Radio Transmission/ Reception, System Performance Requirements and Conformance Testing |  | 328d? | 2006-03-15 A | 2007-06-15 A | 100% | 2006-03-15 | 2007-06-15 | 328d? | finish no earlier than 2007-06-15 | R4 | 2624h | 2624h | LCRTDD-EDCH-RF | CATT | Yuexia Song | Rel-7 |  | Issam |  |
| 1142 | 349 | 1.28 Mcps TDD Enhanced Uplink - UE Conformance Testing |  | 257d? | 2007-09-20 A | 2008-09-12 A | 100% | 2007-09-20 | 2008-09-12 | 257d? | finish no earlier than 2008-09-11 | R5 | 624h | 624h | LCRTDD-EDCH-UEConTest | CATT | chenxiaozhong@datangmobile.cn | Rel-7 | RP-080539 | Ingbert |  |
| 1143 | 350 | MS Antenna Performance Evaluation Method and Requirements |  | 731d? | 2005-01-28 A | 2007-11-16 A | 100% | 2005-01-28 | 2007-11-16 | 731d? | finish no earlier than 2007-11-16 | GP | 5848h | 5848h | APEMR | TeliaSonera | Ulf.Tegth@teliasonera.com | Rel-7 |  | Paolo |  |
| 1144 | 351 | **Lower 700 MHz Inclusion in the GERAN Specifications** |  | 390d? | 2005-01-03 A | 2006-06-30 A | 100% | 2005-01-03 | 2006-06-30 | 390d? |  | GP | 7632h | 7632h | GSM710 | UTC | dcotton@mtview.union-tel.com | Rel-7 |  | Paolo |  |
| 1145 | 351.1 | Inclusion of the 698 – 746 MHz band into GERAN core specifications |  | 129d? | 2005-01-03 A | 2005-06-30 A | 100% | 2005-01-03 | 2005-06-30 | 129d? | finish no earlier than 2005-06-30 | G1 | 1032h | 1032h | GSM710-core |  |  | Rel-7 |  | Paolo |  |
| 1146 | 351.2 | G1 aspects of GSM710 |  | 217.5d? | 2005-08-31 A | 2006-06-30 A | 100% | 2005-08-31 | 2006-06-30 | 217.5d? | finish no earlier than 2006-06-30 | G1 | 1740h | 1740h | GSM-710-test |  |  | Rel-7 |  | Paolo |  |
| 1147 | 351.3 | G3 aspects of GSM710 |  | 217.5d? | 2005-08-31 A | 2006-06-30 A | 100% | 2005-08-31 | 2006-06-30 | 217.5d? | finish no earlier than 2006-06-30 | G3new | 1740h | 1740h | GSM-710-test |  |  | Rel-7 |  | Ingbert |  |
| 1148 | 352 | **Support of Conversational Services in A/Gb mode via the PS domain** |  | 626d? | 2005-04-08 A | 2007-08-31 A | 100% | 2005-04-08 | 2007-08-31 | 626d? |  | GP | 15442.8h | 15442.8h | SCSAGB | Ericsson | gunnar.hedby@ericsson.com | Rel-7 |  | Paolo |  |
| 1149 | 352.1 | Minimise the transfer delay between the SGSN and the MS |  | 604.95d? | 2005-04-08 A | 2007-08-31 A | 100% | 2005-04-08 | 2007-08-31 | 604.95d? | finish no earlier than 2007-08-31 | GP | 4839.6h | 4839.6h | SCSAGB-MTD | Ericsson | gunnar.hedby@ericsson.com | Rel-7 |  | Paolo |  |
| 1150 | 352.2 | Definition of radio resource management functionality |  | 626d? | 2005-04-08 A | 2007-08-31 A | 100% | 2005-04-08 | 2007-08-31 | 626d? | finish no earlier than 2007-08-31 | G1 | 5008h | 5008h | SCSAGB-RRM | Ericsson | gunnar.hedby@ericsson.com | Rel-7 |  | Paolo |  |
| 1151 | 352.3 | Support of Conversational Services in A/Gb mode via the PS domain – RLC Non-Persistent mode |  | 101d? | 2006-06-30 A | 2006-11-17 A | 100% | 2006-06-30 | 2006-11-17 | 101d? | finish no earlier than 2006-11-17 | G2 | 808h | 808h | SCSAGB-RLCNP | Ericsson | gunnar.hedby@ericsson.com | Rel-7 |  | Gert |  |
| 1152 | 352.4 | Deleted- Radio Channel Support | milestone | 0d? | 2006-07-17 A | 2006-07-17 A | 100% | 2006-07-17 | 2006-07-17 | 0d? | start no earlier than 2006-07-17 | G2 |  |  | SCSAGB-RCHS | Ericsson | gunnar.hedby@ericsson.com | Rel-7 |  | Gert | SP-32 |
| 1153 | 352.5 | Deleted- Modifications to FLO | milestone | 0d? | 2006-07-17 A | 2006-07-17 A | 100% | 2006-07-17 | 2006-07-17 | 0d? | start no earlier than 2006-07-17 | G2 |  |  | SCSAGB-FLO | Ericsson | gunnar.hedby@ericsson.com | Rel-7 |  | Gert | SP-32 |

Notes:
- 1125: Completed Dec 2006, SR in RP-060684
- 1126: Feature completed and closed at RP#33 with the presentation of the test WI / Text3: 25.202
- 1127: Feature completed and closed at RP#33 with the presentation of the test WI / Text3: 25.221, 25.222, 25.223, 25.224,25.225
- 1128: Feature completed and closed at RP#33 with the presentation of the test WI / Text3: 25.301, 25.302, 25.305, 25.306, 25.321, 25.331
- 1129: Feature completed and closed at RP#33 with the presentation of the test WI / Text3: 25.401, 25.420, 25.423, 25.425, 25.427, 25.430, 25.433, 25.435
- 1130: Feature completed and closed at RP#33 with the presentation of the test WI / Text3: 25.102, 25.105, 25.123, 25.133, 25.142
- 1131: Completed Dec 2006, SR in RP-060684
- 1132: -
- 1133: - / Text3: 25.201, 25.221,25.222, 25.223, 25.224, 25.225
- 1134: - / Text3: 25.301, 25.302, 25.306, 25.321, 25.331
- 1135: - / Text3: 25.401, 25.420, 25.423, 25.427, 25.430, 25.433, 25.435
- 1136: - / Text3: 25.102, 25.105, 25.123, 25.142
- 1137: Completed May 2007; SR in RP-070038 and RP-070296
- 1138: - / Text3: 25.201, 25.221, 25.222, 25.223, 25.224, 25.225
- 1139: - / Text3: 25.301, 25.302, 25.306, 25.321, 25.331
- 1140: - / Text3: 25.401, 25.420, 25.423, 25.425, 25.427, 25.430, 25.433, 25.435
- 1141: - / Text3: 25.102, 25.105, 25.123, 25.142
- 1142: UID_350046->350146. 05/08: Linked to Feature UID_20055 (LCRTDD-EDCH). SR in RP-080539. RP#41 completed / Text3: 34.108, 34.122, 34.123-1/2/3
- 1143: GP#36 completed for R7 / Text3: 25.914, 25.144, 45.005
- 1144: - / Text3: 24.008, 43.022, 44.018, 44.118, 45, 001, 45.005, 51.010, 51.021
- 1145: Completed / Text3: 24.008, 43.022, 44.018, 44.118, 45, 001, 45.005,
- 1146: - / Text3: 51.021
- 1147: - / Text3: 51.010
- 1148: Originally started Nov. 2003 as GP-030443
- 1149: -
- 1150: -
- 1151: - / Text3: 43.955, 43.064, 44.060, 45.001, 45.002, 45.003, 45.005, 45.010, 51.010, 51.021
- 1152: -
- 1153: -

| ID | WBS | Task | Duration | Start | Finish | Complete | Baseline start | Baseline finish | Baseline duration | Constraint | Resources | Work | Actual work | Text1 | Text4 | Text5 | Text6 | Text8 | Text12 |
| --- | --- | --- | --- | --- | --- | --- | --- | --- | --- | --- | --- | --- | --- | --- | --- | --- | --- | --- | --- |
| 1154 | 353 | **Addition of new frequency band to GSM (T-GSM810)** | 626d? | 2005-04-08 A | 2007-08-31 A | 100% | 2005-04-08 | 2007-08-31 | 626d? |  | GP | 12112h | 12112h | TGSM810 | Huawei | chende@huawei.com | Rel-7 | Paolo |  |
| 1155 | 353.1 | Changes to core specification | 106d? | 2005-04-08 A | 2005-09-02 A | 100% | 2005-04-08 | 2005-09-02 | 106d? | finish no earlier than 2005-09-02 | GP | 848h | 848h | TGSM810-Core | Huawei | chende@huawei.com | Rel-7 | Paolo |  |
| 1156 | 353.2 | Changes to MS testing specification | 626d? | 2005-04-08 A | 2007-08-31 A | 100% | 2005-04-08 | 2007-08-31 | 626d? | finish no earlier than 2007-08-31 | G3new | 5008h | 5008h | TGSM810-MStest | Huawei | chende@huawei.com | Rel-7 | Ingbert |  |
| 1157 | 353.3 | Changes to BTS testing specification | 156d? | 2005-04-08 A | 2005-11-11 A | 100% | 2005-04-08 | 2005-11-11 | 156d? | finish no earlier than 2005-11-11 | G1 | 1248h | 1248h | TGSM810-BTStest | Huawei | chende@huawei.com | Rel-7 | Paolo |  |
| 1158 | 354 | **Handover of dedicated and shared resources while in Dual Transfer Mode** | 421d? | 2005-04-08 A | 2006-11-17 A | 100% | 2005-04-08 | 2006-11-17 | 421d? |  | GP | 12672h | 12672h | HODSRDTM | Nokia | rami.vaittinen@nokia.com | Rel-7 | Paolo |  |
| 1159 | 354.1 | Handover of dedicated and shared resources while in Dual Transfer Mode | 321d? | 2005-04-08 A | 2006-06-30 A | 100% | 2005-04-08 | 2006-06-30 | 321d? | finish no earlier than 2006-06-30 | G2 | 2568h | 2568h | HODSRDTM-G2 | Nokia | rami.vaittinen@nokia.com | Rel-7 | Gert |  |
| 1160 | 354.2 | Deleted - MS Conformance Testing | 421d? | 2005-04-08 A | 2006-11-17 A | 100% | 2005-04-08 | 2006-11-17 | 421d? | finish no earlier than 2006-11-17 | G3new | 3368h | 3368h | HODSRDTM-Mstest | Nokia | rami.vaittinen@nokia.com | Rel-7 | Ingbert | GP-32 |
| 1161 | 354.3 | Deleted - BTS conformance testing | 421d? | 2005-04-08 A | 2006-11-17 A | 100% | 2005-04-08 | 2006-11-17 | 421d? | finish no earlier than 2006-11-17 | G1 | 3368h | 3368h | HODSRDTM-BTStest | Nokia | rami.vaittinen@nokia.com | Rel-7 | Paolo | GP-32 |
| 1162 | 355 | **Mobile Station Receive Diversity (DARP Phase II)** | 526d? | 2005-11-11 A | 2007-11-16 A | 100% | 2005-11-11 | 2007-11-16 | 526d? |  | GP | 16360h | 16360h | MSRD2 | Nokia | kent.pedersen@nokia.com | Rel-7 | Paolo |  |
| 1163 | 355.1 | Performance Requirements for Mobile Station Receive Diversity, DARP Phase II | 331d? | 2005-11-11 A | 2007-02-16 A | 100% | 2005-11-11 | 2007-02-16 | 331d? | finish no earlier than 2007-02-16 | GP | 2648h | 2648h | MSRD2-PerfReq | Nokia | kent.pedersen@nokia.com | Rel-7 | Paolo |  |
| 1164 | 355.2 | Capability signalling of Mobile Station Receive Diversity, DARP Phase II | 331d? | 2005-11-11 A | 2007-02-16 A | 100% | 2005-11-11 | 2007-02-16 | 331d? | finish no earlier than 2007-02-16 | GP | 2648h | 2648h | MSRD2-CapSig | Nokia | kent.pedersen@nokia.com | Rel-7 | Paolo |  |
| 1165 | 355.3 | Test Scenarios for Mobile Station Receive Diversity, DARP Phase II | 331d? | 2005-11-11 A | 2007-02-16 A | 100% | 2005-11-11 | 2007-02-16 | 331d? | finish no earlier than 2007-02-16 | GP | 2648h | 2648h | MSRD2-TestSc | Nokia | kent.pedersen@nokia.com | Rel-7 | Paolo |  |
| 1166 | 355.4 | MS conformance test of DARP Phase II (MSRD) | 526d? | 2005-11-11 A | 2007-11-16 A | 100% | 2005-11-11 | 2007-11-16 | 526d? | finish no earlier than 2007-11-16 | GP | 4208h | 4208h | MSRD2-Msconf | Nokia | kent.pedersen@nokia.com | Rel-7 | Ingbert |  |
| 1167 | 356 | **Downlink Dual Carrier** | 421d? | 2006-01-20 A | 2007-08-31 A | 100% | 2006-01-20 | 2007-08-31 | 421d? |  | GP | 7664h | 7664h | GDCDL | Nokia Siemens Networks | leonardo.provvedi@roke.co.uk | Rel-7 | Paolo |  |
| 1168 | 356.1 | Downlink Dual Carrier Stage 2 | 116d? | 2006-01-20 A | 2006-06-30 A | 100% | 2006-01-20 | 2006-06-30 | 116d? | finish no earlier than 2006-06-30 | G1 | 928h | 928h | GDCDL-Stage2 | Nokia Siemens Networks | leonardo.provvedi@roke.co.uk | Rel-7 | Paolo |  |
| 1169 | 356.2 | Downlink Dual Carrier Stage 3 | 421d? | 2006-01-20 A | 2007-08-31 A | 100% | 2006-01-20 | 2007-08-31 | 421d? | finish no earlier than 2007-08-31 | G1 | 3368h | 3368h | GDCDL-Stage2 | Nokia Siemens Networks | leonardo.provvedi@roke.co.uk | Rel-7 | Paolo |  |
| 1170 | 357 | **Downlink Dual Carrier – MS Conformance Test** | 947d? | 2006-01-20 A | 2009-09-04 A | 100% | 2006-01-20 | 2009-09-04 | 947d? |  | G3new | 11150.6h | 11150.6h | GDCDL-Stage3 | Nokia Siemens Networks | leonardo.provvedi@roke.co.uk | Rel-7 | Ingbert |  |
| 1171 | 357.1 | Downlink Dual Carrier – MS Conformance Test | 446.82d? | 2006-01-20 A | 2009-09-04 A | 100% | 2006-01-20 | 2009-09-04 | 446.82d? | finish no earlier than 2009-09-04 | G3new | 3574.6h | 3574.6h | GDCDL-Stage3 | Nokia Siemens Networks | leonardo.provvedi@roke.co.uk | Rel-7 | Ingbert |  |
| 1172 | 358 | Support of SIGTRAN in GERAN | 116d? | 2006-01-20 A | 2006-06-30 A | 100% | 2006-01-20 | 2006-06-30 | 116d? | finish no earlier than 2006-06-30 | G3new | 928h | 928h | GDCDL-MStest | Ericsson | peter.ostrup@ericsson.com | Rel-7 | Ingbert |  |
| 1173 | 359 | **Latency Reductions** | 306d? | 2006-06-30 A | 2007-08-31 A | 100% | 2006-06-30 | 2007-08-31 | 306d? |  | GP | 7344h | 7344h | LATRED | Ericsson | Hakan.Persson@Ericsson.com | Rel-7 | Paolo |  |
| 1174 | 359.1 | Improved Ack/Nack reporting | 306d? | 2006-06-30 A | 2007-08-31 A | 100% | 2006-06-30 | 2007-08-31 | 306d? | finish no earlier than 2007-08-31 | G2 | 2448h | 2448h | LATRED-ACKNAR | Ericsson | Hakan.Persson@Ericsson.com | Rel-7 | Gert |  |
| 1175 | 359.2 | Reduced TTI | 306d? | 2006-06-30 A | 2007-08-31 A | 100% | 2006-06-30 | 2007-08-31 | 306d? | finish no earlier than 2007-08-31 | G2 | 2448h | 2448h | LATRED-REDTTI | Ericsson | Hakan.Persson@Ericsson.com | Rel-7 | Gert |  |
| 1176 | 360 | PS Handover between GERAN/UTRAN mode and GAN Mode | 166d? | 2006-06-30 A | 2007-02-16 A | 100% | 2006-06-30 | 2007-02-16 | 166d? | finish no earlier than 2007-02-16 | G2 | 1328h | 1328h | GUGAN | Ericsson | John.Diachina@Ericsson.com | Rel-7 | Gert |  |
| 1177 | 361 | **Higher Uplink performance for GERAN Evolution** | 516d? | 2006-09-08 A | 2008-08-29 A | 100% | 2006-09-08 | 2008-08-29 | 516d? |  | GP | 15440h | 15440h | HUGE | Nokia Siemens Networks, Ericsson | eddie.riddington@nokia.com, stefan.g.eriksson@ericsson.com | Rel-7 | Paolo |  |
| 1178 | 361.1 | Stage 2 of HUGE | 261d? | 2006-09-08 A | 2007-09-07 A | 100% | 2006-09-08 | 2007-09-07 | 261d? | finish no earlier than 2007-09-07 | G1 | 2088h | 2088h | HUGE-Stage2 | Nokia Siemens Networks, Ericsson | eddie.riddington@nokia.com, stefan.g.eriksson@ericsson.com | Rel-7 | Paolo |  |
| 1179 | 361.2 | Layer 1 Support of HUGE | 381d? | 2006-09-08 A | 2008-02-22 A | 100% | 2006-09-08 | 2008-02-22 | 381d? | finish no earlier than 2008-02-22 | G1 | 3048h | 3048h | HUGE-Layer1 | Nokia Siemens Networks, Ericsson | eddie.riddington@nokia.com, stefan.g.eriksson@ericsson.com | Rel-7 | Paolo |  |
| 1180 | 361.3 | Layer 2/3 Support of HUGE | 256d? | 2006-09-08 A | 2007-08-31 A | 100% | 2006-09-08 | 2007-08-31 | 256d? | finish no earlier than 2007-08-31 | G2 | 2048h | 2048h | HUGE-Layer23 | Nokia Siemens Networks, Ericsson | eddie.riddington@nokia.com, stefan.g.eriksson@ericsson.com | Rel-7 | Gert |  |
| 1181 | 361.4 | Performance requirements | 516d? | 2006-09-08 A | 2008-08-29 A | 100% | 2006-09-08 | 2008-08-29 | 516d? | finish no earlier than 2008-08-29 | G1 | 4128h | 4128h | HUGE-Perfreq | Nokia Siemens Networks, Ericsson | eddie.riddington@nokia.com, stefan.g.eriksson@ericsson.com | Rel-7 | Paolo |  |

Notes:
- 1154: - / Text3: 45.005, 45.050, 24.008, 45.008, 45.001, 43.022, 43.030, 44.018, 44.060, 51.010-1, 51.021
- 1155: - / Text3: 45.005, 45.050, 24.008, 45.008, 45.001, 43.022, 43.030, 44.018, 44.060
- 1156: - / Text3: 51010-1
- 1157: - / Text3: 51021
- 1158: GP#30 completed. Started at GP#24
- 1159: GP#30 completed / Text3: 43.055, 44.018, 44.060
- 1160: Stopped, no work done. 12/2008 Marked as stopped ("deleted") / Text3: 51-010
- 1161: Stopped, no work done. 12/2008 Marked as stopped ("deleted") / Text3: 51.026
- 1162: GP#36 completed / Text3: 24.008, 45.005, 51.010
- 1163: GP#33 completed / Text3: 45.005
- 1164: GP#33 completed / Text3: 24.008
- 1165: GP#33 completed / Text3: 45.005
- 1166: GP#36 completed / Text3: 51.010
- 1167: GP#35 completed
- 1168: GP#30 completed / Text3: 43.055, 43.064
- 1169: GP#35 completed / Text3: 24.008, 44.018, 44.060, 45.001, 45.002, 45.005, 45.008
- 1170: GP#43 completed / Text3: 51.010
- 1171: GP#43 completed / Text3: 51.010
- 1172: GP#30 completed / Text3: 48.001, 48.006, 43.059, 49.031
- 1173: GP#35 completed / Text3: 45.001, 45.002, 45.003, 45.005, 45.010, 43.055, 43.064, 44.060, 51.010-1, 51.021
- 1174: GP#35 completed / Text3: 45.001, 45.002, 45.003, 45.005, 45.010, 43.055, 43.064, 44.060, 51.010-1, 51.021
- 1175: GP#35 completed / Text3: 45.001, 45.002, 45.003, 45.005, 45.010, 43.055, 43.064, 44.060, 51.010-1, 51.021
- 1176: GP#33 completed / Text3: 43.318, 44.318, 43.129, 25.306, 24.008, 44.060, 25.331, 51.010
- 1177: GP#39 completed. SP#42 split core from testing specification work.
- 1178: GP#35 completed / Text3: 43.055, 43.064
- 1179: GP#37 completed / Text3: 45.001, 45.002, 45.003, 45.004, 45.008
- 1180: GP#35 completed / Text3: 24.008, 44.018, 44.060
- 1181: GP#39 completed / Text3: 45.005

| ID | WBS | Task | Type | Duration | Start | Finish | Complete | Remaining | Baseline start | Baseline finish | Baseline duration | Total slack | Constraint | Resources | Work | Actual work | Text1 | Text4 | Text5 | Text6 | Text8 | Text12 |
| --- | --- | --- | --- | --- | --- | --- | --- | --- | --- | --- | --- | --- | --- | --- | --- | --- | --- | --- | --- | --- | --- | --- |
| 1182 | 362 | **HUGE Conformance Testing** |  | 912d? | 2006-09-08 A | 2010-03-05 | 57% | 392.6d? | 2006-09-08 | 2010-03-05 | 912d? | 400d |  | G1,G3new | 20832h | 8066h | HUGE | Nokia Siemens Networks, Ericsson | eddie.riddington@nokia.com, stefan.g.eriksson@ericsson.com | Rel-7 | Paolo |  |
| 1183 | 362.1 | HUGE - MS Conformance Test |  | 911d? | 2006-09-08 A | 2010-03-05 | 20% | 728.8d? | 2006-09-08 | 2010-03-05 | 911d? | 400d | finish no earlier than 2010-03-05 | G3new | 7288h | 1457.6h | HUGE-Mstest | Nokia Siemens Networks, Ericsson | eddie.riddington@nokia.com, stefan.g.eriksson@ericsson.com | Rel-7 | Ingbert |  |
| 1184 | 362.2 | HUGE - BTS Conformance Test |  | 782d? | 2006-09-08 A | 2009-09-04 A | 100% |  | 2006-09-08 | 2009-09-04 | 782d? |  | finish no earlier than 2009-09-04 | G1 | 6248h | 6248h | HUGE-BTStest | Nokia Siemens Networks, Ericsson | eddie.riddington@nokia.com, stefan.g.eriksson@ericsson.com | Rel-7 | Paolo |  |
| 1185 | 363 | **REduced symbol Duration, Higher Order modulation and Turbo coding (RED HOT) for downlink** |  | 391d? | 2006-11-17 A | 2008-05-16 A | 100% |  | 2006-11-17 | 2008-05-16 | 391d? |  |  | GP | 7904h | 7904h | REDHOT | Ericsson, Nokia Siemens Networks, Marvell | stefan.g.eriksson@ericsson.com | Rel-7 | Paolo |  |
| 1186 | 363.1 | Stage 2 for REDHOT |  | 206d? | 2006-11-17 A | 2007-08-31 A | 100% |  | 2006-11-17 | 2007-08-31 | 206d? |  | finish no earlier than 2007-08-31 | G1 | 1648h | 1648h | REDHOT-Stage2 | Ericsson, Nokia Siemens Networks, Marvell | stefan.g.eriksson@ericsson.com | Rel-7 | Paolo |  |
| 1187 | 363.2 | Stage 3 for REDHOT |  | 391d? | 2006-11-17 A | 2008-05-16 A | 100% |  | 2006-11-17 | 2008-05-16 | 391d? |  | finish no earlier than 2008-05-16 | G1 | 3128h | 3128h | REDHOT-Stage3 | Ericsson, Nokia Siemens Networks, Marvell | stefan.g.eriksson@ericsson.com | Rel-7 | Paolo |  |
| 1188 | 364 | **REDHOT Conformance Testing** |  | 862d? | 2006-11-17 A | 2010-03-05 | 54% | 392.69d? | 2006-11-17 | 2010-03-05 | 862d? | 400d |  | G1,G3new | 18992h | 6926h | REDHOT | Ericsson, Nokia Siemens Networks, Marvell | stefan.g.eriksson@ericsson.com | Rel-7 | Paolo |  |
| 1189 | 364.1 | REDHOT - MS Conformance Tests |  | 861d? | 2006-11-17 A | 2010-03-05 | 20% | 688.8d? | 2006-11-17 | 2010-03-05 | 861d? | 400d | finish no earlier than 2010-03-05 | G3new | 6888h | 1377.6h | REDHOT-Mstest | Ericsson | stefan.g.eriksson@ericsson.com | Rel-7 | Ingbert |  |
| 1190 | 364.2 | BTS Conformance Tests |  | 651d? | 2006-11-17 A | 2009-05-15 A | 100% |  | 2006-11-17 | 2009-05-15 | 651d? |  | finish no earlier than 2009-05-15 | G1 | 5208h | 5208h | REDHOT-BTStest | Ericsson, Nokia Siemens Networks, Marvell | stefan.g.eriksson@ericsson.com | Rel-7 | Paolo |  |
| 1191 | 365 | (Small) Technical Enhancements and Improvements for Rel-7 | milestone | 0d? | 2007-03-26 A | 2007-03-26 A | 100% |  | 2007-03-26 | 2007-03-26 | 0d? |  | start no earlier than 2007-03-26 | All |  |  | TEI7 |  |  | Rel-7 |  |  |
| 1192 | 366 | **Deleted - PS domain and IMS support for IMS Emergency sessions** |  | 63.69d? | 2006-06-23 A | 2006-09-21 A | 100% |  | 2006-06-23 | 2006-09-21 | 63.69d? |  |  | S2 |  |  | IMS-EMER | Nokia | curt.c.wong@nokia.com | Rel-7 | Maurice | SP-30 |
| 1193 | 366.1 | Deleted - IMS aspects to support IMS Emergency sessions | milestone | 0d? | 2006-06-23 A | 2006-09-21 A | 100% |  | 2006-06-23 | 2006-09-21 | 0d? |  | start no earlier than 2006-06-23 | S2 |  |  | IMS-EMER | Nokia | curt.c.wong@nokia.com | Rel-7 | Maurice | SP-30 |
| 1194 | 366.2 | Deleted - PS domain aspects to support IMS Emergency sessions | milestone | 0d? | 2006-06-23 A | 2006-09-21 A | 100% |  | 2006-06-23 | 2006-09-21 | 0d? |  | start no earlier than 2006-06-23 | S2 |  |  | IMS-EMER | Nokia | curt.c.wong@nokia.com | Rel-7 | Maurice | SP-30 |
| 1195 | 367 | Deleted - Covered by SI - Personal Network (PN) and Personal Area Network (PAN) | milestone | 0d? | 2005-12-08 A | 2005-12-20 A | 100% |  | 2005-12-08 | 2005-12-20 | 0d? |  | start no earlier than 2005-12-08 | S1 |  |  | PNPAN | Vodafone | armin.toepfer@vodafone.com | Rel-7 | Alain | SP-30 |
| 1196 | 368 | Deleted - Covered by SI - Multimedia Telephony Capabilities for IMS | milestone | 0d? | 2005-12-08 A | 2005-12-20 A | 100% |  | 2005-12-08 | 2005-12-20 | 0d? |  | start no earlier than 2005-12-08 | S1 |  |  | MITE | Ericsson | peter.bleckert@ericsson.com | Rel-7 | Alain | SP-30 |
| 1197 | 369 | Deleted - Covered by SI - Transferring of emergency Call data | milestone | 0d? | 2005-12-08 A | 2005-12-08 A | 100% |  | 2005-12-08 | 2005-12-08 | 0d? |  | start no earlier than 2005-12-08 | S1 |  |  | eCALL | Motorola | steven.vardy@motorola.com | Rel-7 | Alain | SP-30 |
| 1198 | 370 | Deleted - Covered by SI - MBMS Enhancements | milestone | 0d? | 2005-12-08 A | 2005-12-08 A | 100% |  | 2005-12-08 | 2005-12-08 | 0d? |  | start no earlier than 2005-12-08 | S1 |  |  | MBMSE | China Mobile | liuhongyfw@chinamobile.com | Rel-7 | Alain | SP-30 |
| 1199 | 371 | **Deleted - VoIMS bearer related enhancements** |  | 0d? | 2006-07-21 A | 2006-07-21 A | 100% |  | 2006-07-21 | 2006-07-21 | 0d? |  |  | S2 |  |  | VoIMS |  |  | Rel-7 | Maurice | SP-32 |
| 1200 | 371.1 | Deleted - FS on enhancement of radio performance for VoIMS | milestone | 0d? | 2006-07-21 A | 2006-07-21 A | 100% |  | 2006-07-21 | 2006-07-21 | 0d? |  | start no earlier than 2006-07-21 | S2 |  |  | VoIMS | Nortel | Laurence Lautier (lautierl@nortel.com) | Rel-7 | Maurice | SP-32 |
| 1201 | 372 | Release 7 Studies |  | 1d? | 2000-01-03 | 2000-01-03 |  |  | 2000-01-03 | 2000-01-03 | 1d? | 3056d |  | CP,GP,RP,SP | 8h |  |  |  |  | Rel-7 |  |  |
| 1202 | 373 | **Study on Multimedia Telephony Capabilities for IMS** |  | 276d? | 2005-07-11 A | 2006-07-31 A | 100% |  | 2005-07-11 | 2006-07-31 | 276d? |  |  | S1 | 4353.6h | 4353.6h | MITE | Ericsson | peter.bleckert@ericsson.com | Rel-7 | Alain |  |
| 1203 | 373.1 | Deleted covered by UID_31082 - Study of (MITe) - IMS Multimedia Telephony Communication Enabler and supplementary services |  | 276d? | 2005-07-11 A | 2006-07-31 A | 100% |  | 2005-07-11 | 2006-07-31 | 276d? |  | start no earlier than 2005-07-11 | S1 | 2208h | 2208h | MITE | Ericsson | peter.bleckert@ericsson.com | Rel-7 | Alain | SP-28 |
| 1204 | 374 | Study on Behaviour of Multi system UEs |  | 384d? | 2004-06-28 A | 2005-12-15 A | 100% |  | 2004-06-28 | 2005-12-15 | 384d? |  | start no earlier than 2004-06-28 | S1 | 3072h | 3072h | BMSU | Qualcomm Europe | dwilliams@qualcomm.com | Rel-7 | Alain |  |
| 1205 | 375 | Study on Combining CS calls and IMS sessions |  | 189d? | 2004-06-28 A | 2005-03-17 A | 100% |  | 2004-06-28 | 2005-03-17 | 189d? |  | start no earlier than 2004-06-28 | S1 | 1512h | 1512h | IRTSD-CS_IMS |  | Robert Frank | Rel-7 | Alain |  |
| 1206 | 376 | Study on All-IP Network |  | 188d? | 2004-06-28 A | 2005-03-16 A | 100% |  | 2004-06-28 | 2005-03-16 | 188d? |  | start no earlier than 2004-06-28 | S1 | 1504h | 1504h | FS_AIPN | NTT DoCoMo | c.masyu@nttdocomo.co.jp | Rel-7 | Alain |  |
| 1207 | 377 | Study on Videotelephony teleservice |  | 231d? | 2005-03-01 A | 2006-01-17 A | 100% |  | 2005-03-01 | 2006-01-17 | 231d? |  |  | S1 | 1848h | 1848h | VidTel | T-Mobile | kurt.bischinger@t-mobile.at | Rel-7 | Alain |  |
| 1208 | 378 | Study on Network Selection Principles |  | 193d? | 2005-03-15 A | 2005-12-08 A | 100% |  | 2005-03-15 | 2005-12-08 | 193d? |  |  | S1 | 1544h | 1544h | NetSel | O2 | chris.friel@o2.com | Rel-7 | Alain |  |
| 1209 | 379 | Study on Multimedia Priority Service |  | 851d? | 2003-03-28 A | 2006-06-30 A | 100% |  | 2003-03-28 | 2006-06-30 | 851d? |  | finish no earlier than 2005-12-16 | S1 | 6808h | 6808h | PRIOR-MM | Telcordia | jgarraha@telcordia.com | Rel-7 | Alain |  |
| 1210 | 380 | Study on Transferring of emergency Call data |  | 190d? | 2005-07-11 A | 2006-03-31 A | 100% |  | 2005-07-11 | 2006-03-31 | 190d? |  | finish no earlier than 2005-12-08 | S1 | 1520h | 1520h | eCALL | Motorola | steven.vardy@motorola.com | Rel-7 | Alain |  |
| 1211 | 381 | Study on Enhancement of E2E QoS |  | 281.4d? | 2004-06-28 A | 2005-09-15 A | 100% |  | 2004-06-28 | 2005-09-15 | 281.4d? |  | finish no earlier than 2005-12-01 | S2 | 2251.2h | 2251.2h | QoS7 | Huawei | Robert Jaksa | Rel-7 | Maurice |  |
| 1212 | 382 | Study on Bandwidth Saving at Nb Interface with IP transport |  | 261d? | 2006-03-10 A | 2007-03-09 A | 100% |  | 2006-03-10 | 2007-03-09 | 261d? |  | finish no earlier than 2007-03-09 | C3 | 2088h | 2088h | BSNbIP | Siemens | Thomas.Belling@nsn.com | Rel-7 | Gwiho |  |
| 1213 | 383 | Study on Routeing of MT-SMS via the HPLMN |  | 301d? | 2005-10-07 A | 2006-12-01 A | 100% |  | 2005-10-07 | 2006-12-01 | 301d? |  | finish no earlier than 2006-12-01 | C4 | 2408h | 2408h | SMS7 | Vodafone | Nick.Russell@vodafone.com | Rel-7 | Kimmo |  |
| 1214 | 384 | Study on the TCAPsec Gateway concept |  | 96d? | 2005-10-28 A | 2006-03-10 A | 100% |  | 2005-10-28 | 2006-03-10 | 96d? |  | finish no earlier than 2006-03-10 | C4 | 768h | 768h | SEC7-TCAP | Siemens | Ulrich.wiehe@gksag.de | Rel-7 | Kimmo |  |
| 1215 | 385 | Study on using M2PA in 3GPP network |  | 318d? | 2006-03-22 A | 2007-06-08 A | 100% |  | 2006-03-22 | 2007-06-08 | 318d? |  | finish no earlier than 2007-06-08 | C4 | 2544h | 2544h | FS-M2PA | China Mobile | zhaoyuyi@chinamobile.com | Rel-7 | Kimmo |  |

Notes:
- 1182: SP#42 split core from testing specification work
- 1183: GP#44 target 02/10=>03/10 / Text3: 51.010
- 1184: GP#43 completed / Text3: 51.021
- 1185: GP#38 completed. SP#42 split core from testing specification work.
- 1186: GP#35 completed / Text3: 43.055, 43.064
- 1187: GP#38 completed / Text3: 24.008, 44.018, 44.060, 45.001, 45.002, 45.003, 45.004, 45.005, 45.008
- 1188: SP#42 split core from testing specification work
- 1189: GP#44 completion 02/10=>03/10 / Text3: 51.010
- 1190: GP#42 completed / Text3: 51.021
- 1191: - / Text3: CP-070260
- 1192: Approved at SP#29 / Text3: 23.867, 23.abc, 23.060, 23.002, 23.271
- 1193: Approved at SP#29 / Text3: 23.867, 23.abc, 23.060, 23.002, 23.271
- 1194: Approved at SP#29 / Text3: 23.867, 23.abc, 23.060, 23.002, 23.271
- 1195: -
- 1196: -
- 1197: -
- 1198: -
- 1199: Created by MCC to group all VoIMS related items, after consultation of chairs
- 1200: WID approved SP#28: SA2#52: CLOSED - To be removed from the work plan / Text3: 23.807
- 1201: -
- 1202: Spin-off Feature UID_7038 (MTSI) / Text3: 22.973
- 1203: Duplicate entry with 31082 / Text3: 22.973
- 1204: - / Text3: 22.936
- 1205: - / Text3: 22.979
- 1206: 07/08 Moved to Rel-7 as Study out of stopped Rel-8 Feature UID_31067 All-IP Network (AIPN) / Text3: 22.978
- 1207: - / Text3: 22.903
- 1208: Spin-off Feature Network selection enhancements (NSP-CR) UID_7041 / Text3: 22.811
- 1209: Spin-off Feature PRIOR UID_340044 / Text3: 22.953
- 1210: - / Text3: 22.967
- 1211: - / Text3: 23.802
- 1212: Moved to FS at CT32 (in line with slides) / Text3: 29.814
- 1213: Previously known as "Study of a SMS Centre for MT SMS" / Text3: 23.840
- 1214: TR 29.800 content moved to TS 29.204 under implementation WI UID_310005 TCAPsec Gateway / Text3: 29.800
- 1215: - / Text3: 29.801

| ID | WBS | Task | Type | Duration | Start | Finish | Complete | Baseline start | Baseline finish | Baseline duration | Total slack | Constraint | Resources | Work | Actual work | Text1 | Text3 | Text4 | Text5 | Text6 | Text8 | Text11 | Text12 |
| --- | --- | --- | --- | --- | --- | --- | --- | --- | --- | --- | --- | --- | --- | --- | --- | --- | --- | --- | --- | --- | --- | --- | --- |
| 1216 | 386 | **Study on Support of (G)MSC-S - (G)MSC-S Nc Interface based on the SIP-I protocol** |  | 350d? | 2006-05-15 A | 2007-09-14 A | 100% | 2006-05-15 | 2007-09-14 | 350d? |  |  | C4 | 7800h | 7800h | NcSIP | 29.802 | Vodafone | david.hutton@vodafone.com | Rel-7 | Kimmo |  |  |
| 1217 | 386.1 | CT4 aspects of NcSIP |  | 275d? | 2006-05-15 A | 2007-06-01 A | 100% | 2006-05-15 | 2007-06-01 | 275d? |  | finish no earlier than 2007-06-01 | C4 | 2200h | 2200h | NcSIP | 29.802 | Vodafone | david.hutton@vodafone.com | Rel-7 | Kimmo |  |  |
| 1218 | 386.2 | CT3 aspects of NcSIP |  | 350d? | 2006-05-15 A | 2007-09-14 A | 100% | 2006-05-15 | 2007-09-14 | 350d? |  | finish no earlier than 2007-09-14 | C3 | 2800h | 2800h | NcSIP | 29.802 | Ericsson | ragnar.huslende@ericsson.com | Rel-7 | Gwiho |  |  |
| 1219 | 387 | Study on SOAP/HTTP IRP Solution Sets |  | 330d? | 2005-09-02 A | 2006-12-07 A | 100% | 2005-09-02 | 2006-12-07 | 330d? |  | finish no earlier than 2006-12-07 | S5 | 2640h | 2640h | OAM7-NIM-XML | 32.809 | Nortel |  | Rel-7 | Dionisio |  |  |
| 1220 | 388 | Study on Itf-N Implementation Conformance Statement (ICS) template |  | 400d? | 2005-09-02 A | 2007-03-15 A | 100% | 2005-09-02 | 2007-03-15 | 400d? |  | finish no earlier than 2007-03-15 | S5 | 3200h | 3200h | OAM7-NIM-ICS | 32.812 | China Mobile |  | Rel-7 | Dionisio |  |  |
| 1221 | 389 | Study on IRP Information Model |  | 400d? | 2005-09-02 A | 2007-03-15 A | 100% | 2005-09-02 | 2007-03-15 | 400d? |  | finish no earlier than 2007-03-15 | S5 | 3200h | 3200h | OAM7-NIM-IM | 32.810 | Motorola |  | Rel-7 | Dionisio |  |  |
| 1222 | 390 | Study on Evolved UTRA and UTRAN |  | 458d? | 2004-12-15 A | 2006-09-15 A | 100% | 2004-12-15 | 2006-09-15 | 458d? |  | finish no earlier than 2006-09-15 | RP | 3664h | 3664h | RANFS-Evo | 25.912 | NTT DoCoMo | nakamurata@NTTDOCOMO.CO.JP | Rel-7 | Issam | RP-060472 |  |
| 1223 | 391 | Study on Performance Evaluation of the UE behaviour in high speed trains with speeds up to 350 kmph |  | 328d? | 2005-03-15 A | 2006-06-15 A | 100% | 2005-03-15 | 2006-06-15 | 328d? |  | finish no earlier than 2006-06-15 | R4 | 2624h | 2624h | RANFS-HSTrains | none | Vodafone | Mike.vogel@vodafone.com,tim.frost@vodafone.com | Rel-7 | Issam | RP-060412 |  |
| 1224 | 392 | Study on UTRA Tower Mounted Amplifier (FDD) |  | 195d? | 2005-06-15 A | 2006-03-14 A | 100% | 2005-06-15 | 2006-03-14 | 195d? |  | finish no earlier than 2006-03-15 | R4 | 1560h | 1560h | RANFS-TMA | 25.818 | Ericsson | Klas.Sjerling@ericsson.com | Rel-7 | Issam | RP-060035 |  |
| 1225 | 393 | Study on Continuous connectivity for packet data users |  | 132d? | 2005-03-15 A | 2005-09-14 A | 100% | 2005-03-15 | 2005-09-14 | 132d? |  | finish no earlier than 2005-09-15 | R1 | 1056h | 1056h | RANFS-cont-packet | none | Siemens | joerg.gustrau@siemens.com | Rel-7 | Patrick | RP-050427 |  |
| 1226 | 394 | Study on Improvement of the Multimedia Broadcast Multicast Service (MBMS) in UTRAN |  | 262d? | 2005-12-15 A | 2006-12-15 A | 100% | 2005-12-15 | 2006-12-15 | 262d? |  | finish no earlier than 2006-12-15 | R2 | 2096h | 2096h | RANFS-MBMSImp | 25.905 | LG Electronics | leego@lge.com | Rel-7 | Joern | RP-060692 |  |
| 1227 | 395 | Study on Performance Improvements in Small Cells using HSDPA/EDCH |  | 131d? | 2005-12-15 A | 2006-06-15 A | 100% | 2005-12-15 | 2006-06-15 | 131d? |  | finish no earlier than 2006-06-15 | R4 | 1048h | 1048h | SMALLCELLS | none | Cingular | Marc Grant | Rel-7 | Issam | RP-060263 |  |
| 1228 | 396 | Study on Further Improved Performance Requirements for UMTS/HSDPA UE (FDD) |  | 383d? | 2005-12-15 A | 2007-06-04 A | 100% | 2005-12-15 | 2007-06-04 | 383d? |  | finish no earlier than 2007-06-04 | R4 | 3064h | 3064h | RANFS-IC | 25.963 | Cingular | Marc Grant | Rel-7 | Issam | RP-070499 |  |
| 1229 | 397 | Study on Scope of future FDD HSPA Evolution |  | 394d? | 2006-03-15 A | 2007-09-17 A | 100% | 2006-03-15 | 2007-09-17 | 394d? |  | finish no earlier than 2007-09-17 | RP | 3152h | 3152h | RANFS-HSPAEvo | 25.999 | Cingular | Don Zelmer (dz1069@att.com) | Rel-7 | Issam | RP-070533 |  |
| 1230 | 398 | Study on Dynamically reconfiguring a FDD UE receiver to reduce power consumption when desired Quality of Service is met | milestone | 0d? | 2007-06-22 A | 2007-06-22 A | 100% | 2007-06-22 | 2007-06-22 | 0d? |  |  | R4 |  |  | FSUEPow | 25.906 | Nokia | Chris.callender@nokia.com, tiina.s.koskinen@nokia.com | Rel-7 | Issam | RP-070534 |  |
| 1231 | 399 | Study on Future GERAN Evolution |  | 486d? | 2005-04-08 A | 2007-02-16 A | 100% | 2005-04-08 | 2007-02-16 | 486d? |  | finish no earlier than 2007-02-16 | GP | 3888h | 3888h | FGE | 45.912 | Nokia | eddie.riddington@nokia.com | Rel-7 | Paolo |  |  |
| 1232 | 400 | Study on GAN Enhancements | milestone | 0d? | 2007-08-31 A | 2007-08-31 A | 100% | 2007-08-31 | 2007-08-31 | 0d? |  | start no earlier than 2007-08-31 | GP |  |  | EGAN | 43.902 | T-Mobile | janne.linkola@t-mobile.com | Rel-7 | Paolo |  |  |
| 1233 | 401 | Deleted - covered by UID33027 - IMS security extensions | milestone | 0d? | 2005-12-08 A | 2005-12-08 A | 100% | 2005-12-08 | 2005-12-08 | 0d? |  | start no earlier than 2005-12-08 | S3 |  |  | IMS-SE |  | Ericsson | Bengt.Sahlin@ericsson.com | Rel-7 | Dionisio |  | SP-30 |
| 1234 | 402 | Deleted - covered by 32108 - Study of work on an LCS architecture for I-WLAN | milestone | 0d? | 2006-12-08 A | 2006-12-08 A | 100% | 2006-12-08 | 2006-12-08 | 0d? |  | start no earlier than 2006-12-08 | S2 |  |  | IMS-SE |  | LG Electronics | Donghee Shim dhshim@lge.com ; phede@lge.com | Rel-7 | Maurice |  | SP-33 |
| 1235 | 403 | **Deleted: Study on applicability of GALILEO for LCS** |  | 0d? | 2005-06-30 A | 2005-06-30 A | 100% | 2005-06-30 | 2005-06-30 | 0d? |  |  | S2 |  |  | Galileo |  |  |  | Rel-7 | Maurice |  | SP-25 |
| 1236 | 403.1 | Deleted - TR on Stage 2 | milestone | 0d? | 2005-06-30 A | 2005-06-30 A | 100% | 2005-06-30 | 2005-06-30 | 0d? |  | finish no earlier than 2005-06-30 | S2 |  |  | Galileo |  |  |  | Rel-7 | Maurice |  | SP-25 |
| 1237 | 403.2 | Deleted - GERAN review of the TR | milestone | 0d? | 2005-06-30 A | 2005-06-30 A | 100% | 2005-06-30 | 2005-06-30 | 0d? |  | start no earlier than 2005-06-30 | GP |  |  | Galileo |  |  |  | Rel-7 | Paolo |  | SP-26 |
| 1238 | 16.7 | **Deleted - IMS Local services** |  | 0d? | 2006-01-06 A | 2006-01-06 A | 100% | 2006-01-06 | 2006-01-06 | 0d? |  |  | S2 |  |  | IMSLocal | 23.228 |  |  | Rel-7 | Maurice |  | SP-28 |
| 1239 | 16.7.1 | Deleted - Stage 2 | milestone | 0d | 2006-01-06 A | 2006-01-06 A | 100% | 2006-01-06 | 2006-01-06 | 0d |  | start no earlier than 2006-01-06 | S2 |  |  | IMSLocal |  |  |  | Rel-7 | Maurice |  | SP-26 |
| 1240 | 404.2 | Deleted - Stage 3 for IMS Local services | milestone | 0d? | 2006-01-06 A | 2006-01-06 A | 100% | 2006-01-06 | 2006-01-06 | 0d? |  | finish no earlier than 2006-01-06 | C1 |  |  | IMSLocal |  | Lucent | Keith Drage (drage@alcatel-lucent.com) | Rel-7 | Frederic |  | SP-25 |
| 1241 | 405 | Deleted - IMS Phase 3 | milestone | 0d? | 2006-01-06 A | 2006-01-06 A | 100% | 2006-01-06 | 2006-01-06 | 0d? |  | start no earlier than 2006-01-06 | S2 |  |  |  |  |  |  | Rel-7 | Maurice |  | SP-25 |
| 1242 | 406 | Deleted - Improvements of Radio Interface | milestone | 0d? | 2004-09-15 A | 2004-09-15 A | 100% | 2004-09-15 | 2004-09-15 | 0d? |  | start no earlier than 2004-09-15 | RP |  |  | RInImp |  |  |  | Rel-7 | Issam |  | SP-24 |
| 1243 | 407 | Deleted: Generic User Profile Phase 2 | milestone | 0d | 2005-08-08 A | 2006-06-30 A | 100% | 2005-08-08 | 2006-06-30 | 0d |  |  | C4 |  |  |  |  |  |  | Rel-7 | Kimmo |  | SP-27 |
| 1244 | 30.4 | Deleted - Stage 3 - Common objects | milestone | 0d | 2005-08-08 A | 2006-06-30 A | 100% | 2005-08-08 | 2006-06-30 | 0d |  | finish no earlier than 2006-06-30 | C4 |  |  |  | 24.241 |  |  | Rel-7 | Kimmo |  | SP-27 |
| 1245 | 409 | Deleted was duplicated- Study of Customised Alerting Tone (CAT) Requirements | milestone | 0d? | 2006-06-30 A | 2006-06-30 A | 100% | 2006-06-30 | 2006-06-30 | 0d? |  | start no earlier than 2006-06-30 | S1 |  |  | CAT |  |  |  | Rel-7 | Alain |  | SP-31 |
| 1246 | 410 | Deleted - FS of enhanced support of Video Telephony | milestone | 0d? | 2006-06-30 A | 2006-06-30 A | 100% | 2006-06-30 | 2006-06-30 | 0d? |  | start no earlier than 2006-06-30 | GP |  |  | VIDGER |  | Ericsson | stefan.g.eriksson@ericsson.com | Rel-7 | Paolo |  | SP-32 |
| 1247 | 411 | Deleted (moved to Rel8) - Study on Transferring of emergency call data – in-band modem solution | milestone | 0d? | 2007-06-22 A | 2007-06-22 A | 100% | 2007-06-22 | 2007-06-22 | 0d? |  | start no earlier than 2007-06-22 | S4 |  |  | eCALLIBMS | 26.967 | Airbiquity | lhong@airbiquity.com | Rel-7 | Paolo |  | SP-38 |
| 1248 | 412 | Deleted - covered by UID 20053 - Study on Interference Cancellation for UTRA FDD UE |  | 1d? | 2007-03-28 A | 2007-03-28 A | 100% | 2007-03-28 | 2007-03-28 | 1d? |  | start no earlier than 2007-03-28 | R4 | 8h | 8h | RANFS-InterfCanc |  |  |  | Rel-7 | Issam |  | SP-38 |
| 1249 | 413 | Deleted - Study of Personal Network and Personal Area Network | milestone | 0d? | 2006-10-20 A | 2006-10-20 A | 100% | 2006-10-20 | 2006-10-20 | 0d? |  | finish no earlier than 2006-10-20 | S1 |  |  | PNPAN |  |  |  | Rel-7 | Alain |  | SP-31 |
| 1250 | 414 | Deleted - Study on IMS with real time services deployment |  | 316d? | 2004-06-28 A | 2005-09-12 A | 100% | 2004-06-28 | 2005-09-12 | 316d? |  |  | S1 | 2528h | 2528h | IRTSD |  |  |  | Rel-7 | Alain |  | SP-30 |
| 1251 | 415 | Deleted - Study on Stage 2 (IMS services using CS bearers) |  | 316d? | 2004-06-28 A | 2005-09-12 A | 100% | 2004-06-28 | 2005-09-12 | 316d? |  | finish no earlier than 2005-09-12 | S2 | 2528h | 2528h | IRTSD-IMSCS | 23.899 | Nortel | Mark Watson | Rel-7 | Maurice |  | SP-30 |
| 1252 | 416 | Deleted - Study on IMS enhancements and optimizations for real time communication. |  | 430d? | 2005-10-10 A | 2007-06-01 A | 100% | 2005-10-10 | 2007-06-01 | 430d? |  | finish no earlier than 2007-06-01 | S2 | 3440h | 3440h | IMS-RT | 23.818 | Ericsson | stephen.terrill@ericsson.com | Rel-7 | Maurice |  | SP-35 |
| 1253 | 417 | Deleted - Study on Terminating Session handling |  | 255d? | 2006-01-09 A | 2006-12-29 A | 100% | 2006-01-09 | 2006-12-29 | 255d? |  | finish no earlier than 2006-12-29 | S2 | 2040h | 2040h | CSIterm | 23.819 | Samsung |  | Rel-7 | Maurice |  | SP-32 |
| 1254 | 418 | Deleted - Study on IRP usage scenarios |  | 330d? | 2005-09-02 A | 2006-12-07 A | 100% | 2005-09-02 | 2006-12-07 | 330d? |  | finish no earlier than 2006-12-07 | S5 | 2640h | 2640h | OAM-Study | 32.8xy | Lucent |  | Rel-7 | Dionisio |  | SP-32 |
| 1255 | 419 | Release 6 Features |  | 1d? | 2000-01-03 | 2000-01-03 |  | 2000-01-03 | 2000-01-03 | 1d? | 3056d |  | NP,GP, RP,SP,TP | 8h |  |  |  |  |  | Rel-6 |  |  |  |

Notes:
- 1216: -
- 1217: -
- 1218: -
- 1219: SP#34 completed
- 1220: SP#35 completed
- 1221: SP#35 completed
- 1222: RP#33 (Sep 2006) completed. SR in RP-060472
- 1223: RP#32 (Jun 2006) completed. SR in RP-060412
- 1224: RP#31 (Mar 2006) completed. SR in RP-060035
- 1225: RP#29 (Sep 2006) completed. SR in RP-050427
- 1226: RP#34 (Dec 2006) completed. SR in RP-060692
- 1227: RP#32 (Jun 2006) closed (no progress). SR in RP-060263
- 1228: RP#36 (May 2007) completed. SR in RP-070499
- 1229: RP#37 (Sep 2007) completed. SR in RP-070533
- 1230: RP#37 (Sep 2007) completed. SR in RP-070534
- 1231: GP#33 completed
- 1232: GP#35 completed
- 1233: -
- 1234: S2#52: Entry created
- 1235: -
- 1236: -
- 1237: -
- 1238: -
- 1239: DAB - Not yet required in SA2 as it exists in previous releases
- 1240: -
- 1241: -
- 1242: Stage 2 description of Interim conclusion
- 1243: Created at TSG#27 by A. Sultan because of the move to Rel-7 of "Common Objects".
- 1244: No progress in CN4#26. This have to be moved to Rel-7. It was deleted from WID
- 1245: Awaiting MCC SA3 input
- 1246: FS CLOSED at G#28 (no input)
- 1247: SP-38 stopped
- 1248: Deleted. Same as FS on Further Improved Performance Requirements for UMTS/HSDPA UE (FDD)
- 1249: Moved from FS section Feb 06
- 1250: -
- 1251: SP-30: S2 has no intention for TR completion
- 1252: abandoned at 65%
- 1253: SP#32 Jun 2006 Study abandoned => spin-off Implementation work UID_320029
- 1254: -
- 1255: -

| ID | WBS | Task | Duration | Start | Finish | Complete | Baseline start | Baseline finish | Baseline duration | Constraint | Resources | Work | Actual work | Text1 | Text6 | Text8 | Text4 | Text5 | Text3 | Text10 | Text12 |
| --- | --- | --- | --- | --- | --- | --- | --- | --- | --- | --- | --- | --- | --- | --- | --- | --- | --- | --- | --- | --- | --- |
| 1256 | 8 | **Rel-6 Improvements of Radio Interface** | 1393d? | 2000-08-14 A | 2005-12-14 A | 100% | 2000-08-14 | 2005-12-14 | 1393d? |  | RP | 38664h | 38664h | RInImp | Rel-6 | Issam |  |  |  |  |  |
| 1257 | 420.1 | Improved support of IMS Realtime Services using HSDPA/EDCH | 197d? | 2005-03-15 A | 2005-12-14 A | 100% | 2005-03-15 | 2005-12-14 | 197d? | finish no earlier than 2005-12-14 | R2 | 1576h | 1576h | RInImp-IMSRealTime | Rel-6 | Joern | Cingular | Don Zelmer (dz1069@att.com) |  |  |  |
| 1258 | 420.2 | Improving Receiver Performance Requirements for the FDD UE | 401d | 2002-03-08 A | 2003-09-19 A | 100% | 2002-03-08 | 2003-09-19 | 401d | start no earlier than 2002-03-08 | R4 | 3208h | 3208h | RInImp-UERecPerf | Rel-6 | Issam | Intel | shimon.moshavi@INTEL.COM | 25.101 |  |  |
| 1259 | 8.2 | **Base station classification** | 603d | 2000-08-14 A | 2002-12-04 A | 100% | 2000-08-14 | 2002-12-04 | 603d |  | R4 | 9648h | 9648h | RInImp-BSClass | Rel-6 | Issam |  |  |  |  |  |
| 1260 | 8.2.1 | FDD Base station classification | 603d | 2000-08-14 A | 2002-12-04 A | 100% | 2000-08-14 | 2002-12-04 | 603d | finish no earlier than 2002-12-04 | R4 | 4824h | 4824h | RInImp-BSClass-FDD | Rel-6 | Issam | Nokia | antti.toskala@nokia.com | 25.104, 25.141 |  |  |
| 1261 | 420.4 | UMTS-850 | 266d | 2002-12-06 A | 2003-12-12 A | 100% | 2002-12-06 | 2003-12-12 | 266d | finish no earlier than 2003-12-15 | R4 | 2128h | 2128h | RInImp-UMTS850 | Rel-6 | Issam | Cingular | Don Zelmer (dz1069@att.com) | 25.101, 25.104, 25.133, 25.141, 25.307, 25.331, 25.942 |  |  |
| 1262 | 420.5 | DS-CDMA introduction in the 800 MHz band | 196d | 2003-03-14 A | 2003-12-12 A | 100% | 2003-03-14 | 2003-12-12 | 196d | finish no earlier than 2003-12-15 | R4 | 1568h | 1568h | RInImp-UMTS800 | Rel-6 | Issam | NTT DoCoMo | Takehiro Nakamura (nakamurata@nttdocomo.co.jp) | 25.101, 25.104, 25.133, 25.141, 25.307, 25.331 |  |  |
| 1263 | 420.6 | UMTS 1.7/2.1 GHz | 261d | 2003-03-14 A | 2004-03-12 A | 100% | 2003-03-14 | 2004-03-12 | 261d | finish no earlier than 2004-03-15 | R4 | 2088h | 2088h | RInImp-UMTS1721 | Rel-6 | Issam | Nokia | jussi.numminen@NOKIA.COM | 25.101, 25.104, 25.133, 25.141, 25.307, 25.331 |  |  |
| 1264 | 420.7 | **Improved Receiver Performance Requirements for HSDPA** | 392d? | 2003-12-15 A | 2005-06-14 A | 100% | 2003-12-15 | 2005-06-14 | 392d? |  | R4 | 7304h | 7304h | RInImp-HSPerf | Rel-6 | Issam | Nokia | jussi.numminen@NOKIA.COM |  |  |  |
| 1265 | 420.7.1 | Improved Minimum Performance Requirements for HSDPA UE categories 7 and 8 | 195d? | 2004-09-15 A | 2005-06-14 A | 100% | 2004-09-15 | 2005-06-14 | 195d? | finish no earlier than 2005-06-14 | R4 | 1560h | 1560h | RInImp-HSPerf-10code | Rel-6 | Issam | Nokia | jussi.numminen@nokia.com | 25.101 |  |  |
| 1266 | 420.7.2 | Performance Requirements of Receive Diversity for HSDPA | 326d | 2003-12-15 A | 2005-03-14 A | 100% | 2003-12-15 | 2005-03-14 | 326d | finish no earlier than 2005-03-14 | R4 | 2608h | 2608h | RInImp-HSPerf-RxDiv | Rel-6 | Issam | NTT DoCoMo | Takehiro Nakamura (nakamurata@nttdocomo.co.jp) | 25.101 |  |  |
| 1267 | 421 | **Rel-6 RAN Feasibility Studies** | 1196d? | 2000-08-14 A | 2005-03-14 A | 100% | 2000-08-14 | 2005-03-14 | 1196d? |  | RP | 43048h | 43048h |  | Rel-6 |  |  |  |  |  |  |
| 1268 | 421.1 | FS of the improved access to UE measurement data for CRNC to support TDD RRM | 270d? | 2002-12-06 A | 2003-12-18 A | 100% | 2002-12-06 | 2003-12-18 | 270d? | finish no earlier than 2003-09-19 | R3 | 2160h | 2160h | RANimp-RRMopt-FSUEMsD | Rel-6 | Juha | Interdigital | jim.miller@interdigital.com | 25.801, 25.423 | SP-24 |  |
| 1269 | 421.2 | FS on Radio link performance enhancements | 1067d | 2000-08-14 A | 2004-09-14 A | 100% | 2000-08-14 | 2004-09-14 | 1067d | finish no earlier than 2004-09-14 | R1 | 8536h | 8536h | RInImp-Rlperf | Rel-6 | Patrick | Nokia | antti.toskala@nokia.com | 25.899 |  |  |
| 1270 | 421.3 | FS on Improvement of inter-frequency and inter-system measurements for 1.28 Mcps TDD | 461d | 2001-12-14 A | 2003-09-19 A | 100% | 2001-12-14 | 2003-09-19 | 461d | start no earlier than 2001-12-14 | R1 | 3688h | 3688h | RInImp-IfIsMLCR | Rel-6 | Patrick | Samsung | Li Xiao Qiang (xqli@samsung.co.kr) | 25.888 |  |  |
| 1271 | 421.4 | FS for the analysis of OFDM for UTRAN enhancement | 526d | 2002-06-10 A | 2004-06-14 A | 100% | 2002-06-10 | 2004-06-14 | 526d | start no earlier than 2002-06-10 | R1 | 4208h | 4208h | RInImp-FSOFDM | Rel-6 | Patrick | Nortel | Sarah Boumendil | 25.892 |  |  |
| 1272 | 421.5 | FS on Uplink Enhancements for Dedicated Transport Channels | 396d | 2002-09-06 A | 2004-03-12 A | 100% | 2002-09-06 | 2004-03-12 | 396d | finish no earlier than 2004-03-12 | R1 | 3168h | 3168h | RInImp-FSUpDTrCh | Rel-6 | Patrick | Nokia | Karri.Ranta-aho@nsn.com | 25.896 |  |  |
| 1273 | 421.6 | FS on Analysis on Higher Chip Rates for UTRA TDD evolutions | 528d | 2002-09-06 A | 2004-09-14 A | 100% | 2002-09-06 | 2004-09-14 | 528d | finish no earlier than 2004-09-14 | R1 | 4224h | 4224h | RInImp-FSVHCRTDD | Rel-6 | Patrick | IPWireless | mbeale@ipwireless.com | 25.895 |  |  |
| 1274 | 421.7 | FS on Low Output Powers for general purpose FDD BSs | 128d | 2003-06-13 A | 2004-03-12 A | 100% | 2003-06-13 | 2004-03-12 | 128d | finish no earlier than 2004-03-12 | R3 | 1024h | 1024h | RInImp-FSLoPw | Rel-6 | Juha | Telefonica | Ana Burgos (burgos_a@tsm.es) | 25.807 |  |  |
| 1275 | 421.8 | FS on Uplink enhancements for UTRA TDD | 462d | 2003-06-06 A | 2005-03-14 A | 100% | 2003-06-06 | 2005-03-14 | 462d | finish no earlier than 2005-03-14 | R1 | 3696h | 3696h | RInImp-FSUpEnhTDD | Rel-6 | Patrick | Interdigital | Marian.Rudolf@InterDigital.com | 25.804 |  |  |
| 1276 | 8.8 | FS on UE antenna efficiency test methods performance requirements (2) | 131d | 2002-03-08 A | 2002-09-06 A | 100% | 2002-03-08 | 2002-09-06 | 131d | finish no earlier than 2002-09-06 | R4 | 1048h | 1048h | RInImp-UEAnTM2 | Rel-6 | Issam | Allgon | Alf Ahlström |  |  |  |
| 1277 | 9.4 | Deleted - FS on the evolution of the UTRAN architecture | 592d | 2002-09-09 A | 2004-12-14 A | 100% | 2002-09-09 | 2004-12-14 | 592d | finish no earlier than 2004-12-15 | R3 | 4736h | 4736h | RANimp-FSEvo | Rel-6 | Juha | Nokia | woonhee.hwang@nsn.com, Antti.Toskala@nokia.com |  |  | RP-26 |
| 1278 | 422 | **FDD Enhanced Uplink** | 393d | 2004-03-15 A | 2005-09-14 A | 100% | 2004-03-15 | 2005-09-14 | 393d |  | RP | 14128h | 14128h | EDCH | Rel-6 |  | Ericsson | Joakim Bergström |  |  |  |
| 1279 | 422.1 | FDD Enhanced Uplink - Stage 2 | 197d | 2004-03-15 A | 2004-12-14 A | 100% | 2004-03-15 | 2004-12-14 | 197d | finish no earlier than 2004-12-14 | R2 | 1576h | 1576h | EDCH-Stage2 | Rel-6 | Joern |  |  | 25.309 |  |  |
| 1280 | 422.2 | FDD Enhanced Uplink - Physical Layer | 261d | 2004-03-15 A | 2005-03-14 A | 100% | 2004-03-15 | 2005-03-14 | 261d | finish no earlier than 2005-03-14 | R1 | 2088h | 2088h | EDCH-Phys | Rel-6 | Patrick | Nokia | Karri.Ranta-aho@nsn.com | 25.211, 25.212, 25.213, 25.214, 25.215 |  |  |
| 1281 | 422.3 | FDD Enhanced Uplink - Layer 2 and 3 Protocol Aspects | 261d | 2004-03-15 A | 2005-03-14 A | 100% | 2004-03-15 | 2005-03-14 | 261d | finish no earlier than 2005-03-14 | R2 | 2088h | 2088h | EDCH-L23 | Rel-6 | Joern | Ericsson | Joakim Bergström | 25.301, 25.302, 25.306, 25.321, 25.331 |  |  |
| 1282 | 422.4 | FDD Enhanced Uplink - UTRAN Iub/Iur Protocol Aspects | 261d | 2004-03-15 A | 2005-03-14 A | 100% | 2004-03-15 | 2005-03-14 | 261d | finish no earlier than 2005-03-14 | R3 | 2088h | 2088h | EDCH-IurIub | Rel-6 | Juha | Nortel | Saso Stojanovski | 25.401, 25.420, 25.423, 25.430, 25.433 |  |  |
| 1283 | 422.5 | FDD Enhanced Uplink - RF Radio Transmission/ Reception, System Performance Requirements and Conformance Testing | 393d | 2004-03-15 A | 2005-09-14 A | 100% | 2004-03-15 | 2005-09-14 | 393d | finish no earlier than 2005-09-15 | R4 | 3144h | 3144h | EDCH-RF | Rel-6 | Issam | Ericsson | thomas.unshelm@ERICSSON.COM | 25.101, 25.104, 25.133, 25.141 |  |  |

Notes:
- 1256: This is a generic feature without particular end date
- 1257: -
- 1258: -
- 1259: -
- 1260: -
- 1261: Introduction of UMTS850 (Band V) in 25.307
- 1262: Introduction of UMTS800 in 25.307
- 1263: Introduction of UMTS1700/2100 (Band IV)
- 1264: -
- 1265: Approved at RP#25 as RP-040375
- 1266: -
- 1267: -
- 1268: -
- 1269: Study finished at RP#25
- 1270: -
- 1271: -
- 1272: -
- 1273: Study finished at RP#25
- 1274: -
- 1275: -
- 1276: The RInImp-UEAnTM FS was re-opened at TSG RP#15 upon request from WG4
- 1277: Study Closed, work will continue within the FS on evolved UTRA and UTRAN
- 1278: -
- 1279: -
- 1280: -
- 1281: -
- 1282: -
- 1283: -

| ID | WBS | Task | Type | Duration | Start | Finish | Complete | Baseline start | Baseline finish | Baseline duration | Constraint | Resources | Work | Actual work | Text1 | Text6 | Text3 | Text4 | Text5 | Text8 | Text12 | Text10 |
| --- | --- | --- | --- | --- | --- | --- | --- | --- | --- | --- | --- | --- | --- | --- | --- | --- | --- | --- | --- | --- | --- | --- |
| 1284 | 423 | **Rel-6 RAN improvements** |  | 656d? | 2002-09-09 A | 2005-03-14 A | 100% | 2002-09-09 | 2005-03-14 | 656d? |  | RP | 28312h | 28312h | RANimp | Rel-6 |  |  |  |  |  |  |
| 1285 | 9.2 | **RAB support enhancement** |  | 522d? | 2003-03-14 A | 2005-03-14 A | 100% | 2003-03-14 | 2005-03-14 | 522d? |  | R2 | 9360h | 9360h | RANimp-RABSE | Rel-6 | 25.862 | Nokia | Jussi Kähtävä (juha.mikola@nokia.com) | Joern |  |  |
| 1286 | 423.1.1 | Optimization of downlink channelisation code utilisation |  | 262d | 2004-03-12 A | 2005-03-14 A | 100% | 2004-03-12 | 2005-03-14 | 262d | finish no earlier than 2005-03-14 | R1 | 2096h | 2096h | RANimp-RABSE-CodeOptFDD | Rel-6 |  | Nortel | Sarah Boumendil | Patrick |  |  |
| 1287 | 423.1.2 | optimization of channelisation code utilisation for 3.84 Mcps TDD |  | 261d | 2004-03-15 A | 2005-03-14 A | 100% | 2004-03-15 | 2005-03-14 | 261d | finish no earlier than 2005-03-15 | R1 | 2088h | 2088h | RANimp-RABSE-CodOptTDD | Rel-6 |  | IPWireless | Nicholas Anderson | Patrick |  |  |
| 1288 | 423.1.3 | HS-DPCCH ACK/NACK Enhancement |  | 65d? | 2004-09-15 A | 2004-12-14 A | 100% | 2004-09-15 | 2004-12-14 | 65d? | finish no earlier than 2004-12-15 | R1 | 520h | 520h | RANimp-RABSE-ACKNACK | Rel-6 | 25.212, 25.214, 24.331, 25.433 | Nokia | Jussi Kähtävä (juha.mikola@nokia.com) | Patrick |  |  |
| 1289 | 423.1.4 | Deleted - Iu enhancements for IMS support in RAN |  | 320d? | 2003-03-14 A | 2004-06-03 A | 100% | 2003-03-14 | 2004-06-03 | 320d? | start no earlier than 2003-03-14 | R3 | 2560h | 2560h | RANimp-RABSE-IuEnhIMS | Rel-6 |  | Nortel | Philippe.Godin@nortelnetworks.com | Juha | RP-24 |  |
| 1290 | 423.1.5 | Deleted - Improvement of RRM across RNS and RNS/BSS | milestone | 0d? | 2003-12-05 A | 2003-12-05 A | 100% | 2003-12-05 | 2003-12-05 | 0d? | finish no earlier than 2003-12-05 | R3 |  |  | RANimp-RRM1 | Rel-6 |  | Nokia | antti.toskala@nokia.com | Juha | RP-23 |  |
| 1291 | 9.1 | Beamforming Enhancements |  | 66d | 2003-09-19 A | 2003-12-19 A | 100% | 2003-09-19 | 2003-12-19 | 66d | finish no earlier than 2004-03-12 | R1 | 528h | 528h | RANimp-BFE | Rel-6 | 24.215, 25.423, 25.425, 25.433, 25.435 | Nokia | Jussi Kähtävä (juha.mikola@nokia.com) | Patrick |  |  |
| 1292 | 423.3 | **Rel6 RRM optimization for Iur and Iub** |  | 126d | 2003-09-19 A | 2004-03-12 A | 100% | 2003-09-19 | 2004-03-12 | 126d |  | R3 | 2016h | 2016h | RANimp-RRMopt | Rel-6 |  | Ericsson | Gert-Jan.van.Lieshout@eln.ericsson.se | Juha |  |  |
| 1293 | 423.3.1 | Improved access to UE measurement data for CRNC to support TDD RRM |  | 126d | 2003-09-19 A | 2004-03-12 A | 100% | 2003-09-19 | 2004-03-12 | 126d | finish no earlier than 2004-03-15 | R3 | 1008h | 1008h | RANimp-RRMopt-UEMsD | Rel-6 | 25.423 | Interdigital | jim.miller@interdigital.com | Juha | RP-22 |  |
| 1294 | 423.4 | **Remote Control of Electrical Tilting Antennas** |  | 395d? | 2003-03-14 A | 2004-09-16 A | 100% | 2003-03-14 | 2004-09-16 | 395d? |  | R3 | 7464h | 7464h | RANimp-TiltAnt | Rel-6 |  | Vodafone | Andreas.Hauser@vodafone.com | Juha |  |  |
| 1295 | 423.4.1 | Tilting Antenna - RAN aspects |  | 393d? | 2003-03-14 A | 2004-09-14 A | 100% | 2003-03-14 | 2004-09-14 | 393d? | finish no earlier than 2004-09-14 | R3 | 3144h | 3144h | RANimp-TiltAnt | Rel-6 | 25.460, 25.461, 25.462, 25.463 | Vodafone | Andreas.Hauser@vodafone.com | Juha |  |  |
| 1296 | 423.4.2 | OAM&P impacts |  | 145d | 2004-02-27 A | 2004-09-16 A | 100% | 2004-02-27 | 2004-09-16 | 145d | finish no earlier than 2004-09-16 | S5 | 1160h | 1160h | RANimp-TiltAnt-OAM | Rel-6 | 32.804, 32.64x | Vodafone | Adrian.Neal@vodafone.com | Dionisio |  | SP-24 |
| 1297 | 423.5 | Network Assisted Cell Change (NACC) from UTRAN to GERAN - network-side aspects |  | 462d? | 2002-09-09 A | 2004-06-15 A | 100% | 2002-09-09 | 2004-06-15 | 462d? | finish no earlier than 2004-06-15 | R3 | 3696h | 3696h | RANimp-NACC | Rel-6 |  | Vodafone | Brendan.McWilliams@gb.vodafone.co.uk | Juha |  |  |
| 1298 | 12 | **Location Services enhancements 2** |  | 1024d? | 2001-01-15 A | 2004-12-16 A | 100% | 2001-01-15 | 2004-12-16 | 1024d? |  | S2,S5,N4,RP | 78152h | 78152h | LCS2 | Rel-6 | 23.271 |  |  | Maurice |  |  |
| 1299 | 12.1 | **Improvement on Le interface** |  | 653d? | 2002-06-17 A | 2004-12-15 A | 100% | 2002-06-17 | 2004-12-15 | 653d? |  | S2 | 9872h | 9872h | LCS2 | Rel-6 |  |  |  | Maurice |  |  |
| 1300 | 424.1.1 | Stage 2 |  | 331d? | 2002-06-17 A | 2003-09-22 A | 100% | 2002-06-17 | 2003-09-22 | 331d? | start no earlier than 2002-06-17 | S2 | 2648h | 2648h | LCS2 | Rel-6 |  |  |  | Maurice |  |  |
| 1301 | 424.1.2 | Stage 3 - impacts MLP (Mobile Location Protocol) |  | 250d? | 2004-01-01 A | 2004-12-15 A | 100% | 2004-01-01 | 2004-12-15 | 250d? | finish no earlier than 2004-12-15 | OMA | 2000h | 2000h | LCS2 | Rel-6 |  |  | OMA-LIAISON@mail.openmobilealliance.org |  |  |  |
| 1302 | 12.2 | **Enhanced support for anonymity and user privacy** |  | 638d? | 2002-07-08 A | 2004-12-15 A | 100% | 2002-07-08 | 2004-12-15 | 638d? |  | S2 | 9144h | 9144h | LCS2 | Rel-6 |  |  |  | Maurice |  |  |
| 1303 | 424.2.1 | Stage 2 |  | 255d? | 2002-07-08 A | 2003-06-27 A | 100% | 2002-07-08 | 2003-06-27 | 255d? | finish no earlier than 2003-06-27 | S2 | 2040h | 2040h | LCS2 | Rel-6 |  |  |  | Maurice |  |  |
| 1304 | 424.2.2 | Stage 3 - impacts MLP and RLP |  | 250d? | 2004-01-01 A | 2004-12-15 A | 100% | 2004-01-01 | 2004-12-15 | 250d? | finish no earlier than 2004-12-15 | OMA | 2000h | 2000h | LCS2 | Rel-6 |  |  | OMA-LIAISON@mail.openmobilealliance.org |  |  |  |
| 1305 | 12.3 | **Enhanced inter-GMLC interface** |  | 648d? | 2002-06-24 A | 2004-12-15 A | 100% | 2002-06-24 | 2004-12-15 | 648d? |  | S2 | 9704h | 9704h | LCS2 | Rel-6 |  |  |  | Maurice |  |  |
| 1306 | 424.3.1 | Stage 2 |  | 315d? | 2002-06-24 A | 2003-09-05 A | 100% | 2002-06-24 | 2003-09-05 | 315d? | finish no earlier than 2003-09-05 | S2 | 2520h | 2520h | LCS2 | Rel-6 |  |  |  | Maurice |  |  |
| 1307 | 424.3.2 | Stage 3 - definition of RLP and PCP |  | 250d? | 2004-01-01 A | 2004-12-15 A | 100% | 2004-01-01 | 2004-12-15 | 250d? | finish no earlier than 2004-12-15 | OMA | 2000h | 2000h | LCS2 | Rel-6 |  |  | OMA-LIAISON@mail.openmobilealliance.org |  |  |  |

Notes:
- 1284: Generic feature
- 1285: building block without particular end date
- 1286: -
- 1287: WIDS modified in RP#26, RP-040551
- 1288: Approved at RP#25 as RP-040390
- 1289: Closed RP#24 due to the lack of progress
- 1290: abandoned RP-23
- 1291: -
- 1292: -
- 1293: -
- 1294: -
- 1295: Finished at RP#25
- 1296: SP#25 09/2004 completed
- 1297: -
- 1298: -
- 1299: -
- 1300: -
- 1301: Updated according to SP-040232
- 1302: -
- 1303: -
- 1304: Updated according to SP-040232
- 1305: -
- 1306: -
- 1307: Updated according to SP-040232

| ID | WBS | Task | Type | Duration | Start | Finish | Complete | Baseline start | Baseline finish | Baseline duration | Constraint | Resources | Work | Actual work | Text1 | Text6 | Text8 | Text5 | Text4 | Text12 |
| --- | --- | --- | --- | --- | --- | --- | --- | --- | --- | --- | --- | --- | --- | --- | --- | --- | --- | --- | --- | --- |
| 1308 | 12.4 | **Location Services support for IMS public identities** |  | 473d? | 2003-02-24 A | 2004-12-15 A | 100% | 2003-02-24 | 2004-12-15 | 473d? |  | S2 | 7704h | 7704h | LCS2 | Rel-6 | Maurice |  |  |  |
| 1309 | 424.4.1 | Stage 2 |  | 240d? | 2003-02-24 A | 2004-01-23 A | 100% | 2003-02-24 | 2004-01-23 | 240d? | finish no earlier than 2004-01-23 | S2 | 1920h | 1920h | LCS2 | Rel-6 | Maurice |  |  |  |
| 1310 | 424.4.2 | Stage 3 - impacts MLP, RLP and PCP |  | 250d? | 2004-01-01 A | 2004-12-15 A | 100% | 2004-01-01 | 2004-12-15 | 250d? | finish no earlier than 2004-12-15 | OMA | 2000h | 2000h | LCS2 | Rel-6 |  | OMA-LIAISON@mail.openmobilealliance.org |  |  |
| 1311 | 12.5 | **New area event for location service triggering reports** |  | 663d? | 2002-06-03 A | 2004-12-15 A | 100% | 2002-06-03 | 2004-12-15 | 663d? |  | S2 | 11416h | 11416h | LCS2 | Rel-6 | Maurice |  |  |  |
| 1312 | 424.5.1 | Stage 2 |  | 280d? | 2002-06-03 A | 2003-06-27 A | 100% | 2002-06-03 | 2003-06-27 | 280d? | finish no earlier than 2003-06-27 | S2 | 2240h | 2240h | LCS2 | Rel-6 | Maurice |  |  |  |
| 1313 | 424.5.2 | Stage 3 for UE-CN signalling |  | 234d? | 2003-10-09 A | 2004-08-31 A | 100% | 2003-10-09 | 2004-08-31 | 234d? | start no earlier than 2003-10-09 | N4 | 1872h | 1872h | LCS2 | Rel-6 | Kimmo |  |  |  |
| 1314 | 424.5.3 | Stage 3 - impacts MLP, RLP and PCP |  | 250d? | 2004-01-01 A | 2004-12-15 A | 100% | 2004-01-01 | 2004-12-15 | 250d? | finish no earlier than 2004-12-15 | OMA | 2000h | 2000h | LCS2 | Rel-6 |  | OMA-LIAISON@mail.openmobilealliance.org |  |  |
| 1315 | 12.7 | **UE positioning** |  | 957d? | 2001-01-15 A | 2004-09-14 A | 100% | 2001-01-15 | 2004-09-14 | 957d? |  | RP | 18480h | 18480h | LCS2-UEpos | Rel-6 | Issam |  |  |  |
| 1316 | 12.8 | Open SMLC-SRNC Interface within the UTRAN to support UTRAN Rel4 positioning methods |  | 700d? | 2001-01-15 A | 2003-09-19 A | 100% | 2001-01-15 | 2003-09-19 | 700d? | finish no earlier than 2003-09-19 | R2 | 5600h | 5600h | LCS-Rel4Pos | Rel-6 | Joern | Meik.Kottkamp@siemens.com | Siemens |  |
| 1317 | 424.6.2 | A-GPS minimum performance specification |  | 333d? | 2003-06-06 A | 2004-09-14 A | 100% | 2003-06-06 | 2004-09-14 | 333d? | finish no earlier than 2004-09-14 | R4 | 2664h | 2664h | LCS-UEPos-AGPSPerf | Rel-6 | Issam | donglin.shen@attws.com | AT&T Wireless |  |
| 1318 | 12.7.2 | FS on Enhancements to OTDOA Positioning using advanced blanking methods |  | 320d | 2002-07-01 A | 2003-09-19 A | 100% | 2002-07-01 | 2003-09-19 | 320d | finish no earlier than 2003-09-19 | R2 | 2560h | 2560h | LCS2-UEpos-FSBlank | Rel-6 | Joern | david.bartlett@cursor-system.com | Cambridge Positioning Systems |  |
| 1319 | 424.6.4 | Deleted - UE positioning enhancements - other methods | milestone | 0d? | 2003-09-26 A | 2003-09-26 A | 100% | 2003-09-26 | 2003-09-26 | 0d? | finish no earlier than 2003-09-26 | R2 |  |  | LCS2-UEpos-enh | Rel-6 | Joern | Meik.Kottkamp@siemens.com | Siemens | RP-24 |
| 1320 | 424.7 | LCS charging |  | 455d? | 2003-03-21 A | 2004-12-16 A | 100% | 2003-03-21 | 2004-12-16 | 455d? | start no earlier than 2003-03-21 | S5 | 3640h | 3640h | LCS2-CH | Rel-6 | Dionisio | alain.bibas@orange-ft.com | France Telecom |  |
| 1321 | 14 | **Rel-6 Security enhancements** |  | 1018d? | 2001-01-03 A | 2004-11-26 A | 100% | 2001-01-03 | 2004-11-26 | 1018d? |  | S3 | 28824h | 28824h | SEC1 | Rel-6 | Dionisio | Peter.Howard@vodafone.com | Vodafone |  |
| 1322 | 14.1 | **Enhanced HE control of security (including positive authentication reporting)** |  | 712d | 2001-01-03 A | 2003-09-25 A | 100% | 2001-01-03 | 2003-09-25 | 712d |  | S3 | 14064h | 14064h | SEC1 | Rel-6 | Dionisio | Peter.Howard@vodafone.com | Vodafone |  |
| 1323 | 14.1.1 | Deleted - SEC1 Stage 2 (Enhanced HE control of security) |  | 378d | 2001-01-03 A | 2002-06-14 A | 100% | 2001-01-03 | 2002-06-14 | 378d | finish no earlier than 2002-06-14 | S3 | 3024h | 3024h | SEC1 | Rel-6 | Dionisio |  |  | SP-16 |
| 1324 | 14.1.3 | **Network domain security** |  | 334d | 2002-06-17 A | 2003-09-25 A | 100% | 2002-06-17 | 2003-09-25 | 334d |  | S3 | 5344h | 5344h | SEC1-NDS | Rel-6 | Dionisio | Geir-myrdahl.koien@telenor.com | Telenor |  |
| 1325 | 14.1.3.1 | IP network layer security (NDS/IP) |  | 334d | 2002-06-17 A | 2003-09-25 A | 100% | 2002-06-17 | 2003-09-25 | 334d | finish no earlier than 2003-09-25 | S3 | 2672h | 2672h | SEC1-NDS-IP | Rel-6 | Dionisio |  |  |  |
| 1326 | 425.2 | Network Domain Security; Authentication Framework (NDS/AF) |  | 521d? | 2002-02-15 A | 2004-02-13 A | 100% | 2002-02-15 | 2004-02-13 | 521d? | finish no earlier than 2004-02-13 | S3 | 4168h | 4168h | SEC1-NDS-AF | Rel-6 | Dionisio | tommi.viitanen@nokia.com | Nokia |  |
| 1327 | 425.3 | Key Management of group keys for Voice Group Call Services |  | 306d | 2003-09-26 A | 2004-11-26 A | 100% | 2003-09-26 | 2004-11-26 | 306d | finish no earlier than 2004-11-26 | S3 | 2448h | 2448h | SECGKYV | Rel-6 | Dionisio | benno.tietz@vodafone.com | Vodafone |  |
| 1328 | 16 | **IMS Phase 2** |  | 1395d? | 2000-08-28 A | 2005-12-30 A | 100% | 2000-08-28 | 2005-12-30 | 1395d? |  | S1,S2,S3,S5,NP | 130248h | 130248h | IMS2 | Rel-6 | Alain |  |  |  |
| 1329 | 426.1 | Enhancements to the Cx and Sh interfaces |  | 323d? | 2003-06-06 A | 2004-08-31 A | 100% | 2003-06-06 | 2004-08-31 | 323d? | finish no earlier than 2004-08-31 | N4 | 2584h | 2584h | IMS2-CCR | Rel-6 | Kimmo |  |  |  |
| 1330 | 16.12 | **IMS Group Management** |  | 715d? | 2002-03-14 A | 2004-12-08 A | 100% | 2002-03-14 | 2004-12-08 | 715d? |  | S1 | 12680h | 12680h | IMSGM | Rel-6 | Alain | juha.kalliokulju@nokia.com | Nokia |  |
| 1331 | 16.12.1 | Stage 1 - TS on IMS group management |  | 193d | 2002-03-14 A | 2002-12-09 A | 100% | 2002-03-14 | 2002-12-09 | 193d | finish no earlier than 2002-12-09 | S1 | 1544h | 1544h | IMSGM | Rel-6 | Alain | juha.kalliokulju@nokia.com | Nokia |  |
| 1332 | 426.2.2 | Stage 2 |  | 158d? | 2003-05-26 A | 2003-12-31 A | 100% | 2003-05-26 | 2003-12-31 | 158d? | finish no earlier than 2003-12-31 | S2 | 1264h | 1264h | IMSGM | Rel-6 | Maurice |  |  |  |
| 1333 | 426.2.3 | Stage 3 for IMS Group management (e.g. chat) |  | 519d? | 2002-12-13 A | 2004-12-08 A | 100% | 2002-12-13 | 2004-12-08 | 519d? | finish no earlier than 2004-12-08 | N1 | 4152h | 4152h | IMSGM | Rel-6 | Frederic | Keith Drage (drage@alcatel-lucent.com) | Lucent |  |

Notes:
- 1308: -
- 1309: -
- 1310: Updated according to SP-040232
- 1311: -
- 1312: -
- 1313: 31/10/2003 work has started. Current stage 3 fullfills the requirements of stage 2. ......
- 1314: Updated according to SP-040232
- 1315: -
- 1316: - / Text3: 25.305, 25.401, 25.450, 25.452, 25.453
- 1317: Finished at RP#25 / Text3: 25.171
- 1318: -
- 1319: building block without particular end date
- 1320: SP#26 12/2004 completed / Text3: 32.271
- 1321: Added BB UE authentication and rapporteur added.
- 1322: Added by SP-000575 without any dates. 18/10/00: Change of WI title, added hyperlink rapporteur new end date 03/01. New end date and correct Release to be decided S3#18
- 1323: New end date and correct Release to be decided S3#18. Marked as stopped 12/2008
- 1324: WID approved for Rel-6 at SP#17. Completed 2004-12
- 1325: Should be complete after SA3#27. Completed 2004-12 / Text3: 33.210
- 1326: WID approved SP#19. Work started after FS approved SP#18
- 1327: Approved TSG#21. Completed 2004-12 / Text3: 42.068, 43.068, 44.068, 42.069, 43.069, 44.069, 31.102, 24.008, 48.008, 42.009, 43.020
- 1328: Not yet available: verbally approved at SA15, actual WID to be provided at SA16 by Lucent / Text3: 23.228
- 1329: Shared public user identities need to be solved. If email approval CR is accepted. Work 100% done....
- 1330: -
- 1331: -
- 1332: -
- 1333: Depends on CN decision on CPCP in Rel-6. Complete, if unresolved IETF dependencies are dropped (-> LS to CN plenary)

| ID | WBS | Task | Type | Duration | Start | Finish | Complete | Baseline start | Baseline finish | Baseline duration | Constraint | Resources | Work | Actual work | Text6 | Text8 | Text4 | Text5 | Text1 | Text3 | Text12 |
| --- | --- | --- | --- | --- | --- | --- | --- | --- | --- | --- | --- | --- | --- | --- | --- | --- | --- | --- | --- | --- | --- |
| 1334 | 426.3 | **IMS Conferencing** |  | 548d? | 2002-11-04 A | 2004-12-08 A | 100% | 2002-11-04 | 2004-12-08 | 548d? |  | N1 | 10960h | 10960h | Rel-6 | Frederic |  |  |  |  |  |
| 1335 | 426.3.1 | Stage 2 |  | 303d? | 2002-11-04 A | 2003-12-31 A | 100% | 2002-11-04 | 2003-12-31 | 303d? | finish no earlier than 2003-12-31 | S2 | 2424h | 2424h | Rel-6 | Maurice |  |  |  |  |  |
| 1336 | 426.3.2 | Stage 3 |  | 519d? | 2002-12-13 A | 2004-12-08 A | 100% | 2002-12-13 | 2004-12-08 | 519d? | finish no earlier than 2004-12-08 | N1 | 4152h | 4152h | Rel-6 | Frederic | Lucent | Keith Drage (drage@alcatel-lucent.com) |  |  |  |
| 1337 | 16.11 | **IMS Messaging** |  | 992d? | 2002-03-14 A | 2005-12-30 A | 100% | 2002-03-14 | 2005-12-30 | 992d? |  | S1 | 23912h | 23912h | Rel-6 | Alain | Nokia | juha.kalliokulju@nokia.com | IMSM |  |  |
| 1338 | 16.11.1 | TR on support of messaging in the IMS |  | 193d | 2002-03-14 A | 2002-12-09 A | 100% | 2002-03-14 | 2002-12-09 | 193d | finish no earlier than 2002-12-09 | S1 | 1544h | 1544h | Rel-6 | Alain | Nokia | juha.kalliokulju@nokia.com | IMSM-TR |  |  |
| 1339 | 426.4.2 | Stage 1 22.340 |  | 23d? | 2002-11-11 A | 2002-12-11 A | 100% | 2002-11-11 | 2002-12-11 | 23d? | finish no earlier than 2002-12-11 | S1 | 184h | 184h | Rel-6 | Alain | Nokia | juha.kalliokulju@nokia.com | IMSM-TS | 22.340 |  |
| 1340 | 426.4.3 | CRs to 22.140 & 22.228 |  | 263d? | 2002-03-14 A | 2003-03-17 A | 100% | 2002-03-14 | 2003-03-17 | 263d? | finish no earlier than 2003-03-17 | S1 | 2104h | 2104h | Rel-6 | Alain | Nokia | juha.kalliokulju@nokia.com | IMSM-CR | 22.140,22.228 |  |
| 1341 | 16.11.3 | Stage 2 |  | 477d | 2002-11-04 A | 2004-08-31 A | 100% | 2002-11-04 | 2004-08-31 | 477d | finish no earlier than 2004-08-31 | S2 | 3816h | 3816h | Rel-6 | Maurice |  |  |  |  |  |
| 1342 | 426.4.5 | Stage 3 for IMS Messaging |  | 519d? | 2002-12-13 A | 2004-12-08 A | 100% | 2002-12-13 | 2004-12-08 | 519d? | finish no earlier than 2004-12-08 | N1 | 4152h | 4152h | Rel-6 | Frederic | Lucent | Keith Drage (drage@alcatel-lucent.com) |  |  |  |
| 1343 | 426.4.6 | SIP/SIMPLE Instant messaging |  | 522d? | 2004-01-01 A | 2005-12-30 A | 100% | 2004-01-01 | 2005-12-30 | 522d? | finish no earlier than 2005-06-30 | OMA | 4176h | 4176h | Rel-6 |  |  | OMA-LIAISON@mail.openmobilealliance.org |  |  |  |
| 1344 | 426.5 | **Additional SIP Capabilities support not covered by Rel-5** |  | 680d? | 2002-11-11 A | 2005-06-17 A | 100% | 2002-11-11 | 2005-06-17 | 680d? |  | N1 | 13392h | 13392h | Rel-6 | Frederic |  |  |  |  |  |
| 1345 | 426.5.1 | Stage 2 for add SIP cap (e.g. forking) |  | 335d? | 2002-11-11 A | 2004-02-20 A | 100% | 2002-11-11 | 2004-02-20 | 335d? | finish no earlier than 2004-02-20 | S2 | 2680h | 2680h | Rel-6 | Maurice |  |  |  |  |  |
| 1346 | 426.5.2 | Stage 3 for Additional SIP Capabilities |  | 454d? | 2002-12-13 A | 2004-09-08 A | 100% | 2002-12-13 | 2004-09-08 | 454d? | finish no earlier than 2004-09-08 | N1 | 3632h | 3632h | Rel-6 | Frederic | Lucent | Keith Drage (drage@alcatel-lucent.com) |  |  |  |
| 1347 | 426.5.3 | Procedured associated with IMS-ALG |  | 205d? | 2004-09-06 A | 2005-06-17 A | 100% | 2004-09-06 | 2005-06-17 | 205d? | start no earlier than 2004-09-06 | N1 | 1640h | 1640h | Rel-6 | Frederic |  |  |  |  |  |
| 1348 | 426.6 | Review additional SIP Capabilities against IMS |  | 454d? | 2002-12-13 A | 2004-09-08 A | 100% | 2002-12-13 | 2004-09-08 | 454d? | finish no earlier than 2004-09-08 | N1 | 3632h | 3632h | Rel-6 | Frederic | Lucent | Keith Drage (drage@alcatel-lucent.com) |  |  |  |
| 1349 | 16.5 | **Interworking between IMS and IP networks** |  | 1118d? | 2000-08-28 A | 2004-12-08 A | 100% | 2000-08-28 | 2004-12-08 | 1118d? |  | N3 | 31712h | 31712h | Rel-6 | Gwiho | BT | nigel.holland@bt.com | IMS-CCR-IWIP | 23.821, 29.061, 29.162 |  |
| 1350 | 16.5.1 | Interworking for 3GPP_SIP and IETF_SIP |  | 730d | 2000-08-28 A | 2003-06-13 A | 100% | 2000-08-28 | 2003-06-13 | 730d | finish no earlier than 2003-06-13 | N3 | 5840h | 5840h | Rel-6 | Gwiho | Siemens | Thomas.Belling@nsn.com |  | New 29.962 |  |
| 1351 | 16.5.2 | Interworking for IPv6 to IPv4 |  | 1118d | 2000-08-28 A | 2004-12-08 A | 100% | 2000-08-28 | 2004-12-08 | 1118d | finish no earlier than 2004-12-08 | N3 | 8944h | 8944h | Rel-6 | Gwiho |  |  |  | 29.163 |  |
| 1352 | 426.7.3 | Interworking for IPv6 to IPv4 (SIP / SDP aspects) |  | 87d? | 2004-05-11 A | 2004-09-08 A | 100% | 2004-05-11 | 2004-09-08 | 87d? | finish no earlier than 2004-09-08 | N1 | 696h | 696h | Rel-6 | Frederic |  |  |  |  |  |
| 1353 | 16.8.1 | stage 3 of interworking with non-IMS IP networks |  | 911d | 2001-03-14 A | 2004-09-08 A | 100% | 2001-03-14 | 2004-09-08 | 911d | finish no earlier than 2004-09-08 | N1 | 7288h | 7288h | Rel-6 | Frederic |  |  |  |  |  |
| 1354 | 16.6.1 | Interworking between IMS and CS networks |  | 929d? | 2000-08-28 A | 2004-03-18 A | 100% | 2000-08-28 | 2004-03-18 | 929d? | finish no earlier than 2004-03-18 | N3 | 7432h | 7432h | Rel-6 | Gwiho | Vodafone | Brendan.McWilliams@gb.vodafone.co.uk | IMS-CCR-IWCS | 29.163, 29.061, 24.228, and new CN4 specification |  |
| 1355 | 16.10 | Mn interface (IM-MGW to MGCF) enhancements (CN4 Part) |  | 418d | 2001-08-07 A | 2004-09-01 A | 100% | 2001-08-07 | 2004-09-01 | 418d | finish no earlier than 2004-09-01 | N4 | 3344h | 3344h | Rel-6 | Kimmo |  |  | IMS-CCR-Mn |  |  |
| 1356 | 426.10 | Study of subscriber and operators relationship in IMS and related ISIM requirements for Rel 6” |  | 20d? | 2002-11-15 A | 2002-12-12 A | 100% | 2002-11-15 | 2002-12-12 | 20d? | finish no earlier than 2002-12-12 | S1 | 160h | 160h | Rel-6 | Alain | Nokia | juha.kalliokulju@nokia.com |  |  |  |
| 1357 | 426.11 | Lawful Interception in the 3GPP Rel-6 architecture |  | 269d? | 2002-12-09 A | 2003-12-18 A | 100% | 2002-12-09 | 2003-12-18 | 269d? | finish no earlier than 2003-12-18 | S3 | 2152h | 2152h | Rel-6 | Dionisio | Reg TP | berthold.wilhelm@regtp.de | SEC1-LI | 33.106, 33.107, 33.108 |  |
| 1358 | 426.12 | IMS Subscription and access scenarios |  | 130d? | 2002-12-16 A | 2003-06-13 A | 100% | 2002-12-16 | 2003-06-13 | 130d? | start no earlier than 2002-12-16 | S1 | 1040h | 1040h | Rel-6 | Alain |  |  |  | 22.800 |  |
| 1359 | 426.13 | IMS charging |  | 455d? | 2003-03-21 A | 2004-12-16 A | 100% | 2003-03-21 | 2004-12-16 | 455d? | finish no earlier than 2004-12-16 | S5 | 3640h | 3640h | Rel-6 | Dionisio | Ericsson | Patrik TEPPO | IMS2-CH | 32.260 |  |
| 1360 | 426.14 | IMS Management objects |  | 306d? | 2004-09-03 A | 2005-11-04 A | 100% | 2004-09-03 | 2005-11-04 | 306d? | finish no earlier than 2005-03-04 | N1 | 2448h | 2448h | Rel-6 | Frederic |  |  |  | 24.167 |  |
| 1361 | 426.15 | Deleted - Stage 2 of IMS Phase 2 | milestone | 0d? | 2003-09-19 A | 2003-09-19 A | 100% | 2003-09-19 | 2003-09-19 | 0d? | finish no earlier than 2003-09-19 | S2 |  |  | Rel-6 | Maurice |  |  | IMS2 |  | SP-21 |

Notes:
- 1334: -
- 1335: -
- 1336: Depends on CN decision on IETF dependencies in Rel-6. Higher figure if CPCP is dropped (-> LS to CN plenary)
- 1337: -
- 1338: -
- 1339: -
- 1340: -
- 1341: -
- 1342: -
- 1343: Updated according to SP-040232
- 1344: -
- 1345: -
- 1346: -
- 1347: -
- 1348: -
- 1349: [DAB 14.02.02] - end date pushed back to March 2003
- 1350: [DAB - 20.08.03] - CN Part of TR Complete @ CN#20
- 1351: -
- 1352: -
- 1353: -
- 1354: [DAB - 25.05.04] - CN3 consider this work to be complete
- 1355: TISPAN issue is open
- 1356: -
- 1357: -
- 1358: -
- 1359: SP#26 12/2004 completed
- 1360: -
- 1361: -

| ID | WBS | Task | Type | Duration | Start | Finish | Complete | Baseline start | Baseline finish | Baseline duration | Constraint | Resources | Work | Actual work | Text1 | Text4 | Text5 | Text6 | Text8 | Text3 | Text10 | Text12 |
| --- | --- | --- | --- | --- | --- | --- | --- | --- | --- | --- | --- | --- | --- | --- | --- | --- | --- | --- | --- | --- | --- | --- |
| 1362 | 427 | **3GPP Enablers for services like Push to Talk over Cellular (PoC)** |  | 459d? | 2003-09-08 A | 2005-06-09 A | 100% | 2003-09-08 | 2005-06-09 | 459d? |  | S2,S4,S5 | 10696h | 10696h | PoC | Ericsson | Shabnam Sultana | Rel-6 | Maurice |  |  |  |
| 1363 | 427.1 | Feasibility Study |  | 322d? | 2003-09-08 A | 2004-11-30 A | 100% | 2003-09-08 | 2004-11-30 | 322d? | finish no earlier than 2004-11-30 | S2 | 2576h | 2576h | PoC | Ericsson | Shabnam Sultana | Rel-6 | Maurice | 23.979 | SP-24 |  |
| 1364 | 427.2 | Dependencies on OMA PoC |  | 303d? | 2004-01-01 A | 2005-02-28 A | 100% | 2004-01-01 | 2005-02-28 | 303d? | finish no earlier than 2004-12-30 | OMA | 2424h | 2424h | PoC |  | OMA-LIAISON@mail.openmobilealliance.org | Rel-6 |  |  | SP-24 |  |
| 1365 | 427.3 | Selection of one or more PoC codec(s) for PoC |  | 69d? | 2004-09-13 A | 2004-12-16 A | 100% | 2004-09-13 | 2004-12-16 | 69d? | start no earlier than 2004-09-13 | S4 | 552h | 552h | PoC |  |  | Rel-6 | Paolo | 26.235, 26.236 | SP-25 |  |
| 1366 | 427.4 | PoC charging |  | 184d? | 2004-09-27 A | 2005-06-09 A | 100% | 2004-09-27 | 2005-06-09 | 184d? | finish no earlier than 2005-06-09 | S5 | 1472h | 1472h | PoC-CH | Siemens | Gerald GÖRMER | Rel-6 | Dionisio | 32.272 |  |  |
| 1367 | 428 | Study on Interworking aspects and migration scenarios for IPv4 based IMS Implementations |  | 210d? | 2003-09-08 A | 2004-06-25 A | 100% | 2003-09-08 | 2004-06-25 | 210d? | finish no earlier than 2004-06-25 | S2 | 1680h | 1680h | IPv4IMS | Siemens | Alexander Milinski | Rel-6 | Maurice | 23.981 |  |  |
| 1368 | 16.3 | **Interoperability and Commonality between IMS using different "IP-connectivity Networks"** |  | 325d? | 2002-09-16 A | 2003-12-12 A | 100% | 2002-09-16 | 2003-12-12 | 325d? |  | S2 | 9176h | 9176h | IMSCOOP |  |  | Rel-6 | Maurice | 23.864 |  |  |
| 1369 | 16.3.1 | Stage 2 for Interoperability |  | 272d | 2002-09-16 A | 2003-09-30 A | 100% | 2002-09-16 | 2003-09-30 | 272d | finish no earlier than 2003-09-30 | S2 | 2176h | 2176h | IMSCOOP | Nokia | balazs.bertenyi@nsn.com | Rel-6 | Maurice | 23.864 |  |  |
| 1370 | 429.2 | Stage 2 for commonality |  | 265d? | 2002-09-16 A | 2003-09-19 A | 100% | 2002-09-16 | 2003-09-19 | 265d? | start no earlier than 2002-09-16 | S2 | 2120h | 2120h | IMSCOOP | Nokia | balazs.bertenyi@nsn.com | Rel-6 | Maurice | 23.864 |  |  |
| 1371 | 16.3.2 | Stage 3 |  | 305d | 2002-10-14 A | 2003-12-12 A | 100% | 2002-10-14 | 2003-12-12 | 305d | finish no earlier than 2003-12-12 | N1 | 2440h | 2440h | IMSCOOP | Lucent | Keith Drage (drage@alcatel-lucent.com) | Rel-6 | Frederic |  |  |  |
| 1372 | 17 | **Support of Push Services** |  | 823d | 2001-01-03 A | 2004-02-27 A | 100% | 2001-01-03 | 2004-02-27 | 823d |  | S1 | 11390.6h | 11390.6h | PUSH | NTT Comware | Yoshinori Kitada | Rel-6 | Alain | 23.976 |  |  |
| 1373 | 17.1 | Stage 1 |  | 378d | 2001-01-03 A | 2002-06-14 A | 100% | 2001-01-03 | 2002-06-14 | 378d | finish no earlier than 2002-06-14 | S1 | 3024h | 3024h | PUSH |  |  | Rel-6 | Alain |  |  |  |
| 1374 | 17.3 | TR 23.976 on Push Architecture |  | 340d | 2002-11-11 A | 2004-02-27 A | 100% | 2002-11-11 | 2004-02-27 | 340d | finish no earlier than 2004-02-27 | S2 | 2720h | 2720h | PUSH | RIM | Nick Alfano | Rel-6 | Maurice | 23.976 |  |  |
| 1375 | 18 | **Multimedia Messaging (MMS) enhancements** |  | 865d? | 2002-08-15 A | 2005-12-07 A | 100% | 2002-08-15 | 2005-12-07 | 865d? |  | T2,S1,S4,S5,OMA | 31936h | 31936h | MMS6 | Siemens | Josef.Laumen@SAL.SIEMENS.DE | Rel-6 | Kimmo |  |  |  |
| 1376 | 18.1 | **Definition of service requirements** |  | 286d? | 2002-11-15 A | 2003-12-19 A | 100% | 2002-11-15 | 2003-12-19 | 286d? |  | S1 | 4576h | 4576h | MMS6-SR |  |  | Rel-6 | Alain | 22.140 |  |  |
| 1377 | 431.1.1 | Definition of service requirements charging |  | 286d? | 2002-11-15 A | 2003-12-19 A | 100% | 2002-11-15 | 2003-12-19 | 286d? | finish no earlier than 2003-12-20 | S1 | 2288h | 2288h | MMS6-SR | Siemens | Josef.Laumen@SAL.SIEMENS.DE | Rel-6 | Alain | 22.140 |  |  |
| 1378 | 18.2 | Technical realization |  | 591d | 2002-09-06 A | 2004-12-10 A | 100% | 2002-09-06 | 2004-12-10 | 591d | finish no earlier than 2004-12-10 | T2 | 4728h | 4728h | MMS6 | Siemens | Josef.Laumen@SAL.SIEMENS.DE | Rel-6 | Kimmo | 23.140 |  |  |
| 1379 | 18.3 | OMA dependencies |  | 446d | 2003-08-15 A | 2005-04-29 A | 100% | 2003-08-15 | 2005-04-29 | 446d | finish no earlier than 2004-12-10 | OMA | 3568h | 3568h | MMS6 |  |  | Rel-6 | Kimmo | OMA specs |  |  |
| 1380 | 18.4 | MMS formats and codecs |  | 865d | 2002-08-15 A | 2005-12-07 A | 100% | 2002-08-15 | 2005-12-07 | 865d | finish no earlier than 2005-12-07 | S4 | 6920h | 6920h | MMS6-Codec | Nokia | roberto.castagno@nokia.com | Rel-6 | Paolo | 26.140, 26.936 |  |  |
| 1381 | 431.5 | Handling of private addressing schemes in MMS |  | 263d | 2003-12-10 A | 2004-12-10 A | 100% | 2003-12-10 | 2004-12-10 | 263d | finish no earlier than 2004-12-10 | T2 | 2104h | 2104h | MMS6 | T-Mobile | Steffen.Habermann@T-MOBILE.DE | Rel-6 | Kimmo | 23.140 |  |  |
| 1382 | 431.6 | MMS charging |  | 390d? | 2003-03-21 A | 2004-09-16 A | 100% | 2003-03-21 | 2004-09-16 | 390d? | start no earlier than 2003-03-21 | S5 | 3120h | 3120h | MMS6-CH |  |  | Rel-6 | Dionisio | 32.270 |  |  |
| 1383 | 431.7 | Deleted - FS Multiple MMS Relay/Server Architecture | milestone | 0d | 2004-12-10 A | 2004-12-10 A | 100% | 2004-12-10 | 2004-12-10 | 0d | finish no earlier than 2004-12-10 | T2 |  |  | MMS6 | Telefónica Móviles | Juan Gorospe (gorospe_j@tsm.es) | Rel-6 | Kimmo | probably Annex to 23.140 |  | TP-26 |
| 1384 | 19 | **Rel-6 MExE enhancements** |  | 326d | 2002-03-08 A | 2003-06-06 A | 100% | 2002-03-08 | 2003-06-06 | 326d |  | T2 | 7328h | 7328h | MEXE6 |  |  | Rel-6 | Kimmo |  |  |  |
| 1385 | 19.1 | MExE Rel-6 Improvements and Investigations |  | 264d | 2002-03-08 A | 2003-03-12 A | 100% | 2002-03-08 | 2003-03-12 | 264d | finish no earlier than 2003-03-12 | T2 | 2112h | 2112h | MEXE6-ENHANC | TTPCom | Lars Brenk ( (lsb_ttpcom@HOTMAIL.COM) | Rel-6 |  |  |  |  |
| 1386 | 19.2 | MExE Run-Time Independent Framework Feasibility Study |  | 326d | 2002-03-08 A | 2003-06-06 A | 100% | 2002-03-08 | 2003-06-06 | 326d | finish no earlier than 2003-06-06 | T2 | 2608h | 2608h | MEXE6-RTIF | Intel | Aaron.Cohen@intel.com | Rel-6 |  | 22.857 |  |  |
| 1387 | 21 | Subscription Management |  | 650d | 2002-09-20 A | 2005-03-17 A | 100% | 2002-09-20 | 2005-03-17 | 650d | finish no earlier than 2005-03-17 | S5 | 5200h | 5200h | SuM | T-Mobile | istvan.aba@t-mobile.at | Rel-6 | Dionisio | 32.140/1, 32.171/2/5, 32.803 |  |  |

Notes:
- 1362: -
- 1363: -
- 1364: Updated according to SP-040232
- 1365: Completed
- 1366: SP#28 06/2005 completed
- 1367: -
- 1368: -
- 1369: No contributions assumed that no more will be done in 3GPP hence work may need to be done in 3GPP2
- 1370: -
- 1371: -
- 1372: Changed from FS to actual support of Push
- 1373: -
- 1374: -
- 1375: -
- 1376: -
- 1377: -
- 1378: -
- 1379: -
- 1380: -
- 1381: -
- 1382: SP#25 09/2004 completed
- 1383: originally it was intended to create a FS TR but most likely the work will become an Annex of 23.140
- 1384: -
- 1385: -
- 1386: -
- 1387: SP#27 03/2005 completed

| ID | WBS | Task | Duration | Start | Finish | Complete | Baseline start | Baseline finish | Baseline duration | Constraint | Resources | Work | Actual work | Text1 | Text4 | Text5 | Text6 | Text8 | Text3 |
| --- | --- | --- | --- | --- | --- | --- | --- | --- | --- | --- | --- | --- | --- | --- | --- | --- | --- | --- | --- |
| 1388 | 22 | **Presence Capability** | 1233d? | 2001-03-19 A | 2005-12-07 A | 100% | 2001-03-19 | 2005-12-07 | 1233d? |  | S1 | 37112h | 37112h | PRESNC | Motorola | Mark Cataldo | Rel-6 | Alain |  |
| 1389 | 22.1 | Stage 1 | 610d | 2001-03-19 A | 2003-07-18 A | 100% | 2001-03-19 | 2003-07-18 | 610d | finish no earlier than 2003-07-18 | S1 | 4880h | 4880h | PRESNC |  |  | Rel-6 | Alain | 22.141 |
| 1390 | 22.2 | Stage 2 | 268d | 2001-09-12 A | 2002-09-20 A | 100% | 2001-09-12 | 2002-09-20 | 268d | finish no earlier than 2002-09-20 | S2 | 2144h | 2144h | PRESNC | Nokia | balazs.bertenyi@nsn.com | Rel-6 | Maurice |  |
| 1391 | 22.3 | Stage 3 | 703d | 2002-04-01 A | 2004-12-08 A | 100% | 2002-04-01 | 2004-12-08 | 703d | finish no earlier than 2004-12-08 | N1 | 5624h | 5624h | PRESNC | Lucent | Keith Drage (drage@alcatel-lucent.com) | Rel-6 | Frederic |  |
| 1392 | 434.4 | Stage 3 (CN3 Part Pk interface) | 770d? | 2002-04-01 A | 2005-03-11 A | 100% | 2002-04-01 | 2005-03-11 | 770d? | finish no earlier than 2005-03-11 | N3 | 6160h | 6160h | PRESNC |  |  | Rel-6 | Gwiho |  |
| 1393 | 434.5 | Media Codecs and Formats for IMS Messaging and Presence | 650d? | 2003-06-12 A | 2005-12-07 A | 100% | 2003-06-12 | 2005-12-07 | 650d? | finish no earlier than 2005-12-07 | S4 | 5200h | 5200h | PRESNC-COFIMP | Nokia | harri.honko@nokia.com | Rel-6 | Paolo | 26.141, 26.936 |
| 1394 | 22.4 | Security issues | 79d | 2002-08-26 A | 2002-12-12 A | 100% | 2002-08-26 | 2002-12-12 | 79d | finish no earlier than 2002-12-12 | S3 | 632h | 632h | PRESNC |  |  | Rel-6 | Dionisio |  |
| 1395 | 434.7 | SIMPLE Presence | 326d? | 2004-01-01 A | 2005-03-31 A | 100% | 2004-01-01 | 2005-03-31 | 326d? | finish no earlier than 2004-12-30 | OMA | 2608h | 2608h | PRESNC |  | OMA-LIAISON@mail.openmobilealliance.org | Rel-6 |  |  |
| 1396 | 25 | **Enhanced A/Gb feasibility study** | 51d? | 2002-08-30 A | 2002-11-08 A | 100% | 2002-08-30 | 2002-11-08 | 51d? |  | GP | 3264h | 3264h | AGbEnFS | Vodafone | jose-luis.carrizo@vodafone.co.uk | Rel-6 | Paolo | None |
| 1397 | 25.1 | **Feasibility study on A/Gb enhancements** | 51d? | 2002-08-30 A | 2002-11-08 A | 100% | 2002-08-30 | 2002-11-08 | 51d? |  | G2 | 2856h | 2856h | AGbEnFS-FS | Vodafone | jose-luis.carrizo@vodafone.co.uk | Rel-6 | Gert | None |
| 1398 | 25.1.1 | Requirements for the support of conversational services | 51d | 2002-08-30 A | 2002-11-08 A | 100% | 2002-08-30 | 2002-11-08 | 51d | finish no earlier than 2002-11-08 | GP | 408h | 408h | AGbEnFS-FS |  |  | Rel-6 | Paolo | None |
| 1399 | 435.1.2 | Identification of the different building blocks for the provision of conversational services on the existing A/Gb protocol stack | 51d? | 2002-08-30 A | 2002-11-08 A | 100% | 2002-08-30 | 2002-11-08 | 51d? | finish no earlier than 2002-11-08 | GP | 408h | 408h | AGbEnFS-FS |  |  | Rel-6 | Paolo | None |
| 1400 | 435.1.3 | Outline of impact and feasibility of these building blocks and their different solutions | 51d? | 2002-08-30 A | 2002-11-08 A | 100% | 2002-08-30 | 2002-11-08 | 51d? | finish no earlier than 2002-11-08 | GP | 408h | 408h | AGbEnFS-FS |  |  | Rel-6 | Paolo | None |
| 1401 | 25.1.4 | Impact on 3GPP architecture and requirement to co-ordinatge with other TSGs (CN, SA) | 51d | 2002-08-30 A | 2002-11-08 A | 100% | 2002-08-30 | 2002-11-08 | 51d | finish no earlier than 2002-11-08 | GP | 408h | 408h | AGbEnFS-FS |  |  | Rel-6 | Paolo | None |
| 1402 | 25.1.5 | Standardisation effort | 51d | 2002-08-30 A | 2002-11-08 A | 100% | 2002-08-30 | 2002-11-08 | 51d | finish no earlier than 2002-11-08 | GP | 408h | 408h | AGbEnFS-FS |  |  | Rel-6 | Paolo | None |
| 1403 | 25.1.6 | Dependency to other features | 51d | 2002-08-30 A | 2002-11-08 A | 100% | 2002-08-30 | 2002-11-08 | 51d | finish no earlier than 2002-11-08 | GP | 408h | 408h | AGbEnFS-FS |  |  | Rel-6 | Paolo | None |
| 1404 | 26 | **Flexible Layer One for GERAN** | 1171d | 2000-01-03 A | 2004-06-25 A | 100% | 2000-01-03 | 2004-06-25 | 1171d |  | GP | 71551h | 71551h | FLOGER | Nokia | benoist.sebire@nokia.com | Rel-6 | Paolo |  |
| 1405 | 26.1 | **Realisation of a Flexible Layer One** | 1126d | 2000-01-03 A | 2004-04-23 A | 100% | 2000-01-03 | 2004-04-23 | 1126d |  | GP | 42816h | 42816h | FLOGER-Real | Nokia | benoist.sebire@nokia.com | Rel-6 | Paolo |  |
| 1406 | 26.1.1 | Technical Report | 471d | 2002-04-19 A | 2004-02-06 A | 100% | 2002-04-19 | 2004-02-06 | 471d | finish no earlier than 2004-02-06 | GP | 3768h | 3768h | FLOGER-Real |  |  | Rel-6 | Paolo |  |
| 1407 | 26.1.2 | Architecture in 45.001 and 43.051 | 526d | 2002-04-19 A | 2004-04-23 A | 100% | 2002-04-19 | 2004-04-23 | 526d | finish no earlier than 2004-04-23 | G1 | 4208h | 4208h | FLOGER-Real |  |  | Rel-6 |  |  |
| 1408 | 26.1.3 | Multiplexing in 45.002 | 526d | 2002-04-19 A | 2004-04-23 A | 100% | 2002-04-19 | 2004-04-23 | 526d | finish no earlier than 2004-04-23 | G1 | 4208h | 4208h | FLOGER-Real |  |  | Rel-6 |  |  |
| 1409 | 26.1.4 | Channel Coding in 45.003 | 526d | 2002-04-19 A | 2004-04-23 A | 100% | 2002-04-19 | 2004-04-23 | 526d | finish no earlier than 2004-04-23 | G1 | 4208h | 4208h | FLOGER-Real |  |  | Rel-6 |  |  |
| 1410 | 26.1.5 | Performance Requirements in 45.005 | 1126d | 2000-01-03 A | 2004-04-23 A | 100% | 2000-01-03 | 2004-04-23 | 1126d | finish no earlier than 2004-04-23 | G1 | 9000h | 9000h | FLOGER-Real |  |  | Rel-6 |  |  |
| 1411 | 26.1.6 | Radio subsystem link control in 45.008 | 526d | 2002-04-19 A | 2004-04-23 A | 100% | 2002-04-19 | 2004-04-23 | 526d | finish no earlier than 2004-04-23 | G1 | 4208h | 4208h | FLOGER-Real |  |  | Rel-6 |  |  |
| 1412 | 26.1.7 | Requirements in 44.004 | 526d | 2002-04-19 A | 2004-04-23 A | 100% | 2002-04-19 | 2004-04-23 | 526d | finish no earlier than 2004-04-23 | G2 | 4208h | 4208h | FLOGER-Real |  |  | Rel-6 | Gert |  |

Notes:
- 1388: merged "Presence Service Enhancements" (UID31028, PRES1) to this feature as no answer was provided on why Presence and Presence Encmts had same target completion date
- 1389: -
- 1390: -
- 1391: Dependency to 2 IETF drafts, no known work at the moment
- 1392: No Contributions so far - only requires a little work
- 1393: -
- 1394: LSs handled in SA3. WID approved SP#17 Contribution at S3#25 & following e-mail discussion. Marked as closed 12/2008 (was marked 90% complete)
- 1395: Updated according to SP-040232
- 1396: -
- 1397: -
- 1398: -
- 1399: -
- 1400: -
- 1401: -
- 1402: -
- 1403: -
- 1404: -
- 1405: -
- 1406: -
- 1407: -
- 1408: -
- 1409: -
- 1410: -
- 1411: -
- 1412: -

| ID | WBS | Task | Type | Duration | Start | Finish | Complete | Baseline start | Baseline finish | Baseline duration | Constraint | Resources | Work | Actual work | Text1 | Text4 | Text5 | Text6 | Text8 | Text12 | Text3 |
| --- | --- | --- | --- | --- | --- | --- | --- | --- | --- | --- | --- | --- | --- | --- | --- | --- | --- | --- | --- | --- | --- |
| 1413 | 26.2 | **Signalling and protocol support for a Flexible Layer One** |  | 571d | 2002-04-19 A | 2004-06-25 A | 100% | 2002-04-19 | 2004-06-25 | 571d |  | G2 | 13704h | 13704h | FLOGER-SigPro | Nokia | benoist.sebire@nokia.com | Rel-6 | Gert |  |  |
| 1414 | 26.2.1 | Modifications to RLC/MAC in 44.060 and 44.160 |  | 571d | 2002-04-19 A | 2004-06-25 A | 100% | 2002-04-19 | 2004-06-25 | 571d | finish no earlier than 2004-06-25 | G2 | 4568h | 4568h | FLOGER-SigPro |  |  | Rel-6 | Gert |  |  |
| 1415 | 26.2.2 | Modifications to RRC in 44.118 and 44.018 |  | 571d | 2002-04-19 A | 2004-06-25 A | 100% | 2002-04-19 | 2004-06-25 | 571d | finish no earlier than 2004-06-25 | G2 | 4568h | 4568h | FLOGER-SigPro |  |  | Rel-6 | Gert |  |  |
| 1416 | 26.3 | **Security for a Flexible Layer One** |  | 356d | 2002-04-19 A | 2003-08-29 A | 100% | 2002-04-19 | 2003-08-29 | 356d |  | S3, G2 | 5663.03h | 5663.03h | FLOGER-SecFLO | Nokia | benoist.sebire@nokia.com | Rel-6 | Dionisio |  |  |
| 1417 | 26.3.1 | Ciphering in 44.160,44.118, 44.060 and 44.018 |  | 356d | 2002-04-19 A | 2003-08-29 A | 100% | 2002-04-19 | 2003-08-29 | 356d | finish no earlier than 2003-08-29 | S3, G2 | 2848h | 2848h | FLOGER-SecFLO |  |  | Rel-6 | Dionisio |  |  |
| 1418 | 26.4 | **Deleted - GERAN MS Conformance test for the Flexible Layer One - DELETE** |  | 0d | 2004-02-06 A | 2004-02-06 A | 100% | 2004-02-06 | 2004-02-06 | 0d |  | G4,G5 |  |  | FLOGER-Msconf | Nokia | benoist.sebire@nokia.com | Rel-6 | Paolo | GP-27 |  |
| 1419 | 26.4.1 | Deleted at TSG #27 - MS Test in 51.010 | milestone | 0d | 2004-02-06 A | 2004-02-06 A | 100% | 2004-02-06 | 2004-02-06 | 0d | finish no earlier than 2004-02-06 | G4,G5 |  |  | FLOGER-Msconf |  |  | Rel-6 | Paolo | GP-22 |  |
| 1420 | 26.5 | **Deleted - GERAN BTS Conformance test for the Flexible Layer One - DELETE** |  | 0d | 2004-02-06 A | 2004-02-06 A | 100% | 2004-02-06 | 2004-02-06 | 0d |  | G3new |  |  | FLOGER-BTSconf | Nokia | benoist.sebire@nokia.com | Rel-6 | Ingbert | GP-27 |  |
| 1421 | 26.5.1 | Deleted at TGS #27 - BTS Test in 51.021 - DELETE | milestone | 0d | 2004-02-06 A | 2004-02-06 A | 100% | 2004-02-06 | 2004-02-06 | 0d | finish no earlier than 2004-02-06 | G3new |  |  | FLOGER-BTSconf |  |  | Rel-6 | Ingbert | GP-22 |  |
| 1422 | 27 | Uplink TDOA feasibility study |  | 151d | 2001-11-30 A | 2002-06-28 A | 100% | 2001-11-30 | 2002-06-28 | 151d | finish no earlier than 2002-06-28 | GP | 1208h | 1208h | TDOAF | TruePosition | Bob Gross (rlgross@trueposition.com) | Rel-6 | Paolo |  | 45.811 |
| 1423 | 28 | **Multimedia Broadcast and Multicast Service** |  | 1781d? | 2001-05-11 A | 2008-03-07 A | 100% | 2001-05-11 | 2008-03-07 | 1781d? |  | S1,S2,S4,S5,T1,RP,GP | 158712h | 158712h | MBMS |  |  | Rel-6 | Alain |  |  |
| 1424 | 28.1 | Stage 1 |  | 232d | 2001-05-11 A | 2002-04-01 A | 100% | 2001-05-11 | 2002-04-01 | 232d | finish no earlier than 2002-04-01 | S1 | 1856h | 1856h | MBMS |  |  | Rel-6 | Alain |  | 22.146, 22.101 |
| 1425 | 28.2 | **Stage 2** |  | 648d | 2001-09-24 A | 2004-03-17 A | 100% | 2001-09-24 | 2004-03-17 | 648d |  | S2 | 10408h | 10408h | MBMS |  |  | Rel-6 | Maurice |  |  |
| 1426 | 28.2.1 | TR on Architectural Study |  | 240d | 2001-09-24 A | 2002-08-23 A | 100% | 2001-09-24 | 2002-08-23 | 240d | finish no earlier than 2002-08-23 | S2 | 1920h | 1920h | MBMS |  |  | Rel-6 | Maurice |  | 23.846 |
| 1427 | 28.2.2 | Stage 2 Specification Work |  | 413d | 2002-08-19 A | 2004-03-17 A | 100% | 2002-08-19 | 2004-03-17 | 413d | finish no earlier than 2004-03-17 | S2 | 3304h | 3304h | MBMS |  |  | Rel-6 | Maurice |  | 23.246 |
| 1428 | 28.3 | **Introduction of MBMS in RAN** |  | 967d? | 2002-01-01 A | 2005-09-14 A | 100% | 2002-01-01 | 2005-09-14 | 967d? |  | R2 | 15992h | 15992h | MBMS-RAN | Nokia | juho.pirskanen@nokia.com | Rel-6 | Joern |  | 25.346, 25.304, 25.321, 25.322, 25.323, 25.331 |
| 1429 | 438.3.1 | Introduction of MBMS in RAN (physical & upper layers, access network interfaces) |  | 771d? | 2002-01-01 A | 2004-12-14 A | 100% | 2002-01-01 | 2004-12-14 | 771d? | finish no earlier than 2004-12-14 | R2 | 6168h | 6168h | MBMS-RAN | Nokia | juho.pirskanen@nokia.com | Rel-6 | Joern |  | 25.346, 25.304, 25.321, 25.322, 25.323 |
| 1430 | 438.3.2 | UE Performance Requirements for MBMS |  | 261d? | 2004-09-15 A | 2005-09-14 A | 100% | 2004-09-15 | 2005-09-14 | 261d? | finish no earlier than 2005-09-15 | R4 | 2088h | 2088h | MBMS-RAN-RF | Ericsson | Torgny.Palenius@ericsson.com | Rel-6 | Issam |  | 25.101, 25.133 |
| 1431 | 28.4 | Support of the MBMS in CN protocols |  | 647d | 2002-06-18 A | 2004-12-08 A | 100% | 2002-06-18 | 2004-12-08 | 647d | finish no earlier than 2004-12-08 | N1 | 5176h | 5176h | MBMS |  |  | Rel-6 | Frederic |  |  |
| 1432 | 438.5 | Gmb interface for MBMS (CN3 part) |  | 334d | 2003-08-29 A | 2004-12-08 A | 100% | 2003-08-29 | 2004-12-08 | 334d | finish no earlier than 2004-12-08 | N3 | 2672h | 2672h | MBMS |  |  | Rel-6 | Gwiho |  | 29.061 |
| 1433 | 28.5 | Security Aspects of MBMS |  | 710d | 2002-07-01 A | 2005-03-18 A | 100% | 2002-07-01 | 2005-03-18 | 710d | finish no earlier than 2005-03-18 | S3 | 5680h | 5680h | MBMS |  | adrian.escott@three.co.uk | Rel-6 | Dionisio |  |  |
| 1434 | 28.6 | **Support of MBMS in GERAN** |  | 892d? | 2001-08-30 A | 2005-01-28 A | 100% | 2001-08-30 | 2005-01-28 | 892d? |  | GP | 71040h | 71040h | MBMS-GERAN |  |  | Rel-6 | Paolo |  |  |
| 1435 | 28.6.1 | Impact on the logical and physical channels |  | 631d | 2002-08-30 A | 2005-01-28 A | 100% | 2002-08-30 | 2005-01-28 | 631d | finish no earlier than 2005-01-28 | GP | 5048h | 5048h | MBMS-GERAN |  |  | Rel-6 | Paolo |  |  |
| 1436 | 28.6.4 | Re-synchronisation at cell change |  | 631d | 2002-08-30 A | 2005-01-28 A | 100% | 2002-08-30 | 2005-01-28 | 631d | finish no earlier than 2005-01-28 | G2 | 5048h | 5048h | MBMS-GERAN |  |  | Rel-6 | Gert |  |  |
| 1437 | 438.7.3 | Simultaneous support of MBMS services |  | 631d? | 2002-08-30 A | 2005-01-28 A | 100% | 2002-08-30 | 2005-01-28 | 631d? | finish no earlier than 2005-01-28 | GP | 5048h | 5048h | MBMS-GERAN |  |  | Rel-6 | Paolo |  |  |
| 1438 | 438.7.4 | Simultaneous support of MBMS and non-MBMS services |  | 892d? | 2001-08-30 A | 2005-01-28 A | 100% | 2001-08-30 | 2005-01-28 | 892d? | finish no earlier than 2005-01-28 | GP | 7136h | 7136h | MBMS-GERAN |  |  | Rel-6 | Paolo |  |  |
| 1439 | 438.7.5 | Resynchronisation at cell change |  | 892d? | 2001-08-30 A | 2005-01-28 A | 100% | 2001-08-30 | 2005-01-28 | 892d? | finish no earlier than 2005-01-28 | GP | 7136h | 7136h | MBMS-GERAN |  |  | Rel-6 | Paolo |  |  |
| 1440 | 28.6.5 | Decision making process between point-to-point or pont-to-multipoint configurations |  | 631d | 2002-08-30 A | 2005-01-28 A | 100% | 2002-08-30 | 2005-01-28 | 631d | finish no earlier than 2005-01-28 | GP | 5048h | 5048h | MBMS-GERAN |  |  | Rel-6 | Paolo |  |  |
| 1441 | 28.6.6 | MBMS channel allocations procedures to multiple MSs |  | 631d | 2002-08-30 A | 2005-01-28 A | 100% | 2002-08-30 | 2005-01-28 | 631d | finish no earlier than 2005-01-28 | GP | 5048h | 5048h | MBMS-GERAN |  |  | Rel-6 | Paolo |  |  |
| 1442 | 28.6.7 | Changes to the Gb interface |  | 631d | 2002-08-30 A | 2005-01-28 A | 100% | 2002-08-30 | 2005-01-28 | 631d | finish no earlier than 2005-01-28 | GP | 5048h | 5048h | MBMS-GERAN |  |  | Rel-6 | Paolo |  |  |
| 1443 | 28.6.8 | GERAN specific changes to the Iu-ps interface |  | 631d | 2002-08-30 A | 2005-01-28 A | 100% | 2002-08-30 | 2005-01-28 | 631d | finish no earlier than 2005-01-28 | GP | 5048h | 5048h | MBMS-GERAN |  |  | Rel-6 | Paolo |  |  |
| 1444 | 28.6.9 | Interaction between MBMS and Iu-flex |  | 631d | 2002-08-30 A | 2005-01-28 A | 100% | 2002-08-30 | 2005-01-28 | 631d | finish no earlier than 2005-01-28 | GP | 5048h | 5048h | MBMS-GERAN |  |  | Rel-6 | Paolo |  |  |
| 1445 | 28.6.10 | Security aspects |  | 631d | 2002-08-30 A | 2005-01-28 A | 100% | 2002-08-30 | 2005-01-28 | 631d | finish no earlier than 2005-01-28 | GP | 5048h | 5048h | MBMS-GERAN |  |  | Rel-6 | Paolo |  |  |
| 1446 | 438.7.12 | MBMS-GERAN - MS conformance tests |  | 786d? | 2002-01-25 A | 2005-01-28 A | 100% | 2002-01-25 | 2005-01-28 | 786d? | finish no earlier than 2005-01-28 | G3new | 6288h | 6288h | MBMS-GERAN |  |  | Rel-6 | Ingbert |  |  |
| 1447 | 438.7.13 | Deleted - MS conformance tests - G5 | milestone | 0d? | 2003-06-27 A | 2003-06-27 A | 100% | 2003-06-27 | 2003-06-27 | 0d? | start no earlier than 2003-06-27 | G5 |  |  | MBMS-GERAN |  |  | Rel-6 | Paolo | GP-19 |  |

Notes:
- 1413: -
- 1414: -
- 1415: -
- 1416: -
- 1417: -
- 1418: -
- 1419: -
- 1420: -
- 1421: -
- 1422: -
- 1423: Title renamed at SP#13
- 1424: This may or may not be a separate stage 1. In the meantime, CRs are proposed for 22.101
- 1425: -
- 1426: -
- 1427: -
- 1428: -
- 1429: Was "Introduction of MBMS in RAN" before RP#25. Created w/o WIDS after RAN approved the WT for RF aspects.Take WIDS from the parent BB
- 1430: Approved at RP#25 as RP-040370
- 1431: -
- 1432: -
- 1433: WID approved SP#17. 2004-12: Expected completion March 2005
- 1434: -
- 1435: -
- 1436: -
- 1437: -
- 1438: -
- 1439: -
- 1440: -
- 1441: -
- 1442: -
- 1443: -
- 1444: -
- 1445: -
- 1446: -
- 1447: -

| ID | WBS | Task | Type | Duration | Start | Finish | Complete | Baseline start | Baseline finish | Baseline duration | Constraint | Deadline | Resources | Work | Actual work | Text1 | Text6 | Text8 | Text4 | Text5 | Text10 | Text12 |
| --- | --- | --- | --- | --- | --- | --- | --- | --- | --- | --- | --- | --- | --- | --- | --- | --- | --- | --- | --- | --- | --- | --- |
| 1448 | 28.1 | **MBMS User Services** |  | 743d? | 2003-05-13 A | 2006-03-16 A | 100% | 2003-05-13 | 2006-03-16 | 743d? |  |  | S1 | 13576h | 13576h | MBMS | Rel-6 | Alain |  |  |  |  |
| 1449 | 28.1 | MBMS User Services Stage 1 |  | 233d | 2003-05-13 A | 2004-04-01 A | 100% | 2003-05-13 | 2004-04-01 | 233d | start no earlier than 2003-05-13 |  | S1 | 1864h | 1864h | MBMS | Rel-6 | Alain |  |  |  |  |
| 1450 | 438.8.2 | Definition of MBMS user services, media codecs, formats and transport/application protocols using MBMS |  | 721d? | 2003-06-12 A | 2006-03-16 A | 100% | 2003-06-12 | 2006-03-16 | 721d? | finish no earlier than 2006-03-16 |  | S4 | 5768h | 5768h | MBMS-TSMBMS | Rel-6 | Paolo | Nokia | igor.curcio@nokia.com |  |  |
| 1451 | 438.9 | MBMS charging |  | 108d? | 2005-01-11 A | 2005-06-09 A | 100% | 2005-01-11 | 2005-06-09 | 108d? | start no earlier than 2005-01-11 |  | S5 | 864h | 864h | MBMS-CH | Rel-6 | Dionisio |  |  |  |  |
| 1452 | 438.10 | **MBMS UE Conformance Testing** |  | 521d? | 2006-03-10 A | 2008-03-07 A | 100% | 2006-03-10 | 2008-03-07 | 521d? |  |  | R5,T1 | 17200h | 17200h | MBMS-UEConTest | Rel-6 | Ingbert |  |  |  |  |
| 1453 | 16.5.1 | RF/RRM Conformance Test Aspects – MBMS (FDD) |  | 461d | 2006-06-02 A | 2008-03-07 A | 100% | 2006-06-02 | 2008-03-07 | 461d | finish no earlier than 2008-03-07 | 2006-06-02 | R5,T1 | 3688h | 3688h | MBMS-RAN-RF_Test | Rel-6 | Ingbert | Ericsson | leif.mattisson@ericsson.com | Fri 11/03/05 |  |
| 1454 | 438.10.2 | Conformance Test Aspects - MBMS for 3.84 Mcps and 7.68 Mcps TDD |  | 318d? | 2006-09-20 A | 2007-12-07 A | 100% | 2006-09-20 | 2007-12-07 | 318d? | finish no earlier than 2007-12-07 |  | R5,T1 | 2544h | 2544h | MBMS-UEConTest_TDH | Rel-6 | Ingbert | IPWireless | Timothy Speight (tspeight@ipwireless.com) |  |  |
| 1455 | 438.10.3 | Signalling Conformance Test Aspects – MBMS for LCR TDD |  | 318d? | 2006-09-20 A | 2007-12-07 A | 100% | 2006-09-20 | 2007-12-07 | 318d? | finish no earlier than 2007-12-07 |  | R5,T1 | 2544h | 2544h | MBMS-UEConTest_SIGTDL | Rel-6 | Ingbert | DATANG | zhaojian@datangmobile.cn |  |  |
| 1456 | 438.10.4 | Conformance Test Aspects – MBMS |  | 396d? | 2006-03-10 A | 2007-09-14 A | 100% | 2006-03-10 | 2007-09-14 | 396d? | finish no earlier than 2007-09-14 |  | R5,T1 | 3168h | 3168h | MBMS_Test | Rel-6 | Ingbert | Qualcomm Europe | Shubhang Vora (svora@qualcomm.com) |  |  |
| 1457 | 16.5.1 | Conformance Test Aspects - 1.28 Mcps TDD MBMS RF/RRM |  | 136d | 2007-06-01 A | 2007-12-07 A | 100% | 2007-06-01 | 2007-12-07 | 136d | finish no earlier than 2007-12-07 | 2006-06-02 | R5,T1 | 1088h | 1088h | MBMS-UEConTest_RFTDL | Rel-6 | Ingbert | Datang Mobile | chenxiaozhong@datangmobile.cn | Fri 11/03/05 |  |
| 1458 | 29 | **Speech Recognition and Speech Enabled Services** |  | 1105d? | 2001-10-08 A | 2005-12-30 A | 100% | 2001-10-08 | 2005-12-30 | 1105d? |  |  | S1 | 20176h | 20176h | SRSES | Rel-6 | Alain |  |  |  |  |
| 1459 | 29.1 | Speech Enabled Services Based on Distributed Speech Recognition (DSR) |  | 115d | 2001-10-08 A | 2002-03-15 A | 100% | 2001-10-08 | 2002-03-15 | 115d | finish no earlier than 2002-03-15 |  | S1 | 920h | 920h | DSR | Rel-6 | Alain | Qualcomm Europe | Dwilliams@qualcomm.com |  |  |
| 1460 | 29.2 | TR on Architectural impacts |  | 212d | 2003-05-12 A | 2004-03-02 A | 100% | 2003-05-12 | 2004-03-02 | 212d | finish no earlier than 2004-03-02 |  | S2 | 1696h | 1696h | SRSES | Rel-6 |  |  |  |  |  |
| 1461 | 439.3 | Codec Work to Support Speech Recognition Framework for Automated Voice Services |  | 568d? | 2002-10-15 A | 2004-12-16 A | 100% | 2002-10-15 | 2004-12-16 | 568d? | finish no earlier than 2004-12-16 |  | S4 | 4544h | 4544h | SRSES-Codec | Rel-6 | Paolo | Motorola | David Pearce (bdp003@motorola.com) |  |  |
| 1462 | 439.4 | Multimodal support |  | 522d? | 2004-01-01 A | 2005-12-30 A | 100% | 2004-01-01 | 2005-12-30 | 522d? | finish no earlier than 2005-06-30 |  | OMA | 4176h | 4176h | SRSES | Rel-6 |  |  | OMA-LIAISON@mail.openmobilealliance.org | SP-24 |  |
| 1463 | 439.5 | Deleted - SES codec negotiation at Session Description Protocol (SDP) | milestone | 0d? | 2003-06-04 A | 2003-06-04 A | 100% | 2003-06-04 | 2003-06-04 | 0d? | start no earlier than 2003-06-04 |  | N1 |  |  | SRSES | Rel-6 | Frederic |  |  |  | NP-23 |
| 1464 | 30 | **Generic User Profile Rel-6** |  | 889d | 2001-10-08 A | 2005-03-03 A | 100% | 2001-10-08 | 2005-03-03 | 889d |  |  | S1 | 24295.8h | 24295.8h | GUP | Rel-6 | Alain |  |  |  |  |
| 1465 | 30.1 | Stage 1 - Requirements |  | 430d | 2001-10-08 A | 2003-05-30 A | 100% | 2001-10-08 | 2003-05-30 | 430d | finish no earlier than 2002-12-09 |  | S1 | 3440h | 3440h | GUP | Rel-6 | Alain | T-Mobile | kurt.bischinger@t-mobile.at |  |  |
| 1466 | 30.3 | Stage 2 - Architecture |  | 355d | 2002-01-28 A | 2003-06-06 A | 100% | 2002-01-28 | 2003-06-06 | 355d | finish no earlier than 2003-06-06 |  | S2 | 2840h | 2840h | GUP | Rel-6 | Maurice | Nokia | harri.o.koskinen@nokia.com |  |  |
| 1467 | 30.2 | Stage 2 - Data Description Method |  | 586d | 2002-12-05 A | 2005-03-03 A | 100% | 2002-12-05 | 2005-03-03 | 586d | finish no earlier than 2005-03-03 |  | N4 | 4688h | 4688h | GUP | Rel-6 | Kimmo | T-Mobile | kurt.bischinger@t-mobile.at |  |  |
| 1468 | 30.5 | Stage 3 - Network |  | 468.98d | 2003-05-19 A | 2005-03-03 A | 100% | 2003-05-19 | 2005-03-03 | 468.98d | finish no earlier than 2005-03-03 |  | N4 | 3751.83h | 3751.83h | GUP | Rel-6 | Kimmo |  |  |  |  |
| 1469 | 30.6 | Security Aspects |  | 308d | 2002-07-16 A | 2003-09-18 A | 100% | 2002-07-16 | 2003-09-18 | 308d | finish no earlier than 2003-09-18 |  | S3 | 2464h | 2464h | GUP | Rel-6 | Dionisio | Lucent | Owen, Bradley (bvowen@lucent.com) |  |  |
| 1470 | 31 | **Digital Rights Management** |  | 690d? | 2001-10-08 A | 2004-05-28 A | 100% | 2001-10-08 | 2004-05-28 | 690d? |  |  | S1 | 10152h | 10152h | DRM | Rel-6 | Alain |  |  |  |  |
| 1471 | 31.1 | Requirements |  | 179d | 2001-10-08 A | 2002-06-13 A | 100% | 2001-10-08 | 2002-06-13 | 179d | finish no earlier than 2002-06-13 |  | S1 | 1432h | 1432h | DRM | Rel-6 | Alain | Openwave | nicholas.wood@openwave.com |  |  |
| 1472 | 441.2 | Stage 2 |  | 107d? | 2004-01-01 A | 2004-05-28 A | 100% | 2004-01-01 | 2004-05-28 | 107d? | finish no earlier than 2004-05-28 |  | OMA | 856h | 856h | DRM | Rel-6 |  |  | OMA-LIAISON@mail.openmobilealliance.org | SP-24 |  |
| 1473 | 441.3 | Stage 3 |  | 107d? | 2004-01-01 A | 2004-05-28 A | 100% | 2004-01-01 | 2004-05-28 | 107d? | finish no earlier than 2004-05-28 |  | OMA | 856h | 856h | DRM | Rel-6 |  |  | OMA-LIAISON@mail.openmobilealliance.org | SP-24 |  |
| 1474 | 31.3 | Security |  | 186d | 2002-06-17 A | 2003-03-03 A | 100% | 2002-06-17 | 2003-03-03 | 186d | finish no earlier than 2003-03-03 |  | OMA | 1488h | 1488h | DRM | Rel-6 |  |  |  |  |  |
| 1475 | 441.5 | Deleted - Monitoring of Stages 2 and 3 progress (actual work to be done by OMA) | milestone | 0d? | 2003-03-21 A | 2003-03-21 A | 100% | 2003-03-21 | 2003-03-21 | 0d? | start no earlier than 2002-08-19 |  | S1 |  |  | DRM | Rel-6 | Alain |  |  |  | SP-19 |

Notes:
- 1448: - / Text3: 22.246
- 1449: - / Text3: 22.246
- 1450: TR26.946 tbc by March 06 / Text3: 26.346, 26.936, 26.946
- 1451: SP#28 06/2005 completed / Text3: 32.273
- 1452: BB place holder for a number of RAN5 Tasks. Moved in from the Stoyan/Testing WP / Text3: 34.108, 34.109, 34.121-1, 34.121-2, 34.122, 34.123-1, 34.123-2, 34.123-3
- 1453: TS 34.109 is under RAN2; RAN5 need to identify possible new requirements on UE test loop functionality to enable testing / Text3: 34.108, 34.109, 34.121-1, 34.121-2
- 1454: - / Text3: 34.108, 34.122, 34.123-1, 34.123-2, 34.123-3
- 1455: - / Text3: 34.108, 34.123-1, 34.123-2, 34.123-3
- 1456: - / Text3: 34.108, 34.123-1, 34.123-2, 34.123-3
- 1457: - / Text3: 34.108, 34.109, 34.122
- 1458: -
- 1459: - / Text3: 22.941, 23.207, 22.243
- 1460: - / Text3: 23.877
- 1461: - / Text3: 26.235, 26.236, 26.243, 26.177, 26.943
- 1462: -
- 1463: Abandoned NP-23
- 1464: -
- 1465: - / Text3: 22.240, 22.228
- 1466: - / Text3: 23.240
- 1467: TR approved in CN#26 / Text3: 23.241
- 1468: - / Text3: 29.240
- 1469: WID approved SP#17. SA WG3 progress slow, depends on progress in other groups. / Text3: 33.102, 33.203, 33.210
- 1470: Foreseen start and completion dates introduced by MCC (no indication at all on the WID)
- 1471: -
- 1472: -
- 1473: -
- 1474: SA3 acknowledge role in WI at SA3#20. Active contribution S3#24, S3#25. S3 WID approved SP#17
- 1475: Replaced by UID 60005 and 60006

| ID | WBS | Task | Duration | Start | Finish | Complete | Baseline start | Baseline finish | Baseline duration | Constraint | Resources | Work | Actual work | Text1 | Text4 | Text5 | Text6 | Text8 | Text3 | Text10 |
| --- | --- | --- | --- | --- | --- | --- | --- | --- | --- | --- | --- | --- | --- | --- | --- | --- | --- | --- | --- | --- |
| 1476 | 32 | **WLAN-UMTS Interworking Rel-6** | 1495d? | 2000-01-03 A | 2005-09-22 A | 100% | 2000-01-03 | 2005-09-22 | 1495d? |  | S1 | 48472h | 48472h | WLAN | Telenor | frederic.paint@telenor.com | Rel-6 | Alain |  |  |
| 1477 | 32.1 | Technical Report | 901d? | 2000-01-03 A | 2003-06-13 A | 100% | 2000-01-03 | 2003-06-13 | 901d? | finish no earlier than 2003-06-13 | S1 | 7200h | 7200h | WLAN-TR | Telenor | frederic.paint@telenor.com | Rel-6 | Alain | 22.934, 22.101, 22.105 |  |
| 1478 | 442.2 | **Stage 1** | 375d? | 2003-01-06 A | 2004-06-11 A | 100% | 2003-01-06 | 2004-06-11 | 375d? |  | S1 | 3920h | 3920h | WLAN-TS | Telenor | frederic.paint@telenor.com | Rel-6 | Alain | 22.234 | SP-24 |
| 1479 | 442.2.1 | Global stage 1 | 375d? | 2003-01-06 A | 2004-06-11 A | 100% | 2003-01-06 | 2004-06-11 | 375d? | finish no earlier than 2004-06-11 | S1 | 3000h | 3000h | WLAN-TS | Telenor | frederic.paint@telenor.com | Rel-6 | Alain | 22.234 | SP-24 |
| 1480 | 32.2 | Architecture Definition for scenarii 2 and 3 | 571d | 2002-03-25 A | 2004-05-31 A | 100% | 2002-03-25 | 2004-05-31 | 571d | finish no earlier than 2004-05-31 | S2 | 4568h | 4568h | WLAN |  |  | Rel-6 | Maurice | 23.234 |  |
| 1481 | 32.3 | Security | 125d | 2002-09-30 A | 2003-03-21 A | 100% | 2002-09-30 | 2003-03-21 | 125d | finish no earlier than 2003-03-21 | S3 | 1000h | 1000h | WLAN | Ericsson | luis.lopez-soria@ece.ericsson.se | Rel-6 | Dionisio | 21.133, 33.106, 33.107, 33.108, 33.200, 33.203, 33.210 |  |
| 1482 | 442.5 | Stage 3 - CN4 aspects | 334d? | 2003-05-23 A | 2004-09-01 A | 100% | 2003-05-23 | 2004-09-01 | 334d? | finish no earlier than 2004-09-01 | N4 | 2672h | 2672h | WLAN-IW | Nokia | raquel.rodriguez@nokia.com | Rel-6 | Kimmo | 29.234, 29.061 |  |
| 1483 | 442.6 | Stage 3 - CN3 aspects (Wi Interface for Scenario 3) | 355d? | 2003-05-23 A | 2004-09-30 A | 100% | 2003-05-23 | 2004-09-30 | 355d? | start no earlier than 2003-05-23 | N3 | 2840h | 2840h | WLAN |  |  | Rel-6 | Gwiho | 29.161 | SP-24 |
| 1484 | 442.7 | Stage 3 for scenario 2 | 339d? | 2003-05-23 A | 2004-09-08 A | 100% | 2003-05-23 | 2004-09-08 | 339d? | finish no earlier than 2004-09-08 | N1 | 2712h | 2712h | WLAN |  |  | Rel-6 | Frederic |  |  |
| 1485 | 442.8 | Stage 3 for scenario 3 | 404d? | 2003-05-23 A | 2004-12-08 A | 100% | 2003-05-23 | 2004-12-08 | 404d? | finish no earlier than 2004-12-08 | N1 | 3232h | 3232h | WLAN |  |  | Rel-6 | Frederic |  | SP-24 |
| 1486 | 442.9 | WLAN charging | 655d? | 2003-03-21 A | 2005-09-22 A | 100% | 2003-03-21 | 2005-09-22 | 655d? | finish no earlier than 2005-09-22 | S5 | 5240h | 5240h | WLAN-CH | Nokia | Benni ALEXANDER | Rel-6 | Dionisio | 32.252 |  |
| 1487 | 442.10 | USIM enhancements for WLAN Interworking | 391d? | 2003-09-05 A | 2005-03-04 A | 100% | 2003-09-05 | 2005-03-04 | 391d? | finish no earlier than 2005-03-04 | T3 | 3128h | 3128h | WLAN | Axalto | Jabellan@axalto.com | Rel-6 |  |  |  |
| 1488 | 33 | **Priority Service** | 347d? | 2002-05-30 A | 2003-09-26 A | 100% | 2002-05-30 | 2003-09-26 | 347d? |  | S1 | 6464h | 6464h | PRIOR1 | Telcordia | Biplab K. Pramanik (bpramani@telcordia.com) | Rel-6 | Alain |  |  |
| 1489 | 33.1 | Feasibility Study | 1d | 2002-06-14 A | 2002-06-14 A | 100% | 2002-06-14 | 2002-06-14 | 1d | finish no earlier than 2002-06-14 | S1 | 8h | 8h | PRIOR-FS | Telcordia | Biplab K. Pramanik (bpramani@telcordia.com) | Rel-6 | Alain | 22.950 |  |
| 1490 | 33.2 | Stage 1 - Requirements | 340d | 2002-05-30 A | 2003-09-17 A | 100% | 2002-05-30 | 2003-09-17 | 340d | finish no earlier than 2003-09-17 | S1 | 2720h | 2720h | PRIOR-SR | Telcordia | James J. Garrahan (bpramani@telcordia.com) | Rel-6 | Alain |  |  |
| 1491 | 443.3 | Priority service implementation guide | 131d? | 2003-03-28 A | 2003-09-26 A | 100% | 2003-03-28 | 2003-09-26 | 131d? | finish no earlier than 2003-09-26 | S1 | 1048h | 1048h | PRIOR1 | Telcordia | Biplab K. Pramanik (bpramani@telcordia.com) | Rel-6 | Alain | 22.952 |  |
| 1492 | 34 | **Network Sharing** | 498d? | 2003-01-20 A | 2004-12-15 A | 100% | 2003-01-20 | 2004-12-15 | 498d? |  | S1 | 16608h | 16608h | NTShar | T-Mobile | michele.zarri@t-mobile.co.uk | Rel-6 | Alain |  |  |
| 1493 | 34.1 | Technical Report | 240d? | 2003-01-20 A | 2003-12-19 A | 100% | 2003-01-20 | 2003-12-19 | 240d? |  | S1 | 1920h | 1920h | NTShar-TR | T-Mobile | michele.zarri@t-mobile.co.uk | Rel-6 | Alain | 22.951 |  |
| 1494 | 444.2 | Stage 1 - CRs to implement Network Sharing | 240d? | 2003-01-20 A | 2003-12-19 A | 100% | 2003-01-20 | 2003-12-19 | 240d? | finish no earlier than 2003-12-19 | S1 | 1920h | 1920h | NTSharCR | T-Mobile | michele.zarri@t-mobile.co.uk | Rel-6 | Alain | 22.011, 22.101, 22.115, 22.129 |  |
| 1495 | 444.3 | Stage 2 | 372d? | 2003-02-27 A | 2004-07-30 A | 100% | 2003-02-27 | 2004-07-30 | 372d? | finish no earlier than 2004-07-30 | S2 | 2976h | 2976h | NTShar | T-Mobile | michele.zarri@t-mobile.co.uk | Rel-6 | Maurice | 23.002, 23.060, 23.221, 23.236, new 23.251 |  |
| 1496 | 444.4 | Network sharing - stage 3 | 404d? | 2003-05-23 A | 2004-12-08 A | 100% | 2003-05-23 | 2004-12-08 | 404d? | finish no earlier than 2004-12-08 | N1 | 3232h | 3232h | NTShar | T-Mobile | michele.zarri@t-mobile.co.uk | Rel-6 | Frederic | 23.008, 23.122, 24.007, 24.008, 29.018 |  |
| 1497 | 444.5 | Enhancement of the support of network sharing in the UTRAN | 324d | 2003-09-19 A | 2004-12-15 A | 100% | 2003-09-19 | 2004-12-15 | 324d | finish no earlier than 2004-12-15 | R2 | 2592h | 2592h | NTShar-UTRANEnh | TeliaSonera | Anders.Dahlen@TeliaSonera.com | Rel-6 | Joern | 25.401, 25.413, 25.331, 25.304 |  |
| 1498 | 35 | **QoS Improvements** | 628d? | 2002-07-15 A | 2004-12-08 A | 100% | 2002-07-15 | 2004-12-08 | 628d? |  | S2,N3 | 13128h | 13128h | QoS1 | Nokia |  | Rel-6 | Maurice | 23.107, 23.207, 23.221 |  |
| 1499 | 35.1 | FS on Dynamic Policy control enhancements for end-to-end QoS | 465d | 2002-07-15 A | 2004-04-23 A | 100% | 2002-07-15 | 2004-04-23 | 465d | finish no earlier than 2004-04-23 | S2 | 3720h | 3720h | QoS1 | Nortel | Claire Mousset | Rel-6 | Maurice | 23.917 withdrawn (Contents all in 23.207) |  |
| 1500 | 445.2 | Definition of the Gq interface | 214d? | 2003-07-01 A | 2004-04-23 A | 100% | 2003-07-01 | 2004-04-23 | 214d? | finish no earlier than 2004-04-23 | S2 | 1712h | 1712h | QoS1 |  | Janne Rinne | Rel-6 |  | 23.207 |  |
| 1501 | 445.3 | Gq interface specification for Dynamic Policy control enhancements – Stage 3 | 334d | 2003-08-29 A | 2004-12-08 A | 100% | 2003-08-29 | 2004-12-08 | 334d | finish no earlier than 2004-12-08 | N3 | 2672h | 2672h | QoS1 | Nokia | Anna.Sillanpaai@nokia.com | Rel-6 | Gwiho | 29.207, 29.208, 29.209 |  |

Notes:
- 1476: -
- 1477: -
- 1478: -
- 1479: -
- 1480: -
- 1481: Active contribution S3#24, S3#25. WID approved SP#17
- 1482: WID approved at CN#19
- 1483: -
- 1484: -
- 1485: -
- 1486: SP#28: delayed 09/2005. WT also under SA5 BB 35017 Charging Management for Bearer level
- 1487: -
- 1488: -
- 1489: -
- 1490: -
- 1491: -
- 1492: -
- 1493: -
- 1494: -
- 1495: -
- 1496: -
- 1497: -
- 1498: -
- 1499: -
- 1500: -
- 1501: [DAB - 25.05.04] - Delayed to Sept - possibly Dec 2004

| ID | WBS | Task | Type | Duration | Start | Finish | Complete | Baseline start | Baseline finish | Baseline duration | Constraint | Resources | Work | Actual work | Text1 | Text4 | Text5 | Text6 | Text8 | Text10 | Text12 |
| --- | --- | --- | --- | --- | --- | --- | --- | --- | --- | --- | --- | --- | --- | --- | --- | --- | --- | --- | --- | --- | --- |
| 1502 | 36 | **Subscriber certificates** |  | 728d? | 2002-02-25 A | 2004-12-08 A | 100% | 2002-02-25 | 2004-12-08 | 728d? |  | S3,S2,N1,N4,T3,OMA | 12888h | 12888h | SEC1-SC | Nokia | valtteri.niemi@nokia.com | Rel-6 | Dionisio |  |  |
| 1503 | 36.1 | Stage 1 |  | 144d | 2002-02-25 A | 2002-09-12 A | 100% | 2002-02-25 | 2002-09-12 | 144d | finish no earlier than 2002-09-12 | S3 | 1152h | 1152h | SEC1-SC | Nokia | valtteri.niemi@nokia.com | Rel-6 | Dionisio |  |  |
| 1504 | 36.2 | Architecture review |  | 24d | 2002-10-14 A | 2002-11-14 A | 100% | 2002-10-14 | 2002-11-14 | 24d | finish no earlier than 2002-11-14 | S2 | 192h | 192h | SEC1-SC | Nokia |  | Rel-6 | Maurice |  |  |
| 1505 | 446.3 | Stage 3 |  | 313d? | 2003-09-19 A | 2004-11-30 A | 100% | 2003-09-19 | 2004-11-30 | 313d? | finish no earlier than 2004-11-30 | N4,T3 | 2504h | 2504h | SEC1-SC | Nokia | Lauri Laitinen | Rel-6 | Kimmo |  |  |
| 1506 | 446.4 | Stage 3 Ua & Ub interfaces |  | 288d? | 2003-11-03 A | 2004-12-08 A | 100% | 2003-11-03 | 2004-12-08 | 288d? | finish no earlier than 2004-12-08 | N1 | 2304h | 2304h | SEC1-SC | Nokia |  | Rel-6 | Frederic |  |  |
| 1507 | 446.5 | OMA dependencies on Subscriber certificates |  | 114d? | 2004-01-01 A | 2004-06-08 A | 100% | 2004-01-01 | 2004-06-08 | 114d? | finish no earlier than 2004-06-08 | OMA | 912h | 912h | SEC1-SC | Nokia | OMA-LIAISON@mail.openmobilealliance.org | Rel-6 |  | SP-24 |  |
| 1508 | 447 | **Rel-6 OSA enhancements** |  | 616d? | 2002-10-31 A | 2005-03-10 A | 100% | 2002-10-31 | 2005-03-10 | 616d? |  | N5 | 22576h | 22576h | OSA3 | Alcatel | Chelo.Abarca@alcatel.fr | Rel-6 | Kimmo |  |  |
| 1509 | 447.1 | Scope of the Open Service Access Release 6 |  | 66d? | 2003-03-28 A | 2003-06-27 A | 100% | 2003-03-28 | 2003-06-27 | 66d? | finish no earlier than 2003-06-27 | S1 | 528h | 528h | OSA3 |  |  | Rel-6 | Alain |  |  |
| 1510 | 447.2 | OSA Stage 2 |  | 150d? | 2004-08-13 A | 2005-03-10 A | 100% | 2004-08-13 | 2005-03-10 | 150d? | finish no earlier than 2005-03-10 | N5 | 1200h | 1200h | OSA3 |  |  | Rel-6 | Kimmo |  |  |
| 1511 | 447.3 | Multi Media Messaging function |  | 487d? | 2002-10-31 A | 2004-09-10 A | 100% | 2002-10-31 | 2004-09-10 | 487d? | finish no earlier than 2004-09-10 | N5 | 3896h | 3896h | OSA3 |  |  | Rel-6 | Kimmo |  |  |
| 1512 | 447.4 | Policy management extensions |  | 292d? | 2002-10-31 A | 2003-12-12 A | 100% | 2002-10-31 | 2003-12-12 | 292d? | finish no earlier than 2003-12-12 | N5 | 2336h | 2336h | OSA3 |  |  | Rel-6 | Kimmo |  |  |
| 1513 | 447.5 | TS on Presence and Availability Management (from the PRESNC WI) |  | 367d? | 2002-10-31 A | 2004-03-26 A | 100% | 2002-10-31 | 2004-03-26 | 367d? | finish no earlier than 2004-03-26 | N5 | 2936h | 2936h | OSA3 |  |  | Rel-6 | Kimmo |  |  |
| 1514 | 447.6 | OSA interfaces at different levels of abstractions (Parlay X, Web services) |  | 305d? | 2003-07-14 A | 2004-09-10 A | 100% | 2003-07-14 | 2004-09-10 | 305d? | finish no earlier than 2004-09-10 | N5 | 2440h | 2440h | OSA3 |  |  | Rel-6 | Kimmo |  |  |
| 1515 | 447.7 | Introduction of migration support mechanism |  | 290d? | 2002-10-31 A | 2003-12-10 A | 100% | 2002-10-31 | 2003-12-10 | 290d? | finish no earlier than 2003-12-12 | N5 | 2320h | 2320h | OSA3 |  |  | Rel-6 | Kimmo |  |  |
| 1516 | 447.8 | Framework Function for Federation |  | 225d? | 2003-02-03 A | 2003-12-12 A | 100% | 2003-02-03 | 2003-12-12 | 225d? | finish no earlier than 2003-12-12 | N5 | 1800h | 1800h | OSA3 |  |  | Rel-6 | Kimmo |  |  |
| 1517 | 447.9 | OMA potential overlaps with 3GPP OSA Stage 3 (Web services) |  | 196d? | 2003-12-18 A | 2004-09-16 A | 100% | 2003-12-18 | 2004-09-16 | 196d? | start no earlier than 2003-12-18 | OMA | 1568h | 1568h | OSA3 |  |  | Rel-6 |  | SP-24 |  |
| 1518 | 447.10 | Deleted - TR on Presence and Availability Management (from the PRESNC WI) | milestone | 0d? | 2004-09-17 A | 2004-09-17 A | 100% | 2004-09-17 | 2004-09-17 | 0d? | start no earlier than 2004-09-17 | N5 |  |  | OSA3 |  |  | Rel-6 | Kimmo |  | NP-24 |
| 1519 | 39 | **Addition of frequency bands to GSM (TAPS)** |  | 676d | 2002-06-28 A | 2005-01-28 A | 100% | 2002-06-28 | 2005-01-28 | 676d |  | GP | 16640h | 16640h | TAPS | Nokia | Torben Themsen | Rel-6 | Paolo |  |  |
| 1520 | 39.1 | **Addition of frequency bands to GSM – Changes to core specs** |  | 26d | 2002-11-15 A | 2002-12-20 A | 100% | 2002-11-15 | 2002-12-20 | 26d |  | G1 | 416h | 416h | TAPS-Specs | Nokia | Torben Themsen | Rel-6 | Paolo |  |  |
| 1521 | 39.1.1 | Changes to core specs |  | 26d | 2002-11-15 A | 2002-12-20 A | 100% | 2002-11-15 | 2002-12-20 | 26d | finish no earlier than 2002-12-20 | G1 | 208h | 208h | TAPS-Specs | Nokia | Torben Themsen | Rel-6 | Paolo |  |  |
| 1522 | 39.2 | **Deleted - Addition of frequency bands to GSM – Changes for conformance tests** |  | 676d | 2002-06-28 A | 2005-01-28 A | 100% | 2002-06-28 | 2005-01-28 | 676d |  | G4 | 10816h | 10816h | TAPS-Conf | Nokia | Torben Themsen | Rel-6 | Paolo |  | GP-23 |
| 1523 | 39.2.1 | Deleted - 51.010-1 Add testing |  | 676d | 2002-06-28 A | 2005-01-28 A | 100% | 2002-06-28 | 2005-01-28 | 676d | finish no earlier than 2005-01-28 | G4 | 5408h | 5408h | TAPS-Conf | Nokia | Torben Themsen | Rel-6 | Paolo |  | GP-23 |
| 1524 | 40 | **Seamless support of streaming services in A/Gb mode** |  | 1426d? | 2000-01-03 A | 2005-06-17 A | 100% | 2000-01-03 | 2005-06-17 | 1426d? |  | GP | 53096h | 53096h | SSStrea | Vodafone | José Luis Carrizo Martínez | Rel-6 | Paolo |  |  |
| 1525 | 40.1 | **Identification of requirements for streaming** |  | 46d? | 2003-06-27 A | 2003-08-29 A | 100% | 2003-06-27 | 2003-08-29 | 46d? |  | G1 | 736h | 736h | SSStrea | Vodafone | José Luis Carrizo Martínez | Rel-6 | Paolo |  |  |
| 1526 | 449.1.1 | Requirements |  | 46d? | 2003-06-27 A | 2003-08-29 A | 100% | 2003-06-27 | 2003-08-29 | 46d? | finish no earlier than 2003-08-29 | G1 | 368h | 368h | SSStrea | Vodafone | José Luis Carrizo Martínez | Rel-6 | Paolo |  |  |

Notes:
- 1502: Approved at SP#14. May require BBs from CN1, CN4, SA5 and T3
- 1503: Contribution received S3#24, S3#25 / Text3: 33.220, 33.221, 33.222, 33.246
- 1504: -
- 1505: Finished in CN4#26 / Text3: 23.003, 23.008, 29.109, 29.230, T3 31.102, 31.103, 31.111
- 1506: - / Text3: 24.109
- 1507: Updated according to SP-040420
- 1508: CN#25: Updated WID NP-040351 replaces NP-040144. / Text3: 22.127, 23.198, 29.198, 29.199, 29.998
- 1509: -
- 1510: Inherited by CN5 from SA2 at TSG#25 Sep 2004. SA2's 23.127 (OSA/VHE Stage 2) replaced from Rel-6 onwards by a new CN5 TS 23.198 (Stage 2 OSA-only). / Text3: 23.198 OSA Stage 2-ONLY replaces 23.127 (OSA/VHE) from Rel-6 onwards
- 1511: - / Text3: 29.198-15
- 1512: - / Text3: 29.198, 29.998
- 1513: N5#26: Split WI into TS & TR. / Text3: 29.198-14
- 1514: - / Text3: 29.199
- 1515: - / Text3: 29.198, 29.998
- 1516: - / Text3: 29.198, 29.998
- 1517: TSG#25 Approved CN5 29.199 Parlay X Web services. Ongoing 3GPP/OMA co-ordination to avoid OMA producing conflicting/OVERLAPING specs (NP-040283/SP-040493).
- 1518: N5#26:TR Completion 09/04; consistent with CN1 delayed Rel-6 completion.
- 1519: -
- 1520: -
- 1521: -
- 1522: -
- 1523: -
- 1524: -
- 1525: -
- 1526: -

| ID | WBS | Task | Duration | Start | Finish | Complete | Baseline start | Baseline finish | Baseline duration | Constraint | Resources | Work | Actual work | Text1 | Text4 | Text5 | Text6 | Text8 | Text12 | Text3 |
| --- | --- | --- | --- | --- | --- | --- | --- | --- | --- | --- | --- | --- | --- | --- | --- | --- | --- | --- | --- | --- |
| 1527 | 40.2 | **Performance study of cell change mechanisms** | 956d? | 2000-01-03 A | 2003-08-29 A | 100% | 2000-01-03 | 2003-08-29 | 956d? |  | G1 | 30568h | 30568h | SSStrea | Vodafone | José Luis Carrizo Martínez | Rel-6 | Paolo |  |  |
| 1528 | 449.2.1 | Performance of NACC | 956d? | 2000-01-03 A | 2003-08-29 A | 100% | 2000-01-03 | 2003-08-29 | 956d? | finish no earlier than 2003-08-29 | G1 | 7640h | 7640h | SSStrea | Vodafone | José Luis Carrizo Martínez | Rel-6 | Paolo |  |  |
| 1529 | 449.2.2 | Performance of cell change in DTM for the PS domain | 956d? | 2000-01-03 A | 2003-08-29 A | 100% | 2000-01-03 | 2003-08-29 | 956d? | finish no earlier than 2003-08-29 | G1 | 7640h | 7640h | SSStrea | Vodafone | José Luis Carrizo Martínez | Rel-6 | Paolo |  |  |
| 1530 | 449.2.3 | Handover | 956d? | 2000-01-03 A | 2003-08-29 A | 100% | 2000-01-03 | 2003-08-29 | 956d? | finish no earlier than 2003-08-29 | G1 | 7640h | 7640h | SSStrea | Vodafone | José Luis Carrizo Martínez | Rel-6 | Paolo |  |  |
| 1531 | 40.3 | **Reduction of service interruption times and packet loss during mobility procedures** | 516d? | 2003-06-27 A | 2005-06-17 A | 100% | 2003-06-27 | 2005-06-17 | 516d? |  | G2 | 10800h | 10800h | SSStrea | Vodafone | José Luis Carrizo Martínez | Rel-6 | Gert |  |  |
| 1532 | 449.3.1 | optimizations of existing mechanisms/procedures | 106d? | 2003-06-27 A | 2003-11-21 A | 100% | 2003-06-27 | 2003-11-21 | 106d? | finish no earlier than 2003-11-21 | G2 | 848h | 848h | SSStrea | Vodafone | José Luis Carrizo Martínez | Rel-6 | Gert |  |  |
| 1533 | 449.3.2 | Inter-system NACC | 106d? | 2003-06-27 A | 2003-11-21 A | 100% | 2003-06-27 | 2003-11-21 | 106d? | finish no earlier than 2003-11-21 | G2 | 848h | 848h | SSStrea | Vodafone | José Luis Carrizo Martínez | Rel-6 | Gert |  |  |
| 1534 | 449.3.3 | PS Handover (within GERAN and between GERAN and UTRAN) | 516d? | 2003-06-27 A | 2005-06-17 A | 100% | 2003-06-27 | 2005-06-17 | 516d? | finish no earlier than 2003-11-21 | G2 | 4128h | 4128h | SSStrea | Vodafone | José Luis Carrizo Martínez | Rel-6 | Gert |  |  |
| 1535 | 449.3.4 | Dependency to other features | 106d? | 2003-06-27 A | 2003-11-21 A | 100% | 2003-06-27 | 2003-11-21 | 106d? | finish no earlier than 2003-11-21 | G2 | 848h | 848h | SSStrea | Vodafone | José Luis Carrizo Martínez | Rel-6 | Gert |  |  |
| 1536 | 40.5 | **Deleted - MS conformance testing** | 31d? | 2003-12-19 A | 2004-01-30 A | 100% | 2003-12-19 | 2004-01-30 | 31d? |  | G3new | 248h | 248h | SSStrea | Vodafone | José Luis Carrizo Martínez | Rel-6 | Ingbert | GP-27 |  |
| 1537 | 449.4.1 | Deleted - MS conformance tests | 31d? | 2003-12-19 A | 2004-01-30 A | 100% | 2003-12-19 | 2004-01-30 | 31d? | finish no earlier than 2004-01-30 | G4,G5 | 248h | 248h | SSStrea | Vodafone | José Luis Carrizo Martínez | Rel-6 | Ingbert | GP-27 |  |
| 1538 | 449.5 | GERAN A/Gb mode security enhancements | 612d? | 2002-09-26 A | 2005-01-28 A | 100% | 2002-09-26 | 2005-01-28 | 612d? | finish no earlier than 2005-01-28 | S3 | 4896h | 4896h | SSStrea | Vodafone | peter.howard@vodafone.com | Rel-6 | Dionisio |  | 33.102 |
| 1539 | 41 | Performance characterisation of default codecs for PS conversational multimedia application | 455d | 2002-09-13 A | 2004-06-10 A | 100% | 2002-09-13 | 2004-06-10 | 455d | finish no earlier than 2004-06-10 | S4 | 3640h | 3640h | CODCAR | Nokia | pasi.s.ojala@nokia.com | Rel-6 | Paolo |  | 26.935 |
| 1540 | 43 | Study on Privacy Capability | 83d | 2003-11-10 A | 2004-03-03 A | 100% | 2003-11-10 | 2004-03-03 | 83d | start no earlier than 2003-11-10 | S1 | 664h | 664h | PrivCap | Lucent | Liz Daniel | Rel-6 | Alain |  | 22.949 |
| 1541 | 44 | **OAM&P Rel-6** | 652d? | 2002-09-12 A | 2005-03-11 A | 100% | 2002-09-12 | 2005-03-11 | 652d? |  | S5 | 30819.5h | 30819.5h | OAM | Motorola |  | Rel-6 | Dionisio |  |  |
| 1542 | 44.1 | Principles, high level Requirements and Architecture | 526d | 2002-09-12 A | 2004-09-16 A | 100% | 2002-09-12 | 2004-09-16 | 526d | finish no earlier than 2004-09-16 | S5 | 4208h | 4208h | OAM-AR | Motorola |  | Rel-6 | Dionisio |  | 32.101, 32.102 |
| 1543 | 44.2 | Performance Management | 591d | 2002-09-12 A | 2004-12-16 A | 100% | 2002-09-12 | 2004-12-16 | 591d | finish no earlier than 2004-12-16 | S5 | 4728h | 4728h | OAM-PM | Nortel |  | Rel-6 | Dionisio |  | 32.401/3, 52.402, 32.411/2/3, 32.432/5/6 |
| 1544 | 44.4 | Network Infrastructure Management | 591d | 2002-09-12 A | 2004-12-16 A | 100% | 2002-09-12 | 2004-12-16 | 591d | finish no earlier than 2004-12-16 | S5 | 4728h | 4728h | OAM-NIM | Ericsson | thomas.tovinger@ericsson.com | Rel-6 | Dionisio |  | 32.15x, 32.3/6/7xy |
| 1545 | 44.5 | **Trace Management Rel-6** | 646d? | 2002-09-20 A | 2005-03-11 A | 100% | 2002-09-20 | 2005-03-11 | 646d? |  | S5 | 12061.9h | 12061.9h | OAM-Trace | Nokia | kari.t.ronka@nokia.com | Rel-6 | Dionisio |  | 32.42x, 52.008 |
| 1546 | 452.4.1 | Subscriber and UE trace management | 585d | 2002-09-20 A | 2004-12-16 A | 100% | 2002-09-20 | 2004-12-16 | 585d | finish no earlier than 2004-12-16 | S5 | 4680h | 4680h | OAM-Trace | Nokia | kari.t.ronka@nokia.com | Rel-6 | Dionisio |  | 32.421/2/3, 52.008 |
| 1547 | 452.4.2 | Subscriber and equipment trace in UTRAN | 268d? | 2003-06-06 A | 2004-06-15 A | 100% | 2003-06-06 | 2004-06-15 | 268d? | finish no earlier than 2004-06-15 | R3 | 2144h | 2144h | OAM-Trace-RAN | Nortel | Yann Sehedi (sehedic@nortelnetworks.com) | Rel-6 | Juha |  | 25.413, 25.420, 25.423 |
| 1548 | 452.4.3 | Trace Management, Stage3 | 193.74d? | 2004-06-09 A | 2005-03-11 A | 100% | 2004-06-09 | 2005-03-11 | 193.74d? | finish no earlier than 2005-03-11 | N4 | 1549.92h | 1549.92h | OAM-Trace | Nokia | seppo.kauntola@nokia.com | Rel-6 | Kimmo |  | 23.205, 29.232, 29.060, 29.002, 29.228 |
| 1549 | 453 | **Charging Management** | 666d? | 2002-11-21 A | 2005-06-09 A | 100% | 2002-11-21 | 2005-06-09 | 666d? |  | S5 | 55320h | 55320h | CH | T-Mobile | karl-heinz.nenner@t-mobile.de | Rel-6 | Dionisio |  | 32.2xy |
| 1550 | 453.1 | Charging architecture and principles | 390d? | 2003-03-21 A | 2004-09-16 A | 100% | 2003-03-21 | 2004-09-16 | 390d? | start no earlier than 2003-03-21 | S5 | 3120h | 3120h | CH |  |  | Rel-6 | Dionisio |  | 32.240 |
| 1551 | 453.2 | Charging Data Record (CDR) file format and transfer | 260d? | 2003-03-21 A | 2004-03-18 A | 100% | 2003-03-21 | 2004-03-18 | 260d? | start no earlier than 2003-03-21 | S5 | 2080h | 2080h | CH |  |  | Rel-6 | Dionisio |  | 32.297 |
| 1552 | 453.3 | CDR parameter description | 580d? | 2003-03-21 A | 2005-06-09 A | 100% | 2003-03-21 | 2005-06-09 | 580d? | finish no earlier than 2005-06-09 | S5 | 4640h | 4640h | CH |  |  | Rel-6 | Dionisio |  | 32.298 |
| 1553 | 453.4 | Diameter charging applications | 390d? | 2003-03-21 A | 2004-09-16 A | 100% | 2003-03-21 | 2004-09-16 | 390d? | start no earlier than 2003-03-21 | S5 | 3120h | 3120h | CH |  |  | Rel-6 | Dionisio |  | 32.299 |
| 1554 | 453.5 | Online Charging System (OCS) architecture study | 130d? | 2003-03-21 A | 2003-09-18 A | 100% | 2003-03-21 | 2003-09-18 | 130d? | start no earlier than 2003-03-21 | S5 | 1040h | 1040h | CH |  |  | Rel-6 | Dionisio |  | 32.815 |
| 1555 | 453.6 | OCS: Applications and interfaces | 455d? | 2003-03-21 A | 2004-12-16 A | 100% | 2003-03-21 | 2004-12-16 | 455d? | start no earlier than 2003-03-21 | S5 | 3640h | 3640h | CH |  |  | Rel-6 | Dionisio |  | 32.296 |

Notes:
- 1527: -
- 1528: -
- 1529: -
- 1530: -
- 1531: Completed at GERP#17
- 1532: -
- 1533: -
- 1534: -
- 1535: -
- 1536: Marked as stopped 10/2009
- 1537: Marked as stopped 10/2009
- 1538: Possible changes to 33.102 or new specification needed
- 1539: -
- 1540: -
- 1541: SP#26: Updated WID SP-040766 was SP-020445. Completion delayed 12/04->03/05 due to OAM-Trace in CN1/4.
- 1542: SP#25 09/2004 completed
- 1543: SP#26 12/2004 completed
- 1544: SP#26 12/2004 completed
- 1545: SP#26 12/2004 SA5 completed 12/04. Signalling Based Trace Activation for IMS (SIP) moved to Rel-7. Reason: CN1 cannot complete 24.229 trace without IETF dependency => estimate 05/2005.
- 1546: SP#26 12/2004 completed
- 1547: -
- 1548: -
- 1549: SP#28 Target 09/2005 for WLAN Charging 32.252
- 1550: SP#25 09/2004 completed
- 1551: SP#23 03/2004 completed
- 1552: SP#28 06/2005 completed
- 1553: SP#25 09/2004 completed
- 1554: SP#21 09/2003 completed
- 1555: SP#26 12/2004 completed

| ID | WBS | Task | Duration | Start | Finish | Complete | Baseline start | Baseline finish | Baseline duration | Constraint | Resources | Work | Actual work | Text1 | Text4 | Text5 | Text6 | Text8 | Text10 | Text12 |
| --- | --- | --- | --- | --- | --- | --- | --- | --- | --- | --- | --- | --- | --- | --- | --- | --- | --- | --- | --- | --- |
| 1556 | 453.7 | **Charging Management for Bearer level** | 390d? | 2003-03-21 A | 2004-09-16 A | 100% | 2003-03-21 | 2004-09-16 | 390d? |  | S5 | 11440h | 11440h | CH-BC | Nokia | Benni ALEXANDER | Rel-6 | Dionisio |  |  |
| 1557 | 453.7.1 | CS domain charging | 260d? | 2003-03-21 A | 2004-03-18 A | 100% | 2003-03-21 | 2004-03-18 | 260d? | start no earlier than 2003-03-21 | S5 | 2080h | 2080h | CH |  |  | Rel-6 | Dionisio |  |  |
| 1558 | 453.7.2 | PS domain charging | 390d? | 2003-03-21 A | 2004-09-16 A | 100% | 2003-03-21 | 2004-09-16 | 390d? | start no earlier than 2003-03-21 | S5 | 3120h | 3120h | CH |  |  | Rel-6 | Dionisio |  |  |
| 1559 | 453.7.3 | CDR transfer | 390d? | 2003-03-21 A | 2004-09-16 A | 100% | 2003-03-21 | 2004-09-16 | 390d? | start no earlier than 2003-03-21 | S5 | 3120h | 3120h | CH |  |  | Rel-6 | Dionisio |  |  |
| 1560 | 453.8 | Charging Management for the IMS | 455d? | 2003-03-21 A | 2004-12-16 A | 100% | 2003-03-21 | 2004-12-16 | 455d? | finish no earlier than 2004-12-16 | S5 | 3640h | 3640h | IMS2-CH | Ericsson | Patrik TEPPO | Rel-6 | Dionisio |  |  |
| 1561 | 453.9 | Charging Management for the Service domain | 580d? | 2003-03-21 A | 2005-06-09 A | 100% | 2003-03-21 | 2005-06-09 | 580d? | finish no earlier than 2005-06-09 | S5 | 4640h | 4640h | CH | Siemens | Gerald GÖRMER | Rel-6 | Dionisio |  |  |
| 1562 | 453.10 | **Overall architectural aspects of IP flow based bearer level charging** | 602d? | 2002-11-21 A | 2005-03-11 A | 100% | 2002-11-21 | 2005-03-11 | 602d? |  | S2 | 12632h | 12632h | CH-FBC |  |  | Rel-6 | Maurice |  |  |
| 1563 | 453.10.1 | Overall definition of FBC architecture | 334d? | 2002-11-21 A | 2004-03-02 A | 100% | 2002-11-21 | 2004-03-02 | 334d? | start no earlier than 2002-11-21 | S2 | 2672h | 2672h | CH-FBC |  |  | Rel-6 | Maurice | SP-24 |  |
| 1564 | 453.10.2 | Study on providing policy control with FBC | 130d? | 2004-02-02 A | 2004-07-30 A | 100% | 2004-02-02 | 2004-07-30 | 130d? | start no earlier than 2004-02-01 | S2 | 1040h | 1040h | CH-FBC |  |  | Rel-6 | Maurice | SP-24 |  |
| 1565 | 453.10.3 | Gx interface for flow based charging | 223d? | 2004-02-02 A | 2004-12-08 A | 100% | 2004-02-02 | 2004-12-08 | 223d? | start no earlier than 2004-02-01 | N3 | 1784h | 1784h | CH-FBC | Nokia | juha.a.rasanen@nokia.com | Rel-6 | Gwiho | SP-25 |  |
| 1566 | 453.10.4 | Rx interface for flow based charging | 290d? | 2004-02-02 A | 2005-03-11 A | 100% | 2004-02-02 | 2005-03-11 | 290d? | finish no earlier than 2005-03-11 | N3 | 2320h | 2320h | CH-FBC | Nortel | Javier Gonzalez Gallego | Rel-6 | Gwiho | SP-25 |  |
| 1567 | 13 | **Rel-6 UICC/USIM enhancements and interworking** | 1164d? | 2000-09-25 A | 2005-03-10 A | 100% | 2000-09-25 | 2005-03-10 | 1164d? |  | T3 | 43088h | 43088h | USAT1 |  |  | Rel-6 | Xavier |  |  |
| 1568 | 13.1 | **UICC API** | 777d | 2002-03-20 A | 2005-03-10 A | 100% | 2002-03-20 | 2005-03-10 | 777d |  | T3 | 15024h | 15024h | USAT1-API |  |  | Rel-6 | Xavier |  |  |
| 1569 | 13.1.1 | Java API Test specification | 59d | 2002-03-20 A | 2002-06-10 A | 100% | 2002-03-20 | 2002-06-10 | 59d | finish no earlier than 2002-09-20 | T3 | 472h | 472h | USAT1-API | Microelectrónica Española | Mario Pérez | Rel-6 | Xavier |  |  |
| 1570 | 454.1.2 | 2G/3G Java Card™ API based applet interworking | 255d | 2003-03-17 A | 2004-03-05 A | 100% | 2003-03-17 | 2004-03-05 | 255d | finish no earlier than 2004-02-19 | T3 | 2040h | 2040h | USAT1-API | Oberthur Card Systems | Stéphane Andrau | Rel-6 | Xavier |  |  |
| 1571 | 454.1.3 | (U)SIM API for Java Card Testing | 519d | 2003-03-17 A | 2005-03-10 A | 100% | 2003-03-17 | 2005-03-10 | 519d | finish no earlier than 2005-03-10 | T3 | 4152h | 4152h | USAT1-API | Axalto | Christophe Begassat (cbegassat@axalto.com) | Rel-6 | Xavier |  |  |
| 1572 | 13.1.2 | Deleted - Java API Test specification (TS 43.019 Rel-5) | 268d | 2002-05-30 A | 2003-06-09 A | 100% | 2002-05-30 | 2003-06-09 | 268d | finish no earlier than 2003-09-17 | T3 | 2144h | 2144h | USAT1-API | Microelectrónica Española | Mario Pérez | Rel-6 | Xavier |  | TP-20 |
| 1573 | 454.2 | **Rel-6 USIM toolkit enhancements** | 1160d? | 2000-09-25 A | 2005-03-04 A | 100% | 2000-09-25 | 2005-03-04 | 1160d? |  | T3 | 21848h | 21848h | USAT1-API-MULTOS | Aspects Software | Neil Livingston | Rel-6 | Xavier |  |  |
| 1574 | 454.2.1 | **C SIM API** | 525d | 2000-09-25 A | 2002-09-27 A | 100% | 2000-09-25 | 2002-09-27 | 525d |  | T3 | 9960h | 9960h | USAT1-API-MULTOS | Aspects Software | Neil Livingston | Rel-6 | Xavier |  |  |
| 1575 | 454.2.1.1 | Specification | 525d | 2000-09-25 A | 2002-09-27 A | 100% | 2000-09-25 | 2002-09-27 | 525d | finish no earlier than 2002-09-27 | T3 | 4200h | 4200h | USAT1-API-MULTOS | Aspects Software | Neil Livingston | Rel-6 | Xavier |  |  |
| 1576 | 454.2.1.2 | Test specification | 195d | 2001-01-01 A | 2001-09-28 A | 100% | 2001-01-01 | 2001-09-28 | 195d | finish no earlier than 2001-09-28 | T3 | 1560h | 1560h | USAT1-API-MULTOS | Aspects Software | Neil Livingston | Rel-6 | Xavier |  |  |
| 1577 | 454.2.2 | USIM application toolkit Conformance Test Specification for Mobile Equipments | 326d? | 2003-12-05 A | 2005-03-04 A | 100% | 2003-12-05 | 2005-03-04 | 326d? | start no earlier than 2003-12-05 | T3 | 2608h | 2608h | USAT1-API-MULTOS | Gemplus | Eric.laffont@gemplus.com | Rel-6 | Xavier |  |  |
| 1578 | 455 | **Packet Switched Streaming Services Rel-6** | 798d? | 2002-11-18 A | 2005-12-07 A | 100% | 2002-11-18 | 2005-12-07 | 798d? |  | S4,S1 | 13304h | 13304h | PSSrel6 | Ericsson | olle.franceschi@ericsson.com | Rel-6 | Paolo |  |  |
| 1579 | 455.1 | Stage 1 | 86d? | 2002-11-18 A | 2003-03-17 A | 100% | 2002-11-18 | 2003-03-17 | 86d? | finish no earlier than 2003-03-17 | S1 | 688h | 688h | PSSrel6 | Ericsson |  | Rel-6 | Alain |  |  |
| 1580 | 455.2 | Stage 3 | 779d? | 2002-12-13 A | 2005-12-07 A | 100% | 2002-12-13 | 2005-12-07 | 779d? | finish no earlier than 2005-12-07 | S4 | 6232h | 6232h | PSSrel6-Stage3 | Ericsson | olle.franceschi@ericsson.com | Rel-6 | Paolo |  |  |
| 1581 | 456 | AMR-WB extension for high audio quality | 779d | 2002-12-13 A | 2005-12-07 A | 100% | 2002-12-13 | 2005-12-07 | 779d | finish no earlier than 2005-12-07 | S4 | 6232h | 6232h | AMRWB+ | Nokia | janne.m.vainio@nokia.com | Rel-6 | Paolo |  |  |
| 1582 | 457 | Codec Enhancements for Packet Switched Conversational Multimedia Applications | 198d? | 2004-03-16 A | 2004-12-16 A | 100% | 2004-03-16 | 2004-12-16 | 198d? | finish no earlier than 2004-12-16 | S4 | 1584h | 1584h | CEPSCM | Nokia | miska.hannuksela@nokia.com | Rel-6 | Paolo |  |  |
| 1583 | 458 | 3G-324M Improvements | 198d? | 2004-03-16 A | 2004-12-16 A | 100% | 2004-03-16 | 2004-12-16 | 198d? | finish no earlier than 2004-12-16 | S4 | 1584h | 1584h | 3G-324MI | Ericsson | bo.burman@ericsson.com | Rel-6 | Paolo |  |  |
| 1584 | 459 | Single Antenna Receiver Interference Cancellation (SAIC) | 420.92d? | 2002-11-15 A | 2004-06-25 A | 100% | 2002-11-15 | 2004-06-25 | 420.92d? | finish no earlier than 2004-08-27 | GP,G1 | 3367.36h | 3367.36h | SAIC | Cingular | Marc Grant | Rel-6 | Paolo |  |  |

Notes:
- 1556: SP#28 Target 09/2005 for WLAN Charging 32.252
- 1557: SP#23 03/2004 completed / Text3: 32.250
- 1558: SP#25 09/2004 completed / Text3: 32.251
- 1559: SP#25 09/2004 completed / Text3: 32.295
- 1560: SP#26 12/2004 completed / Text3: 32.260
- 1561: SP#26: Updated WID SP-040778 was SP-030050. Target completion 06/2005. Consisting of MMS-CH, LCS-CH, WLAN-CH, POC-CH, MBMS-CH / Text3: 32.252, 32.270, 32.271, 32.272
- 1562: - / Text3: 23.125
- 1563: -
- 1564: -
- 1565: - / Text3: 29.210
- 1566: - / Text3: 29.209
- 1567: -
- 1568: 8/3/2001: test spec is based on R99 core spec, so deleted from Workplan
- 1569: -
- 1570: -
- 1571: - / Text3: 31.213
- 1572: MOVED to Rel-5 WP
- 1573: -
- 1574: - / Text3: 31.101, 31.102, 31.103, 31.111, 31.113, new 31.115, 31.116
- 1575: -
- 1576: -
- 1577: - / Text3: 31.124
- 1578: -
- 1579: 2nd resp SA4 / Text3: 22.233
- 1580: TR tbc by Sept. 05 / Text3: 26.233, 26.234, 26.244, 26.245, 26.246, 26.401, 26.402, 26.403, 26.404, 26.405, 26.406, 26.410, 26.411, 26.412, 26.273, 26.290, 26.304, 26.412, 26.274, 26.936
- 1581: TR tbc by Sept. 05 / Text3: 26.290, 26.304, 26.273, 26.274, 26.412, 26.936
- 1582: - / Text3: 26.235, 26.236
- 1583: - / Text3: 26.111, 26.911
- 1584: - / Text3: 45.903

| ID | WBS | Task | Type | Duration | Start | Finish | Complete | Baseline start | Baseline finish | Baseline duration | Constraint | Resources | Work | Actual work | Text1 | Text3 | Text4 | Text5 | Text6 | Text8 | Text12 |
| --- | --- | --- | --- | --- | --- | --- | --- | --- | --- | --- | --- | --- | --- | --- | --- | --- | --- | --- | --- | --- | --- |
| 1585 | 460 | **Enhancement of dialled service for CAMEL** |  | 199d | 2003-03-28 A | 2003-12-31 A | 100% | 2003-03-28 | 2003-12-31 | 199d |  | S1,N2,N4 | 3184h | 3184h | EDCAMEL | 22.078 | Samsung | Craig Bishop | Rel-6 | Alain |  |
| 1586 | 460.1 | Stages 2 and 3 |  | 199d | 2003-03-28 A | 2003-12-31 A | 100% | 2003-03-28 | 2003-12-31 | 199d | finish no earlier than 2003-09-19 | N2,N4 | 1592h | 1592h | EDCAMEL | 23.008, 23.016, 23.018, 23.078, 29.002, 29.078 | Samsung | Richard Brook | Rel-6 | Kimmo |  |
| 1587 | 461 | Study on Bandwidth and resource savings in CS networks |  | 273d? | 2003-06-01 A | 2004-06-16 A | 100% | 2003-06-01 | 2004-06-16 | 273d? | finish no earlier than 2004-06-16 | S2 | 2184h | 2184h | BARS | 23.977 |  |  | Rel-6 | Maurice |  |
| 1588 | 462 | FS on (U)SIM Security Reuse by Peripheral Devices on Local Interfaces |  | 127d? | 2003-07-03 A | 2003-12-26 A | 100% | 2003-07-03 | 2003-12-26 | 127d? | finish no earlier than 2003-12-26 | S3 | 1016h | 1016h |  | 33.817 | Toshiba | Raziq Yaqub (ryaqub@tari.toshiba.com) | Rel-6 | Dionisio |  |
| 1589 | 463 | **Multiple TBF in A/Gb mode** |  | 736d? | 2002-04-05 A | 2005-01-28 A | 100% | 2002-04-05 | 2005-01-28 | 736d? |  | GP,G2 | 17600h | 17600h | MULTBF |  | Ericsson | gunnar.mildh@era.ericsson.se | Rel-6 | Paolo |  |
| 1590 | 463.1 | **Multiple TBF in A/Gb mode** |  | 366d? | 2002-04-05 A | 2003-08-29 A | 100% | 2002-04-05 | 2003-08-29 | 366d? |  | GP,G2 | 11712h | 11712h | MULTBF-Agbmode |  | Ericsson | gunnar.mildh@era.ericsson.se | Rel-6 | Paolo |  |
| 1591 | 463.1.1 | Multiple TBF Concept paper |  | 366d? | 2002-04-05 A | 2003-08-29 A | 100% | 2002-04-05 | 2003-08-29 | 366d? | finish no earlier than 2003-08-29 | GP,G2 | 2928h | 2928h | MULTBF-Agbmode |  |  |  | Rel-6 | Paolo |  |
| 1592 | 463.1.2 | Multiple TBF Stage 2 (43.064) CRs |  | 366d? | 2002-04-05 A | 2003-08-29 A | 100% | 2002-04-05 | 2003-08-29 | 366d? | finish no earlier than 2003-08-29 | GP,G2 | 2928h | 2928h | MULTBF-Agbmode |  |  |  | Rel-6 | Paolo |  |
| 1593 | 463.1.3 | Multiple TBF Stage 3 (44.060) CRs |  | 366d? | 2002-04-05 A | 2003-08-29 A | 100% | 2002-04-05 | 2003-08-29 | 366d? | finish no earlier than 2003-08-29 | GP,G2 | 2928h | 2928h | MULTBF-Agbmode |  |  |  | Rel-6 | Paolo |  |
| 1594 | 463.2 | Deleted - Multiple TBF in A/Gb mode – MS testing | milestone | 0d? | 2005-01-28 A | 2005-01-28 A | 100% | 2005-01-28 | 2005-01-28 | 0d? | start no earlier than 2005-01-28 | G3new |  |  | MULTBF-Testing |  | Ericsson | gunnar.mildh@era.ericsson.se | Rel-6 | Paolo | GP-27 |
| 1595 | 464 | **Alignment between the test-regimes for GERAN capable MS** |  | 526d? | 2003-08-29 A | 2005-09-02 A | 100% | 2003-08-29 | 2005-09-02 | 526d? |  | G3new | 4208h | 4208h | ALTERE |  | Ericsson | Toubassi | Rel-6 | Ingbert |  |
| 1596 | 464.1 | Determine the controversial test cases in the different test regimes and align them with 3GPP GERAN test specifications. Such test cases to be added to TS 51.010. |  | 526d? | 2003-08-29 A | 2005-09-02 A | 100% | 2003-08-29 | 2005-09-02 | 526d? | finish no earlier than 2005-09-02 | G3new | 4208h | 4208h | ALTERE-TC |  |  |  | Rel-6 | Ingbert |  |
| 1597 | 465 | Addition of U-TDOA in the CS domain |  | 111d? | 2003-11-21 A | 2004-04-23 A | 100% | 2003-11-21 | 2004-04-23 | 111d? | finish no earlier than 2004-04-23 | GP | 888h | 888h | UTDOACS |  | TruePosition | Bob Gross, Rhys Robinson (rlgross@trueposition.com) | Rel-6 | Paolo |  |
| 1598 | 466 | Addition of U-TDOA in the PS domain |  | 361d? | 2003-06-27 A | 2004-11-12 A | 100% | 2003-06-27 | 2004-11-12 | 361d? | finish no earlier than 2004-11-12 | GP | 2888h | 2888h | UTDOAPS |  | TruePosition | Bob Gross, Rhys Robinson (rlgross@trueposition.com) | Rel-6 | Paolo |  |
| 1599 | 467 | **Downlink Advanced Receiver Performance** |  | 466d? | 2003-11-21 A | 2005-09-02 A | 100% | 2003-11-21 | 2005-09-02 | 466d? |  | GP | 19160h | 19160h | DARP |  | Nokia | tommy.bysted@nokia.com | Rel-6 | Paolo |  |
| 1600 | 467.1 | DARP test scenarios |  | 201d? | 2003-11-21 A | 2004-08-27 A | 100% | 2003-11-21 | 2004-08-27 | 201d? | finish no earlier than 2004-08-27 | GP | 1608h | 1608h | DARP-TS |  | Nokia | tommy.bysted@nokia.com | Rel-6 | Paolo |  |
| 1601 | 467.2 | **DARP for GMSK modulated voice services** |  | 201d? | 2004-02-06 A | 2004-11-12 A | 100% | 2004-02-06 | 2004-11-12 | 201d? |  | GP | 4824h | 4824h | DARP-GMSK |  | Nokia | tommy.bysted@nokia.com | Rel-6 | Paolo |  |
| 1602 | 467.2.1 | Performance requirements in 45.005 |  | 201d? | 2004-02-06 A | 2004-11-12 A | 100% | 2004-02-06 | 2004-11-12 | 201d? | finish no earlier than 2004-11-12 | GP | 1608h | 1608h | DARP-GMSK-Perf |  |  |  | Rel-6 | Paolo |  |
| 1603 | 467.2.2 | Radio subsystem link control in 45.008 |  | 201d? | 2004-02-06 A | 2004-11-12 A | 100% | 2004-02-06 | 2004-11-12 | 201d? | finish no earlier than 2004-11-12 | GP | 1608h | 1608h | DARP-GMSK-LC |  |  |  | Rel-6 | Paolo |  |
| 1604 | 467.3 | **DARP for GPRS and EGPRS MCS1-MCS4** |  | 201d? | 2004-02-06 A | 2004-11-12 A | 100% | 2004-02-06 | 2004-11-12 | 201d? |  | GP | 4824h | 4824h | DARP-GPRSE |  | Nokia | tommy.bysted@nokia.com | Rel-6 | Paolo |  |
| 1605 | 467.3.1 | Performance requirements in 45.005 |  | 201d? | 2004-02-06 A | 2004-11-12 A | 100% | 2004-02-06 | 2004-11-12 | 201d? | finish no earlier than 2004-11-12 | GP | 1608h | 1608h | DARP-GPRSE-Perf |  |  |  | Rel-6 | Paolo |  |
| 1606 | 467.3.2 | Radio subsystem link control in 45.008 |  | 201d? | 2004-02-06 A | 2004-11-12 A | 100% | 2004-02-06 | 2004-11-12 | 201d? | finish no earlier than 2004-11-12 | GP | 1608h | 1608h | DARP-GPRSE-LC |  |  |  | Rel-6 | Paolo |  |
| 1607 | 467.4 | DARP Capability signalling |  | 256d? | 2003-11-21 A | 2004-11-12 A | 100% | 2003-11-21 | 2004-11-12 | 256d? | finish no earlier than 2004-11-12 | GP | 2048h | 2048h | DARP-CAPSIG |  | Nokia | tommy.bysted@nokia.com | Rel-6 | Paolo |  |
| 1608 | 467.5 | GERAN MS Conformance test for DARP |  | 266d? | 2004-08-27 A | 2005-09-02 A | 100% | 2004-08-27 | 2005-09-02 | 266d? | finish no earlier than 2005-06-24 | G3new | 2128h | 2128h | ARP-ConfTest |  | Nokia | tommy.bysted@nokia.com | Rel-6 | Ingbert |  |

Notes:
- 1585: -
- 1586: -
- 1587: -
- 1588: Approved TSG#20
- 1589: GP#17 Nov 2003 Moved from Rel-5 UID_50058 MULTBF (Only Multiple TBF Concept paper produced in Rel-5)
- 1590: -
- 1591: -
- 1592: -
- 1593: -
- 1594: -
- 1595: -
- 1596: -
- 1597: Completed, except for potential LMU performance specs
- 1598: -
- 1599: -
- 1600: -
- 1601: -
- 1602: -
- 1603: -
- 1604: -
- 1605: -
- 1606: -
- 1607: -
- 1608: -

| ID | WBS | Task | Type | Duration | Start | Finish | Complete | Baseline start | Baseline finish | Baseline duration | Constraint | Resources | Work | Actual work | Text1 | Text4 | Text5 | Text6 | Text8 | Text12 | Text3 | Text10 |
| --- | --- | --- | --- | --- | --- | --- | --- | --- | --- | --- | --- | --- | --- | --- | --- | --- | --- | --- | --- | --- | --- | --- |
| 1609 | 468 | **Reduction of PS service interruption in Dual Transfer Mode** |  | 416d? | 2003-11-21 A | 2005-06-24 A | 100% | 2003-11-21 | 2005-06-24 | 416d? |  | G2 | 8360h | 8360h | PSintDTM | Siemens | toby.proctor@roke.co.uk | Rel-6 | Gert |  |  |  |
| 1610 | 468.1 | Use case and requirement definition |  | 111d? | 2003-11-21 A | 2004-04-23 A | 100% | 2003-11-21 | 2004-04-23 | 111d? | finish no earlier than 2004-04-23 | G2 | 888h | 888h | PSintDTM-Req | Siemens | toby.proctor@roke.co.uk | Rel-6 | Gert |  |  |  |
| 1611 | 468.2 | Performance Study of Current Procedures |  | 111d? | 2003-11-21 A | 2004-04-23 A | 100% | 2003-11-21 | 2004-04-23 | 111d? | start no earlier than 2003-11-21 | G2 | 888h | 888h | PSintDTM-Perf | Siemens | toby.proctor@roke.co.uk | Rel-6 | Gert |  |  |  |
| 1612 | 468.3 | Reduction of service interruption times and packet loss during Dual Transfer Mode and mobility procedures |  | 146d? | 2004-04-23 A | 2004-11-12 A | 100% | 2004-04-23 | 2004-11-12 | 146d? | finish no earlier than 2004-11-12 | G2 | 1168h | 1168h | PSintDTM-Reduct | Siemens | toby.proctor@roke.co.uk | Rel-6 | Gert |  |  |  |
| 1613 | 468.4 | Deleted - MS Conformance testing - Reduction of PS service interruption in DTM |  | 261d? | 2004-06-25 A | 2005-06-24 A | 100% | 2004-06-25 | 2005-06-24 | 261d? | finish no earlier than 2005-06-24 | G3new | 2088h | 2088h | PSintDTM-ConfMS |  |  | Rel-6 | Ingbert | GP-25 |  |  |
| 1614 | 468.5 | Deleted - BTS Conformance testing - Reduction of PS service interruption in DTM | milestone | 0d? | 2005-06-24 A | 2005-06-24 A | 100% | 2005-06-24 | 2005-06-24 | 0d? | finish no earlier than 2005-06-24 | G3new |  |  | PSintDTM-ConfBTS |  |  | Rel-6 | Ingbert | GP-25 |  |  |
| 1615 | 469 | CAMEL prepay interworking with SCUDIF |  | 216.3d | 2003-12-08 A | 2004-10-05 A | 100% | 2003-12-08 | 2004-10-05 | 216.3d |  | N4,N3,S1 | 1730.4h | 1730.4h | SCCAMEL | Nokia | Keijo.Palviainen@Nokia.Com | Rel-6 | Kimmo |  | 22.078, 23.078, 29.078, 29.002, 23.172 |  |
| 1616 | 470 | **Circuit Switched Video and Voice Service Improvements** |  | 430d? | 2004-01-12 A | 2005-09-02 A | 100% | 2004-01-12 | 2005-09-02 | 430d? |  | S2,C1 | 9256h | 9256h | CS_VSS | Vodafone | John Watson | Rel-6 | Alain |  |  |  |
| 1617 | 470.1 | Deleted - Stage 1 - Requirements |  | 199d | 2004-01-12 A | 2004-10-14 A | 100% | 2004-01-12 | 2004-10-14 | 199d | finish no earlier than 2004-10-14 | S1 | 1592h | 1592h | CS_VSS | Vodafone | John Watson | Rel-6 | Alain | SP-26 | 22.101 |  |
| 1618 | 470.2 | Stage 2 Study on architecture alternatives |  | 244d? | 2004-01-12 A | 2004-12-16 A | 100% | 2004-01-12 | 2004-12-16 | 244d? | finish no earlier than 2004-08-13 | S2 | 1952h | 1952h | CS_VSS | Vodafone | Chris Pudney | Rel-6 | Maurice |  | 23.903 | SP-24 |
| 1619 | 470.3 | Deleted - Stage 2 description on Redial |  | 164d? | 2004-05-03 A | 2004-12-16 A | 100% | 2004-05-03 | 2004-12-16 | 164d? | finish no earlier than 2004-12-16 | S2 | 1312h | 1312h | CS_VSS | Vodafone | Chris Pudney | Rel-6 | Maurice | SP-26 |  | SP-24 |
| 1620 | 470.4 | Switching between voice and video call - Redial solution |  | 120d? | 2005-01-03 A | 2005-06-17 A | 100% | 2005-01-03 | 2005-06-17 | 120d? | start no earlier than 2005-01-03 | C1 | 960h | 960h | CS_VSS | Vodafone |  | Rel-6 | Frederic |  | 23.009, 24.008 |  |
| 1621 | 470.5 | Deleted - CS_VSS - GERAN2 Part | milestone | 0d | 2005-09-02 A | 2005-09-02 A | 100% | 2005-09-02 | 2005-09-02 | 0d | start no earlier than 2005-09-02 | G2 |  |  | CS_VSS | Vodafone |  | Rel-6 | Gert | GP-26 |  |  |
| 1622 | 470.6 | Deleted - CS_VSS - CN3 Part | milestone | 0d? | 2004-10-14 A | 2004-10-14 A | 100% | 2004-10-14 | 2004-10-14 | 0d? | start no earlier than 2004-10-14 | N3 |  |  | CS_VSS | Vodafone |  | Rel-6 | Gwiho | TP-26 |  |  |
| 1623 | 471 | Network Domain Security; MAP application layer security (NDS/MAPsec) |  | 127d? | 2004-07-06 A | 2004-12-29 A | 100% | 2004-07-06 | 2004-12-29 | 127d? | finish no earlier than 2003-12-26 | S3 | 1016h | 1016h | MAPSEC | Vodafone | Peter.Howard@vodafone.com | Rel-6 | Dionisio |  |  |  |
| 1624 | 472 | FS on Security for early IMS |  | 127d? | 2004-10-01 A | 2005-03-28 A | 100% | 2004-10-01 | 2005-03-28 | 127d? | finish no earlier than 2003-12-26 | S3 | 1016h | 1016h | SEC-IMS | Vodafone | Peter.Howard@vodafone.com | Rel-6 | Dionisio |  | 33.978 |  |
| 1625 | 473 | Reorganisation of CS Data Specifications |  | 14d? | 2004-11-19 A | 2004-12-08 A | 100% | 2004-11-19 | 2004-12-08 | 14d? | finish no earlier than 2004-12-24 | N3 | 112h | 112h | CS Data | Siemens | Thomas.Belling@nsn.com | Rel-6 | Gwiho |  | 23.910, 29.007, new 23.202 |  |
| 1626 | 474 | **Generic Access to A/Gb Interface (GAAI)** |  | 411d? | 2004-06-25 A | 2006-01-20 A | 100% | 2004-06-25 | 2006-01-20 | 411d? |  | GP | 9160h | 9160h | GAAI | Motorola |  | Rel-6 | Paolo |  |  |  |
| 1627 | 474.1 | FS on GAAI |  | 46d? | 2004-06-25 A | 2004-08-27 A | 100% | 2004-06-25 | 2004-08-27 | 46d? | finish no earlier than 2004-08-27 | GP | 368h | 368h | GAAG | Motorola |  | Rel-6 | Paolo |  | 43.901 |  |
| 1628 | 474.2 | GAAI – Stage 2 |  | 161d? | 2004-08-27 A | 2005-04-08 A | 100% | 2004-08-27 | 2005-04-08 | 161d? | finish no earlier than 2005-04-08 | GP | 1288h | 1288h | GAAI-Stage2 | Ericsson | jari.vikberg@ericsson.com | Rel-6 | Paolo |  | 43.318 |  |
| 1629 | 474.3 | GAAI – Stage 3 |  | 161d? | 2004-08-27 A | 2005-04-08 A | 100% | 2004-08-27 | 2005-04-08 | 161d? | finish no earlier than 2005-04-08 | GP | 1288h | 1288h | GAAI-Stage3 |  |  | Rel-6 | Paolo |  | 44.318 |  |
| 1630 | 474.4 | MS Conformance Test for GAAI |  | 366d? | 2004-08-27 A | 2006-01-20 A | 100% | 2004-08-27 | 2006-01-20 | 366d? | finish no earlier than 2006-01-20 | GP | 2928h | 2928h | GAAI-CT |  |  | Rel-6 | Ingbert |  |  |  |
| 1631 | 475 | **Support of PS Handover for GERAN A/Gb mode** |  | 473d? | 2003-11-03 A | 2005-08-24 A | 100% | 2003-11-03 | 2005-08-24 | 473d? |  | GP,G2 | 11352h | 11352h | SPSHAGB | Ericsson | gunnar.hedby@ericsson.com | Rel-6 | Paolo |  |  |  |
| 1632 | 475.1 | Stage 2 |  | 473d? | 2003-11-03 A | 2005-08-24 A | 100% | 2003-11-03 | 2005-08-24 | 473d? | finish no earlier than 2005-09-02 | GP,G2 | 3784h | 3784h | SPSHAGB-Stage2 | Ericsson | gunnar.hedby@ericsson.com | Rel-6 | Paolo |  | 43.129 |  |
| 1633 | 475.2 | PS handover |  | 473d? | 2003-11-03 A | 2005-08-24 A | 100% | 2003-11-03 | 2005-08-24 | 473d? | finish no earlier than 2005-09-02 | GP,G2 | 3784h | 3784h | SPSHAGB-PSHO | Ericsson | gunnar.hedby@ericsson.com | Rel-6 | Paolo |  |  |  |
| 1634 | 475.3 | Definition of radio resource management functionality |  | 473d? | 2003-11-03 A | 2005-08-24 A | 100% | 2003-11-03 | 2005-08-24 | 473d? | finish no earlier than 2005-09-02 | GP,G2 | 3784h | 3784h | SPSHAGB-RRM | Ericsson | gunnar.hedby@ericsson.com | Rel-6 | Paolo |  |  |  |

Notes:
- 1609: -
- 1610: -
- 1611: -
- 1612: -
- 1613: -
- 1614: -
- 1615: -
- 1616: -
- 1617: -
- 1618: -
- 1619: -
- 1620: -
- 1621: -
- 1622: -
- 1623: Approved TSG#24. Marked as closed 12/2008 (was marked 20% complete)
- 1624: SP#24 approved WID. SP#27 completed. SP#46 TR 33.978 withdrawn from Rel-8 onwards
- 1625: Created at TSG#27 as 100 % complete
- 1626: -
- 1627: Feasibility Study
- 1628: -
- 1629: -
- 1630: Marked as closed 12/2008 (was marked 90% complete)
- 1631: Replaces SCSAGB- Originally Started Nov 2003 as GP-030443
- 1632: Replaces SCSAGB-Stage2
- 1633: Replaces SCSAGB-PSH
- 1634: Replaces SCSAGB-RRM

| ID | WBS | Task | Type | Duration | Start | Finish | Complete | Baseline start | Baseline finish | Baseline duration | Total slack | Constraint | Resources | Work | Actual work | Text1 | Text6 | Text3 | Text8 | Text4 | Text5 | Text12 |
| --- | --- | --- | --- | --- | --- | --- | --- | --- | --- | --- | --- | --- | --- | --- | --- | --- | --- | --- | --- | --- | --- | --- |
| 1635 | 476 | **small Technical Enhancements and Improvements for Rel-6** |  | 503d? | 2006-06-02 A | 2008-05-06 A | 100% | 2006-06-02 | 2008-05-06 | 503d? |  |  | All | 4024h | 4024h | TEI6 | Rel-6 |  |  |  |  |  |
| 1636 | 476.1 | Small Technical Enhancements and Improvements for Rel-6 Conformance Testing |  | 503d? | 2006-06-02 A | 2008-05-06 A | 100% | 2006-06-02 | 2008-05-06 | 503d? |  | start no earlier than 2006-06-02 | R5,T1 | 4024h | 4024h | TEI6_Test | Rel-6 | 34.108,34.121-1/2,34.122,34.123-1/2/3 | Ingbert |  |  |  |
| 1637 | 477 | Deleted - Study of Feature Interactions Requirements | milestone | 0d? | 2004-10-01 A | 2004-10-01 A | 100% | 2004-10-01 | 2004-10-01 | 0d? |  | finish no earlier than 2004-10-01 | S1 |  |  | FINTER | Rel-6 |  | Alain |  |  |  |
| 1638 | 478 | Deleted - Enhancements of VGCS in public networks for communication of public authority officials |  | 7d? | 2005-08-24 A | 2005-09-02 A | 100% | 2005-08-24 | 2005-09-02 | 7d? |  | start no earlier than 2005-08-24 | GP,G2 | 56h | 56h | EVGCS | Rel-6 | 44.018, 44.068, 48.008 | Paolo | Siemens | kenneth.isaacs@roke.co.uk | GP-26 |
| 1639 | 479 | **Deleted - Support of Conversational Services in A/Gb mode via the PS domain** |  | 64d? | 2003-11-21 A | 2004-02-19 A | 100% | 2003-11-21 | 2004-02-19 | 64d? |  |  | GP | 512h | 512h | SCSAGB | Rel-6 |  | Paolo | Ericsson | David Bladsjö (david.bladsjo@ericsson.com) |  |
| 1640 | 479.1 | Deleted - Creation of a TR | milestone | 0d? | 2003-11-21 A | 2003-11-21 A | 100% | 2003-11-21 | 2003-11-21 | 0d? |  | start no earlier than 2003-11-21 | GP |  |  | SCSAGB-TR | Rel-6 |  | Paolo | Ericsson | David Bladsjö (david.bladsjo@ericsson.com) | GP-17 |
| 1641 | 479.2 | Deleted - Stage 2 | milestone | 0d? | 2003-11-21 A | 2003-11-21 A | 100% | 2003-11-21 | 2003-11-21 | 0d? |  | finish no earlier than 2003-11-21 | GP |  |  | SCSAGB-Stage2 | Rel-6 |  | Paolo | Ericsson | David Bladsjö (david.bladsjo@ericsson.com) | GP-17 |
| 1642 | 479.3 | Deleted - Radio Channel Support | milestone | 0d? | 2003-11-21 A | 2003-11-21 A | 100% | 2003-11-21 | 2003-11-21 | 0d? |  | finish no earlier than 2003-11-21 | GP |  |  | SCSAGB-RCS | Rel-6 |  | Paolo | Ericsson | David Bladsjö (david.bladsjo@ericsson.com) | GP-17 |
| 1643 | 479.4 | Deleted - Definition of radio resource management functionality | milestone | 0d? | 2003-11-21 A | 2003-11-21 A | 100% | 2003-11-21 | 2003-11-21 | 0d? |  | finish no earlier than 2003-11-21 | GP,G2 |  |  | SCSAGB-RRM | Rel-6 |  | Paolo | Ericsson | David Bladsjö (david.bladsjo@ericsson.com) | GP-17 |
| 1644 | 479.5 | Deleted - replaced by 50561 - PS Handover |  | 64d | 2003-11-21 A | 2004-02-19 A | 100% | 2003-11-21 | 2004-02-19 | 64d |  | start no earlier than 2003-11-21 | GP,GP, N1 | 512h | 512h | SCSAGB-PSH | Rel-6 |  | Paolo | Ericsson | David Bladsjö (david.bladsjo@ericsson.com) | GP-18 |
| 1645 | 479.6 | Deleted - Modifications to FLO | milestone | 0d? | 2003-11-21 A | 2003-11-21 A | 100% | 2003-11-21 | 2003-11-21 | 0d? |  | finish no earlier than 2003-11-21 | GP,G2 |  |  | SCSAGB-FLO | Rel-6 |  | Paolo | Ericsson | David Bladsjö (david.bladsjo@ericsson.com) | RP-29 |
| 1646 | 480 | Deleted - Rel-6 Evolutions of the transport in the UTRAN | milestone | 0d | 2003-12-31 A | 2003-12-31 A | 100% | 2003-12-31 | 2003-12-31 | 0d |  | start no earlier than 2003-12-31 | RP |  |  | ETRAN | Rel-6 |  | Issam | Alcatel | Francois Courau | RP-22 |
| 1647 | 481 | Release 5 Features |  | 1d? | 2000-01-03 | 2000-01-03 |  | 2000-01-03 | 2000-01-03 | 1d? | 3056d |  | NP,GP, RP,SP,TP | 8h |  |  | Rel-5 |  |  |  |  |  |
| 1648 | 75 | IP transport in the UTRAN |  | 445d | 2000-07-17 A | 2002-03-29 A | 100% | 2000-07-17 | 2002-03-29 | 445d |  | finish no earlier than 2002-03-29 | R3 | 3560h | 3560h | ETRAN-IPtrans | Rel-5 |  | Juha | Alcatel | Nicolas Drevon |  |
| 1649 | 76 | FS on Usage of SUA |  | 205d | 2001-03-12 A | 2001-12-21 A | 100% | 2001-03-12 | 2001-12-21 | 205d |  | finish no earlier than 2001-12-21 | N4 | 1640h | 1640h | SS7IP | Rel-5 |  | Kimmo |  |  |  |
| 1650 | 77 | **High Speed Downlink Packet Access** |  | 570d | 2001-04-02 A | 2003-06-06 A | 100% | 2001-04-02 | 2003-06-06 | 570d |  |  | R2 | 15272h | 15272h | HSDPA | Rel-5 |  | Joern | Motorola | Ravi Kuchibhotla |  |
| 1651 | 77.1 | Physical Layer |  | 257d | 2001-04-05 A | 2002-03-29 A | 100% | 2001-04-05 | 2002-03-29 | 257d |  | finish no earlier than 2002-03-29 | R1 | 2056h | 2056h | HSDPA-Phys | Rel-5 |  | Patrick | Motorola | Amitava Ghosh |  |
| 1652 | 77.2 | Layer 2 and 3 aspects |  | 257d | 2001-04-05 A | 2002-03-29 A | 100% | 2001-04-05 | 2002-03-29 | 257d |  | finish no earlier than 2002-03-29 | R2 | 2056h | 2056h | HSDPA-L23 | Rel-5 |  | Joern | Motorola | Ravi Kuchibhotla |  |
| 1653 | 77.3 | Iub/Iur protocol aspects |  | 260d | 2001-04-02 A | 2002-03-29 A | 100% | 2001-04-02 | 2002-03-29 | 260d |  | finish no earlier than 2002-03-29 | R3 | 2080h | 2080h | HSDPA-IubIur | Rel-5 |  | Juha | Motorola | Mike Diesen |  |
| 1654 | 77.4 | RF Radio Transmission/ Reception, System Performance Requirements and Conformance Testing |  | 565d | 2001-04-09 A | 2003-06-06 A | 100% | 2001-04-09 | 2003-06-06 | 565d |  | finish no earlier than 2003-06-06 | R4 | 4520h | 4520h | HSDPA-RF | Rel-5 |  | Issam | Motorola | Howard Benn |  |
| 1655 | 78 | **Rel-5 Improvements of Radio Interface** |  | 535d | 2000-08-14 A | 2002-08-30 A | 100% | 2000-08-14 | 2002-08-30 | 535d |  |  | RP | 30376h | 30376h | RInImp | Rel-5 |  |  |  |  |  |
| 1656 | 78.1 | **Base station classification** |  | 480d | 2000-08-14 A | 2002-06-14 A | 100% | 2000-08-14 | 2002-06-14 | 480d |  |  | R4 | 9208h | 9208h | RInImp-BSClass | Rel-5 |  | Issam | Nokia | antti.toskala@nokia.com |  |
| 1657 | 78.1.1 | TDD Base station classification |  | 410d | 2000-08-14 A | 2002-03-08 A | 100% | 2000-08-14 | 2002-03-08 | 410d |  | finish no earlier than 2002-03-08 | R4 | 3280h | 3280h | RInImp-BSClass-TDD | Rel-5 |  | Issam | Nokia | antti.toskala@nokia.com |  |
| 1658 | 78.1.2 | Base Station Classification for 1.28 Mcps TDD option |  | 261d | 2001-06-15 A | 2002-06-14 A | 100% | 2001-06-15 | 2002-06-14 | 261d |  | finish no earlier than 2002-06-14 | R4 | 2088h | 2088h | RInImp-BSClass-LCRTDD | Rel-5 |  | Issam | Siemens | Meik.Kottkamp@siemens.com |  |
| 1659 | 78.2 | Enhancement on the DSCH hard split mode |  | 271d | 2001-03-16 A | 2002-03-29 A | 100% | 2001-03-16 | 2002-03-29 | 271d |  | finish no earlier than 2002-03-29 | R1 | 2168h | 2168h | RInImp-DSCHhsp | Rel-5 |  | Patrick | Samsung | Jaeyoel KIM |  |
| 1660 | 78.3 | Hybrid ARQ II/III |  | 355d | 2000-08-21 A | 2001-12-28 A | 100% | 2000-08-21 | 2001-12-28 | 355d |  | finish no earlier than 2001-12-28 | R2 | 2840h | 2840h | RInImp-HARQ | Rel-5 |  | Joern | Siemens | A. Sitte | RP-14 |
| 1661 | 78.4 | FS on USTS |  | 355d | 2000-08-14 A | 2001-12-21 A | 100% | 2000-08-14 | 2001-12-21 | 355d |  | finish no earlier than 2001-12-21 | R1 | 2840h | 2840h | RInImp-USTS | Rel-5 |  | Patrick | SK Telecom | D. Kim |  |
| 1662 | 78.5 | FS on UE antenna efficiency test method performance requirements |  | 255d | 2000-09-25 A | 2001-09-14 A | 100% | 2000-09-25 | 2001-09-14 | 255d |  | finish no earlier than 2001-09-14 | R4 | 2040h | 2040h | RInImp-UEAnTM | Rel-5 |  | Issam | Allgon | O. Edvardsson |  |
| 1663 | 78.6 | FS on the re-introduction of the downlink SIR measurement |  | 200d | 2001-03-12 A | 2001-12-14 A | 100% | 2001-03-12 | 2001-12-14 | 200d |  | finish no earlier than 2001-12-14 | R4 | 1600h | 1600h | RInImp-SIR | Rel-5 |  | Issam | Ericsson | Torgny.Palenius@ericsson.com |  |
| 1664 | 78.7 | FS on mitigating the effect of CPICH interference at the UE |  | 255d | 2001-03-19 A | 2002-03-08 A | 100% | 2001-03-19 | 2002-03-08 | 255d |  | finish no earlier than 2002-03-08 | R4 | 2040h | 2040h | RInImp-CPICH_Intf | Rel-5 |  | Issam | Intel | shimon.moshavi@INTEL.COM |  |

Notes:
- 1635: "Joker" WI, to be used for a Rel 6 CR not related to any feature and with very limited impact on the system. Moved in from Stoyan/Testing WP
- 1636: "Joker" WI, to be used for small modifications applicable to Rel 4 conformance testing
- 1637: SP-23 - To be abandoned?
- 1638: GP#26 moved to Rel-7 as UID_11045 Enhancements of VGCS in public networks for communication of public authority officials
- 1639: -
- 1640: -
- 1641: Started
- 1642: Not started
- 1643: Not started
- 1644: Started
- 1645: Not started
- 1646: Generic feature
- 1647: -
- 1648: -
- 1649: -
- 1650: -
- 1651: -
- 1652: -
- 1653: -
- 1654: -
- 1655: -
- 1656: -
- 1657: -
- 1658: -
- 1659: -
- 1660: Stopped at RP#14; work on this task was performed as part of High Speed Downlink Packet Access feature
- 1661: -
- 1662: -
- 1663: -
- 1664: -

| ID | WBS | Task | Duration | Start | Finish | Complete | Baseline start | Baseline finish | Baseline duration | Constraint | Resources | Work | Actual work | Text6 | Text8 | Text12 | Text1 | Text4 | Text5 | Text3 |
| --- | --- | --- | --- | --- | --- | --- | --- | --- | --- | --- | --- | --- | --- | --- | --- | --- | --- | --- | --- | --- |
| 1665 | 78.8 | **Deleted - Conformance Test Spec. improvements in Radio Interface** | 140d | 2002-02-18 A | 2002-08-30 A | 100% | 2002-02-18 | 2002-08-30 | 140d |  | T1 | 3360h | 3360h | Rel-5 | Ingbert | TP-22 |  |  |  |  |
| 1666 | 78.8.1 | Deleted - Testing improvement of inter-frequency and inter-system measurement | 140d | 2002-02-18 A | 2002-08-30 A | 100% | 2002-02-18 | 2002-08-30 | 140d | finish no earlier than 2002-08-30 | T1 | 1120h | 1120h | Rel-5 | Ingbert | TP-22 |  |  |  |  |
| 1667 | 78.8.2 | Deleted - Testing Hybrid ARQ II/III | 140d | 2002-02-18 A | 2002-08-30 A | 100% | 2002-02-18 | 2002-08-30 | 140d | finish no earlier than 2002-08-30 | T1 | 1120h | 1120h | Rel-5 | Ingbert | TP-22 |  |  |  |  |
| 1668 | 79 | **Rel-5 RAN improvements** | 772d? | 2001-03-16 A | 2004-03-01 A | 100% | 2001-03-16 | 2004-03-01 | 772d? |  | RP | 39984h | 39984h | Rel-5 |  |  | RANimp |  |  |  |
| 1669 | 79.1 | **RRM optimization for Iur and Iub** | 318d | 2001-03-16 A | 2002-06-04 A | 100% | 2001-03-16 | 2002-06-04 | 318d |  | R3 | 8904h | 8904h | Rel-5 | Juha |  | RANimp-RRMopt | Ericsson | Gert-Jan.van.Lieshout@eln.ericsson.se |  |
| 1670 | 79.1.1 | Iur common transport channel efficiency optimization | 271d | 2001-03-16 A | 2002-03-29 A | 100% | 2001-03-16 | 2002-03-29 | 271d | finish no earlier than 2002-03-29 | R3 | 2168h | 2168h | Rel-5 | Juha |  | RANimp-RRMopt-ctc | Ericsson | Shahrokh Amirijoo |  |
| 1671 | 79.1.2 | Iur neighbouring cell reporting efficiency optimization | 271d | 2001-03-16 A | 2002-03-29 A | 100% | 2001-03-16 | 2002-03-29 | 271d | finish no earlier than 2002-03-29 | R3 | 2168h | 2168h | Rel-5 | Juha |  | RANimp-RRMopt-ncr | Ericsson | Shahrokh Amirijoo |  |
| 1672 | 79.1.3 | FS Introduction of direct transport bearers between SRNC and Node-B | 253d | 2001-06-15 A | 2002-06-04 A | 100% | 2001-06-15 | 2002-06-04 | 253d | finish no earlier than 2002-06-28 | R3 | 2024h | 2024h | Rel-5 | Juha |  | RAN-imp-RRMopt-DTB | Ericsson | Risto Sepponen |  |
| 1673 | 79.2 | RL Timing Adjustment | 271d | 2001-03-16 A | 2002-03-29 A | 100% | 2001-03-16 | 2002-03-29 | 271d | finish no earlier than 2002-03-29 | R3 | 2168h | 2168h | Rel-5 | Juha |  | RANimp-RLTA | Ericsson | Elena Voltolina |  |
| 1674 | 79.3 | Separation of resource reservation and radio link activation | 271d | 2001-03-16 A | 2002-03-29 A | 100% | 2001-03-16 | 2002-03-29 | 271d | finish no earlier than 2002-03-29 | R3 | 2168h | 2168h | Rel-5 | Juha |  | RANimp-SepRR | Ericsson | Gert-Jan.van.Lieshout@eln.ericsson.se |  |
| 1675 | 79.4 | FS SRNS Relocation Procedure Enhancement | 318d | 2001-06-15 A | 2002-09-03 A | 100% | 2001-06-15 | 2002-09-03 | 318d | finish no earlier than 2002-09-06 | R3 | 2544h | 2544h | Rel-5 | Juha |  | RANimp-SRNS | Nokia | Olivier Guyot |  |
| 1676 | 79.5 | FS Improvement of Radio Resource Management across RNS and RNS/PSS | 201d | 2001-03-16 A | 2001-12-21 A | 100% | 2001-03-16 | 2001-12-21 | 201d | finish no earlier than 2001-12-21 | R3 | 1608h | 1608h | Rel-5 | Juha |  | RANimp-ImpRRM | Nokia | antti.toskala@nokia.com |  |
| 1677 | 79.6 | Re-arrangements of Iub transport bearers | 271d | 2001-03-16 A | 2002-03-29 A | 100% | 2001-03-16 | 2002-03-29 | 271d | finish no earlier than 2002-03-29 | R3 | 2168h | 2168h | Rel-5 | Juha |  | RANimp-TTPS | Nokia | antti.toskala@nokia.com |  |
| 1678 | 79.7 | RAB support enhancement for Rel-5 | 325d | 2001-04-02 A | 2002-06-28 A | 100% | 2001-04-02 | 2002-06-28 | 325d | finish no earlier than 2002-06-28 | R2 | 2600h | 2600h | Rel-5 | Joern |  | RANimp-RABSE5 | Nokia | Juha Mikola |  |
| 1679 | 79.8 | Beamforming requirements for UE | 61d | 2001-09-21 A | 2001-12-14 A | 100% | 2001-09-21 | 2001-12-14 | 61d | finish no earlier than 2001-12-14 | R1 | 488h | 488h | Rel-5 | Patrick |  | RANimp-BFR-UE | Nokia | Jussi Kähtävä (juha.mikola@nokia.com) |  |
| 1680 | 79.9 | Support of Site Selection Diversity Transmission in UTRAN | 123d | 2001-12-14 A | 2002-06-04 A | 100% | 2001-12-14 | 2002-06-04 | 123d | finish no earlier than 2002-06-04 | R1 | 984h | 984h | Rel-5 | Patrick |  | RANimp-SSDT | NEC |  |  |
| 1681 | 79.10 | Node B Synchronisation for 1.28 Mcps TDD | 271d | 2001-03-16 A | 2002-03-29 A | 100% | 2001-03-16 | 2002-03-29 | 271d | finish no earlier than 2002-03-29 | R1 | 2168h | 2168h | Rel-5 | Patrick |  | RANimp-NBSLCR | CATT | Jinling HU |  |
| 1682 | 79.12 | **Deleted - Conformance Test Aspects - RAN Improvements** | 565d? | 2002-01-01 A | 2004-03-01 A | 100% | 2002-01-01 | 2004-03-01 | 565d? |  | T1 | 8008h | 8008h | Rel-5 | Ingbert |  |  |  |  | 0% |
| 1683 | 79.12.1 | Deleted - Testing Radio access bearer support enhancements | 175d | 2002-01-01 A | 2002-09-02 A | 100% | 2002-01-01 | 2002-09-02 | 175d | finish no earlier than 2002-09-02 | T1 | 1400h | 1400h | Rel-5 | Ingbert | TP-22 |  |  |  |  |
| 1684 | 486.11.2 | Deleted - General changes to TS34.121 and TS34.122 corresponding to release 5 | 261d? | 2003-03-03 A | 2004-03-01 A | 100% | 2003-03-03 | 2004-03-01 | 261d? | finish no earlier than 2004-03-01 | T1 | 2088h | 2088h | Rel-5 | Ingbert |  | RANimp-test |  |  | 34.108, 34.121, 34.122 |
| 1685 | 80 | UTRAN Sharing in Connected Mode | 197d | 2001-12-03 A | 2002-09-03 A | 100% | 2001-12-03 | 2002-09-03 | 197d | finish no earlier than 2002-09-06 | R3 | 1576h | 1576h | Rel-5 | Juha |  | NETSHARE | Ericsson | Martin Israelsson |  |
| 1686 | 81 | **Provisioning of IP-based multimedia services** | 1089d | 2000-01-03 A | 2004-03-03 A | 100% | 2000-01-03 | 2004-03-03 | 1089d |  | S1,S2,S5 | 187156h | 187156h | Rel-5 | Alain |  | IMS | Openwave | Mark Cataldo |  |
| 1687 | 81.1 | **Call control and roaming to support IMS in UMTS** | 641d | 2000-01-03 A | 2002-06-14 A | 100% | 2000-01-03 | 2002-06-14 | 641d |  | S2 | 82528h | 82528h | Rel-5 | Maurice |  | IMS-CCR | Lucent | Liz Daniel |  |
| 1688 | 81.1.1 | Stage 1 | 215d | 2000-02-21 A | 2000-12-15 A | 100% | 2000-02-21 | 2000-12-15 | 215d | finish no earlier than 2000-09-21 | S1 | 1720h | 1720h | Rel-5 | Alain |  | IMS-CCR | Motorola | Mark Cataldo | 22.228 |
| 1689 | 81.1.2 | Stage 2 (Architecture and Main flows) | 246d | 2000-04-14 A | 2001-03-23 A | 100% | 2000-04-14 | 2001-03-23 | 246d | finish no earlier than 2001-03-23 | S2 | 1968h | 1968h | Rel-5 | Maurice |  | IMS-CCR | Lucent | Liz Daniel | 23.228 |
| 1690 | 81.1.3 | Impact on MM/CC/SM | 400d | 2000-08-28 A | 2002-03-08 A | 100% | 2000-08-28 | 2002-03-08 | 400d | finish no earlier than 2002-03-08 | N1 | 3200h | 3200h | Rel-5 | Frederic |  | IMS-CCR-IWMM | Lucent | Keith Drage (drage@alcatel-lucent.com) |  |

Notes:
- 1665: Marked as stopped 12/2008
- 1666: start/finish dates set...Marked as stopped 12/2008
- 1667: start/finish dates set...Marked as stopped 12/2008
- 1668: -
- 1669: -
- 1670: -
- 1671: -
- 1672: FS was closed and introduction of WI not agreed at RAN #16
- 1673: -
- 1674: -
- 1675: -
- 1676: FS was closed and WI was introduced at RAN #14
- 1677: -
- 1678: RFC 3095 context relocation
- 1679: -
- 1680: RP-020356
- 1681: -
- 1682: Marked as stopped 12/2008
- 1683: duration set to 6 months (was 0)...Marked as stopped 12/2008
- 1684: Marked as stopped 12/2008
- 1685: Formerly 'Shared Network support in connected mode', renamed at RAN #16.
- 1686: S1 WI proposed S1-000290 / TR22.976, WI Rapporteur, Mark Cataldo, Motorola
- 1687: -
- 1688: Issues include e.g.: Roaming requirements, Requirements on supplementary services, Interworking requirements
- 1689: Issues include e.g.: Mobile IP, RAB selection principles, Optimized VoIP bearer mechanisms, SIP multimedia protocol
- 1690: Per 26/2-02: This is understood to be the PCO & TFT CRs which CN1 provides to TSGN #15 for approval. If this is correct understanding, then the task is 100 % complete.

| ID | WBS | Task | Duration | Start | Finish | Complete | Baseline start | Baseline finish | Baseline duration | Constraint | Resources | Work | Actual work | Text1 | Text3 | Text4 | Text5 | Text6 | Text8 |
| --- | --- | --- | --- | --- | --- | --- | --- | --- | --- | --- | --- | --- | --- | --- | --- | --- | --- | --- | --- |
| 1691 | 81.1.4 | **SIP Call Control protocol for the IMS** | 641d | 2000-01-03 A | 2002-06-14 A | 100% | 2000-01-03 | 2002-06-14 | 641d |  | N1 | 70808h | 70808h | IMS-CCR | 24.228, 24.229, 23.218 | Lucent | Keith Drage (drage@alcatel-lucent.com) | Rel-5 | Frederic |
| 1692 | 81.1.4.1 | IMS signalling flows | 385d | 2000-10-02 A | 2002-03-22 A | 100% | 2000-10-02 | 2002-03-22 | 385d | finish no earlier than 2002-03-22 | N1 | 3080h | 3080h | IMS-CCR | 24.228 |  |  | Rel-5 | Frederic |
| 1693 | 81.1.4.2 | IMS stage 3 | 385d | 2000-10-02 A | 2002-03-22 A | 100% | 2000-10-02 | 2002-03-22 | 385d | finish no earlier than 2002-03-22 | N1 | 3080h | 3080h | IMS-CCR | 24.229 |  |  | Rel-5 | Frederic |
| 1694 | 81.1.4.3 | IMS Session Handling; stage 2 | 385d | 2000-10-02 A | 2002-03-22 A | 100% | 2000-10-02 | 2002-03-22 | 385d | finish no earlier than 2002-03-22 | N1 | 3080h | 3080h | IMS-CCR | 23.218 |  |  | Rel-5 | Frederic |
| 1695 | 81.1.4.4 | **Main IETF dependencies** | 636d | 2000-01-03 A | 2002-06-07 A | 100% | 2000-01-03 | 2002-06-07 | 636d |  | NP | 45400h | 45400h | IMS |  |  |  | Rel-5 | Kimmo |
| 1696 | 81.1.4.4.1 | IETF: RFC 3261 (Session Initiation Protocol) | 346d | 2000-11-24 A | 2002-03-22 A | 100% | 2000-11-24 | 2002-03-22 | 346d | finish no earlier than 2002-03-22 | N1 | 2768h | 2768h | IMS |  |  |  | Rel-5 | Frederic |
| 1697 | 81.1.4.4.2 | IETF: RFC 3262 (Reliability of provisional responses) | 346d | 2000-11-24 A | 2002-03-22 A | 100% | 2000-11-24 | 2002-03-22 | 346d | finish no earlier than 2002-03-22 | N1 | 2768h | 2768h | IMS |  |  |  | Rel-5 | Frederic |
| 1698 | 81.1.4.4.3 | IETF: RFC 3312 (Without COMET)(Integration of resource management and SIP) | 382d | 2000-11-24 A | 2002-05-13 A | 100% | 2000-11-24 | 2002-05-13 | 382d | finish no earlier than 2002-05-13 | N1 | 3056h | 3056h | IMS |  |  |  | Rel-5 | Frederic |
| 1699 | 81.1.4.4.4 | IETF: RFC 3323 (SIP extensions for caller identity and privacy) | 382d | 2000-11-24 A | 2002-05-13 A | 100% | 2000-11-24 | 2002-05-13 | 382d | finish no earlier than 2002-05-13 | N1 | 3056h | 3056h | IMS |  |  |  | Rel-5 | Frederic |
| 1700 | 81.1.4.4.5 | IETF: RFC 3313 (SIP extensions for media authorization) | 382d | 2000-11-24 A | 2002-05-13 A | 100% | 2000-11-24 | 2002-05-13 | 382d | finish no earlier than 2002-05-13 | N1 | 3056h | 3056h | IMS |  |  |  | Rel-5 | Frederic |
| 1701 | 81.1.4.4.6 | IETF: RFC 3265 (specific event notification) | 346d | 2000-11-24 A | 2002-03-22 A | 100% | 2000-11-24 | 2002-03-22 | 346d | finish no earlier than 2002-03-22 | N1 | 2768h | 2768h | IMS |  |  |  | Rel-5 | Frederic |
| 1702 | 81.1.4.4.7 | IETF: RFC editor Queue (refer method) | 401d | 2000-11-24 A | 2002-06-07 A | 100% | 2000-11-24 | 2002-06-07 | 401d | finish no earlier than 2002-06-07 | N1 | 3208h | 3208h | IMS |  |  |  | Rel-5 | Frederic |
| 1703 | 81.1.4.4.8 | IETF: RFC editor Queue (DHCP options for SIP servers) | 382d | 2000-11-24 A | 2002-05-13 A | 100% | 2000-11-24 | 2002-05-13 | 382d | finish no earlier than 2002-05-13 | N1 | 3056h | 3056h | IMS |  |  |  | Rel-5 | Frederic |
| 1704 | 81.1.4.4.10 | IETF: RFC 3267 (AMR and AMR WB RTP and SDP) | 346d | 2000-11-24 A | 2002-03-22 A | 100% | 2000-11-24 | 2002-03-22 | 346d | finish no earlier than 2002-03-22 | N1 | 2768h | 2768h | IMS |  |  |  | Rel-5 | Frederic |
| 1705 | 81.1.4.4.11 | IETF: RFC 3266 (IPv6 support within SDP) | 581d | 2000-01-03 A | 2002-03-22 A | 100% | 2000-01-03 | 2002-03-22 | 581d | finish no earlier than 2002-03-22 | N1 | 4640h | 4640h | IMS |  |  |  | Rel-5 | Frederic |
| 1706 | 81.1.4.4.12 | IETF: RFC 3311 (The Update method) | 382d | 2000-11-24 A | 2002-05-13 A | 100% | 2000-11-24 | 2002-05-13 | 382d | finish no earlier than 2002-05-13 | N1 | 3056h | 3056h | IMS |  |  |  | Rel-5 | Frederic |
| 1707 | 81.1.4.4.13 | IETF: RFC 3324 (Network Asserted Identity) | 382d | 2000-11-24 A | 2002-05-13 A | 100% | 2000-11-24 | 2002-05-13 | 382d | finish no earlier than 2002-05-13 | N1 | 3056h | 3056h | IMS |  |  |  | Rel-5 | Frederic |
| 1708 | 81.1.4.4.14 | IETF: RFC editor Queue (Various 3GPP Private Extensions) | 382d | 2000-11-24 A | 2002-05-13 A | 100% | 2000-11-24 | 2002-05-13 | 382d | finish no earlier than 2002-05-13 | N1 | 3056h | 3056h | IMS |  |  |  | Rel-5 | Frederic |
| 1709 | 81.1.4.5 | **Addressing** | 380d | 2000-10-09 A | 2002-03-22 A | 100% | 2000-10-09 | 2002-03-22 | 380d |  | S2 | 7744h | 7744h | IMS |  |  |  | Rel-5 | Maurice |
| 1710 | 81.1.4.5.1 | Architectural issues | 235d | 2000-10-09 A | 2001-08-31 A | 100% | 2000-10-09 | 2001-08-31 | 235d | finish no earlier than 2001-03-16 | S2 | 1880h | 1880h | IMS |  |  |  | Rel-5 | Maurice |
| 1711 | 81.1.4.5.2 | Impact on HSS | 353d | 2000-11-15 A | 2002-03-22 A | 100% | 2000-11-15 | 2002-03-22 | 353d | finish no earlier than 2002-03-22 | N4 | 2824h | 2824h | IMS |  |  |  | Rel-5 | Kimmo |
| 1712 | 81.1.4.6 | **Service Examples (Work stopped)** | 304d | 2001-04-17 A | 2002-06-14 A | 100% | 2001-04-17 | 2002-06-14 | 304d |  | S1 | 4864h | 4864h | IMS-Sex | 22.928 | Motorola | Mark Cataldo | Rel-5 | Alain |
| 1713 | 81.1.4.6.1 | IMS Framework Report (work stopped) | 304d | 2001-04-17 A | 2002-06-14 A | 100% | 2001-04-17 | 2002-06-14 | 304d | finish no earlier than 2002-06-14 | S1 | 2432h | 2432h | IMS-FrWk | 22.941 | SBC | Randolph Wohlert (rwohlert@tri.sbc.com) | Rel-5 | Alain |
| 1714 | 81.2 | **Access Security for IMS** | 190d | 2001-10-08 A | 2002-06-28 A | 100% | 2001-10-08 | 2002-06-28 | 190d |  | S3 | 4120h | 4120h | IMS-ASEC |  | Ericsson | krister.boman@emw.ericsson.se | Rel-5 | Dionisio |
| 1715 | 81.2.2 | IMS impacts on UICC (ISIM application) | 185d | 2001-10-08 A | 2002-06-21 A | 100% | 2001-10-08 | 2002-06-21 | 185d | finish no earlier than 2002-06-21 | T3 | 1480h | 1480h |  |  | Vodafone | Jeremy Norris | Rel-5 |  |
| 1716 | 81.2.3 | SIP extensions for Integrity protection | 140d | 2001-12-17 A | 2002-06-28 A | 100% | 2001-12-17 | 2002-06-28 | 140d | finish no earlier than 2002-06-28 | N1 | 1120h | 1120h |  |  |  |  | Rel-5 | Frederic |
| 1717 | 81.3 | Security Aspects of Requirement for Network Configuration Independence | 130d | 2001-07-02 A | 2001-12-28 A | 100% | 2001-07-02 | 2001-12-28 | 130d | finish no earlier than 2001-12-28 | S3 | 1040h | 1040h | SEC1-NCI |  | AT&T Wireless | hugh.shieh@attws.com | Rel-5 | Dionisio |
| 1718 | 81.4 | Lawful interception | 410d | 2000-09-04 A | 2002-03-29 A | 100% | 2000-09-04 | 2002-03-29 | 410d | finish no earlier than 2002-03-29 | S3 | 3280h | 3280h | IMS-LI |  | Reg TP | berthold.wilhelm@regtp.de | Rel-5 | Dionisio |
| 1719 | 81.5 | Charging and OAM&P for IMS | 383d | 2000-12-25 A | 2002-06-12 A | 100% | 2000-12-25 | 2002-06-12 | 383d | finish no earlier than 2002-06-12 | S5 | 3064h | 3064h | IMS-OAM | 32-series | VoiceStream, Motorola |  | Rel-5 | Dionisio |

Notes:
- 1691: TSGN_10 approved the change:CN1 - SA2 SIP joint meeting spotted one more place for improvement: work tasks with ID 1998 and 1278 are actually subtasks under of single CN1 WT. One WI has been approved for the CN1 WT with title "SIP Call Control protocol
- 1692: 24.228
- 1693: 24.229
- 1694: 23.218
- 1695: -
- 1696: -
- 1697: -
- 1698: -
- 1699: -
- 1700: -
- 1701: -
- 1702: -
- 1703: -
- 1704: -
- 1705: -
- 1706: -
- 1707: -
- 1708: -
- 1709: -
- 1710: -
- 1711: Covered by 29.228 & 29228
- 1712: -
- 1713: -
- 1714: TS33.203 will be presented for info at SP#14 and is scheduled for approval at SP#15. Dependencies on IETF exist. Approved SP#15
- 1715: -
- 1716: Per 26/2-02: CN1 is not aware of any requirements and is not doing anything on this task.
- 1717: Incorporated into IMS access security TS (33.203) which will be presented for info at SP#14 and is scheduled for approval at SP#15.Editors notes removed SP#16&17
- 1718: Rel-5 33.106 and 33.107 approved at SP#12.Revised WID including new Rel-5 specification (33.108) scheduled for approval at SP#14. 33.108 approved SP#16. CR at SP#17
- 1719: -

| ID | WBS | Task | Duration | Start | Finish | Complete | Baseline start | Baseline finish | Baseline duration | Constraint | Resources | Work | Actual work | Text1 | Text3 | Text4 | Text5 | Text6 | Text8 |
| --- | --- | --- | --- | --- | --- | --- | --- | --- | --- | --- | --- | --- | --- | --- | --- | --- | --- | --- | --- |
| 1720 | 81.6 | **Multimedia codecs and protocols for conversational PS services** | 568d | 2000-07-26 A | 2002-09-27 A | 100% | 2000-07-26 | 2002-09-27 | 568d |  | S4 | 15640h | 15640h | IMS-CODEC | 26.235, 26.236 | Toshiba, Nokia | B. Aronson (Toshiba), pasi.s.ojala@nokia.com | Rel-5 | Paolo |
| 1721 | 81.6.1 | Codecs | 427d | 2000-07-26 A | 2002-03-14 A | 100% | 2000-07-26 | 2002-03-14 | 427d | finish no earlier than 2001-03-21 | S4 | 3416h | 3416h |  | 26.235, 26.236 |  |  | Rel-5 | Paolo |
| 1722 | 81.6.2 | Transport protocols | 1d | 2002-03-12 A | 2002-03-12 A | 100% | 2002-03-12 | 2002-03-12 | 1d | finish no earlier than 2002-03-12 | S4 | 8h | 8h | IMS-CODEC | 26.236 | Nokia | P. Ojala | Rel-5 | Paolo |
| 1723 | 81.6.4 | recommendation for QoS parameter values for various media types | 195d | 2001-12-31 A | 2002-09-27 A | 100% | 2001-12-31 | 2002-09-27 | 195d | finish no earlier than 2002-09-27 | S4 | 1560h | 1560h |  |  |  |  | Rel-5 | Paolo |
| 1724 | 81.6.5 | IETF: RFC 3310 (HTTP Digest Authentication using AKA) | 382d | 2000-11-24 A | 2002-05-13 A | 100% | 2000-11-24 | 2002-05-13 | 382d | finish no earlier than 2002-05-13 | N1 | 3056h | 3056h |  |  |  |  | Rel-5 | Frederic |
| 1725 | 81.6.6 | IETF: RFC 3329 (Security mechanism agreement for SIP connections) | 382d | 2000-11-24 A | 2002-05-13 A | 100% | 2000-11-24 | 2002-05-13 | 382d | finish no earlier than 2002-05-13 | N1 | 3056h | 3056h |  |  |  |  | Rel-5 | Frederic |
| 1726 | 81.7 | **SIP message compression** | 185d | 2001-09-24 A | 2002-06-07 A | 100% | 2001-09-24 | 2002-06-07 | 185d |  | S2 | 3128h | 3128h |  |  |  |  | Rel-5 | Maurice |
| 1727 | 81.7.1 | Stage 2 | 25d | 2001-09-24 A | 2001-10-26 A | 100% | 2001-09-24 | 2001-10-26 | 25d | finish no earlier than 2001-10-26 | S2 | 200h | 200h |  |  |  |  | Rel-5 | Maurice |
| 1728 | 81.7.2 | Compression signalling | 181d | 2001-09-28 A | 2002-06-07 A | 100% | 2001-09-28 | 2002-06-07 | 181d | finish no earlier than 2002-06-07 | N1 | 1448h | 1448h |  |  |  |  | Rel-5 | Frederic |
| 1729 | 81.8 | **Stage 3 description of IMS interfaces** | 383d | 2001-03-14 A | 2002-08-30 A | 100% | 2001-03-14 | 2002-08-30 | 383d |  | NP | 29531.6h | 29531.6h |  |  |  |  | Rel-5 | Kimmo |
| 1730 | 81.8.1 | Cx interface (HSS to CSCF) | 135.95d | 2001-03-14 A | 2002-06-07 A | 100% | 2001-03-14 | 2002-06-07 | 135.95d | finish no earlier than 2002-06-07 | N4 | 1087.58h | 1087.58h |  |  |  |  | Rel-5 | Kimmo |
| 1731 | 81.8.2 | Mp interface (MRFC - MRFP) enhancements | 258d | 2001-03-14 A | 2002-03-08 A | 100% | 2001-03-14 | 2002-03-08 | 258d | finish no earlier than 2002-06-07 | N4 | 2064h | 2064h |  |  |  |  | Rel-5 | Kimmo |
| 1732 | 81.8.3 | Mw interface (CSCF to P-CSCF) | 323d | 2001-03-14 A | 2002-06-07 A | 100% | 2001-03-14 | 2002-06-07 | 323d | finish no earlier than 2002-06-07 | N1 | 2584h | 2584h |  |  |  |  | Rel-5 | Frederic |
| 1733 | 81.8.4 | Mr interface (CSCF to MRF) | 273d | 2001-03-14 A | 2002-03-29 A | 100% | 2001-03-14 | 2002-03-29 | 273d | finish no earlier than 2002-03-29 | N1 | 2184h | 2184h |  |  |  |  | Rel-5 | Frederic |
| 1734 | 81.8.5 | Dx interface (I-CSCF to SLF) | 323d | 2001-03-14 A | 2002-06-07 A | 100% | 2001-03-14 | 2002-06-07 | 323d | finish no earlier than 2002-06-07 | N4 | 2584h | 2584h |  |  |  |  | Rel-5 | Kimmo |
| 1735 | 81.8.6 | Go interface (GGSN to PCF) | 323d | 2001-03-14 A | 2002-06-07 A | 100% | 2001-03-14 | 2002-06-07 | 323d | finish no earlier than 2002-06-07 | N3 | 2584h | 2584h |  |  |  |  | Rel-5 | Gwiho |
| 1736 | 81.8.7 | ISC (IMS Service Control) Interface | 323d | 2001-03-14 A | 2002-06-07 A | 100% | 2001-03-14 | 2002-06-07 | 323d | finish no earlier than 2002-06-07 | N1 | 2584h | 2584h |  |  |  |  | Rel-5 | Frederic |
| 1737 | 81.8.8 | Sh interface (HSS to AS) | 82d | 2002-02-14 A | 2002-06-07 A | 100% | 2002-02-14 | 2002-06-07 | 82d | finish no earlier than 2002-06-07 | N4 | 656h | 656h |  |  |  |  | Rel-5 | Kimmo |
| 1738 | 81.8.9 | Si interface (HSS to IM-SSF) | 162.5d | 2002-01-16 A | 2002-08-30 A | 100% | 2002-01-16 | 2002-08-30 | 162.5d | finish no earlier than 2002-06-07 | N4 | 1300h | 1300h |  |  |  |  | Rel-5 | Kimmo |
| 1739 | 81.8.10 | Gm interface (UE to CSCF) | 323d | 2001-03-14 A | 2002-06-07 A | 100% | 2001-03-14 | 2002-06-07 | 323d | finish no earlier than 2002-06-07 | N1 | 2584h | 2584h |  |  |  |  | Rel-5 | Frederic |
| 1740 | 81.8.11 | Mi interface (CSCF to BGCF) | 323d | 2001-03-14 A | 2002-06-07 A | 100% | 2001-03-14 | 2002-06-07 | 323d | finish no earlier than 2002-06-07 | N1 | 2584h | 2584h |  |  |  |  | Rel-5 | Frederic |
| 1741 | 81.8.12 | Mj interface (BGCF to MGCF) | 323d | 2001-03-14 A | 2002-06-07 A | 100% | 2001-03-14 | 2002-06-07 | 323d | finish no earlier than 2002-06-07 | N1 | 2584h | 2584h |  |  |  |  | Rel-5 | Frederic |
| 1742 | 81.8.13 | Mk interface (BGCF to BGCF) | 323d | 2001-03-14 A | 2002-06-07 A | 100% | 2001-03-14 | 2002-06-07 | 323d | finish no earlier than 2002-06-07 | N1 | 2584h | 2584h |  |  |  |  | Rel-5 | Frederic |
| 1743 | 81.9 | Support of VHE/OSA by entities and protocols of the IMS (e.g. CSCF) | 186d | 2001-09-21 A | 2002-06-07 A | 100% | 2001-09-21 | 2002-06-07 | 186d | finish no earlier than 2002-06-07 | N5 | 1488h | 1488h | IMS-ONOSA | 29.198, 29.998 | Ericsson | Ard.Jan.Moerdijk@eln.ericsson.se | Rel-5 | Kimmo |

Notes:
- 1720: -
- 1721: -
- 1722: -
- 1723: -
- 1724: -
- 1725: -
- 1726: -
- 1727: -
- 1728: -
- 1729: -
- 1730: -
- 1731: [DAB 08-03-02] - No work required in CN4
- 1732: -
- 1733: -
- 1734: CN4#11 30/11/01: No inputs received in CN4 / 14/02/02 Completed(introduced in 29.228)
- 1735: [DAB - 23/05/03] - 100 % complete
- 1736: -
- 1737: CN4#11 30/11/01: No inputs received in CN4 / CN4#12bis 14/02/02: WID approved / 17th May 100% complete. 3GPP TS 29.329 will be sent for approval in CN#16
- 1738: SA16: Part of Rel5 only if completed in September 02. Marked as closed 12/2008 (was marked 72% complete)
- 1739: -
- 1740: -
- 1741: -
- 1742: -
- 1743: -

| ID | WBS | Task | Duration | Start | Finish | Predecessors | Complete | Baseline start | Baseline finish | Baseline duration | Constraint | Resources | Work | Actual work | Text1 | Text4 | Text5 | Text6 | Text8 | Text12 | Text3 |
| --- | --- | --- | --- | --- | --- | --- | --- | --- | --- | --- | --- | --- | --- | --- | --- | --- | --- | --- | --- | --- | --- |
| 1744 | 81.10 | **CAMEL control of IMS services** | 365d | 2001-04-16 A | 2002-09-06 A |  | 100% | 2001-04-16 | 2002-09-06 | 365d |  | N2 | 9952h | 9952h | IMS-CAMEL | Lucent | Angelica Remoquillo | Rel-5 | Kimmo |  |  |
| 1745 | 81.10.1 | Stage2 work 'general' | 365d | 2001-04-16 A | 2002-09-06 A |  | 100% | 2001-04-16 | 2002-09-06 | 365d | finish no earlier than 2002-09-06 | N2 | 2920h | 2920h |  |  |  | Rel-5 | Kimmo |  |  |
| 1746 | 81.10.2 | Stage3 work 'CAP' | 175d | 2002-01-07 A | 2002-09-06 A |  | 100% | 2002-01-07 | 2002-09-06 | 175d | finish no earlier than 2002-09-06 | N2 | 1400h | 1400h |  |  |  | Rel-5 | Kimmo |  |  |
| 1747 | 81.10.3 | Stage2 work 'Si interface' | 175d | 2002-01-07 A | 2002-09-06 A |  | 100% | 2002-01-07 | 2002-09-06 | 175d | finish no earlier than 2002-09-06 | N2 | 1400h | 1400h |  |  |  | Rel-5 | Kimmo |  |  |
| 1748 | 81.10.4 | Stage3 work 'Si interface' | 82d | 2002-02-14 A | 2002-06-07 A |  | 100% | 2002-02-14 | 2002-06-07 | 82d | finish no earlier than 2002-06-07 | N4 | 656h | 656h |  |  |  | Rel-5 | Kimmo |  |  |
| 1749 | 81.10.5 | Deleted - SDM issues for CAMEL control of IMS | 82d | 2002-02-14 A | 2002-06-07 A |  | 100% | 2002-02-14 | 2002-06-07 | 82d | finish no earlier than 2002-06-07 | N4 | 656h | 656h |  |  |  | Rel-5 | Kimmo | NP-21 |  |
| 1750 | 81.11 | Pre-pay/real-time charging in IMS | 196d | 2001-06-15 A | 2002-03-15 A |  | 100% | 2001-06-15 | 2002-03-15 | 196d | finish no earlier than 2002-03-15 | S1 | 1568h | 1568h |  |  |  | Rel-5 | Alain |  |  |
| 1751 | 81.12 | **Charging** | 289d | 2001-08-06 A | 2002-09-12 A |  | 100% | 2001-08-06 | 2002-09-12 | 289d |  | S2,S5 | 6632h | 6632h | OAM-CH | T-Mobile | karl-heinz.nenner@t-mobile.de | Rel-5 | Dionisio |  | 32.225 |
| 1752 | 81.12.1 | Charging Implications of IMS architecture | 75d | 2001-08-06 A | 2001-11-16 A |  | 100% | 2001-08-06 | 2001-11-16 | 75d | finish no earlier than 2001-11-16 | S2 | 600h | 600h |  |  |  | Rel-5 | Maurice |  |  |
| 1753 | 81.12.2 | Charging management for IMS (off-line & on-line) | 214d | 2001-11-19 A | 2002-09-12 A | 1752 | 100% | 2001-11-19 | 2002-09-12 | 214d | finish no earlier than 2002-09-12 | S5 | 1712h | 1712h | OAM-CH |  |  | Rel-5 | Dionisio |  | 32.225 |
| 1754 | 86.1.6.10 | Billing, accounting and call detail record aspects | 251d | 2001-09-27 A | 2002-09-12 A |  | 100% | 2001-09-27 | 2002-09-12 | 251d | finish no earlier than 2002-09-12 | S5 | 2008h | 2008h | OAM-CH | T-Mobile | Karl-Heinz.Nenner@T-MOBILE.DE | Rel-5 | Dionisio |  | 32.225 |
| 1755 | 81.13 | **Other IETF dependencies** | 401d | 2000-11-24 A | 2002-06-07 A |  | 100% | 2000-11-24 | 2002-06-07 | 401d |  | NP | 9624h | 9624h |  |  |  | Rel-5 |  |  |  |
| 1756 | 81.13.1 | IETF: draft-ietf-aaa-diameter - should be CN4 | 401d | 2000-11-24 A | 2002-06-07 A |  | 100% | 2000-11-24 | 2002-06-07 | 401d | finish no earlier than 2002-06-07 | NP | 3208h | 3208h |  |  |  | Rel-5 |  |  |  |
| 1757 | 81.13.2 | IETF: draft-johansson-aaa-diameter-mm-app - should be CN4 | 401d | 2000-11-24 A | 2002-06-07 A |  | 100% | 2000-11-24 | 2002-06-07 | 401d | finish no earlier than 2002-06-07 | NP | 3208h | 3208h |  |  |  | Rel-5 |  |  |  |
| 1758 | 81.15 | Conformance Test Aspects - Provisioning of IMS | 205d | 2002-03-18 A | 2002-12-27 A |  | 100% | 2002-03-18 | 2002-12-27 | 205d | finish no earlier than 2002-12-27 | T1 | 1640h | 1640h | IMS-TEST |  |  | Rel-5 | Ingbert |  |  |
| 1759 | 81.16 | Testing of support for IMS - prose | 270d | 2002-09-18 A | 2003-09-30 A |  | 100% | 2002-09-18 | 2003-09-30 | 270d | finish no earlier than 2003-09-30 | T1 | 2160h | 2160h |  | Anritsu | dan.fox@eu.anritsu.com | Rel-5 | Ingbert |  | 34.108, 34.123 |
| 1760 | 81.17 | Testing of support for IMS - TTCN | 381d | 2002-09-18 A | 2004-03-03 A |  | 100% | 2002-09-18 | 2004-03-03 | 381d | finish no earlier than 2004-03-03 | T1 | 3048h | 3048h |  | Anritsu | dan.fox@eu.anritsu.com | Rel-5 | Ingbert |  | 34.108, 34.123 |
| 1761 | 82 | **Extended Transparent End-to-End PS Streaming Service** | 313d? | 2002-01-03 A | 2003-03-17 A |  | 100% | 2002-01-03 | 2003-03-17 | 313d? |  | S4 | 6224h | 6224h | PSS-E | Ericsson | olle.franceschi@ericsson.com | Rel-5 | Paolo |  | 26.233, 26.234 |
| 1762 | 82.1 | **Stage 1** | 86d? | 2002-11-18 A | 2003-03-17 A |  | 100% | 2002-11-18 | 2003-03-17 | 86d? |  | S1 | 1376h | 1376h |  | Vodafone | stephen.wolak@vodafone.com | Rel-5 | Alain |  | 22.233 |
| 1763 | 489.1.1 | Interaction with other services | 86d? | 2002-11-18 A | 2003-03-17 A |  | 100% | 2002-11-18 | 2003-03-17 | 86d? | finish no earlier than 2003-03-17 | S1 | 688h | 688h |  | Vodafone | stephen.wolak@vodafone.com | Rel-5 | Alain |  | 22.233 |
| 1764 | 82.2 | Stage 2 (version Rel5 of TS 26.234) | 51d | 2002-01-03 A | 2002-03-14 A |  | 100% | 2002-01-03 | 2002-03-14 | 51d | finish no earlier than 2002-03-26 | S4 | 408h | 408h |  |  |  | Rel-5 | Paolo |  | 26.234 |
| 1765 | 82.3 | RTP usage model | 242d | 2002-01-03 A | 2002-12-06 A |  | 100% | 2002-01-03 | 2002-12-06 | 242d | finish no earlier than 2002-12-06 | S4 | 1936h | 1936h |  |  |  | Rel-5 | Paolo |  | 26.937 |
| 1766 | 83 | **Rel-5 OSA enhancements** | 955d | 1999-04-27 A | 2002-12-20 A |  | 100% | 1999-04-27 | 2002-12-20 | 955d |  | S1 | 62480h | 62480h | OSA1 | Siemens | Joerg Swetina (joerg.swetina@nw.neclab.eu) | Rel-5 | Alain |  | 22.127, 23.127, 29.198-x, 29.998-x |
| 1767 | 83.1 | General Stage 2 for Rel5 | 194d | 2001-09-11 A | 2002-06-07 A |  | 100% | 2001-09-11 | 2002-06-07 | 194d |  | S2 | 1232h | 1232h |  |  |  | Rel-5 | Maurice |  |  |

Notes:
- 1744: SA16: Part of Rel5 only if Si completed in September 02
- 1745: DAB 12.12.01 split into cn4 and cn2 parts
- 1746: DAB 12.12.01 split into cn4 and cn2 parts
- 1747: DAB 12.12.01 split into cn4 and cn2 parts
- 1748: [DAB 08-03-02] - UID 12004 is MASTER of UID 14998 / 17 May need to be recearch possible impact on 23.008 & 23.016, changes to 29.002 are done.
- 1749: [DAB 08-03-02] - No activity on this in CN4. Marked as stopped 12/2008
- 1750: Marked as closed 12/2008 (was marked 60% complete)
- 1751: -
- 1752: -
- 1753: -
- 1754: -
- 1755: Was introduced at SP#13 by Ileana Leuca (exact position in the WP and related WG have to be defined)
- 1756: Marked as closed 12/2008 (was marked 90% complete)
- 1757: Marked as closed 12/2008 (was marked 50% complete)
- 1758: The task is a building block, individual work items are being considered but are constrained by lack of supporting companies. Marked as stopped 12/2008
- 1759: Marked as stopped 12/2008
- 1760: Marked as stopped 12/2008
- 1761: -
- 1762: 2nd resp SA4
- 1763: 2nd resp SA4. Marked as closed 12/2008 (was marked 65% complete)
- 1764: 2nd resp SA2
- 1765: Marked as closed 12/2008 (was marked 90% complete)
- 1766: -
- 1767: Marked as closed 12/2008 (was marked 47% complete)

| ID | WBS | Task | Duration | Start | Finish | Predecessors | Complete | Baseline start | Baseline finish | Baseline duration | Constraint | Resources | Work | Actual work | Text1 | Text6 | Text8 | Text3 | Text4 | Text5 |
| --- | --- | --- | --- | --- | --- | --- | --- | --- | --- | --- | --- | --- | --- | --- | --- | --- | --- | --- | --- | --- |
| 1768 | 83.2 | **OSA APIs for Multimedia Call Control** | 499d | 2000-07-11 A | 2002-06-07 A |  | 100% | 2000-07-11 | 2002-06-07 | 499d |  | S2 | 5960h | 5960h | OSA1-CSCF | Rel-5 | Maurice |  |  |  |
| 1769 | 83.2.1 | Stage 1 | 438d | 2000-07-11 A | 2002-03-14 A |  | 100% | 2000-07-11 | 2002-03-14 | 438d | finish no earlier than 2002-03-14 | S1 | 3504h | 3504h |  | Rel-5 | Alain | 22.127 | Siemens | Manfred.leitgeb@siemens.at |
| 1770 | 83.2.2 | (Multimedia) Call Control - Stages 2 and 3 | 194d | 2001-09-11 A | 2002-06-07 A |  | 100% | 2001-09-11 | 2002-06-07 | 194d | finish no earlier than 2002-06-07 | N5 | 1552h | 1552h |  | Rel-5 | Kimmo | 29.198-04 |  |  |
| 1771 | 83.3 | Generic user interaction - Stage 3 | 194d | 2001-09-11 A | 2002-06-07 A |  | 100% | 2001-09-11 | 2002-06-07 | 194d | finish no earlier than 2002-06-07 | N5 | 1552h | 1552h |  | Rel-5 | Kimmo | 29.198-05 |  |  |
| 1772 | 83.4 | Charging - Stage 3 | 194d | 2001-09-11 A | 2002-06-07 A |  | 100% | 2001-09-11 | 2002-06-07 | 194d | finish no earlier than 2002-06-07 | N5 | 1552h | 1552h |  | Rel-5 | Kimmo | 29.198-12 |  |  |
| 1773 | 83.5 | Call Control Service Mapping; Multiparty Call Control SIP - Stage 3 | 194d | 2001-09-11 A | 2002-06-07 A |  | 100% | 2001-09-11 | 2002-06-07 | 194d | finish no earlier than 2002-06-07 | N5 | 1552h | 1552h |  | Rel-5 | Kimmo | 29.998-04-4 |  |  |
| 1774 | 83.6 | WSDL APIs for SOAP/HTTP - Stage 3 | 455d | 2000-09-11 A | 2002-06-07 A |  | 100% | 2000-09-11 | 2002-06-07 | 455d | finish no earlier than 2002-06-07 | N5 | 3640h | 3640h |  | Rel-5 | Kimmo | 29.198, 29.998 |  |  |
| 1775 | 83.7 | **OSA security** | 639d | 2000-07-11 A | 2002-12-20 A |  | 100% | 2000-07-11 | 2002-12-20 | 639d |  | S3 | 15000h | 15000h | OSA1-SEC | Rel-5 | Dionisio |  | BT | colin.blanchard@bt.com |
| 1776 | 83.7.1 | Stage 1 | 349d | 2000-07-11 A | 2001-11-09 A |  | 100% | 2000-07-11 | 2001-11-09 | 349d | finish no earlier than 2001-11-09 | S1 | 2792h | 2792h |  | Rel-5 | Alain | 22.127 | Siemens | Manfred.leitgeb@siemens.at |
| 1777 | 83.7.2 | Stage 3 | 430d | 2000-10-23 A | 2002-06-14 A |  | 100% | 2000-10-23 | 2002-06-14 | 430d | finish no earlier than 2002-06-14 | S3 | 3440h | 3440h |  | Rel-5 | Dionisio |  |  |  |
| 1778 | 83.7.3 | security related SCF(s) definition | 186d | 2001-09-21 A | 2002-06-07 A |  | 100% | 2001-09-21 | 2002-06-07 | 186d | finish no earlier than 2002-06-07 | N5 | 1488h | 1488h |  | Rel-5 | Kimmo | 29.198, 29.998 | Ericsson | Ard.Jan.Moerdijk@eln.ericsson.se |
| 1779 | 83.7.4 | (possibly) changes required from supporting platforms, e.g. gsmSCF, HLR | 69d | 2000-09-11 A | 2000-12-14 A |  | 100% | 2000-09-11 | 2000-12-14 | 69d | finish no earlier than 2000-12-14 | S3 | 552h | 552h |  | Rel-5 | Dionisio |  |  |  |
| 1780 | 490.7.5 | Security (moved from Rel-6) | 202d | 2002-03-14 A | 2002-12-20 A |  | 100% | 2002-03-14 | 2002-12-20 | 202d | finish no earlier than 2002-12-20 | S3 | 1616h | 1616h |  | Rel-5 | Dionisio |  |  |  |
| 1781 | 83.8 | **Interactions OSA - e-commerce** | 815d | 1999-04-27 A | 2002-06-07 A |  | 100% | 1999-04-27 | 2002-06-07 | 815d |  | S2 | 6152h | 6152h | OSA1-ECOM | Rel-5 | Maurice |  |  |  |
| 1782 | 83.8.1 | Stage 1 | 439d | 1999-04-27 A | 2000-12-28 A |  | 100% | 1999-04-27 | 2000-12-28 | 439d | finish no earlier than 2000-12-28 | S1 | 3504h | 3504h |  | Rel-5 | Alain | 22.127 | Siemens | Joerg Swetina (joerg.swetina@nw.neclab.eu) |
| 1783 | 83.8.2 | Stages 2 and 3 | 186d | 2001-09-21 A | 2002-06-07 A |  | 100% | 2001-09-21 | 2002-06-07 | 186d | finish no earlier than 2002-06-07 | N5 | 1488h | 1488h |  | Rel-5 | Kimmo | 29.198, 29.998 | Ericsson | Ard.Jan.Moerdijk@eln.ericsson.se |
| 1784 | 83.9 | Policy Management - Stage 3 | 194d | 2001-09-11 A | 2002-06-07 A |  | 100% | 2001-09-11 | 2002-06-07 | 194d | finish no earlier than 2002-06-07 | N5 | 1552h | 1552h |  | Rel-5 | Kimmo | 29.198-13 |  |  |
| 1785 | 83.10 | Presence and Availability Management (PAM) - Stage 3 | 194d | 2001-09-11 A | 2002-06-07 A |  | 100% | 2001-09-11 | 2002-06-07 | 194d | finish no earlier than 2002-06-07 | N5 | 1552h | 1552h |  | Rel-5 | Kimmo | 29.198-14 |  |  |
| 1786 | 83.11 | **CHECK STATUS - LCS - OSA interfaces** | 455d | 2000-09-11 A | 2002-06-07 A |  | 100% | 2000-09-11 | 2002-06-07 | 455d |  | S1 | 5656h | 5656h | OSA1-LCSI | Rel-5 | Alain |  | Siemens | Joerg Swetina (joerg.swetina@nw.neclab.eu) |
| 1787 | 83.11.1 | Stage 1 | 65d | 2000-09-11 A | 2000-12-08 A |  | 100% | 2000-09-11 | 2000-12-08 | 65d | finish no earlier than 2000-12-08 | S1 | 520h | 520h |  | Rel-5 | Alain | 22.127 | Siemens | Joerg Swetina (joerg.swetina@nw.neclab.eu) |
| 1788 | 83.11.2 | Stage 2 | 1d | 2000-12-11 A | 2000-12-11 A | 1787 | 100% | 2000-12-11 | 2000-12-11 | 1d | finish no earlier than 2000-12-11 | S2 | 8h | 8h |  | Rel-5 | Maurice | 23.127 | Ericsson | Christophe GOURRAUD |
| 1789 | 83.11.3 | Stage 3 | 186d | 2001-09-21 A | 2002-06-07 A | 1788 | 100% | 2001-09-21 | 2002-06-07 | 186d | finish no earlier than 2002-06-07 | N5 | 1488h | 1488h |  | Rel-5 | Kimmo | 29.198, 29.998 | Ericsson | Ard.Jan.Moerdijk@eln.ericsson.se |
| 1790 | 490.12 | Access to User Profile | 145d | 2001-06-01 A | 2001-12-20 A |  | 100% | 2001-06-01 | 2001-12-20 | 145d | finish no earlier than 2001-12-20 | S1 | 1160h | 1160h | OSA2-UP | Rel-5 | Alain |  |  |  |
| 1791 | 490.13 | **Retrieval of Terminal capabilities** | 634d | 2000-07-11 A | 2002-12-13 A |  | 100% | 2000-07-11 | 2002-12-13 | 634d |  | S2 | 10808h | 10808h | OSA2-TC | Rel-5 | Maurice |  |  |  |
| 1792 | 490.13.1 | Stage 1 | 132d | 2000-07-11 A | 2001-01-10 A |  | 100% | 2000-07-11 | 2001-01-10 | 132d | finish no earlier than 2001-01-10 | S1 | 1056h | 1056h |  | Rel-5 | Alain | 22.127 | Siemens | Joerg Swetina (joerg.swetina@nw.neclab.eu) |
| 1793 | 490.13.2 | Stages 2 and 3 | 321d | 2001-09-21 A | 2002-12-13 A | 1792 | 100% | 2001-09-21 | 2002-12-13 | 321d | finish no earlier than 2002-12-13 | N5 | 2568h | 2568h |  | Rel-5 | Kimmo | 29.198, 29.998 | Ericsson | Ard.Jan.Moerdijk@eln.ericsson.se |
| 1794 | 490.13.3 | Provisioning of the terminal capabilities | 445d | 2001-04-02 A | 2002-12-13 A |  | 100% | 2001-04-02 | 2002-12-13 | 445d | finish no earlier than 2002-12-13 | T2 | 3560h | 3560h |  | Rel-5 |  | 23.057 |  |  |

Notes:
- 1768: For Rel5 even if completed by March
- 1769: -
- 1770: -
- 1771: -
- 1772: -
- 1773: -
- 1774: -
- 1775: CR to correct security specifications in 29.198 scheduled for approval at CN#15
- 1776: -
- 1777: Marked as closed 12/2008 (was marked 80% complete)
- 1778: -
- 1779: -
- 1780: Contribution at S3#25
- 1781: -
- 1782: Marked as closed 12/2008 (was marked 95% complete)
- 1783: -
- 1784: -
- 1785: -
- 1786: az: CN#13 - changed to Rel5
- 1787: -
- 1788: az 24/05/01: Rel4 completion 90->100%.
- 1789: -
- 1790: -
- 1791: -
- 1792: -
- 1793: -
- 1794: According to T2 SWG1 M. Cataldo this is automatically supported by the MExE support of UAProf therefore 100% complete

| ID | WBS | Task | Duration | Start | Finish | Predecessors | Complete | Baseline start | Baseline finish | Baseline duration | Constraint | Resources | Work | Actual work | Text1 | Text4 | Text5 | Text6 | Text8 | Text3 |
| --- | --- | --- | --- | --- | --- | --- | --- | --- | --- | --- | --- | --- | --- | --- | --- | --- | --- | --- | --- | --- |
| 1795 | 84 | **CAMEL phase 4** | 625d | 2000-04-17 A | 2002-09-06 A |  | 100% | 2000-04-17 | 2002-09-06 | 625d |  | S1 | 41104h | 41104h | CAMEL4 | Nokia | keijo.palviainen@nokia.com | Rel-5 | Alain |  |
| 1796 | 84.1 | Service requirements | 565d | 2000-04-17 A | 2002-06-14 A |  | 100% | 2000-04-17 | 2002-06-14 | 565d | finish no earlier than 2002-06-14 | S1 | 4520h | 4520h |  |  |  | Rel-5 | Alain |  |
| 1797 | 84.2 | Call Party Handling | 500d | 2000-07-10 A | 2002-06-07 A |  | 100% | 2000-07-10 | 2002-06-07 | 500d | finish no earlier than 2002-06-07 | N2 | 4000h | 4000h | CAMEL4-CPH |  |  | Rel-5 | Kimmo |  |
| 1798 | 84.3 | Mid call procedure for MO and MT calls | 495d | 2000-07-17 A | 2002-06-07 A |  | 100% | 2000-07-17 | 2002-06-07 | 495d | finish no earlier than 2002-06-07 | N2 | 3960h | 3960h | CAMEL4-MCP |  |  | Rel-5 | Kimmo |  |
| 1799 | 84.4 | Interactions with Optimal Routing | 430d | 2000-07-17 A | 2002-03-08 A |  | 100% | 2000-07-17 | 2002-03-08 | 430d | finish no earlier than 2002-03-08 | N2 | 3440h | 3440h | CAMEL4-IOR |  |  | Rel-5 | Kimmo |  |
| 1800 | 84.5 | Inclusion of flexible tone injection | 430d | 2000-07-17 A | 2002-03-08 A |  | 100% | 2000-07-17 | 2002-03-08 | 430d | finish no earlier than 2002-03-08 | N2 | 3440h | 3440h | CAMEL4-IFTI |  |  | Rel-5 | Kimmo |  |
| 1801 | 84.6 | CSE control over MT SMS | 430d | 2000-07-17 A | 2002-03-08 A |  | 100% | 2000-07-17 | 2002-03-08 | 430d | finish no earlier than 2002-03-08 | N2 | 3440h | 3440h | CAMEL4-CCSMS |  |  | Rel-5 | Kimmo |  |
| 1802 | 84.7 | Notification of GPRS mobility management to CSE | 331d | 2001-03-02 A | 2002-06-07 A |  | 100% | 2001-03-02 | 2002-06-07 | 331d | finish no earlier than 2002-06-07 | N2 | 2648h | 2648h | CAMEL4-NMM |  |  | Rel-5 | Kimmo |  |
| 1803 | 84.8 | Provision of location information of called subscriber | 266d | 2001-03-02 A | 2002-03-08 A |  | 100% | 2001-03-02 | 2002-03-08 | 266d | finish no earlier than 2002-03-08 | N2 | 2128h | 2128h | CAMEL4-LOCB |  |  | Rel-5 | Kimmo |  |
| 1804 | 84.9 | Inclusion of ODB data in the CSE_HLR interface | 175d | 2001-07-09 A | 2002-03-08 A |  | 100% | 2001-07-09 | 2002-03-08 | 175d | finish no earlier than 2002-03-08 | N2 | 1400h | 1400h | CAMEL4-ODB |  |  | Rel-5 | Kimmo |  |
| 1805 | 84.10 | Location information during an ongoing call (Handover DP) | 280d | 2001-05-14 A | 2002-06-07 A |  | 100% | 2001-05-14 | 2002-06-07 | 280d | finish no earlier than 2002-06-07 | N2 | 2240h | 2240h | CAMEL4-HODP |  |  | Rel-5 | Kimmo |  |
| 1806 | 84.11 | GPRS Any Time Interrogation | 240d | 2001-07-09 A | 2002-06-07 A |  | 100% | 2001-07-09 | 2002-06-07 | 240d | finish no earlier than 2002-06-07 | N2 | 1920h | 1920h | CAMEL4-ATI |  |  | Rel-5 | Kimmo |  |
| 1807 | 84.12 | Transfer of IMEI (with SW version) to CSE | 240d | 2001-07-09 A | 2002-06-07 A |  | 100% | 2001-07-09 | 2002-06-07 | 240d | finish no earlier than 2002-06-07 | N2 | 1920h | 1920h | CAMEL4-ATI |  |  | Rel-5 | Kimmo |  |
| 1808 | 84.13 | Handling of partial implementations of CAMEL4 | 131d | 2002-03-08 A | 2002-09-06 A |  | 100% | 2002-03-08 | 2002-09-06 | 131d | finish no earlier than 2002-06-07 | N2 | 1048h | 1048h | CAMEL4-SUB |  |  | Rel-5 | Kimmo |  |
| 1809 | 85 | **Rel-5 MExE enhancements** | 250d | 2001-03-26 A | 2002-03-08 A |  | 100% | 2001-03-26 | 2002-03-08 | 250d |  | T2 | 2880h | 2880h | MEXE5 |  |  | Rel-5 | Kimmo |  |
| 1810 | 85.1 | MExE Rel-5 Improvements and Investigations | 110d | 2001-03-26 A | 2002-03-08 A |  | 100% | 2001-03-26 | 2002-03-08 | 110d | finish no earlier than 2001-12-17 | T2 | 880h | 880h | MEXE5-ENHANC | Motorola | Mark Cataldo | Rel-5 |  | 22.057, 23.057 |
| 1811 | 86 | **Wideband Telephony Service - AMR** | 1036d | 2000-01-01 A | 2003-12-19 A |  | 100% | 2000-01-01 | 2003-12-19 | 1036d |  | S4 | 81496h | 81496h | AMRWB | Siemens | Imre.Varga@mch.siemens.de | Rel-5 | Paolo |  |
| 1812 | 86.1 | **Specification** | 636d | 2000-01-01 A | 2002-06-07 A |  | 100% | 2000-01-01 | 2002-06-07 | 636d |  | S4 | 19984h | 19984h |  |  |  | Rel-5 | Paolo |  |
| 1813 | 86.1.1 | Stage 1 | 125d | 2001-10-01 A | 2002-03-22 A |  | 100% | 2001-10-01 | 2002-03-22 | 125d | finish no earlier than 2002-03-22 | S1 | 1000h | 1000h |  |  |  | Rel-5 | Alain |  |
| 1814 | 86.1.2 | **Stage 2** | 77d | 2000-01-03 A | 2000-04-17 A |  | 100% | 2000-01-03 | 2000-04-17 | 77d |  | S4 | 1232h | 1232h |  |  |  | Rel-5 | Paolo |  |
| 1815 | 86.1.2.1 | Design Constraints | 27d | 2000-01-03 A | 2000-02-07 A |  | 100% | 2000-01-03 | 2000-02-07 | 27d |  | S4 [96.3%] | 208h | 208h |  |  |  | Rel-5 | Paolo |  |
| 1816 | 86.1.2.2 | General Description | 51d | 2000-02-07 A | 2000-04-17 A | 1815 | 100% | 2000-02-07 | 2000-04-17 | 51d | start no earlier than 2000-09-25 | S4 | 408h | 408h |  |  |  | Rel-5 | Paolo |  |
| 1817 | 86.1.3 | Feasibility Study | 26d | 2000-04-28 A | 2000-06-02 A | 1816 | 100% | 2000-04-28 | 2000-06-02 | 26d | finish no earlier than 2000-06-02 | S4 | 208h | 208h |  |  |  | Rel-5 | Paolo | 26.901 |
| 1818 | 86.1.4 | N1 Aspects | 66d | 2001-09-21 A | 2001-12-21 A |  | 100% | 2001-09-21 | 2001-12-21 | 66d | finish no earlier than 2001-12-21 | N1 | 528h | 528h |  |  |  | Rel-5 | Frederic |  |
| 1819 | 86.1.5 | N4 work | 83d | 2002-02-13 A | 2002-06-07 A |  | 100% | 2002-02-13 | 2002-06-07 | 83d | finish no earlier than 2002-06-07 | N4 | 664h | 664h |  |  |  | Rel-5 | Kimmo |  |

Notes:
- 1795: -
- 1796: -
- 1797: -
- 1798: -
- 1799: -
- 1800: -
- 1801: -
- 1802: -
- 1803: -
- 1804: Added on May 29, 2001
- 1805: -
- 1806: -
- 1807: -
- 1808: stage2 and stage3 CRs for approval at CN#17
- 1809: -
- 1810: -
- 1811: -
- 1812: -
- 1813: -
- 1814: -
- 1815: -
- 1816: -
- 1817: S4,TD SP-000024: TR 26.901 v.4.0.0
- 1818: Some of N1 tasks: Indication of supported codecs by the MS, Bearer cap negociation, codec indication to MS... / One common set of codec negotiation procedures will be specified as in ID1657.
- 1819: CN4#11 30/11/01: No inputs to CN4 at this meeting / 14/02/02 work started 50% reached / 17 May work is done 100%

| ID | WBS | Task | Duration | Start | Finish | Predecessors | Complete | Baseline start | Baseline finish | Baseline duration | Constraint | Resources | Work | Actual work | Text6 | Text8 | Text1 | Text3 | Text12 | Text4 | Text5 |
| --- | --- | --- | --- | --- | --- | --- | --- | --- | --- | --- | --- | --- | --- | --- | --- | --- | --- | --- | --- | --- | --- |
| 1820 | 86.1.6 | **Codec issues** | 636d | 2000-01-03 A | 2002-06-07 A |  | 100% | 2000-01-03 | 2002-06-07 | 636d |  | S4 | 9496h | 9496h | Rel-5 | Paolo |  |  |  |  |  |
| 1821 | 86.1.6.1 | Codec qualification | 86d | 2000-02-02 A | 2000-05-31 A |  | 100% | 2000-02-02 | 2000-05-31 | 86d | finish no earlier than 2000-05-31 | S4 | 688h | 688h | Rel-5 | Paolo |  |  |  |  |  |
| 1822 | 86.1.6.2 | Codec selection tests | 102d | 2000-06-01 A | 2000-10-20 A | 1821 | 100% | 2000-06-01 | 2000-10-20 | 102d | finish no earlier than 2000-10-20 | S4 | 816h | 816h | Rel-5 | Paolo |  |  |  |  |  |
| 1823 | 86.1.6.3 | Codec selection | 5d | 2000-10-23 A | 2000-10-27 A | 1822 | 100% | 2000-10-23 | 2000-10-27 | 5d | finish no earlier than 2000-10-27 | S4 | 40h | 40h | Rel-5 | Paolo |  |  |  |  |  |
| 1824 | 86.1.6.4 | TFO AMR-WB | 63d | 2001-12-18 A | 2002-03-14 A |  | 100% | 2001-12-18 | 2002-03-14 | 63d | finish no earlier than 2002-03-14 | S4 | 504h | 504h | Rel-5 | Paolo | AMRWB-TFO |  |  |  |  |
| 1825 | 86.1.6.5 | Other codec issues (verif., characterization) | 441d | 2000-09-29 A | 2002-06-07 A |  | 100% | 2000-09-29 | 2002-06-07 | 441d | finish no earlier than 2002-06-07 | S4 | 3528h | 3528h | Rel-5 | Paolo |  | 26.976 |  |  |  |
| 1826 | 86.1.6.6 | AMR-WB and narrrowband interworking | 121d | 2001-09-27 A | 2002-03-14 A |  | 100% | 2001-09-27 | 2002-03-14 | 121d | finish no earlier than 2002-03-14 | S4 | 968h | 968h | Rel-5 | Paolo | AMRWB-IWG |  |  |  |  |
| 1827 | 86.1.6.7 | Interworking with fixed broadband networks | 121d | 2001-09-27 A | 2002-03-14 A |  | 100% | 2001-09-27 | 2002-03-14 | 121d | finish no earlier than 2002-03-14 | S4 | 968h | 968h | Rel-5 | Paolo |  |  |  |  |  |
| 1828 | 86.1.6.8 | Tones and announcements | 121d | 2001-09-27 A | 2002-03-14 A |  | 100% | 2001-09-27 | 2002-03-14 | 121d | finish no earlier than 2002-03-14 | S4 | 968h | 968h | Rel-5 | Paolo |  |  |  |  |  |
| 1829 | 86.1.6.9 | Deleted - WB Conferencing and WB Voice Group calls | 1d | 2000-01-03 A | 2000-01-03 A |  | 100% | 2000-01-03 | 2000-01-03 | 1d | finish no earlier than 2000-01-03 | S1 | 8h | 8h | Rel-5 | Alain |  |  | SP-07 |  |  |
| 1830 | 86.1.8 | **Conformance tests (CRs to 34 series)** | 74d | 2000-01-01 A | 2000-04-12 A |  | 100% | 2000-01-01 | 2000-04-12 | 74d |  | T1 | 1768h | 1768h | Rel-5 | Ingbert |  |  |  |  |  |
| 1831 | 86.1.8.1 | **Terminal Acoustic Characteristics** | 74d | 2000-01-01 A | 2000-04-12 A |  | 100% | 2000-01-01 | 2000-04-12 | 74d |  | S4 | 1176h | 1176h | Rel-5 | Paolo |  |  |  |  |  |
| 1832 | 86.1.8.1.1 | Definition | 22d | 2000-01-01 A | 2000-01-31 A |  | 100% | 2000-01-01 | 2000-01-31 | 22d | finish no earlier than 2000-01-28 | S4 [95.5%] | 168h | 168h | Rel-5 | Paolo |  | 26.131 |  |  |  |
| 1833 | 86.1.8.1.2 | Test specification | 52d | 2000-02-01 A | 2000-04-12 A | 1832 | 100% | 2000-02-01 | 2000-04-12 | 52d | finish no earlier than 2000-03-13 | S4 | 416h | 416h | Rel-5 | Paolo |  | 26.132 |  |  |  |
| 1834 | 86.2 | Floating-point ANSI-C code for the AMR-WB speech codec | 123d | 2001-09-25 A | 2002-03-14 A |  | 100% | 2001-09-25 | 2002-03-14 | 123d | finish no earlier than 2002-03-14 | S4 | 984h | 984h | Rel-5 | Paolo | AMRWB-FP | 26.204 |  | Nokia | janne.m.vainio@nokia.com |
| 1835 | 86.3 | **Support of AMR-WB in GERAN: GMSK and 8PSK WB FR / HR** | 651d | 2000-01-03 A | 2002-06-28 A |  | 100% | 2000-01-03 | 2002-06-28 | 651d |  | GP | 23488h | 23488h | Rel-5 | Paolo | GAMRWB |  |  |  |  |
| 1836 | 86.3.1 | Channel coding in 45.003 | 591d | 2000-01-03 A | 2002-04-05 A |  | 100% | 2000-01-03 | 2002-04-05 | 591d |  | GP | 4720h | 4720h | Rel-5 | Paolo |  |  |  |  |  |
| 1837 | 86.3.2 | Signalling for the A interface | 391d | 2000-01-03 A | 2001-06-29 A |  | 100% | 2000-01-03 | 2001-06-29 | 391d | finish no earlier than 2001-06-29 | GP | 3120h | 3120h | Rel-5 | Paolo |  |  |  |  |  |
| 1838 | 86.3.3 | Signalling for Iu | 651d | 2000-01-03 A | 2002-06-28 A |  | 100% | 2000-01-03 | 2002-06-28 | 651d | finish no earlier than 2002-06-28 | GP | 5200h | 5200h | Rel-5 | Paolo |  |  |  |  |  |
| 1839 | 86.3.4 | Receiver performance in TS 45.005 | 325d | 2001-04-02 A | 2002-06-28 A |  | 100% | 2001-04-02 | 2002-06-28 | 325d | finish no earlier than 2002-06-28 | GP | 2600h | 2600h | Rel-5 | Paolo |  |  |  |  |  |
| 1840 | 86.3.5 | Link Adaptation in 45.009 | 330d | 2001-03-26 A | 2002-06-28 A |  | 100% | 2001-03-26 | 2002-06-28 | 330d | finish no earlier than 2002-06-28 | GP | 2640h | 2640h | Rel-5 | Paolo |  |  |  |  |  |
| 1841 | 86.4 | **Deleted - GERAN MS conformance test for AMR-WB** | 1036d | 2000-01-03 A | 2003-12-19 A |  | 100% | 2000-01-03 | 2003-12-19 | 1036d |  | GP | 16568h | 16568h | Rel-5 | Paolo |  |  |  |  |  |
| 1842 | 86.4.1 | Deleted - MS test for AMR-WB | 1036d | 2000-01-03 A | 2003-12-19 A |  | 100% | 2000-01-03 | 2003-12-19 | 1036d | finish no earlier than 2003-12-19 | GP | 8280h | 8280h | Rel-5 | Paolo |  |  | GP-17 |  |  |
| 1843 | 86.5 | **GERAN BTS conformance test for AMR-WB** | 762d | 2000-01-03 A | 2002-12-02 A |  | 100% | 2000-01-03 | 2002-12-02 | 762d |  | GP | 12184h | 12184h | Rel-5 | Paolo |  |  |  |  |  |
| 1844 | 86.5.1 | BTS test | 762d | 2000-01-03 A | 2002-12-02 A |  | 100% | 2000-01-03 | 2002-12-02 | 762d | finish no earlier than 2002-12-02 | GP | 6088h | 6088h | Rel-5 | Paolo |  |  |  |  |  |

Notes:
- 1820: -
- 1821: -
- 1822: -
- 1823: -
- 1824: -
- 1825: ANSI C-Code , Test Sequences, Speech Transcoding Functions, Error Concealment of lost frames, Source Controlled Bit-Rate Operation, Voice Activity Detector, Frame Structure
- 1826: -
- 1827: -
- 1828: -
- 1829: -
- 1830: -
- 1831: -
- 1832: -
- 1833: -
- 1834: -
- 1835: -
- 1836: 50098 -> 50298
- 1837: -
- 1838: -
- 1839: -
- 1840: -
- 1841: Not started 02/2003. Marked as stopped 12/2008
- 1842: Marked as stopped 12/2008
- 1843: -
- 1844: -

| ID | WBS | Task | Duration | Start | Finish | Complete | Baseline start | Baseline finish | Baseline duration | Constraint | Resources | Work | Actual work | Text1 | Text6 | Text8 | Text3 | Text4 | Text5 |
| --- | --- | --- | --- | --- | --- | --- | --- | --- | --- | --- | --- | --- | --- | --- | --- | --- | --- | --- | --- |
| 1845 | 11 | **Terminal interfaces** | 223d | 2001-05-14 A | 2002-03-20 A | 100% | 2001-05-14 | 2002-03-20 | 223d |  | T2 | 3568h | 3568h | TI | Rel-5 | Kimmo |  |  |  |
| 1846 | 87 | Terminal local model enhancements | 223d | 2001-05-14 A | 2002-03-20 A | 100% | 2001-05-14 | 2002-03-20 | 223d | finish no earlier than 2002-03-20 | T2 | 1784h | 1784h | TLM5 | Rel-5 |  | 23.227 |  |  |
| 1847 | 88 | **Rel-5 Location Services enhancements** | 845d | 2000-04-03 A | 2003-06-27 A | 100% | 2000-04-03 | 2003-06-27 | 845d |  | S2,S5 | 86804h | 86804h | LCS1 | Rel-5 | Maurice |  | Nokia | Jan Kall |
| 1848 | 88.1 | **UE positioning** | 315d | 2001-01-15 A | 2002-03-29 A | 100% | 2001-01-15 | 2002-03-29 | 315d |  | RP | 5560h | 5560h | LCS1-UEpos | Rel-5 | Issam |  |  |  |
| 1849 | 88.1.1 | UE positioning enhancements for 1.28 Mcps TDD | 255d | 2001-04-09 A | 2002-03-29 A | 100% | 2001-04-09 | 2002-03-29 | 255d | finish no earlier than 2002-03-29 | R2 | 2040h | 2040h | LCS-128Pos | Rel-5 | Joern |  | CATT | Xiaohua Mei |
| 1850 | 88.1.2 | Open SMLC-SRNC Interface within the UTRAN to support A-GPS Positioning | 195d | 2001-01-15 A | 2001-10-12 A | 100% | 2001-01-15 | 2001-10-12 | 195d |  | R2 | 1560h | 1560h | LCS-INTF | Rel-5 | Joern |  | Qualcomm Europe | Kirk Burroughs |
| 1851 | 88.2 | **Event based and Periodic LCS** | 535d | 2000-05-22 A | 2002-06-07 A | 100% | 2000-05-22 | 2002-06-07 | 535d |  | S1 | 6288h | 6288h | LCS1-EBP | Rel-5 | Alain |  |  |  |
| 1852 | 88.2.1 | Stage 1 | 130d | 2000-05-22 A | 2000-11-17 A | 100% | 2000-05-22 | 2000-11-17 | 130d | finish no earlier than 2000-07-21 | S1 | 1040h | 1040h |  | Rel-5 | Alain | 22.071 | Pacific Bell Wireless | Randolph Wohlert (rwohlert@tri.sbc.com) |
| 1853 | 88.2.2 | Stage 2 specification | 60d | 2000-11-06 A | 2001-01-26 A | 100% | 2000-11-06 | 2001-01-26 | 60d | finish no earlier than 2001-01-26 | S2 | 480h | 480h |  | Rel-5 | Maurice |  |  |  |
| 1854 | 88.2.3 | Impact on MAP | 61d | 2002-03-15 A | 2002-06-07 A | 100% | 2002-03-15 | 2002-06-07 | 61d | finish no earlier than 2002-06-07 | N4 | 488h | 488h |  | Rel-5 | Kimmo |  |  |  |
| 1855 | 88.3 | **Location Services for GERAN in A/Gb Mode** | 485d | 2000-04-03 A | 2002-02-08 A | 100% | 2000-04-03 | 2002-02-08 | 485d |  | GP | 14760h | 14760h | LCS-GERAN | Rel-5 | Paolo |  |  |  |
| 1856 | 88.3.1 | GERAN LCS Stage 2 (first release) | 485d | 2000-04-03 A | 2002-02-08 A | 100% | 2000-04-03 | 2002-02-08 | 485d | finish no earlier than 2002-02-08 | GP,S2,G1,G2 | 3880h | 3880h |  | Rel-5 | Paolo |  |  |  |
| 1857 | 88.3.2 | Gb interface support for LCS | 370d | 2000-04-03 A | 2001-08-31 A | 100% | 2000-04-03 | 2001-08-31 | 370d | finish no earlier than 2001-08-31 | GP | 2960h | 2960h |  | Rel-5 | Paolo |  |  |  |
| 1858 | 88.3.3 | L3 protocol support for LCS | 305d | 2000-04-03 A | 2001-06-01 A | 100% | 2000-04-03 | 2001-06-01 | 305d | finish no earlier than 2001-06-01 | GP | 2440h | 2440h |  | Rel-5 | Paolo |  |  |  |
| 1859 | 88.3.4 | Stage 3 specifications | 305d | 2000-04-03 A | 2001-06-01 A | 100% | 2000-04-03 | 2001-06-01 | 305d | finish no earlier than 2001-06-01 | GP | 2440h | 2440h |  | Rel-5 | Paolo |  |  |  |
| 1860 | 88.4 | **Location Services for GERAN in Iu Mode** | 585d | 2000-04-03 A | 2002-06-28 A | 100% | 2000-04-03 | 2002-06-28 | 585d |  | S2,G1,G2,R2,R3 | 20996h | 20996h |  | Rel-5 | Paolo |  |  |  |
| 1861 | 88.4.1 | GERAN LCS Stage 2 | 585d | 2000-04-03 A | 2002-06-28 A | 100% | 2000-04-03 | 2002-06-28 | 585d | finish no earlier than 2002-06-28 | S2,G1,G2 | 4680h | 4680h |  | Rel-5 | Paolo |  |  |  |
| 1862 | 88.4.2 | Iu-ps interface support for LCS | 585d | 2000-04-03 A | 2002-06-28 A | 100% | 2000-04-03 | 2002-06-28 | 585d | finish no earlier than 2002-06-28 | R2,R3 | 4680h | 4680h |  | Rel-5 | Paolo |  |  |  |
| 1863 | 88.4.3 | Iu-cs interface support for LCS | 585d | 2000-04-03 A | 2002-06-28 A | 100% | 2000-04-03 | 2002-06-28 | 585d | finish no earlier than 2002-06-28 | R2,R3 | 4680h | 4680h |  | Rel-5 | Paolo |  |  |  |
| 1864 | 88.4.4 | Iur-g interface support for LCS | 62.5d | 2002-01-23 A | 2002-04-19 A | 100% | 2002-01-23 | 2002-04-19 | 62.5d | finish no earlier than 2002-04-19 | G1,G2 | 500h | 500h |  | Rel-5 | Paolo |  |  |  |
| 1865 | 88.4.5 | RRC protocol support for LCS | 75d | 2001-08-20 A | 2001-11-30 A | 100% | 2001-08-20 | 2001-11-30 | 75d | finish no earlier than 2001-11-30 | G1,G2,R2,R3 | 600h | 600h |  | Rel-5 | Paolo |  |  |  |
| 1866 | 88.4.6 | Additional impacts on Broadcast of LCS data on packet channels | 77.5d | 2001-08-20 A | 2001-12-05 A | 100% | 2001-08-20 | 2001-12-05 | 77.5d | finish no earlier than 2001-12-05 | G1,G2,R2,R3 | 620h | 620h |  | Rel-5 | Paolo |  |  |  |
| 1867 | 88.4.7 | Stage 3 specifications | 69.5d | 2002-03-25 A | 2002-06-28 A | 100% | 2002-03-25 | 2002-06-28 | 69.5d | finish no earlier than 2002-06-28 | G1,G2,R2,R3 | 556h | 556h |  | Rel-5 | Paolo |  |  |  |
| 1868 | 88.5 | **GERAN MS Conformance test for LCS** | 280d | 2002-06-03 A | 2003-06-27 A | 100% | 2002-06-03 | 2003-06-27 | 280d |  | GP | 6720h | 6720h | LCS-GERAN-MSconf | Rel-5 | Paolo |  |  |  |
| 1869 | 88.5.1 | Develop LCS MS test case work plan (Release 98/99/4) | 280d | 2002-06-03 A | 2003-06-27 A | 100% | 2002-06-03 | 2003-06-27 | 280d | finish no earlier than 2003-06-27 | G4,G5 | 2240h | 2240h |  | Rel-5 | Paolo |  |  |  |
| 1870 | 88.5.2 | Develop LCS MS test cases | 280d | 2002-06-03 A | 2003-06-27 A | 100% | 2002-06-03 | 2003-06-27 | 280d | finish no earlier than 2003-06-27 | G4,G5 | 2240h | 2240h |  | Rel-5 | Paolo |  |  |  |

Notes:
- 1845: -
- 1846: -
- 1847: -
- 1848: -
- 1849: -
- 1850: Finished at RP#13
- 1851: -
- 1852: Evaluate Event based and Periodic LCS to be included in R00, corresponding Stage 1 description
- 1853: Marked as closed 12/2008 (was marked 51% complete)
- 1854: Possible impact on UTRAN of LCS quality level request / 17 May No stage 2 for event-based & periodic LCS. Work 100% completefor current stage 2
- 1855: -
- 1856: -
- 1857: -
- 1858: -
- 1859: -
- 1860: -
- 1861: -
- 1862: -
- 1863: -
- 1864: FFS
- 1865: -
- 1866: -
- 1867: -
- 1868: -
- 1869: Marked as closed 12/2008 (was marked 60% complete)
- 1870: Marked as closed 12/2008 (was marked 60% complete)

| ID | WBS | Task | Duration | Start | Finish | Predecessors | Complete | Baseline start | Baseline finish | Baseline duration | Constraint | Resources | Work | Actual work | Text1 | Text6 | Text8 | Text12 | Text3 | Text4 | Text5 |
| --- | --- | --- | --- | --- | --- | --- | --- | --- | --- | --- | --- | --- | --- | --- | --- | --- | --- | --- | --- | --- | --- |
| 1871 | 88.6 | **Deleted - GERAN BTS Conformance test for LCS** | 280d | 2002-06-03 A | 2003-06-27 A |  | 100% | 2002-06-03 | 2003-06-27 | 280d |  | GP | 6720h | 6720h | LCS-GERAN-BTSconf | Rel-5 | Paolo | GP-15 |  |  |  |
| 1872 | 88.6.1 | Deleted - Develop LCS BTS test case work plan (Release 98/99/4) | 280d | 2002-06-03 A | 2003-06-27 A |  | 100% | 2002-06-03 | 2003-06-27 | 280d | finish no earlier than 2003-06-27 | G4,G5 | 2240h | 2240h |  | Rel-5 | Paolo | GP-15 |  |  |  |
| 1873 | 88.6.2 | Deleted - Develop LCS BTS test cases | 280d | 2002-06-03 A | 2003-06-27 A |  | 100% | 2002-06-03 | 2003-06-27 | 280d | finish no earlier than 2003-06-27 | G4,G5 | 2240h | 2240h |  | Rel-5 | Paolo | GP-15 |  |  |  |
| 1874 | 88.7 | LCS interoperation stage 2 aspects | 480d | 2000-08-28 A | 2002-06-28 A |  | 100% | 2000-08-28 | 2002-06-28 | 480d |  | S2 | 3840h | 3840h |  | Rel-5 | Maurice |  |  |  |  |
| 1875 | 88.8 | **LCS interoperability aspects to GERAN** | 480d | 2000-08-28 A | 2002-06-28 A |  | 100% | 2000-08-28 | 2002-06-28 | 480d |  | GP,S5 | 7680h | 7680h | LCS-GERAN | Rel-5 | Paolo |  |  |  |  |
| 1876 | 88.8.1 | Co-ordinated development of GSM LCS Phase 2 and UMTS LCS, S2 and GERAN | 480d | 2000-08-28 A | 2002-06-28 A |  | 100% | 2000-08-28 | 2002-06-28 | 480d | finish no earlier than 2002-06-28 | GP,S2,S5,R2,R3,G2,G1 | 3840h | 3840h | LCS-GERAN | Rel-5 | Paolo |  |  |  |  |
| 1877 | 88.9 | FS on LCS support in the IMS | 90d | 2001-02-12 A | 2002-01-18 A |  | 100% | 2001-02-12 | 2002-01-18 | 90d | start no earlier than 2001-02-12 | S1 | 720h | 720h |  | Rel-5 | Alain |  |  |  |  |
| 1878 | 88.10 | Charging and OAM&P for LCS enhancements | 201d | 2001-09-21 A | 2002-06-28 A |  | 100% | 2001-09-21 | 2002-06-28 | 201d | finish no earlier than 2002-06-28 | S5 | 1608h | 1608h | LCS1-OAM | Rel-5 | Dionisio |  | 32-series | VoiceStream, Motorola |  |
| 1879 | 88.11 | New security aspects of LCS (not identified) | 446d | 2000-04-14 A | 2001-12-28 A |  | 100% | 2000-04-14 | 2001-12-28 | 446d | finish no earlier than 2001-12-28 | S3 | 3568h | 3568h | LCS1-SEC | Rel-5 | Dionisio |  |  | Nokia | valtteri.niemi@nokia.com |
| 1880 | 88.12 | Specification for the Le Interface | 45d | 2002-01-14 A | 2002-03-15 A |  | 100% | 2002-01-14 | 2002-03-15 | 45d | start no earlier than 2002-01-14 | S2 | 360h | 360h | LCS1-Le | Rel-5 | Maurice |  |  |  |  |
| 1881 | 88.13 | Deleted - CHECK STATUS - Inter-GMLC interface | 153d | 2002-05-30 A | 2002-12-30 A |  | 100% | 2002-05-30 | 2002-12-30 | 153d | finish no earlier than 2002-12-30 | S2 | 1224h | 1224h |  | Rel-5 | Maurice | SP-10 |  |  |  |
| 1882 | 89 | **Rel-5 Security enhancements** | 615d | 2000-02-21 A | 2002-06-28 A |  | 100% | 2000-02-21 | 2002-06-28 | 615d |  | S3 | 29974.9h | 29974.9h |  | Rel-5 | Dionisio |  |  | Vodafone | Peter.Howard@vodafone.com |
| 1883 | 89.1 | **Network domain security** | 615d | 2000-02-21 A | 2002-06-28 A |  | 100% | 2000-02-21 | 2002-06-28 | 615d |  | S3 | 25054.9h | 25054.9h | SEC1-NDS | Rel-5 | Dionisio |  |  | Telenor | Geir-myrdahl.koien@telenor.com |
| 1884 | 89.1.1 | **Deleted -Control plane protection in core network (e.g., GTP, CAP, MAP/IP, provided by IPsec)** | 541d | 2000-05-12 A | 2002-06-07 A |  | 100% | 2000-05-12 | 2002-06-07 | 541d |  | S3 | 7118.9h | 7118.9h |  | Rel-5 | Dionisio | SP-16 |  |  |  |
| 1885 | 89.1.1.1 | Deleted - Main aspects | 290d | 2000-05-12 A | 2001-06-21 A |  | 100% | 2000-05-12 | 2001-06-21 | 290d | finish no earlier than 2001-06-21 | S3 | 2320h | 2320h |  | Rel-5 | Dionisio | SP-12 |  |  |  |
| 1886 | 89.1.1.2 | Deleted -Integration of GTP signalling security architecture | 191d | 2001-09-14 A | 2002-06-07 A |  | 100% | 2001-09-14 | 2002-06-07 | 191d | finish no earlier than 2002-06-07 | N4 | 1528h | 1528h |  | Rel-5 | Kimmo | NP-16 |  |  |  |
| 1887 | 89.1.2 | **Deleted -User plane protection in core network (e.g., provided by IPsec)** | 615d | 2000-02-21 A | 2002-06-28 A |  | 100% | 2000-02-21 | 2002-06-28 | 615d |  | S3 | 9360h | 9360h |  | Rel-5 | Dionisio | SP-16 |  |  |  |
| 1888 | 89.1.2.1 | Deleted -Main aspects | 349d | 2000-02-21 A | 2001-06-21 A |  | 100% | 2000-02-21 | 2001-06-21 | 349d | finish no earlier than 2001-06-21 | S3 | 2792h | 2792h |  | Rel-5 | Dionisio | SP-12 |  |  |  |
| 1889 | 89.1.2.2 | Deleted -Integration of GTP signalling security architecture | 206d | 2001-09-14 A | 2002-06-28 A |  | 100% | 2001-09-14 | 2002-06-28 | 206d | finish no earlier than 2002-06-28 | N4 | 1648h | 1648h |  | Rel-5 | Kimmo | NP-16 |  |  |  |
| 1890 | 89.1.3 | IP network layer security (NDS/IP) | 457d | 2000-06-15 A | 2002-03-15 A |  | 100% | 2000-06-15 | 2002-03-15 | 457d | finish no earlier than 2002-03-15 | S3 | 3656h | 3656h | SEC1-NDS-IP | Rel-5 | Dionisio |  | 33.210 | Telenor | Geir-myrdahl.koien@telenor.com |
| 1891 | 90 | **Intra Domain Connection of RAN Nodes to Multiple CN Nodes** | 455d | 2000-10-02 A | 2002-06-28 A |  | 100% | 2000-10-02 | 2002-06-28 | 455d |  | S2 | 15136h | 15136h | IUFLEX | Rel-5 | Alain |  | 23.236 | Ericsson | stephen.terrill@ericsson.com |
| 1892 | 90.1 | Overall System Architecture | 188d | 2001-01-03 A | 2001-09-21 A |  | 100% | 2001-01-03 | 2001-09-21 | 188d | finish no earlier than 2001-06-01 | S2 | 1504h | 1504h |  | Rel-5 | Maurice |  |  |  |  |
| 1893 | 90.2 | Stage 3: RAN node selecting CN node | 130d | 2001-09-24 A | 2002-03-22 A | 1892 | 100% | 2001-09-24 | 2002-03-22 | 130d | finish no earlier than 2002-03-22 | R3 | 1040h | 1040h |  | Rel-5 | Juha |  |  | Vodafone | Brendan.McWilliams@gb.vodafone.co.uk |
| 1894 | 90.3 | N1 work | 205d | 2001-09-17 A | 2002-06-28 A |  | 100% | 2001-09-17 | 2002-06-28 | 205d | start no earlier than 2001-09-17 | N1 | 1640h | 1640h |  | Rel-5 | Frederic |  | 24.008 and check 29.018 |  |  |
| 1895 | 90.4 | N4 work | 375d | 2000-10-02 A | 2002-03-08 A |  | 100% | 2000-10-02 | 2002-03-08 | 375d | finish no earlier than 2002-03-15 | N4 | 3000h | 3000h |  | Rel-5 | Kimmo |  |  |  |  |

Notes:
- 1871: Not started 02/3003. Marked as stopped 12/2008
- 1872: Marked as stopped 12/2008
- 1873: Marked as stopped 12/2008
- 1874: Marked as closed 12/2008 (was marked 17% complete)
- 1875: -
- 1876: -
- 1877: Marked as closed 12/2008 (was marked 75% complete)
- 1878: -
- 1879: 14/09/00: WI may need to be split to improve on this date. S3#17 15% complete. No progress since S3#17
- 1880: -
- 1881: Marked as stopped 12/2008
- 1882: Added BB UE authentication and rapporteur added. TO BE DELETED
- 1883: S3#17: All due in Rel5. (WI Update at S3#18). Replaced by NDS-IP and NDS-MAP. TO BE DELETED OR MOVED TO HISTORY FILE
- 1884: Marked as stopped 12/2008
- 1885: TO BE DELETED. Marked as stopped 12/2008
- 1886: Waiting for input from SA3!.... Marked as stopped 12/2008
- 1887: TO BE DELETED. Marked as stopped 12/2008
- 1888: -
- 1889: 14/02/2002 requirements are not clear/not received...Marked as closed 12/2008 (was marked 95 complete)
- 1890: 2002/12: All IPsec RFCs are stable STD Track RFCs. WID updated SP#17
- 1891: No clear indication on the end date. Put to Rel5 by AS.
- 1892: -
- 1893: Not identified
- 1894: -
- 1895: DAB 12.12.01 - % complete to 66% / 14/02/02 Work completed

| ID | WBS | Task | Duration | Start | Finish | Complete | Baseline start | Baseline finish | Baseline duration | Constraint | Resources | Work | Actual work | Text1 | Text4 | Text5 | Text6 | Text8 | Text12 | Text3 |
| --- | --- | --- | --- | --- | --- | --- | --- | --- | --- | --- | --- | --- | --- | --- | --- | --- | --- | --- | --- | --- |
| 1896 | 90.5 | **GERAN work for Intra Domain Connection of RAN Nodes to Multiple CN Nodes** | 101d | 2002-02-08 A | 2002-06-28 A | 100% | 2002-02-08 | 2002-06-28 | 101d |  | GP | 4848h | 4848h | IDCRAN-GERAN | Ericsson | ingemar.backlund@era.ericsson.se | Rel-5 | Paolo |  |  |
| 1897 | 90.5.1 | Stage 2 (changes to ) | 101d | 2002-02-08 A | 2002-06-28 A | 100% | 2002-02-08 | 2002-06-28 | 101d | finish no earlier than 2002-06-28 | G1 | 808h | 808h |  |  |  | Rel-5 |  |  |  |
| 1898 | 90.5.2 | 43.051 Introduction of support for IDNNS in GERAN Iu mode | 101d | 2002-02-08 A | 2002-06-28 A | 100% | 2002-02-08 | 2002-06-28 | 101d | finish no earlier than 2002-06-28 | G1 | 808h | 808h |  |  |  | Rel-5 |  |  |  |
| 1899 | 90.5.3 | Stage 3 (changes to ) | 101d | 2002-02-08 A | 2002-06-28 A | 100% | 2002-02-08 | 2002-06-28 | 101d | finish no earlier than 2002-06-28 | G2 | 808h | 808h |  |  |  | Rel-5 | Gert |  |  |
| 1900 | 90.5.4 | 48.016 Use of Gb interface concepts when a network applies IDNNS | 101d | 2002-02-08 A | 2002-06-28 A | 100% | 2002-02-08 | 2002-06-28 | 101d | finish no earlier than 2002-06-28 | G2 | 808h | 808h |  |  |  | Rel-5 | Gert |  |  |
| 1901 | 90.5.5 | 48.018 Include MSC/VLR identity in CS IMSI paging | 101d | 2002-02-08 A | 2002-06-28 A | 100% | 2002-02-08 | 2002-06-28 | 101d | finish no earlier than 2002-06-28 | G2 | 808h | 808h |  |  |  | Rel-5 | Gert |  |  |
| 1902 | 91 | **Deleted - GERAN improvements 3 (new transport layer on interface A)** | 446d | 2001-04-06 A | 2002-12-20 A | 100% | 2001-04-06 | 2002-12-20 | 446d |  | GP | 14272h | 14272h | GEIMP3 |  |  | Rel-5 | Paolo |  |  |
| 1903 | 91.1 | **Deleted - Evolution of the transport for A** | 446d | 2001-04-06 A | 2002-12-20 A | 100% | 2001-04-06 | 2002-12-20 | 446d |  | GP | 10704h | 10704h | GEIMP3-EtA |  |  | Rel-5 | Paolo | GP-12 |  |
| 1904 | 91.1.1 | Deleted - Definition of a new A/Ater interface Transport Layer option based on the Iu Interface Transport Layer | 446d | 2001-04-06 A | 2002-12-20 A | 100% | 2001-04-06 | 2002-12-20 | 446d | finish no earlier than 2002-12-20 | GP | 3568h | 3568h |  |  |  | Rel-5 | Paolo | GP-12 |  |
| 1905 | 91.1.2 | Deleted - Adaptation of the Layer 3 BSSMAP procedures as required | 446d | 2001-04-06 A | 2002-12-20 A | 100% | 2001-04-06 | 2002-12-20 | 446d | finish no earlier than 2002-12-20 | GP | 3568h | 3568h |  |  |  | Rel-5 | Paolo | GP-12 |  |
| 1906 | 92 | **Rel-5 Charging and OAM&P** | 264d | 2001-09-10 A | 2002-09-12 A | 100% | 2001-09-10 | 2002-09-12 | 264d |  | S5 | 9976h | 9976h | OAM | VoiceStream, Motorola |  | Rel-5 | Dionisio |  |  |
| 1907 | 92.1 | Rel5 Principles, high level Requirements and Architecture | 205d | 2001-09-17 A | 2002-06-28 A | 100% | 2001-09-17 | 2002-06-28 | 205d | finish no earlier than 2002-06-28 | S5 | 1640h | 1640h | OAM-AR/PR | Motorola |  | Rel-5 | Dionisio |  | 32.101, 32.102 |
| 1908 | 92.2 | Rel5 Performance Management | 259d | 2001-09-17 A | 2002-09-12 A | 100% | 2001-09-17 | 2002-09-12 | 259d | finish no earlier than 2002-09-12 | S5 | 2072h | 2072h | OAM-PM | Nortel |  | Rel-5 | Dionisio |  | 32.4xy, 52.402 |
| 1909 | 92.3 | Rel5 Charging Management | 264d | 2001-09-10 A | 2002-09-12 A | 100% | 2001-09-10 | 2002-09-12 | 264d | finish no earlier than 2002-09-12 | S5 | 2112h | 2112h | OAM-CH | T-Mobile | Karl-Heinz.Nenner@T-MOBILE.DE | Rel-5 | Dionisio |  | 32.200, 32.205, 32.215, 32.225, 32.235 |
| 1910 | 92.4 | Rel5 Network Infrastructure Management | 255d | 2001-09-21 A | 2002-09-12 A | 100% | 2001-09-21 | 2002-09-12 | 255d | finish no earlier than 2002-09-12 | S5 | 2040h | 2040h | OAM-NIM | Ericsson | thomas.tovinger@ericsson.com | Rel-5 | Dionisio |  | 32.6xy, 32.3xy |
| 1911 | 93 | **GERAN enhancements for streaming services 1 (RLC enhancements)** | 430d | 2000-11-06 A | 2002-06-28 A | 100% | 2000-11-06 | 2002-06-28 | 430d |  | GP | 8944h | 8944h |  |  |  | Rel-5 | Paolo |  |  |
| 1912 | 93.1 | Concept | 258d | 2000-11-06 A | 2001-10-31 A | 100% | 2000-11-06 | 2001-10-31 | 258d | finish no earlier than 2001-10-31 | GP | 2064h | 2064h |  |  |  | Rel-5 | Paolo |  |  |
| 1913 | 93.2 | RLC protocol enhancement (SDU Discard) | 430d | 2000-11-06 A | 2002-06-28 A | 100% | 2000-11-06 | 2002-06-28 | 430d | finish no earlier than 2002-06-28 | GP | 3440h | 3440h |  |  |  | Rel-5 | Paolo |  |  |
| 1914 | 94 | **GERAN enhancements for streaming services 2 (usage of ECSD)** | 430d | 2000-11-06 A | 2002-06-28 A | 100% | 2000-11-06 | 2002-06-28 | 430d |  | GP | 19840h | 19840h |  | Ericsson | Frank Muller | Rel-5 | Paolo |  |  |
| 1915 | 94.1 | Usage of ECSD Concept | 380d | 2000-11-06 A | 2002-04-19 A | 100% | 2000-11-06 | 2002-04-19 | 380d | finish no earlier than 2002-04-19 | GP | 3040h | 3040h |  |  |  | Rel-5 | Paolo |  |  |
| 1916 | 94.2 | Stage 2 | 380d | 2000-11-06 A | 2002-04-19 A | 100% | 2000-11-06 | 2002-04-19 | 380d | finish no earlier than 2002-04-19 | GP | 3040h | 3040h |  |  |  | Rel-5 | Paolo |  |  |
| 1917 | 94.3 | Stage 3 | 430d | 2000-11-06 A | 2002-06-28 A | 100% | 2000-11-06 | 2002-06-28 | 430d | finish no earlier than 2002-06-28 | GP | 3440h | 3440h |  |  |  | Rel-5 | Paolo |  |  |
| 1918 | 94.4 | RLC PDU formats | 430d | 2000-11-06 A | 2002-06-28 A | 100% | 2000-11-06 | 2002-06-28 | 430d | finish no earlier than 2002-06-28 | GP | 3440h | 3440h |  |  |  | Rel-5 | Paolo |  |  |
| 1919 | 94.5 | MAC header | 430d | 2000-11-06 A | 2002-06-28 A | 100% | 2000-11-06 | 2002-06-28 | 430d | finish no earlier than 2002-06-28 | GP | 3440h | 3440h |  |  |  | Rel-5 | Paolo |  |  |

Notes:
- 1896: Accept changes Gb over IP
- 1897: -
- 1898: -
- 1899: -
- 1900: Closed, accept changes for Gb over IP
- 1901: -
- 1902: Terminated - not standardized. Marked as stopped 12/2008
- 1903: TERMINATED - NOT STANDARDIZED. Marked as stopped 12/2008
- 1904: TERMINATED - NOT STANDARDIZED. Marked as stopped 12/2008
- 1905: TERMINATED - NOT STANDARDIZED. Marked as stopped 12/2008
- 1906: -
- 1907: -
- 1908: -
- 1909: -
- 1910: -
- 1911: -
- 1912: -
- 1913: -
- 1914: AWS, Nokia, Ericsson, Nortel, Siemens, Motorola, Vodafone
- 1915: -
- 1916: -
- 1917: -
- 1918: -
- 1919: -

| ID | WBS | Task | Duration | Start | Finish | Predecessors | Complete | Baseline start | Baseline finish | Baseline duration | Constraint | Resources | Work | Actual work | Text1 | Text4 | Text5 | Text6 | Text8 |
| --- | --- | --- | --- | --- | --- | --- | --- | --- | --- | --- | --- | --- | --- | --- | --- | --- | --- | --- | --- |
| 1920 | 95 | **GERAN/UTRAN interface evolution 1 (evolution of Iu PS)** | 476d | 2000-09-01 A | 2002-06-28 A |  | 100% | 2000-09-01 | 2002-06-28 | 476d |  | GP,R3 | 10688h | 10688h | GERUEV1 | SBC | Marc Grant | Rel-5 | Paolo |
| 1921 | 95.1 | **Evolution of Iu ps** | 476d | 2000-09-01 A | 2002-06-28 A |  | 100% | 2000-09-01 | 2002-06-28 | 476d |  | GP,R3 | 7248h | 7248h | GERUEV1-IuPS |  |  | Rel-5 | Paolo |
| 1922 | 95.1.1 | Identification of GERAN requirements on Iu ps | 326d | 2000-09-01 A | 2001-11-30 A |  | 100% | 2000-09-01 | 2001-11-30 | 326d | finish no earlier than 2001-11-30 | GP,R3 | 2608h | 2608h |  |  |  | Rel-5 | Paolo |
| 1923 | 95.1.2 | Update of specifications | 150d | 2001-12-03 A | 2002-06-28 A | 1922 | 100% | 2001-12-03 | 2002-06-28 | 150d | finish no earlier than 2002-06-28 | GP,R3 | 1200h | 1200h |  |  |  | Rel-5 | Paolo |
| 1924 | 96 | **GERAN/UTRAN interface evolution 2 (evolution of Iu CS)** | 476d | 2000-09-01 A | 2002-06-28 A |  | 100% | 2000-09-01 | 2002-06-28 | 476d |  | GP,R3 | 12816h | 12816h | GERUEV2 |  |  | Rel-5 | Paolo |
| 1925 | 96.1 | **Evolution of Iu cs** | 476d | 2000-09-01 A | 2002-06-28 A |  | 100% | 2000-09-01 | 2002-06-28 | 476d |  | GP,R3 | 10016h | 10016h | GERUEV2-IuCS | Lucent | Krishna Balachandran | Rel-5 | Paolo |
| 1926 | 96.1.1 | Identification of GERAN requirements on Iu cs | 426d | 2000-09-01 A | 2002-06-24 A |  | 100% | 2000-09-01 | 2002-06-24 | 426d | finish no earlier than 2002-04-19 | GP,R3 | 3408h | 3408h |  |  |  | Rel-5 | Paolo |
| 1927 | 96.1.2 | Update of specifications | 476d | 2000-09-01 A | 2002-06-28 A |  | 100% | 2000-09-01 | 2002-06-28 | 476d | finish no earlier than 2002-06-28 | GP,R3 | 3808h | 3808h |  |  |  | Rel-5 | Paolo |
| 1928 | 97 | **End to End QoS for PS Domain including IMS** | 480d | 2000-08-28 A | 2002-06-28 A |  | 100% | 2000-08-28 | 2002-06-28 | 480d |  | S2 | 9856h | 9856h | E2EQoS | Ericsson | Johnson.oyama@era.ericcson.se | Rel-5 | Maurice |
| 1929 | 97.1 | E2E QoSConcept and Architecture | 178d | 2001-01-03 A | 2001-09-07 A |  | 100% | 2001-01-03 | 2001-09-07 | 178d | finish no earlier than 2001-09-07 | S2 | 1424h | 1424h |  |  |  | Rel-5 | Maurice |
| 1930 | 97.2 | E2E QoS interworking | 465d | 2000-08-28 A | 2002-06-07 A |  | 100% | 2000-08-28 | 2002-06-07 | 465d | finish no earlier than 2002-06-07 | N3 | 3720h | 3720h | E2EQoS-IW | Lucent | Daisuke Yokota (yokota@lucent.com) | Rel-5 | Gwiho |
| 1931 | 97.3 | QoS Management (Provisioning and Monitoring) | 201d | 2001-09-21 A | 2002-06-28 A |  | 100% | 2001-09-21 | 2002-06-28 | 201d | finish no earlier than 2002-06-28 | S5 | 1608h | 1608h | E2EQoS-OAM | VoiceStream, Motorola |  | Rel-5 | Dionisio |
| 1932 | 98 | **Messaging enhancements Rel-5** | 467d | 2001-06-15 A | 2003-03-31 A |  | 100% | 2001-06-15 | 2003-03-31 | 467d |  | T2 | 19000h | 19000h | MESS5 |  |  | Rel-5 | Kimmo |
| 1933 | 98.1 | **Multimedia Messaging (MMS) enhancements** | 467d | 2001-06-15 A | 2003-03-31 A |  | 100% | 2001-06-15 | 2003-03-31 | 467d |  | T2 | 11688h | 11688h | MESS5-MMS | Siemens | Josef.Laumen@SAL.SIEMENS.DE | Rel-5 | Alain |
| 1934 | 98.1.1 | Definition of service requirements | 196d | 2001-06-15 A | 2002-03-15 A |  | 100% | 2001-06-15 | 2002-03-15 | 196d | finish no earlier than 2002-03-15 | S1 | 1568h | 1568h | MESS5-SR | Siemens | Josef.Laumen@SAL.SIEMENS.DE | Rel-5 |  |
| 1935 | 98.1.2 | Technical realization | 256d | 2001-06-15 A | 2002-06-07 A |  | 100% | 2001-06-15 | 2002-06-07 | 256d | finish no earlier than 2002-06-07 | T2 | 2048h | 2048h |  | Siemens | Josef.Laumen@SAL.SIEMENS.DE | Rel-5 |  |
| 1936 | 98.1.3 | WAP Forum dependency: MM1 stage 3 | 467d | 2001-06-15 A | 2003-03-31 A |  | 100% | 2001-06-15 | 2003-03-31 | 467d | finish no earlier than 2003-03-31 | T2 | 3736h | 3736h |  |  |  | Rel-5 |  |
| 1937 | 98.1.4 | MMS formats and codecs | 75d | 2001-12-03 A | 2002-03-15 A |  | 100% | 2001-12-03 | 2002-03-15 | 75d | finish no earlier than 2002-03-15 | S4 | 600h | 600h |  |  |  | Rel-5 | Paolo |
| 1938 | 98.2 | **Enhanced Messaging Service (EMS) enhancements** | 191d | 2001-06-15 A | 2002-03-08 A |  | 100% | 2001-06-15 | 2002-03-08 | 191d |  | T2 | 3584h | 3584h | MESS5-EMS | Ericsson | Alan.Baldwin@EML.ERICSSON.SE | Rel-5 |  |
| 1939 | 98.2.1 | Definition of service requirements | 66d | 2001-06-15 A | 2001-09-14 A |  | 100% | 2001-06-15 | 2001-09-14 | 66d | finish no earlier than 2001-09-14 | S1 | 528h | 528h |  | Ericsson | Alan.Baldwin@EML.ERICSSON.SE | Rel-5 | Alain |
| 1940 | 98.2.2 | Technical realization | 191d | 2001-06-15 A | 2002-03-08 A |  | 100% | 2001-06-15 | 2002-03-08 | 191d | finish no earlier than 2002-03-08 | T2 | 1528h | 1528h |  | Ericsson | Alan.Baldwin@EML.ERICSSON.SE | Rel-5 |  |
| 1941 | 99 | **GERAN Inter BSC NACC improvements over the Gb Interface** | 215d | 2001-09-03 A | 2002-06-28 A |  | 100% | 2001-09-03 | 2002-06-28 | 215d |  | GP | 8200h | 8200h | GERNACC |  |  | Rel-5 | Paolo |
| 1942 | 99.1 | **Modification of core network protocols for GERAN Inter BSC NACC over Gb Interface** | 165d | 2001-09-03 A | 2002-04-19 A |  | 100% | 2001-09-03 | 2002-04-19 | 165d |  | N4,S2 | 4064h | 4064h | GERNACC-Cnmod |  |  | Rel-5 | Kimmo |
| 1943 | 99.1.1 | Stage 2 - Concept | 43d | 2001-09-03 A | 2001-10-31 A |  | 100% | 2001-09-03 | 2001-10-31 | 43d | finish no earlier than 2001-10-31 | N4,S2 | 344h | 344h |  |  |  | Rel-5 | Kimmo |
| 1944 | 99.1.2 | Stage 2 - 23.060 change - Definition of Inter BSC NACC | 165d | 2001-09-03 A | 2002-04-19 A |  | 100% | 2001-09-03 | 2002-04-19 | 165d | finish no earlier than 2002-04-19 | N4,S2 | 1320h | 1320h |  |  |  | Rel-5 | Kimmo |
| 1945 | 99.1.3 | Stage 3 (changes to TS 29.060) | 135d | 2001-09-03 A | 2002-03-08 A |  | 100% | 2001-09-03 | 2002-03-08 | 135d | finish no earlier than 2002-03-08 | N4 | 1080h | 1080h |  |  |  | Rel-5 | Kimmo |

Notes:
- 1920: SBC, Motorola, Nokia, Ericsson, Nortel
- 1921: -
- 1922: -
- 1923: -
- 1924: -
- 1925: Lucent, Ericsson, AWS, Nortel
- 1926: -
- 1927: -
- 1928: -
- 1929: - / Text3: 23.207
- 1930: [DAB - 30/07/02] - % complete to 95% (if we exclude Diffserv). Marked as closed 12/2008 (was marked 95% complete) / Text3: 29.208, 29.207, 27.060, 29.061, 24.008, 24.228, , 24.229, 29.060, 29.163
- 1931: - / Text3: 32-series
- 1932: support of UAProf, so this in my opinion is 100% complete
- 1933: -
- 1934: - / Text3: 22.140
- 1935: stage 3 MM7 is missing / Text3: 23.140
- 1936: Marked as closed 12/2008 (was marked 80% complete)
- 1937: - / Text3: 26.140
- 1938: - / Text3: 23.040
- 1939: -
- 1940: - / Text3: 23.040
- 1941: -
- 1942: -
- 1943: -
- 1944: -
- 1945: IP 30/11/01: Input awaited from GERAN2 to CN4 / 17 May Work complete 100%

| ID | WBS | Task | Duration | Start | Finish | Complete | Baseline start | Baseline finish | Baseline duration | Constraint | Resources | Work | Actual work | Text1 | Text6 | Text8 | Text12 | Text3 | Text4 | Text5 |
| --- | --- | --- | --- | --- | --- | --- | --- | --- | --- | --- | --- | --- | --- | --- | --- | --- | --- | --- | --- | --- |
| 1946 | 99.2 | **Modification of Gb protocols for GERAN Inter BSC NACC over Gb Interface** | 151d | 2001-11-30 A | 2002-06-28 A | 100% | 2001-11-30 | 2002-06-28 | 151d |  | GP | 2416h | 2416h | GERNACC-Gbmod | Rel-5 | Paolo |  |  |  |  |
| 1947 | 99.2.1 | Stage 3 (changes to TS 48.018) | 151d | 2001-11-30 A | 2002-06-28 A | 100% | 2001-11-30 | 2002-06-28 | 151d | finish no earlier than 2002-06-28 | GP | 1208h | 1208h |  | Rel-5 | Paolo |  |  |  |  |
| 1948 | 100 | **Enhanced Power Control** | 540d | 2001-11-26 A | 2003-12-19 A | 100% | 2001-11-26 | 2003-12-19 | 540d |  | GP | 12840h | 12840h | EPC | Rel-5 | Paolo |  |  |  |  |
| 1949 | 100.1 | Realization of Enhanced power control and signalling support | 5d | 2001-11-26 A | 2001-11-30 A | 100% | 2001-11-26 | 2001-11-30 | 5d | finish no earlier than 2001-11-30 | GP | 40h | 40h |  | Rel-5 | Paolo |  |  |  |  |
| 1950 | 100.2 | Deleted - GERAN MS Conformance test for Enhanced Power Control | 530d | 2001-12-10 A | 2003-12-19 A | 100% | 2001-12-10 | 2003-12-19 | 530d | finish no earlier than 2003-12-19 | GP | 4240h | 4240h |  | Rel-5 | Paolo | GP-17 |  |  |  |
| 1951 | 100.3 | Deleted - GERAN BTS Conformance test for Enhanced Power Control | 530d | 2001-12-10 A | 2003-12-19 A | 100% | 2001-12-10 | 2003-12-19 | 530d | finish no earlier than 2003-12-19 | GP | 4240h | 4240h |  | Rel-5 | Paolo | GP-17 |  |  |  |
| 1952 | 101 | **8PSK AMR HR** | 530d | 2001-12-10 A | 2003-12-19 A | 100% | 2001-12-10 | 2003-12-19 | 530d |  | GP | 21080h | 21080h | 8PSK-AH | Rel-5 | Paolo |  |  |  |  |
| 1953 | 101.1 | **Definition of channel coding, performance requirements and signalling support** | 145d | 2001-12-10 A | 2002-06-28 A | 100% | 2001-12-10 | 2002-06-28 | 145d |  | GP | 10440h | 10440h |  | Rel-5 | Paolo |  |  |  |  |
| 1954 | 101.1.1 | Concept | 145d | 2001-12-10 A | 2002-06-28 A | 100% | 2001-12-10 | 2002-06-28 | 145d | finish no earlier than 2002-06-28 | GP | 1160h | 1160h |  | Rel-5 | Paolo |  |  |  |  |
| 1955 | 101.1.2 | Changes to 44.018 | 145d | 2001-12-10 A | 2002-06-28 A | 100% | 2001-12-10 | 2002-06-28 | 145d | finish no earlier than 2002-06-28 | G2 | 1160h | 1160h |  | Rel-5 | Gert |  |  |  |  |
| 1956 | 101.1.3 | Changes to 45.001 | 145d | 2001-12-10 A | 2002-06-28 A | 100% | 2001-12-10 | 2002-06-28 | 145d | finish no earlier than 2002-06-28 | G1 | 1160h | 1160h |  | Rel-5 |  |  |  |  |  |
| 1957 | 101.1.4 | Changes to 45.002 | 145d | 2001-12-10 A | 2002-06-28 A | 100% | 2001-12-10 | 2002-06-28 | 145d | finish no earlier than 2002-06-28 | G1 | 1160h | 1160h |  | Rel-5 |  |  |  |  |  |
| 1958 | 101.1.5 | Changes to 45.003 | 145d | 2001-12-10 A | 2002-06-28 A | 100% | 2001-12-10 | 2002-06-28 | 145d | finish no earlier than 2002-06-28 | G1 | 1160h | 1160h |  | Rel-5 |  |  |  |  |  |
| 1959 | 101.1.6 | Changes to 45.005 | 145d | 2001-12-10 A | 2002-06-28 A | 100% | 2001-12-10 | 2002-06-28 | 145d | finish no earlier than 2002-06-28 | G1 | 1160h | 1160h |  | Rel-5 |  |  |  |  |  |
| 1960 | 101.1.7 | Changes to 24.008 | 145d | 2001-12-10 A | 2002-06-28 A | 100% | 2001-12-10 | 2002-06-28 | 145d | finish no earlier than 2002-06-28 | G2 | 1160h | 1160h |  | Rel-5 | Gert |  |  |  |  |
| 1961 | 101.1.8 | Changes to 48.058 | 145d | 2001-12-10 A | 2002-06-28 A | 100% | 2001-12-10 | 2002-06-28 | 145d | finish no earlier than 2002-06-28 | G2 | 1160h | 1160h |  | Rel-5 | Gert |  |  |  |  |
| 1962 | 101.2 | Deleted - GERAN MS Conformance test for 8PSK HR | 530d | 2001-12-10 A | 2003-12-19 A | 100% | 2001-12-10 | 2003-12-19 | 530d | finish no earlier than 2003-12-19 | GP | 4240h | 4240h |  | Rel-5 | Paolo |  |  |  |  |
| 1963 | 101.3 | GERAN BTS Conformance test for 8PSK HR | 270d | 2001-12-10 A | 2002-12-20 A | 100% | 2001-12-10 | 2002-12-20 | 270d | finish no earlier than 2002-12-20 | GP | 2160h | 2160h |  | Rel-5 | Paolo |  |  |  |  |
| 1964 | 102 | Service Change and UDI Fallback | 175d | 2001-10-08 A | 2002-06-07 A | 100% | 2001-10-08 | 2002-06-07 | 175d | finish no earlier than 2002-06-07 | N3 | 1400h | 1400h | SCUDIF | Rel-5 | Gwiho |  | 29.007, 27.001, 24.008 | Ericsson | Rune.Werner.Wiik@ericsson.no |
| 1965 | 103 | **Rel-5 USIM toolkit enhancements** | 865d | 2000-06-05 A | 2003-09-26 A | 100% | 2000-06-05 | 2003-09-26 | 865d |  | T3 | 24352h | 24352h | USAT1-Interpr | Rel-5 | Xavier |  |  | G & D | Michael Meyer |
| 1966 | 103.1 | Deleted - Test specification for USIM toolkit security mechanisms | 349d | 2002-05-28 A | 2003-09-26 A | 100% | 2002-05-28 | 2003-09-26 | 349d | finish no earlier than 2003-09-26 | T3 | 2792h | 2792h |  | Rel-5 |  | TP-21 |  | Gemplus | Sophie Viallet |
| 1967 | 103.2 | **Protocol Standardisation of a SIM Toolkit Interpreter** | 688d | 2000-06-05 A | 2003-01-22 A | 100% | 2000-06-05 | 2003-01-22 | 688d |  | T3 | 12512h | 12512h | USAT1-Interpr | Rel-5 | Xavier |  | 27.103 | G & D | Michael Meyer |
| 1968 | 103.2.1 | Stage 1 | 205d | 2000-06-05 A | 2001-03-16 A | 100% | 2000-06-05 | 2001-03-16 | 205d | finish no earlier than 2001-03-16 | T3 | 1640h | 1640h | USAT1-Interpr | Rel-5 | Xavier |  |  |  |  |
| 1969 | 103.2.2 | Stage 2 and 3 | 308d | 2001-01-03 A | 2002-03-08 A | 100% | 2001-01-03 | 2002-03-08 | 308d | finish no earlier than 2002-03-08 | T3 | 2464h | 2464h | USAT1-Interpr | Rel-5 | Xavier |  |  |  |  |
| 1970 | 103.2.3 | Test specification | 363d | 2001-09-03 A | 2003-01-22 A | 100% | 2001-09-03 | 2003-01-22 | 363d | finish no earlier than 2003-01-22 | T3 | 2904h | 2904h | USAT1-Interpr | Rel-5 | Xavier |  |  | Gemplus | Gérald MAUNIER |

Notes:
- 1946: -
- 1947: -
- 1948: -
- 1949: Completed 11/2001
- 1950: Not started. Marked as stopped 12/2008
- 1951: Not started. Marked as stopped 12/2008
- 1952: Completed for Rel-5
- 1953: -
- 1954: -
- 1955: -
- 1956: -
- 1957: -
- 1958: -
- 1959: -
- 1960: -
- 1961: -
- 1962: Marked as stopped 12/2008
- 1963: -
- 1964: -
- 1965: -
- 1966: Marked as stopped 12/2008
- 1967: 28/5/2001: T3-19 proposed that since the stage 2 and 3 will not be presented to TP-12 for approval as expected, the WI will be moved to rel-5, with completion expected at TP-13.
- 1968: 5/10/2001: Stage one comepeted at TP-12.
- 1969: 5/10/2001: TS 31.112 and 31.113 approved at TP-13. TS 31.114 to be presented to TP-14.
- 1970: 5/10/2001: Work started on test specification. Marked as closed 12/2008 (was marked 12% complete)

| ID | WBS | Task | Duration | Start | Finish | Complete | Baseline start | Baseline finish | Baseline duration | Constraint | Resources | Work | Actual work | Text1 | Text4 | Text5 | Text6 | Text8 | Text12 |
| --- | --- | --- | --- | --- | --- | --- | --- | --- | --- | --- | --- | --- | --- | --- | --- | --- | --- | --- | --- |
| 1971 | 103.4 | **(U)SIM API** | 133d | 2002-03-20 A | 2002-09-20 A | 100% | 2002-03-20 | 2002-09-20 | 133d |  | T3 | 2128h | 2128h | USAT1-API | Microelectrónica Española | Mario Pérez | Rel-5 | Xavier |  |
| 1972 | 103.4.1 | Java API Test specification | 133d | 2002-03-20 A | 2002-09-20 A | 100% | 2002-03-20 | 2002-09-20 | 133d | finish no earlier than 2002-09-20 | T3 | 1064h | 1064h | USAT1-API | Microelectrónica Española | Mario Pérez | Rel-5 | Xavier |  |
| 1973 | 104 | **small Technical Enhancements and Improvements for Rel5** | 2349d? | 2000-01-03 A | 2008-12-31 A | 100% | 2000-01-03 | 2008-12-31 | 2349d? |  | All | 18792h | 18792h | TEI5 |  |  | Rel-5 |  |  |
| 1974 | 511.1 | Small Technical Enhancements and Improvements for Rel-5 Conformance Testing | 2349d? | 2000-01-03 A | 2008-12-31 A | 100% | 2000-01-03 | 2008-12-31 | 2349d? | finish no earlier than 2008-12-31 | R5,T1 | 18792h | 18792h | TEI5_Test |  |  | Rel-5 | Ingbert |  |
| 1975 | 105 | Deleted - Technical Report on UE Functionality Split | 87d | 2000-01-03 A | 2000-05-01 A | 100% | 2000-01-03 | 2000-05-01 | 87d |  | S1 | 688h | 688h | UESPLIT | Motorola | sanjay.gupta@motorola.com | Rel-5 | Alain | SP-08 |
| 1976 | 106 | **User Equipment Management** | 267d | 2001-06-21 A | 2002-06-28 A | 100% | 2001-06-21 | 2002-06-28 | 267d |  | S5 | 3752h | 3752h | UEM | Vodafone | john.mudge@vf.vodafone.co.uk | Rel-5 | Dionisio |  |
| 1977 | 106.1 | FS on User Equipment (UE) Management | 267d | 2001-06-21 A | 2002-06-28 A | 100% | 2001-06-21 | 2002-06-28 | 267d | finish no earlier than 2002-06-28 | S5 | 2136h | 2136h | OAM-UEM | Vodafone | john.mudge@vf.vodafone.co.uk | Rel-5 | Dionisio |  |
| 1978 | 107 | **Flow control supporting an MS with multiple data flows with different QoS over the Gb interface** | 50d | 2002-06-24 A | 2002-08-30 A | 100% | 2002-06-24 | 2002-08-30 | 50d |  | GP | 1288h | 1288h | FlowCon | Ericsson | ingemar.backlund@era.ericsson.se | Rel-5 | Paolo |  |
| 1979 | 107.1 | **Update of stage 2 specifications** | 50d | 2002-06-24 A | 2002-08-30 A | 100% | 2002-06-24 | 2002-08-30 | 50d |  | GP | 808h | 808h |  |  |  | Rel-5 | Paolo |  |
| 1980 | 107.1.1 | Concept document 23.060 (changes to) | 46d | 2002-06-28 A | 2002-08-30 A | 100% | 2002-06-28 | 2002-08-30 | 46d | finish no earlier than 2002-08-30 | S2 | 368h | 368h |  |  |  | Rel-5 | Maurice |  |
| 1981 | 107.1.2 | Flow Control | 5d | 2002-06-24 A | 2002-06-28 A | 100% | 2002-06-24 | 2002-06-28 | 5d | finish no earlier than 2002-06-28 | GP | 40h | 40h |  |  |  | Rel-5 | Paolo |  |
| 1982 | 107.2 | **Modification of BSSGP protocol** | 5d | 2002-06-24 A | 2002-06-28 A | 100% | 2002-06-24 | 2002-06-28 | 5d |  | GP | 80h | 80h |  | Ericsson | ingemar.backlund@era.ericsson.se | Rel-5 | Paolo |  |
| 1983 | 107.2.1 | Stage 3 (changes to 48.018) | 5d | 2002-06-24 A | 2002-06-28 A | 100% | 2002-06-24 | 2002-06-28 | 5d | finish no earlier than 2002-06-28 | G2 | 40h | 40h |  |  |  | Rel-5 | Gert |  |
| 1984 | 108 | **Deleted - Multiple TBF in A/Gb mode - Phase 1** | 421d | 2002-04-19 A | 2003-11-28 A | 100% | 2002-04-19 | 2003-11-28 | 421d |  | GP | 17480h | 17480h | MULTBF | Ericsson | gunnar.mildh@era.ericsson.se | Rel-5 | Paolo | GP-17 |
| 1985 | 108.1 | **Deleted - Multiple TBF in A/Gb mode - Phase 1** | 351d | 2002-04-19 A | 2003-08-22 A | 100% | 2002-04-19 | 2003-08-22 | 351d |  | GP | 8112h | 8112h | MULTBF-Agbmode |  |  | Rel-5 | Paolo | GP-17 |
| 1986 | 108.1.1 | Deleted - Multiple TBF Concept paper | 351d | 2002-04-19 A | 2003-08-22 A | 100% | 2002-04-19 | 2003-08-22 | 351d | finish no earlier than 2003-08-22 | GP | 2808h | 2808h | MULTBF-Agbmode |  |  | Rel-5 | Paolo | GP-17 |
| 1987 | 108.1.2 | Deleted - Multiple TBF Stage 2 (43.064) CRs | 156d | 2002-04-19 A | 2002-11-22 A | 100% | 2002-04-19 | 2002-11-22 | 156d | finish no earlier than 2002-11-22 | G1 | 1248h | 1248h | MULTBF-Agbmode |  |  | Rel-5 | Paolo | GP-12 |
| 1988 | 108.1.3 | Deleted - Multiple TBF Stage 3 (44.060) CRs | 156d | 2002-04-19 A | 2002-11-22 A | 100% | 2002-04-19 | 2002-11-22 | 156d | finish no earlier than 2002-11-22 | G2 | 1248h | 1248h | MULTBF-Agbmode |  |  | Rel-5 | Gert | GP-12 |
| 1989 | 108.2 | **Deleted - Multiple TBF in A/Gb mode – MS testing** | 375d | 2002-06-24 A | 2003-11-28 A | 100% | 2002-06-24 | 2003-11-28 | 375d |  | GP | 6000h | 6000h |  | Ericsson | ingemar.backlund@era.ericsson.se | Rel-5 | Paolo | GP-17 |
| 1990 | 108.2.1 | Deleted - MS conformance tests | 375d | 2002-06-24 A | 2003-11-28 A | 100% | 2002-06-24 | 2003-11-28 | 375d | finish no earlier than 2003-11-28 | G4 | 3000h | 3000h |  |  |  | Rel-5 | Paolo | GP-17 |
| 1991 | 109 | **Alignment of 3G functional split and Iu** | 922d | 2000-06-08 A | 2003-12-19 A | 100% | 2000-06-08 | 2003-12-19 | 922d |  | GP | 126664h | 126664h | GER3GAL | Ericsson | Frank Muller | Rel-5 | Paolo |  |
| 1992 | 109.1 | **GERAN user / control plane** | 540d | 2000-08-07 A | 2002-08-30 A | 100% | 2000-08-07 | 2002-08-30 | 540d |  | GP | 36232h | 36232h | GER3GAL-GUCOPL | Ericsson | Frank Muller | Rel-5 | Paolo |  |
| 1993 | 109.1.1 | **Alignment with UMTS bearer concept** | 540d | 2000-08-07 A | 2002-08-30 A | 100% | 2000-08-07 | 2002-08-30 | 540d |  | GP | 24952h | 24952h |  |  |  | Rel-5 | Paolo |  |
| 1994 | 109.1.1.1 | Enhanced power control | 1d | 2001-08-31 A | 2001-08-31 A | 100% | 2001-08-31 | 2001-08-31 | 1d | finish no earlier than 2001-08-31 | GP | 8h | 8h |  |  |  | Rel-5 | Paolo |  |
| 1995 | 109.1.1.2 | Stage 2 | 235d | 2000-08-07 A | 2001-06-29 A | 100% | 2000-08-07 | 2001-06-29 | 235d | finish no earlier than 2001-06-29 | GP | 1880h | 1880h |  |  |  | Rel-5 | Paolo |  |
| 1996 | 109.1.1.3 | Adoption of the UTRAN PDCP | 295d | 2000-11-06 A | 2001-12-21 A | 100% | 2000-11-06 | 2001-12-21 | 295d | finish no earlier than 2001-12-21 | GP | 2360h | 2360h |  |  |  | Rel-5 | Paolo |  |
| 1997 | 109.1.1.4 | Development of RLC / MAC | 261d | 2001-08-31 A | 2002-08-30 A | 100% | 2001-08-31 | 2002-08-30 | 261d | finish no earlier than 2002-08-30 | GP | 2088h | 2088h |  |  |  | Rel-5 | Paolo |  |
| 1998 | 109.1.1.5 | Development of GERAN RRC | 266d | 2001-06-22 A | 2002-06-28 A | 100% | 2001-06-22 | 2002-06-28 | 266d | finish no earlier than 2002-06-28 | GP | 2128h | 2128h |  |  |  | Rel-5 | Paolo |  |
| 1999 | 109.1.1.6 | Ciphering and integrity protection concept paper | 166d | 2001-08-31 A | 2002-04-19 A | 100% | 2001-08-31 | 2002-04-19 | 166d | finish no earlier than 2002-04-19 | GP | 1328h | 1328h |  |  |  | Rel-5 | Paolo |  |
| 2000 | 109.1.1.7 | Multiple TBF or equivalent Concept paper | 116d | 2001-08-31 A | 2002-02-08 A | 100% | 2001-08-31 | 2002-02-08 | 116d | finish no earlier than 2002-02-08 | GP | 928h | 928h |  |  |  | Rel-5 | Paolo |  |
| 2001 | 109.1.1.8 | Paging concept | 166d | 2001-08-31 A | 2002-04-19 A | 100% | 2001-08-31 | 2002-04-19 | 166d | finish no earlier than 2002-04-19 | GP | 1328h | 1328h |  |  |  | Rel-5 | Paolo |  |
| 2002 | 109.1.1.9 | Dedicated Physical subchannels, includes traffic and control channels | 66d | 2001-08-31 A | 2001-11-30 A | 100% | 2001-08-31 | 2001-11-30 | 66d | finish no earlier than 2001-11-30 | GP | 528h | 528h |  |  |  | Rel-5 | Paolo |  |
| 2003 | 109.1.1.10 | Iu support and broadcast concept | 166d | 2001-08-31 A | 2002-04-19 A | 100% | 2001-08-31 | 2002-04-19 | 166d | finish no earlier than 2002-04-19 | GP | 1328h | 1328h |  |  |  | Rel-5 | Paolo |  |
| 2004 | 109.1.1.11 | Impact of using RLC instead of LAPDm concept | 116d | 2001-08-31 A | 2002-02-08 A | 100% | 2001-08-31 | 2002-02-08 | 116d | finish no earlier than 2002-02-08 | GP | 928h | 928h |  |  |  | Rel-5 | Paolo |  |
| 2005 | 109.1.1.12 | Contention resolution, mobile station identity, and access concept | 66d | 2001-08-31 A | 2001-11-30 A | 100% | 2001-08-31 | 2001-11-30 | 66d | finish no earlier than 2001-11-30 | GP | 528h | 528h |  |  |  | Rel-5 | Paolo |  |
| 2006 | 109.1.1.13 | PDCP concept | 166d | 2001-08-31 A | 2002-04-19 A | 100% | 2001-08-31 | 2002-04-19 | 166d | finish no earlier than 2002-04-19 | GP | 1328h | 1328h |  |  |  | Rel-5 | Paolo |  |
| 2007 | 109.1.1.14 | Downlink delayed TBF release | 261d | 2001-08-31 A | 2002-08-30 A | 100% | 2001-08-31 | 2002-08-30 | 261d | finish no earlier than 2002-08-30 | GP | 2088h | 2088h |  |  |  | Rel-5 | Paolo |  |
| 2008 | 109.1.1.15 | Add transparent RLC Concept | 116d | 2001-08-31 A | 2002-02-08 A | 100% | 2001-08-31 | 2002-02-08 | 116d | finish no earlier than 2002-02-08 | GP | 928h | 928h |  |  |  | Rel-5 | Paolo |  |
| 2009 | 109.1.1.16 | Handover concept | 116d | 2001-08-31 A | 2002-02-08 A | 100% | 2001-08-31 | 2002-02-08 | 116d | finish no earlier than 2002-02-08 | GP | 928h | 928h |  |  |  | Rel-5 | Paolo |  |

Notes:
- 1971: 8/3/2001: test spec is based on R99 core spec, so deleted from Workplan
- 1972: -
- 1973: "Joker" WI, to be used for a Rel 5 CR not related to any feature and with very limited impact on the system
- 1974: "Joker" WI, to be used for small modifications applicable to Rel 5 conformance testing. Moved in from Stoyan/testing WP. / Text3: 34.108, 34.109, 34.121-1, 34.121-2, 34.122, 34.123-1, 34.123-2, 34.123-3, 34.171, 34.229-1, 34.229-2, 34.229-3
- 1975: -
- 1976: - / Text3: 32.802
- 1977: - / Text3: 32.802
- 1978: 50101 -> 50201
- 1979: 50102 -> 50202
- 1980: -
- 1981: 50103 -> 50203
- 1982: -
- 1983: -
- 1984: GP#17 Nov 2003 Moved to Rel-6 as UID_50600 MULTBF (Only Multiple TBF Concept paper produced in Rel-5)
- 1985: Marked as closed 12/2008 (was marked 26% complete)
- 1986: Marked as closed 12/2008 (was marked 50% complete)
- 1987: Marked as stopped 12/2008
- 1988: Marked as stopped 12/2008
- 1989: 08/08: duplicate UID_50106=-> 50206. Marked as stopped 12/2008
- 1990: Not started. Marked as stopped 12/2008
- 1991: AWS, Nokia, Ericsson, Nortel, Siemens, Vodafone
- 1992: AWS, Nokia, Ericsson, Nortel, Siemens, Vodafone
- 1993: -
- 1994: -
- 1995: -
- 1996: Responsible is GERAN; RAN WG2 help may be needed.
- 1997: -
- 1998: -
- 1999: -
- 2000: -
- 2001: -
- 2002: -
- 2003: -
- 2004: -
- 2005: -
- 2006: -
- 2007: -
- 2008: -
- 2009: -

| ID | WBS | Task | Duration | Start | Finish | Complete | Baseline start | Baseline finish | Baseline duration | Constraint | Resources | Work | Actual work | Text6 | Text8 | Text1 | Text4 | Text5 |
| --- | --- | --- | --- | --- | --- | --- | --- | --- | --- | --- | --- | --- | --- | --- | --- | --- | --- | --- |
| 2010 | 109.1.2 | **Physical layer alignment with UMTS bearer concept** | 280d | 2000-11-06 A | 2001-11-30 A | 100% | 2000-11-06 | 2001-11-30 | 280d |  | GP | 6960h | 6960h | Rel-5 | Paolo |  |  |  |
| 2011 | 109.1.2.1 | PDTCH/TCH in 45.003 | 155d | 2000-11-06 A | 2001-06-08 A | 100% | 2000-11-06 | 2001-06-08 | 155d | finish no earlier than 2001-06-08 | GP | 1240h | 1240h | Rel-5 | Paolo |  |  |  |
| 2012 | 109.1.2.2 | Control channels in 45.003 | 155d | 2000-11-06 A | 2001-06-08 A | 100% | 2000-11-06 | 2001-06-08 | 155d | finish no earlier than 2001-06-08 | GP | 1240h | 1240h | Rel-5 | Paolo |  |  |  |
| 2013 | 109.1.2.3 | Receiver performance in 45.005 for PDTCH/TCH and control channels | 280d | 2000-11-06 A | 2001-11-30 A | 100% | 2000-11-06 | 2001-11-30 | 280d | finish no earlier than 2001-11-30 | GP | 2240h | 2240h | Rel-5 | Paolo |  |  |  |
| 2014 | 109.2 | **Iu rg interface** | 430d | 2000-11-06 A | 2002-06-28 A | 100% | 2000-11-06 | 2002-06-28 | 430d |  | GP,RP | 39560h | 39560h | Rel-5 | Paolo | GER3GAL-Iurg | Ericsson | Frank Muller |
| 2015 | 109.2.1 | **Inter BSS interface** | 430d | 2000-11-06 A | 2002-06-28 A | 100% | 2000-11-06 | 2002-06-28 | 430d |  | GP,RP | 20640h | 20640h | Rel-5 | Paolo |  |  |  |
| 2016 | 109.2.1.1 | Identification of requirements | 430d | 2000-11-06 A | 2002-06-28 A | 100% | 2000-11-06 | 2002-06-28 | 430d | finish no earlier than 2002-06-28 | GP | 3440h | 3440h | Rel-5 | Paolo |  |  |  |
| 2017 | 109.2.1.2 | Stage 2 | 430d | 2000-11-06 A | 2002-06-28 A | 100% | 2000-11-06 | 2002-06-28 | 430d | finish no earlier than 2002-06-28 | GP | 3440h | 3440h | Rel-5 | Paolo |  |  |  |
| 2018 | 109.2.1.3 | Adoption of relevant parts from Iur | 430d | 2000-11-06 A | 2002-06-28 A | 100% | 2000-11-06 | 2002-06-28 | 430d | finish no earlier than 2002-06-28 | GP | 3440h | 3440h | Rel-5 | Paolo |  |  |  |
| 2019 | 109.2.1.4 | Complementation with GERAN specifics | 430d | 2000-11-06 A | 2002-06-28 A | 100% | 2000-11-06 | 2002-06-28 | 430d | finish no earlier than 2002-06-28 | GP | 3440h | 3440h | Rel-5 | Paolo |  |  |  |
| 2020 | 109.2.1.5 | Stage 3 | 430d | 2000-11-06 A | 2002-06-28 A | 100% | 2000-11-06 | 2002-06-28 | 430d | finish no earlier than 2002-06-28 | GP | 3440h | 3440h | Rel-5 | Paolo |  |  |  |
| 2021 | 109.2.2 | **Inter BSS-RNS interface** | 430d | 2000-11-06 A | 2002-06-28 A | 100% | 2000-11-06 | 2002-06-28 | 430d |  | GP,RP | 15480h | 15480h | Rel-5 | Paolo |  |  |  |
| 2022 | 109.2.2.1 | Identification of requirements | 430d | 2000-11-06 A | 2002-06-28 A | 100% | 2000-11-06 | 2002-06-28 | 430d | start no earlier than 2000-11-06 | GP,R3 | 3440h | 3440h | Rel-5 | Paolo |  |  |  |
| 2023 | 109.2.2.2 | Stage 2 | 430d | 2000-11-06 A | 2002-06-28 A | 100% | 2000-11-06 | 2002-06-28 | 430d | finish no earlier than 2002-06-28 | GP,R3 | 3440h | 3440h | Rel-5 | Paolo |  |  |  |
| 2024 | 109.2.2.3 | Adoption of relevant parts from Iur | 430d | 2000-11-06 A | 2002-06-28 A | 100% | 2000-11-06 | 2002-06-28 | 430d | finish no earlier than 2002-06-28 | GP,R3 | 3440h | 3440h | Rel-5 | Paolo |  |  |  |
| 2025 | 109.2.2.4 | Complementation with GERAN specifics | 107.5d | 2002-01-30 A | 2002-06-28 A | 100% | 2002-01-30 | 2002-06-28 | 107.5d | finish no earlier than 2002-06-28 | GP,R3 | 860h | 860h | Rel-5 | Paolo |  |  |  |
| 2026 | 109.2.2.5 | Stage 3 | 107.5d | 2002-01-30 A | 2002-06-28 A | 100% | 2002-01-30 | 2002-06-28 | 107.5d | finish no earlier than 2002-06-28 | GP,R3 | 860h | 860h | Rel-5 | Paolo |  |  |  |
| 2027 | 109.3 | **Voice over GERAN PS and CS concept** | 430d | 2000-11-06 A | 2002-06-28 A | 100% | 2000-11-06 | 2002-06-28 | 430d |  | GP,R3 | 18520h | 18520h | Rel-5 | Paolo |  |  |  |
| 2028 | 109.3.1 | Architecture for A, Iu cs and Iu ps | 430d | 2000-11-06 A | 2002-06-28 A | 100% | 2000-11-06 | 2002-06-28 | 430d | finish no earlier than 2002-06-28 | GP,R3 | 3440h | 3440h | Rel-5 | Paolo |  |  |  |
| 2029 | 109.3.2 | Transcoder position/operation | 115d | 2000-11-06 A | 2001-04-13 A | 100% | 2000-11-06 | 2001-04-13 | 115d | finish no earlier than 2001-04-13 | GP | 920h | 920h | Rel-5 | Paolo |  |  |  |
| 2030 | 109.3.3 | Handover | 430d | 2000-11-06 A | 2002-06-28 A | 100% | 2000-11-06 | 2002-06-28 | 430d | finish no earlier than 2002-06-28 | GP,R3 | 3440h | 3440h | Rel-5 | Paolo |  |  |  |
| 2031 | 109.3.4 | RTP payload | 430d | 2000-11-06 A | 2002-06-28 A | 100% | 2000-11-06 | 2002-06-28 | 430d | finish no earlier than 2002-06-28 | GP,R3 | 3440h | 3440h | Rel-5 | Paolo |  |  |  |
| 2032 | 109.3.5 | Codec renegotiation concept | 365d | 2000-11-06 A | 2002-03-29 A | 100% | 2000-11-06 | 2002-03-29 | 365d | finish no earlier than 2002-03-29 | GP,R3 | 2920h | 2920h | Rel-5 | Paolo |  |  |  |
| 2033 | 109.3.6 | LA | 115d | 2000-11-06 A | 2001-04-13 A | 100% | 2000-11-06 | 2001-04-13 | 115d | finish no earlier than 2001-04-13 | GP | 920h | 920h | Rel-5 | Paolo |  |  |  |

Notes:
- 2010: -
- 2011: -
- 2012: -
- 2013: -
- 2014: AWS, Nokia, Ericsson, Nortel, Siemens, Vodafone
- 2015: -
- 2016: -
- 2017: -
- 2018: -
- 2019: -
- 2020: -
- 2021: -
- 2022: -
- 2023: -
- 2024: -
- 2025: -
- 2026: -
- 2027: -
- 2028: -
- 2029: -
- 2030: -
- 2031: -
- 2032: -
- 2033: -

| ID | WBS | Task | Duration | Start | Finish | Complete | Baseline start | Baseline finish | Baseline duration | Total slack | Constraint | Resources | Work | Actual work | Text6 | Text8 | Text12 | Text1 | Text4 | Text5 |
| --- | --- | --- | --- | --- | --- | --- | --- | --- | --- | --- | --- | --- | --- | --- | --- | --- | --- | --- | --- | --- |
| 2034 | 109.4 | **Deleted - GERAN MS Conformance test for GERAN interface evolution** | 660d | 2001-06-11 A | 2003-12-19 A | 100% | 2001-06-11 | 2003-12-19 | 660d |  |  | GP | 10560h | 10560h | Rel-5 | Paolo | GP-17 |  |  |  |
| 2035 | 109.4.1 | Deleted - MS test | 660d | 2001-06-11 A | 2003-12-19 A | 100% | 2001-06-11 | 2003-12-19 | 660d |  | finish no earlier than 2003-12-19 | GP | 5280h | 5280h | Rel-5 | Paolo | GP-17 |  |  |  |
| 2036 | 109.5 | **GERAN BSS Conformance test for GERAN interface evolution** | 922d | 2000-06-08 A | 2003-12-19 A | 100% | 2000-06-08 | 2003-12-19 | 922d |  |  | GP | 14752h | 14752h | Rel-5 | Paolo |  |  |  |  |
| 2037 | 109.5.1 | Deleted - BSS test | 922d | 2000-06-08 A | 2003-12-19 A | 100% | 2000-06-08 | 2003-12-19 | 922d |  | finish no earlier than 2003-12-19 | GP | 7376h | 7376h | Rel-5 | Paolo | GP-17 |  |  |  |
| 2038 | 110 | **GERAN support for IMS** | 690d | 2000-05-01 A | 2002-12-20 A | 100% | 2000-05-01 | 2002-12-20 | 690d |  |  | GP | 39198.4h | 39198.4h | Rel-5 | Paolo |  | GERIMS | Nokia | Shkumbin Hamiti |
| 2039 | 110.1 | **GERAN Header adaptation** | 690d | 2000-05-01 A | 2002-12-20 A | 100% | 2000-05-01 | 2002-12-20 | 690d |  |  | GP,S2,RP | 12302.8h | 12302.8h | Rel-5 | Paolo |  | GERIMS-HEADAPT | Nokia | Shkumbin Hamiti |
| 2040 | 110.1.1 | Definition of compression and removal modes for PDCP protocol | 15.05d | 2000-05-01 A | 2000-06-09 A | 100% | 2000-05-01 | 2000-06-09 | 15.05d |  | finish no earlier than 2000-09-01 | GP,S2,RP | 120.4h | 120.4h | Rel-5 | Paolo |  |  |  |  |
| 2041 | 110.1.2 | Conceptual description in stage 2 | 393d | 2000-05-01 A | 2001-10-31 A | 100% | 2000-05-01 | 2001-10-31 | 393d |  | finish no earlier than 2001-10-31 | GP,S2,RP | 3144h | 3144h | Rel-5 | Paolo |  |  |  |  |
| 2042 | 110.1.3 | Necessary changes on stage 3 regarding header removal | 439.8d | 2000-11-06 A | 2002-12-20 A | 100% | 2000-11-06 | 2002-12-20 | 439.8d |  | finish no earlier than 2002-12-20 | GP,S2,RP | 3518.4h | 3518.4h | Rel-5 | Paolo |  |  |  |  |
| 2043 | 110.2 | **Deleted - GERAN Radio access bearer design for IMS** | 430d | 2000-11-06 A | 2002-06-28 A | 100% | 2000-11-06 | 2002-06-28 | 430d |  |  | GP,S2,RP | 9287.6h | 9287.6h | Rel-5 | Paolo | GP-10 | GERIMS-RABDES | Nokia | Shkumbin Hamiti |
| 2044 | 110.2.1 | **Deleted - MuM control signalling for conversational multimedia services** | 430d | 2000-11-06 A | 2002-06-28 A | 100% | 2000-11-06 | 2002-06-28 | 430d |  |  | GP,S2,RP | 5847.6h | 5847.6h | Rel-5 | Paolo | GP-10 |  |  |  |
| 2045 | 110.2.1.1 | Deleted - Identification of requirements | 330d | 2000-11-06 A | 2002-02-08 A | 100% | 2000-11-06 | 2002-02-08 | 330d |  | finish no earlier than 2002-02-08 | GP,S2,RP | 2640h | 2640h | Rel-5 | Paolo | GP-08 |  |  |  |
| 2046 | 110.2.1.2 | Deleted - Necessary modifications due to SIP | 40d | 2002-05-06 A | 2002-06-28 A | 100% | 2002-05-06 | 2002-06-28 | 40d |  | finish no earlier than 2002-06-28 | GP,S2,RP | 320h | 320h | Rel-5 | Paolo | GP-10 |  |  |  |
| 2047 | 110.3 | **Deleted - GERAN MS Conformance test for support of IMS** | 400d | 2001-06-11 A | 2002-12-20 A | 100% | 2001-06-11 | 2002-12-20 | 400d |  |  | GP | 6400h | 6400h | Rel-5 | Paolo | GP-12 | GERIMS-MSconf | Nokia | Shkumbin Hamiti |
| 2048 | 110.3.1 | Deleted - MS test | 400d | 2001-06-11 A | 2002-12-20 A | 100% | 2001-06-11 | 2002-12-20 | 400d |  | finish no earlier than 2002-12-20 | G4 | 3200h | 3200h | Rel-5 | Paolo | GP-12 |  |  |  |
| 2049 | 110.4 | **Deleted - GERAN BTS Conformance test for support of IMS** | 400d | 2001-06-11 A | 2002-12-20 A | 100% | 2001-06-11 | 2002-12-20 | 400d |  |  | GP | 6400h | 6400h | Rel-5 | Paolo | GP-12 | GERIMS-BTSconf | Nokia | Shkumbin Hamiti |
| 2050 | 110.4.1 | Deleted - BTS test | 400d | 2001-06-11 A | 2002-12-20 A | 100% | 2001-06-11 | 2002-12-20 | 400d |  | finish no earlier than 2002-12-20 | G3new | 3200h | 3200h | Rel-5 | Ingbert | GP-12 |  |  |  |
| 2051 | 518 | MS Conformance Testing of Dual Transfer Mode | 65d? | 2002-11-11 A | 2003-02-07 A | 100% | 2002-11-11 | 2003-02-07 | 65d? |  | finish no earlier than 2003-02-07 | G4,G5 | 520h | 520h | Rel-5 | Paolo |  | MSCTDTM | Vodafone | Dave Fox |
| 2052 | 519 | **Handling of early UEs** | 911d? | 2000-01-03 A | 2003-06-27 A | 100% | 2000-01-03 | 2003-06-27 | 911d? |  |  | S2 | 4488h | 4488h | Rel-5 | Maurice |  | LATE_UE |  |  |
| 2053 | 519.1 | Feasibility Study | 50d? | 2002-10-07 A | 2002-12-13 A | 100% | 2002-10-07 | 2002-12-13 | 50d? |  | finish no earlier than 2002-12-13 | S2 | 400h | 400h | Rel-5 | Maurice |  |  |  |  |
| 2054 | 519.2 | Stage 2 | 125d? | 2003-01-06 A | 2003-06-27 A | 100% | 2003-01-06 | 2003-06-27 | 125d? |  | start no earlier than 2003-01-06 | S2 | 1000h | 1000h | Rel-5 | Maurice |  |  |  |  |
| 2055 | 519.3 | FS for the Early Mobile Handling in UTRAN | 195d | 2002-09-09 A | 2003-06-06 A | 100% | 2002-09-09 | 2003-06-06 | 195d |  | finish no earlier than 2003-06-06 | R2 | 1560h | 1560h | Rel-5 | Joern |  | FSEarlyUE | Vodafone | Alan Law |
| 2056 | 519.4 | Note: Stage 3 RAN part not shown | 1d | 2000-01-03 A | 2000-01-03 A | 100% | 2000-01-03 | 2000-01-03 | 1d |  |  | RP | 8h | 8h | Rel-5 |  |  |  |  |  |
| 2057 | 520 | Release 4 Features | 1d? | 2000-01-03 | 2000-01-03 |  | 2000-01-03 | 2000-01-03 | 1d? | 3056d |  | NP,GP, RP,SP,TP | 8h |  | Rel-4 |  |  |  |  |  |

Notes:
- 2034: Not started. Marked as stopped 12/2008
- 2035: Not started. Marked as stopped 12/2008
- 2036: Not started. Marked as stopped 12/2008
- 2037: Not started. Marked as stopped 12/2008
- 2038: AWS, Nokia, Ericsson, Nortel, Siemens, Motorola
- 2039: AWS, Nokia, Ericsson, Nortel, Siemens, Motorola
- 2040: -
- 2041: -
- 2042: -
- 2043: TERMINATED - NOT STANDARDIZED. Marked as stopped 12/2008
- 2044: TERMINATED - NOT STANDARDIZED. Marked as stopped 12/2008
- 2045: TERMINATED - NOT STANDARDIZED
- 2046: TERMINATED - NOT STANDARDIZED
- 2047: TERMINATED - NOT STANDARDIZED. Marked as stopped 12/2008
- 2048: TERMINATED - NOT STANDARDIZED. Marked as stopped 12/2008
- 2049: TERMINATED - NOT STANDARDIZED. Marked as stopped 12/2008
- 2050: TERMINATED - NOT STANDARDIZED. Marked as stopped 12/2008
- 2051: Needed to complete DTM (R99)
- 2052: -
- 2053: -
- 2054: -
- 2055: -
- 2056: -
- 2057: -

| ID | WBS | Task | Duration | Start | Finish | Predecessors | Complete | Baseline start | Baseline finish | Baseline duration | Constraint | Resources | Work | Actual work | Text1 | Text6 | Text8 | Text3 | Text12 | Text4 | Text5 |
| --- | --- | --- | --- | --- | --- | --- | --- | --- | --- | --- | --- | --- | --- | --- | --- | --- | --- | --- | --- | --- | --- |
| 2058 | 15 | **Miscellaneous UE Conformance Testing Activities** | 958d | 2001-04-02 A | 2004-12-01 A |  | 100% | 2001-04-02 | 2004-12-01 | 958d |  | T1 | 36360h | 36360h | MISTST1 | Rel-4 | Ingbert |  |  |  |  |
| 2059 | 15.1 | Optimization of Test Time, RF Aspects (FDD) | 508d | 2001-09-24 A | 2003-09-03 A |  | 100% | 2001-09-24 | 2003-09-03 | 508d | finish no earlier than 2003-09-03 | T1 | 4064h | 4064h | MISTST1-OpFDD | Rel-4 | Ingbert | 34.121 |  |  |  |
| 2060 | 15.2 | Optimization of Test Time, RF Aspects (TDD) | 508d | 2001-09-24 A | 2003-09-03 A |  | 100% | 2001-09-24 | 2003-09-03 | 508d | finish no earlier than 2003-09-03 | T1 | 4064h | 4064h | MISTST1-OpTDD | Rel-4 | Ingbert | 34.122 |  |  |  |
| 2061 | 15.3 | Extensions to R99 Test cases | 139.4w | 2001-04-02 A | 2003-12-02 A |  | 100% | 2001-04-02 | 2003-12-02 | 139.4w | finish no earlier than 2003-12-02 | T1 | 5576h | 5576h | MISTST1-Ext | Rel-4 | Ingbert | 34.123 p 1,2 |  |  |  |
| 2062 | 15.4 | Extension to R99 Test cases - TTCN | 439d | 2002-06-28 A | 2004-03-03 A |  | 100% | 2002-06-28 | 2004-03-03 | 439d | finish no earlier than 2004-03-03 | T1 | 3512h | 3512h |  | Rel-4 | Ingbert |  |  |  |  |
| 2063 | 15.5 | Creation of R99 TCs for TDD - prose | 719d | 2001-10-01 A | 2004-07-01 A |  | 100% | 2001-10-01 | 2004-07-01 | 719d | finish no earlier than 2004-07-01 | T1 | 5752h | 5752h | MISTST1-TDD | Rel-4 | Ingbert | 34.123-1 |  |  |  |
| 2064 | 15.6 | Deleted - Creation of R99 TCs for TDD - TTCN | 587d | 2002-09-03 A | 2004-12-01 A |  | 100% | 2002-09-03 | 2004-12-01 | 587d | finish no earlier than 2004-12-01 | T1 | 4696h | 4696h |  | Rel-4 | Ingbert |  | TP-26 |  |  |
| 2065 | 15.7 | Deleted - Review all other work items for impact on new or exiting 34 series specs. | 25.8w | 2002-07-02 A | 2002-12-27 A |  | 100% | 2002-07-02 | 2002-12-27 | 25.8w | finish no earlier than 2002-12-27 | T1 | 1032h | 1032h | MISTST1 | Rel-4 | Ingbert | 34.121,122,123,125 | TP-18 |  |  |
| 2066 | 46 | **Facsimile** | 89d | 2000-02-22 A | 2000-06-23 A |  | 100% | 2000-02-22 | 2000-06-23 | 89d |  | S1 | 4376h | 4376h | FAX | Rel-4 | Alain |  |  |  |  |
| 2067 | 46.1 | **Real Time Fax** | 89d | 2000-02-22 A | 2000-06-23 A |  | 100% | 2000-02-22 | 2000-06-23 | 89d |  | S2 | 3664h | 3664h | FAX-RT | Rel-4 | Maurice |  |  |  |  |
| 2068 | 46.1.1 | Terminal capabilities, AT commands | 89d | 2000-02-22 A | 2000-06-23 A |  | 100% | 2000-02-22 | 2000-06-23 | 89d | finish no earlier than 2000-06-23 | T2 | 712h | 712h |  | Rel-4 |  | 21.904, 27.007 |  |  |  |
| 2069 | 46.1.2 | Signalling aspects (e.g. ICM) | 89d | 2000-02-22 A | 2000-06-23 A |  | 100% | 2000-02-22 | 2000-06-23 | 89d | start no earlier than 2000-02-22 | N1 | 712h | 712h |  | Rel-4 | Frederic |  |  |  |  |
| 2070 | 46.1.3 | Service provision | 89d | 2000-02-22 A | 2000-06-23 A |  | 100% | 2000-02-22 | 2000-06-23 | 89d | finish no earlier than 2000-06-23 | N3 | 712h | 712h |  | Rel-4 | Gwiho | 23.146 |  |  |  |
| 2071 | 46.1.4 | Review whether service/stage 1 aspects need to be aligned | 51d | 2000-04-14 A | 2000-06-23 A |  | 100% | 2000-04-14 | 2000-06-23 | 51d | finish no earlier than 2000-12-14 | S1 | 408h | 408h |  | Rel-4 | Alain |  |  |  |  |
| 2072 | 46.1.5 | Review whether architecture/stage 2 aspects need to be aligned | 51d | 2000-04-14 A | 2000-06-23 A |  | 100% | 2000-04-14 | 2000-06-23 | 51d | finish no earlier than 2000-12-14 | S2 | 408h | 408h |  | Rel-4 | Maurice |  |  |  |  |
| 2073 | 47 | Transparent End-to-End PS mobile streaming application | 253d | 2000-04-03 A | 2001-03-21 A |  | 100% | 2000-04-03 | 2001-03-21 | 253d | finish no earlier than 2000-12-29 | S4 | 2024h | 2024h | PSTREAM | Rel-4 | Paolo | 26.233, 26.234 |  |  |  |
| 2074 | 48 | **Multimedia Messaging** | 277d | 2000-02-22 A | 2001-03-14 A |  | 100% | 2000-02-22 | 2001-03-14 | 277d |  | T2,S1 | 9992h | 9992h | MMS | Rel-4 | Kimmo | 22.140, 23.140 |  | Siemens | Josef.Laumen@SAL.SIEMENS.DE |
| 2075 | 48.1 | Definition of service requirements | 72d | 2000-02-22 A | 2000-05-31 A |  | 100% | 2000-02-22 | 2000-05-31 | 72d | start no earlier than 2000-02-22 | S1 | 576h | 576h | MMS | Rel-4 | Alain |  |  |  |  |
| 2076 | 48.2 | Review of definition of service requirements | 205d | 2000-06-01 A | 2001-03-14 A | 2075 | 100% | 2000-06-01 | 2001-03-14 | 205d | finish no earlier than 2000-09-08 | T2 | 1640h | 1640h | MMS | Rel-4 | Kimmo | 22.140, 23.140 |  | Siemens |  |
| 2077 | 48.3 | **Technical Realisation** | 243d | 2000-04-10 A | 2001-03-14 A |  | 100% | 2000-04-10 | 2001-03-14 | 243d |  | T2 | 7776h | 7776h | MMS | Rel-4 | Kimmo | 22.140, 23.140 |  | Siemens | Josef.Laumen@SAL.SIEMENS.DE |
| 2078 | 48.3.1 | Review of definition of reference Achitecture model | 243d | 2000-04-10 A | 2001-03-14 A |  | 100% | 2000-04-10 | 2001-03-14 | 243d | finish no earlier than 2001-03-14 | T2 | 1944h | 1944h | MMS | Rel-4 | Kimmo | 22.140, 23.140 |  | Siemens | Josef.Laumen@SAL.SIEMENS.DE |
| 2079 | 48.3.2 | "Fulfill Requirements of Stage 1" | 243d | 2000-04-10 A | 2001-03-14 A |  | 100% | 2000-04-10 | 2001-03-14 | 243d | finish no earlier than 2001-03-14 | T2 | 1944h | 1944h | MMS | Rel-4 | Kimmo | 22.140, 23.140 |  | Siemens | Josef.Laumen@SAL.SIEMENS.DE |
| 2080 | 48.3.3 | Definition of MMS primitives in Stage 2 | 243d | 2000-04-10 A | 2001-03-14 A |  | 100% | 2000-04-10 | 2001-03-14 | 243d | finish no earlier than 2001-03-14 | T2 | 1944h | 1944h | MMS | Rel-4 | Kimmo | 22.140, 23.140 |  | Siemens | Josef.Laumen@SAL.SIEMENS.DE |
| 2081 | 49 | **Transcoder-Free Operation** | 326d | 2000-01-03 A | 2001-03-30 A |  | 100% | 2000-01-03 | 2001-03-30 | 326d |  | N4,S2,N1 | 10448h | 10448h | TrFO | Rel-4 | Kimmo |  |  |  |  |
| 2082 | 49.1 | **Out-of-Band Transcoder Control solution** | 326d | 2000-01-03 A | 2001-03-30 A |  | 100% | 2000-01-03 | 2001-03-30 | 326d |  | N4 | 8448h | 8448h | TrFO-OoBTC | Rel-4 | Kimmo |  |  | NEC | Toshiyuki Tamura (tamurato@aj.jp.nec.com) |
| 2083 | 49.1.1 | implementation in UTRAN | 145d | 2000-09-11 A | 2001-03-30 A |  | 100% | 2000-09-11 | 2001-03-30 | 145d | finish no earlier than 2001-03-30 | R3 | 1160h | 1160h | TrFO-OoBTC-UTRAN | Rel-4 | Juha | 25.401, 25.410, 25.413, 25.415, 23.153 |  | Siemens | Alexander Vesely |
| 2084 | 49.1.2 | Impact on architecture, Principles and Terminology | 211d | 2000-01-03 A | 2000-10-20 A |  | 100% | 2000-01-03 | 2000-10-20 | 211d | finish no earlier than 2000-10-20 | S2 | 1680h | 1680h | TrFO-OoBTC | Rel-4 | Maurice |  |  |  |  |
| 2085 | 49.1.3 | Codec Negotiation between UE and MSC | 125d | 2000-08-14 A | 2001-02-02 A |  | 100% | 2000-08-14 | 2001-02-02 | 125d | finish no earlier than 2001-02-02 | N1 | 1000h | 1000h | TrFO-OoBTC | Rel-4 | Frederic | 24.008, 23.009, 23.108, (29.002) |  | Motorola | Andrew Howell |
| 2086 | 49.1.4 | Codec Negotiation inter MSC | 125d | 2000-07-03 A | 2000-12-22 A |  | 100% | 2000-07-03 | 2000-12-22 | 125d | finish no earlier than 2000-12-22 | N4 | 1000h | 1000h | TrFO-OoBTC | Rel-4 | Kimmo |  |  |  |  |
| 2087 | 49.1.5 | Bearer establishment inter MSC | 125d | 2000-07-03 A | 2000-12-22 A |  | 100% | 2000-07-03 | 2000-12-22 | 125d | finish no earlier than 2000-12-22 | N4 | 1000h | 1000h | TrFO-OoBTC | Rel-4 | Kimmo | 23.153 |  |  |  |

Notes:
- 2058: -
- 2059: It is believed that the current R99 test spec. can be optimised for faster overall test times. Marked as stopped 12/2008 (was 70% complete)
- 2060: It is believed that the current R99 test spec. can be optimised for faster overall test times
- 2061: Further test coverage of the R99 specification to cover supplementry services. Marked as stopped 12/2008 (was 70% complete)
- 2062: Marked as closed 12/2008 (was marked 50% complete)
- 2063: Marked as closed 12/2008 (was marked 50% complete)
- 2064: Marked as stopped 12/2008
- 2065: Marked as stopped 12/2008
- 2066: -
- 2067: postponed from R99 to R00, SP-000169
- 2068: -
- 2069: -
- 2070: -
- 2071: -
- 2072: -
- 2073: -
- 2074: -
- 2075: -
- 2076: -
- 2077: -
- 2078: -
- 2079: e.g. minimum set of media formats, media format conversion, personalization of MMS.
- 2080: -
- 2081: Lead given to CN4 from CN / [DAB 28/11/00]
- 2082: -
- 2083: moved according to NP-000575
- 2084: e.g. study cascading TrFO/TFO/TrFO
- 2085: the link to NP-000085has been deleted because refering to a R99 status sheet / One common set of codec negotiation procedures will be specified as in ID1656.
- 2086: Bearer establishment inter MSC. TS 23.153 R99 part complete. capabilities moved to annex + list of open issues
- 2087: Bearer establishment inter MSC. TS 23.153 R99 part complete. capabilities moved to annex. / See NP-000127 / Open issues: / Handling of Conference Calls; / Handling of Multi Party Supplementary Services; / Handling of Handover UMTS to GSM; / Handling of Sending a ...

| ID | WBS | Task | Duration | Start | Finish | Complete | Baseline start | Baseline finish | Baseline duration | Constraint | Resources | Work | Actual work | Text1 | Text6 | Text8 | Text4 | Text5 |
| --- | --- | --- | --- | --- | --- | --- | --- | --- | --- | --- | --- | --- | --- | --- | --- | --- | --- | --- |
| 2088 | 49.2 | **Speech Transcoder: Location and Control at the UMTS Core Network Border** | 125d | 2000-04-10 A | 2000-09-29 A | 100% | 2000-04-10 | 2000-09-29 | 125d |  | S2 | 2000h | 2000h | TrFO-STLC | Rel-4 | Maurice |  |  |
| 2089 | 49.2.1 | Transcoder at Edge | 125d | 2000-04-10 A | 2000-09-29 A | 100% | 2000-04-10 | 2000-09-29 | 125d | finish no earlier than 2000-09-29 | NP | 1000h | 1000h | TrFO-STLC | Rel-4 |  |  |  |
| 2090 | 50 | **GERAN improvements 1 (Gb over IP)** | 225d | 2000-05-09 A | 2001-03-19 A | 100% | 2000-05-09 | 2001-03-19 | 225d |  | GP | 6472h | 6472h | GEIMP1 | Rel-4 | Paolo |  |  |
| 2091 | 50.1 | **Gb over IP (Ip-fication of Gb)** | 225d | 2000-05-09 A | 2001-03-19 A | 100% | 2000-05-09 | 2001-03-19 | 225d |  | GP | 4672h | 4672h | GbIP | Rel-4 | Paolo |  |  |
| 2092 | 50.1.1 | Concept | 134d | 2000-05-09 A | 2000-11-10 A | 100% | 2000-05-09 | 2000-11-10 | 134d |  | GP | 1072h | 1072h |  | Rel-4 | Paolo |  |  |
| 2093 | 50.1.2 | Changes to 08.16, 08.18 | 225d | 2000-05-09 A | 2001-03-19 A | 100% | 2000-05-09 | 2001-03-19 | 225d |  | GP | 1800h | 1800h |  | Rel-4 | Paolo |  |  |
| 2094 | 51 | **GERAN improvements 2 (NACC)** | 677d | 2000-11-06 A | 2003-06-10 A | 100% | 2000-11-06 | 2003-06-10 | 677d |  | GP | 19224h | 19224h | GEIMP2 | Rel-4 | Paolo |  |  |
| 2095 | 51.1 | **Gb enhancements** | 155d | 2000-11-06 A | 2001-06-08 A | 100% | 2000-11-06 | 2001-06-08 | 155d |  | GP | 7440h | 7440h | Gben | Rel-4 | Paolo |  |  |
| 2096 | 51.1.1 | **Intra BSC NACC (Network Assisted Cell Change)** | 155d | 2000-11-06 A | 2001-06-08 A | 100% | 2000-11-06 | 2001-06-08 | 155d |  | GP | 6200h | 6200h |  | Rel-4 | Paolo |  |  |
| 2097 | 51.1.1.1 | Concept | 155d | 2000-11-06 A | 2001-06-08 A | 100% | 2000-11-06 | 2001-06-08 | 155d | finish no earlier than 2001-06-08 | GP | 1240h | 1240h |  | Rel-4 | Paolo |  |  |
| 2098 | 51.1.1.2 | Changes in 03.64 | 155d | 2000-11-06 A | 2001-06-08 A | 100% | 2000-11-06 | 2001-06-08 | 155d | finish no earlier than 2001-06-08 | GP | 1240h | 1240h |  | Rel-4 | Paolo |  |  |
| 2099 | 51.1.1.3 | Changes in 04.60 | 155d | 2000-11-06 A | 2001-06-08 A | 100% | 2000-11-06 | 2001-06-08 | 155d | finish no earlier than 2001-06-08 | GP | 1240h | 1240h |  | Rel-4 | Paolo |  |  |
| 2100 | 51.1.1.4 | Changes in 44.008 | 155d | 2000-11-06 A | 2001-06-08 A | 100% | 2000-11-06 | 2001-06-08 | 155d | finish no earlier than 2001-06-08 | GP | 1240h | 1240h |  | Rel-4 | Paolo |  |  |
| 2101 | 51.3 | **MS conformance test for Intra BSC NACC** | 398d | 2001-11-30 A | 2003-06-10 A | 100% | 2001-11-30 | 2003-06-10 | 398d |  | GP | 6368h | 6368h | GEIMP2-Msconf | Rel-4 | Paolo |  |  |
| 2102 | 51.3.1 | Changes in 51.010 | 398d | 2001-11-30 A | 2003-06-10 A | 100% | 2001-11-30 | 2003-06-10 | 398d | finish no earlier than 2003-12-19 | G5,G4 | 3184h | 3184h |  | Rel-4 | Paolo |  |  |
| 2103 | 52 | **GERAN improvements 4 (Delayed TBF)** | 105d | 2001-01-15 A | 2001-06-08 A | 100% | 2001-01-15 | 2001-06-08 | 105d |  | GP | 3960h | 3960h | GEIMP4 | Rel-4 | Paolo |  |  |
| 2104 | 52.1 | **Gb enhancements 2** | 105d | 2001-01-15 A | 2001-06-08 A | 100% | 2001-01-15 | 2001-06-08 | 105d |  | GP | 3120h | 3120h | GEIMP4-Gben2 | Rel-4 | Paolo |  |  |
| 2105 | 52.1.1 | stage 2 | 105d | 2001-01-15 A | 2001-06-08 A | 100% | 2001-01-15 | 2001-06-08 | 105d | finish no earlier than 2001-06-08 | GP | 840h | 840h |  | Rel-4 | Paolo |  |  |
| 2106 | 52.1.2 | **Stage 3 (changes in 44.060)** | 60d | 2001-01-15 A | 2001-04-06 A | 100% | 2001-01-15 | 2001-04-06 | 60d |  | G2 | 1440h | 1440h |  | Rel-4 | Gert |  |  |
| 2107 | 52.1.2.1 | Definition of enhanced countdown procedure | 60d | 2001-01-15 A | 2001-04-06 A | 100% | 2001-01-15 | 2001-04-06 | 60d | finish no earlier than 2001-04-06 | G2 | 480h | 480h |  | Rel-4 | Gert |  |  |
| 2108 | 52.1.2.2 | Definition of enhanced TBF release procedure | 60d | 2001-01-15 A | 2001-04-06 A | 100% | 2001-01-15 | 2001-04-06 | 60d | finish no earlier than 2001-04-06 | G2 | 480h | 480h |  | Rel-4 | Gert |  |  |
| 2109 | 52.1.2.3 | Definition of USF=FREE type polling mechanism on PDCH | 60d | 2001-01-15 A | 2001-04-06 A | 100% | 2001-01-15 | 2001-04-06 | 60d | finish no earlier than 2001-04-06 | G2 | 480h | 480h |  | Rel-4 | Gert |  |  |
| 2110 | 53 | **Low Chip Rate TDD option** | 880d | 2000-07-19 A | 2003-12-02 A | 100% | 2000-07-19 | 2003-12-02 | 880d |  | R1 | 27488h | 27488h | LCRTDD | Rel-4 | Patrick | CWTS | G. Yang |
| 2111 | 53.1 | Physical layer | 183d | 2000-07-19 A | 2001-03-30 A | 100% | 2000-07-19 | 2001-03-30 | 183d | finish no earlier than 2001-03-30 | R1 | 1464h | 1464h | LCRTDD-Phys | Rel-4 | Patrick | CWTS | G. Yang |
| 2112 | 53.2 | Layer 2 and layer 3 protocol aspects | 183d | 2000-07-19 A | 2001-03-30 A | 100% | 2000-07-19 | 2001-03-30 | 183d | finish no earlier than 2001-03-30 | R2 | 1464h | 1464h | LCRTDD-L23 | Rel-4 | Joern | CWTS | Y. Liu |
| 2113 | 53.3 | RF radio transmission/reception, system performance requirements and conformance testing | 165d | 2000-08-14 A | 2001-03-30 A | 100% | 2000-08-14 | 2001-03-30 | 165d | finish no earlier than 2001-03-30 | R4 | 1320h | 1320h | LCRTDD-RF | Rel-4 | Issam | CWTS | D. Zhang |
| 2114 | 53.4 | UE radio access capability | 165d | 2000-08-14 A | 2001-03-30 A | 100% | 2000-08-14 | 2001-03-30 | 165d | finish no earlier than 2001-03-30 | R2 | 1320h | 1320h | LCRTDD-UErac | Rel-4 | Joern | CWTS | Y. Liu |
| 2115 | 53.5 | Iub/Iur protocol aspects | 165d | 2000-08-14 A | 2001-03-30 A | 100% | 2000-08-14 | 2001-03-30 | 165d | finish no earlier than 2001-03-30 | R3 | 1320h | 1320h | LCRTDD-IubIur | Rel-4 | Juha | CWTS | Y. Liu |

Notes:
- 2088: WI description and Tdoc S2-99352 / Speech Transcoder: Location and Control at the UMTS Core Network Border
- 2089: WI description and Tdoc S2-99352...
- 2090: -
- 2091: -
- 2092: -
- 2093: -
- 2094: -
- 2095: -
- 2096: -
- 2097: -
- 2098: -
- 2099: -
- 2100: -
- 2101: -
- 2102: az 05/08: duplicated UID_50099 => 50299. Marked as closed 12/2008 (was marked 50% complete)
- 2103: -
- 2104: -
- 2105: -
- 2106: -
- 2107: -
- 2108: -
- 2109: -
- 2110: -
- 2111: -
- 2112: -
- 2113: -
- 2114: -
- 2115: -

| ID | WBS | Task | Duration | Start | Finish | Predecessors | Complete | Baseline start | Baseline finish | Baseline duration | Constraint | Resources | Work | Actual work | Text6 | Text8 | Text3 | Text12 | Text1 | Text4 | Text5 |
| --- | --- | --- | --- | --- | --- | --- | --- | --- | --- | --- | --- | --- | --- | --- | --- | --- | --- | --- | --- | --- | --- |
| 2116 | 53.6 | **Low chiprate TDD interworking with GERAN** | 101d | 2000-09-01 A | 2001-01-19 A | 2115 | 100% | 2000-09-01 | 2001-01-19 | 101d |  | GP | 1616h | 1616h | Rel-4 | Paolo |  |  |  |  |  |
| 2117 | 53.6.1 | Handover and Cell Selection / Reselection to UTRA 1.28 Mcps TDD | 101d | 2000-09-01 A | 2001-01-19 A |  | 100% | 2000-09-01 | 2001-01-19 | 101d | finish no earlier than 2001-01-19 | GP | 808h | 808h | Rel-4 |  |  |  |  |  |  |
| 2118 | 53.8 | **Conformance Test Aspects - Low Chip Rate TDD** | 577d | 2001-09-17 A | 2003-12-02 A | 2116 | 100% | 2001-09-17 | 2003-12-02 | 577d |  | T1 | 12088h | 12088h | Rel-4 | Ingbert |  |  |  |  |  |
| 2119 | 53.8.1 | Testing Layer 2 and layer 3 protocol aspects | 468d | 2001-09-17 A | 2003-07-02 A |  | 100% | 2001-09-17 | 2003-07-02 | 468d | finish no earlier than 2003-07-02 | T1 | 3744h | 3744h | Rel-4 | Ingbert | 34.123-1, 34.123-2 |  |  |  |  |
| 2120 | 53.8.2 | Deleted - Testing Layer 2 and layer 3 protocol aspects - TTCN | 261d | 2002-12-03 A | 2003-12-02 A |  | 100% | 2002-12-03 | 2003-12-02 | 261d | finish no earlier than 2003-12-02 | T1 | 2088h | 2088h | Rel-4 | Ingbert | 34.123-3 | TP-22 |  |  |  |
| 2121 | 53.8.3 | Testing RF Radio Transmission and Reception | 205d | 2001-09-17 A | 2002-06-28 A |  | 100% | 2001-09-17 | 2002-06-28 | 205d | finish no earlier than 2002-06-28 | T1 | 1640h | 1640h | Rel-4 | Ingbert |  |  |  |  |  |
| 2122 | 54 | **Enable bearer independent CS architecture** | 566d | 2000-01-03 A | 2002-03-01 A |  | 100% | 2000-01-03 | 2002-03-01 | 566d |  | S2 | 20192h | 20192h | Rel-4 | Maurice |  |  | CSSPLIT | Siemens | Alexander Milinski |
| 2123 | 54.1 | **Enable bearer-independent call control** | 425d | 2000-01-03 A | 2001-08-16 A |  | 100% | 2000-01-03 | 2001-08-16 | 425d |  | N4 | 12344h | 12344h | Rel-4 | Kimmo |  |  |  | Ericsson | Heinz-Peter.Keutmann@eed.ericsson.se |
| 2124 | 54.1.1 | Architecture and Stage 2 description | 181d | 2000-01-03 A | 2000-09-08 A |  | 100% | 2000-01-03 | 2000-09-08 | 181d | finish no earlier than 2000-09-08 | S2 | 1440h | 1440h | Rel-4 | Maurice | 23.002 |  |  |  |  |
| 2125 | 54.1.2 | Standardisation of protocols (control & user planes) over Nb interface | 64d | 2001-01-02 A | 2001-03-30 A |  | 100% | 2001-01-02 | 2001-03-30 | 64d | finish no earlier than 2001-03-30 | N3 | 512h | 512h | Rel-4 | Gwiho |  |  |  |  |  |
| 2126 | 54.1.3 | Standardisation of protocols over reference points between MSC server and Gateway MSC server | 130d | 2000-09-25 A | 2001-03-23 A |  | 100% | 2000-09-25 | 2001-03-23 | 130d | finish no earlier than 2001-03-23 | N4 | 1040h | 1040h | Rel-4 | Kimmo |  |  |  |  |  |
| 2127 | 54.1.4 | Standardisation of detailed stage 2 description | 180d | 2000-07-17 A | 2001-03-23 A |  | 100% | 2000-07-17 | 2001-03-23 | 180d | finish no earlier than 2001-03-23 | N4 | 1440h | 1440h | Rel-4 | Kimmo |  |  |  |  |  |
| 2128 | 54.1.5 | **Bearer control between MSC server and MGW** | 250d | 2000-09-01 A | 2001-08-16 A |  | 100% | 2000-09-01 | 2001-08-16 | 250d |  | N4 | 4512h | 4512h | Rel-4 | Kimmo |  |  |  |  |  |
| 2129 | 54.1.5.1 | stage 3 - protocol issues | 250d | 2000-09-01 A | 2001-08-16 A |  | 100% | 2000-09-01 | 2001-08-16 | 250d | finish no earlier than 2001-08-16 | N4 | 2000h | 2000h | Rel-4 | Kimmo |  |  |  |  |  |
| 2130 | 54.1.5.2 | stage 3 - parameter value issues | 64d | 2001-01-02 A | 2001-03-30 A |  | 100% | 2001-01-02 | 2001-03-30 | 64d | finish no earlier than 2001-03-30 | N3 | 512h | 512h | Rel-4 | Gwiho |  |  |  |  |  |
| 2131 | 54.2 | Lawful interception | 155d | 2000-08-21 A | 2001-03-23 A |  | 100% | 2000-08-21 | 2001-03-23 | 155d | finish no earlier than 2001-03-23 | S3 | 1240h | 1240h | Rel-4 | Dionisio |  |  |  |  |  |
| 2132 | 54.4 | Deleted - Conformance Test Aspects - Enable bearer independent CS architecture | 260d | 2001-03-05 A | 2002-03-01 A |  | 100% | 2001-03-05 | 2002-03-01 | 260d |  | T1 | 2080h | 2080h | Rel-4 | Ingbert |  | TP-15 | CSSPLIT-TEST |  |  |
| 2133 | 55 | **MExE enhancements Rel-4** | 511d | 2000-01-03 A | 2001-12-14 A |  | 100% | 2000-01-03 | 2001-12-14 | 511d |  | T2 | 19032h | 19032h | Rel-4 | Kimmo |  |  | MEXE |  |  |
| 2134 | 55.1 | **MExE Security Analysis Activity** | 474d | 2000-02-22 A | 2001-12-14 A |  | 100% | 2000-02-22 | 2001-12-14 | 474d |  | S3 | 8464h | 8464h | Rel-4 | Dionisio |  |  | MEXE-SEC | BT | colin.blanchard@bt.com |
| 2135 | 55.1.1 | Stage 3 | 370d | 2000-07-17 A | 2001-12-14 A |  | 100% | 2000-07-17 | 2001-12-14 | 370d | finish no earlier than 2001-12-14 | S3 | 2960h | 2960h | Rel-4 | Dionisio |  |  | MEXE1-SEC |  |  |
| 2136 | 55.1.2 | Terminal aspects | 214d | 2000-02-22 A | 2000-12-15 A |  | 100% | 2000-02-22 | 2000-12-15 | 214d | finish no earlier than 2000-12-15 | T2 | 1712h | 1712h | Rel-4 |  |  |  |  |  |  |
| 2137 | 55.2 | **MExE Rel4 Improvements and Investigations** | 251d | 2000-01-03 A | 2000-12-15 A |  | 100% | 2000-01-03 | 2000-12-15 | 251d |  | T2 | 6480h | 6480h | Rel-4 |  | 22.057, 23.057 |  | MEXE-ENHANC | Motorola | Mark Cataldo |
| 2138 | 55.2.1 | 3rd MExE classmark | 251d | 2000-01-03 A | 2000-12-15 A |  | 100% | 2000-01-03 | 2000-12-15 | 251d | finish no earlier than 2000-12-15 | T2 | 2000h | 2000h | Rel-4 |  | 22.057, 23.057 |  |  | Motorola | Mark Cataldo |
| 2139 | 55.2.2 | FS on Secure download mechanism and capabilities to support SDR concepts | 225d | 2000-02-07 A | 2000-12-15 A |  | 100% | 2000-02-07 | 2000-12-15 | 225d | finish no earlier than 2000-12-15 | T2 | 1800h | 1800h | Rel-4 |  | 22.057, 23.057 |  |  | Motorola | Mark Cataldo |
| 2140 | 55.2.3 | FS on Support of MP3/MPEG4 content | 225d | 2000-02-07 A | 2000-12-15 A |  | 100% | 2000-02-07 | 2000-12-15 | 225d | finish no earlier than 2000-12-15 | T2 | 1800h | 1800h | Rel-4 |  | 22.057, 23.057 |  |  | Motorola | Mark Cataldo |

Notes:
- 2116: -
- 2117: -
- 2118: -
- 2119: Marked as closed 12/2008 (was marked 60% complete)
- 2120: Marked as stopped 12/2008
- 2121: duration set to 6 months (was 0), finish date set
- 2122: -
- 2123: DAB 12.12.01 should be 100% hence closed
- 2124: R00 stage 2 at least 80 % complete in TSGS #8 21.-23.6.2000
- 2125: -
- 2126: -
- 2127: -
- 2128: -
- 2129: -
- 2130: -
- 2131: Requirements capture: S3#14 (Aug 00), Feature specification: S3#15 (Sep 00), Definition of architecture. Should be included in general LI work mentioned above.
- 2132: Marked as stopped 12/2008
- 2133: -
- 2134: Presentation to S3 of threats and countermeasures analysis: S3#15, Feature specification: S3#16. S3#18: WID updated
- 2135: Analysis undertaken by T2. No additional analysis needed for Rel-4
- 2136: -
- 2137: -
- 2138: Additional features for MExE R2000
- 2139: -
- 2140: -

| ID | WBS | Task | Duration | Start | Finish | Complete | Baseline start | Baseline finish | Baseline duration | Constraint | Resources | Work | Actual work | Text1 | Text6 | Text8 | Text3 | Text4 | Text5 |
| --- | --- | --- | --- | --- | --- | --- | --- | --- | --- | --- | --- | --- | --- | --- | --- | --- | --- | --- | --- |
| 2141 | 56 | **Tandem Free aspects for 3G and between 2G and 3G systems** | 344d | 2000-02-22 A | 2001-06-15 A | 100% | 2000-02-22 | 2001-06-15 | 344d |  | S4 | 9696h | 9696h | TFO | Rel-4 | Paolo |  |  |  |
| 2142 | 56.1 | **Tandem Free AMR** | 344d | 2000-02-22 A | 2001-06-15 A | 100% | 2000-02-22 | 2001-06-15 | 344d |  | S4 | 6944h | 6944h | TFO-AMR | Rel-4 | Paolo |  |  |  |
| 2143 | 56.1.1 | Specification | 284d | 2000-02-22 A | 2001-03-23 A | 100% | 2000-02-22 | 2001-03-23 | 284d | start no earlier than 2000-02-22 | S4 | 2272h | 2272h |  | Rel-4 | Paolo | 28.062 |  |  |
| 2144 | 56.1.2 | **Impact on:** | 115d | 2001-01-08 A | 2001-06-15 A | 100% | 2001-01-08 | 2001-06-15 | 115d |  | NP | 1920h | 1920h |  | Rel-4 | Kimmo |  |  |  |
| 2145 | 56.1.2.1 | CN | 60d | 2001-03-26 A | 2001-06-15 A | 100% | 2001-03-26 | 2001-06-15 | 60d | finish no earlier than 2001-06-15 | NP | 480h | 480h |  | Rel-4 | Kimmo |  |  |  |
| 2146 | 56.1.2.2 | GERAN | 65d | 2001-01-08 A | 2001-04-06 A | 100% | 2001-01-08 | 2001-04-06 | 65d | finish no earlier than 2001-04-06 | GP | 520h | 520h |  | Rel-4 | Paolo |  |  |  |
| 2147 | 57 | **Advanced Speech Call Items enhancements_REL-4** | 334d | 2000-12-03 A | 2002-03-14 A | 100% | 2000-12-03 | 2002-03-14 | 334d |  | N1 | 5925.6h | 5925.6h | ASCI | Rel-4 | Frederic |  | Nortel | sonia.garapaty@nortelnetworks.com |
| 2148 | 57.1 | Stage 2 | 326.7d | 2000-12-03 A | 2002-03-14 A | 100% | 2000-12-03 | 2002-03-14 | 326.7d | finish no earlier than 2002-03-14 | N4 | 2613.6h | 2613.6h |  | Rel-4 | Kimmo | 23.067, 24.067 | Sagem | Vivien Perlic |
| 2149 | 57.2 | Stages 2 and 3 on A interface | 80d | 2000-12-03 A | 2001-03-23 A | 100% | 2000-12-03 | 2001-03-23 | 80d | finish no earlier than 2001-03-23 | N1 | 640h | 640h |  | Rel-4 | Frederic | 44.068, 44.069, 24.008 | Nortel | sonia.garapaty@nortelnetworks.com |
| 2150 | 58 | **700 MHz spectrum support** | 776d | 2000-01-03 A | 2002-12-20 A | 100% | 2000-01-03 | 2002-12-20 | 776d |  | GP | 25016h | 25016h | 700SS | Rel-4 | Paolo |  |  |  |
| 2151 | 58.1 | **GERAN support for the 700 MHz band** | 276d | 2000-01-03 A | 2001-01-19 A | 100% | 2000-01-03 | 2001-01-19 | 276d |  | GP | 8808h | 8808h |  | Rel-4 | Paolo |  |  |  |
| 2152 | 58.1.1 | Signalling support | 276d | 2000-01-03 A | 2001-01-19 A | 100% | 2000-01-03 | 2001-01-19 | 276d | finish no earlier than 2001-01-19 | GP | 2200h | 2200h |  | Rel-4 | Paolo |  |  |  |
| 2153 | 58.1.2 | Physical layer definitions | 276d | 2000-01-03 A | 2001-01-19 A | 100% | 2000-01-03 | 2001-01-19 | 276d | finish no earlier than 2001-01-19 | GP | 2200h | 2200h |  | Rel-4 | Paolo |  |  |  |
| 2154 | 58.1.3 | Receiver performance and RF budget | 276d | 2000-01-03 A | 2001-01-19 A | 100% | 2000-01-03 | 2001-01-19 | 276d | finish no earlier than 2001-01-19 | GP | 2200h | 2200h |  | Rel-4 | Paolo |  |  |  |
| 2155 | 58.2 | **GERAN MS Conformance test for 700 MHz band** | 175d | 2001-04-02 A | 2001-11-30 A | 100% | 2001-04-02 | 2001-11-30 | 175d |  | GP | 2800h | 2800h |  | Rel-4 | Paolo |  |  |  |
| 2156 | 58.2.1 | MS test | 175d | 2001-04-02 A | 2001-11-30 A | 100% | 2001-04-02 | 2001-11-30 | 175d | finish no earlier than 2001-11-30 | GP | 1400h | 1400h |  | Rel-4 | Paolo |  |  |  |
| 2157 | 58.3 | **GERAN BTS Conformance test for 700 MHz band** | 450d | 2001-04-02 A | 2002-12-20 A | 100% | 2001-04-02 | 2002-12-20 | 450d |  | GP | 7200h | 7200h |  | Rel-4 | Paolo |  |  |  |
| 2158 | 58.3.1 | BTS test | 450d | 2001-04-02 A | 2002-12-20 A | 100% | 2001-04-02 | 2002-12-20 | 450d | finish no earlier than 2002-12-20 | GP | 3600h | 3600h |  | Rel-4 | Paolo |  |  |  |
| 2159 | 59 | Operator Determined Barring for Packet Oriented Services | 208d | 2000-06-01 A | 2001-03-19 A | 100% | 2000-06-01 | 2001-03-19 | 208d | finish no earlier than 2001-03-19 | NP | 1664h | 1664h | ODB | Rel-4 |  |  | NEC | Toshiyuki Tamura (tamurato@aj.jp.nec.com) |
| 2160 | 60 | **UMTS QoS Architecture for PS Domain** | 759d | 2000-01-03 A | 2002-11-27 A | 100% | 2000-01-03 | 2002-11-27 | 759d |  | S2 | 41312h | 41312h | QoSPS | Rel-4 | Maurice |  | Ericsson | Ina.widegren@era.ericsson.se |
| 2161 | 60.1 | Architecture | 153d | 2000-06-05 A | 2001-01-03 A | 100% | 2000-06-05 | 2001-01-03 | 153d | finish no earlier than 2001-01-03 | S2 | 1224h | 1224h |  | Rel-4 | Maurice | 23.107 |  |  |
| 2162 | 60.2 | Charging and OAM&P for QoS Management | 201d | 2001-09-21 A | 2002-06-28 A | 100% | 2001-09-21 | 2002-06-28 | 201d | finish no earlier than 2002-06-28 | S5 | 1608h | 1608h | QoSPS-OAM | Rel-4 | Dionisio | 32-series | VoiceStream, Motorola |  |
| 2163 | 60.3 | **RAB Quality of Service (re)Negotiation over Iu** | 155d | 2000-08-21 A | 2001-03-23 A | 100% | 2000-08-21 | 2001-03-23 | 155d |  | R3 | 3648h | 3648h | QoSPS-MAPEND-RABQoS | Rel-4 | Juha | 25.413 | Ericsson | A. Molander |
| 2164 | 60.3.1 | RAB Quality of Service Negotiation over Iu | 155d | 2000-08-21 A | 2001-03-23 A | 100% | 2000-08-21 | 2001-03-23 | 155d | finish no earlier than 2001-03-23 | R3 | 1240h | 1240h | QoSPS-MAPEND-RABQoS-Negot | Rel-4 | Juha |  | Ericsson | A. Molander |
| 2165 | 60.3.2 | RAB Quality of Service Negotiation over Iu during relocation | 16d | 2001-03-02 A | 2001-03-23 A | 100% | 2001-03-02 | 2001-03-23 | 16d | start no earlier than 2001-03-02 | R3 | 128h | 128h | QoSPS-MAPEND-RABQoS-NegotReloc | Rel-4 | Juha |  |  |  |
| 2166 | 60.3.3 | RAB Quality of Service Re-Negotiation over Iu | 130d | 2000-09-25 A | 2001-03-23 A | 100% | 2000-09-25 | 2001-03-23 | 130d | finish no earlier than 2001-03-23 | R3 | 1040h | 1040h | QoSPS-MAPEND-RABQoS-ReNegot | Rel-4 | Juha |  | Motorola | S. Irwin |

Notes:
- 2141: RAN and CN to verify no problems for GSM terminals roaming in 3G R99
- 2142: RAN and CN to verify UMTS_AMR_2 support
- 2143: -
- 2144: "Implementation" changed to "Impact on:" by A. Sultan (for better wording)
- 2145: RAN and CN to verify UMTS_AMR_2 support
- 2146: End date Modified from June to March to have it in Rel4
- 2147: Approved at CN#10
- 2148: CN4#11 30/11/02: no inputs received in CN4
- 2149: -
- 2150: -
- 2151: -
- 2152: -
- 2153: -
- 2154: -
- 2155: -
- 2156: -
- 2157: -
- 2158: -
- 2159: Completed WI missing from the P-plan Added for tracking
- 2160: -
- 2161: -
- 2162: -
- 2163: -
- 2164: -
- 2165: -
- 2166: -

| ID | WBS | Task | Duration | Start | Finish | Complete | Baseline start | Baseline finish | Baseline duration | Constraint | Resources | Work | Actual work | Text1 | Text6 | Text8 | Text12 | Text4 | Text5 | Text3 |
| --- | --- | --- | --- | --- | --- | --- | --- | --- | --- | --- | --- | --- | --- | --- | --- | --- | --- | --- | --- | --- |
| 2167 | 60.4 | **GERAN QoS Aspects - Handovers: maintenance of real-time QoS while moving between cells in the PLMN including inter-SGSN and SRNS relocation or possibly other mechanisms** | 501d | 2000-01-03 A | 2001-11-30 A | 100% | 2000-01-03 | 2001-11-30 | 501d |  | GP | 14456h | 14456h | GERQoS | Rel-4 | Paolo |  |  |  |  |
| 2168 | 60.4.1 | **Handover Concept for the PS domain** | 501d | 2000-01-03 A | 2001-11-30 A | 100% | 2000-01-03 | 2001-11-30 | 501d |  | GP | 10448h | 10448h |  | Rel-4 | Paolo |  |  |  |  |
| 2169 | 60.4.1.1 | Stable RT handover report 25.936 including header removal | 14d | 2000-01-03 A | 2000-01-19 A | 100% | 2000-01-03 | 2000-01-19 | 14d | start no earlier than 2000-01-03 | GP [92.9%] | 104h | 104h |  | Rel-4 | Paolo |  |  |  |  |
| 2170 | 60.4.1.2 | Update of stage 2 | 293d | 2000-01-03 A | 2001-02-13 A | 100% | 2000-01-03 | 2001-02-13 | 293d | finish no earlier than 2001-02-13 | GP | 2336h | 2336h |  | Rel-4 | Paolo |  |  |  |  |
| 2171 | 60.4.1.3 | Update of relevant stage 3 specs -> RRC | 501d | 2000-01-03 A | 2001-11-30 A | 100% | 2000-01-03 | 2001-11-30 | 501d | finish no earlier than 2001-11-30 | G2 | 4000h | 4000h |  | Rel-4 | Gert |  |  |  |  |
| 2172 | 60.5 | **Deleted - GERAN MS Conformance test for inter-system and intra-system Packet data real-time Handover** | 324d | 2001-08-31 A | 2002-11-27 A | 100% | 2001-08-31 | 2002-11-27 | 324d |  | G4,R3 | 12960h | 12960h | GERQoS-Mstest | Rel-4 | Paolo | GP-12 |  |  |  |
| 2173 | 60.5.1 | **Deleted - Handover for the PS domain** | 324d | 2001-08-31 A | 2002-11-27 A | 100% | 2001-08-31 | 2002-11-27 | 324d |  | G4,R3 | 10368h | 10368h |  | Rel-4 | Paolo | GP-12 |  |  |  |
| 2174 | 60.5.1.1 | Deleted - Stable RT handover report 25.936 including header removal | 324d | 2001-08-31 A | 2002-11-27 A | 100% | 2001-08-31 | 2002-11-27 | 324d | finish no earlier than 2002-11-27 | G4,R3 | 2592h | 2592h |  | Rel-4 | Paolo | GP-12 |  |  |  |
| 2175 | 60.5.1.2 | Deleted - Update of stage 2 | 324d | 2001-08-31 A | 2002-11-27 A | 100% | 2001-08-31 | 2002-11-27 | 324d | finish no earlier than 2002-11-27 | G4,R3 | 2592h | 2592h |  | Rel-4 | Paolo | GP-12 |  |  |  |
| 2176 | 60.5.1.3 | Deleted - Update of relevant stage 3 specs | 324d | 2001-08-31 A | 2002-11-27 A | 100% | 2001-08-31 | 2002-11-27 | 324d | finish no earlier than 2002-11-27 | G4,R3 | 2592h | 2592h |  | Rel-4 | Paolo | GP-12 |  |  |  |
| 2177 | 60.6 | PS-domain handover for real-time services | 155d | 2000-08-28 A | 2001-03-30 A | 100% | 2000-08-28 | 2001-03-30 | 155d | finish no earlier than 2001-03-30 | R3 | 1240h | 1240h | QoSPS-PSdoRTS | Rel-4 | Juha |  | Nokia | A. Lansisalmi |  |
| 2178 | 60.7 | Deleted - RAB QoS Renegotiation at Relocation | 58d | 2001-01-03 A | 2001-03-23 A | 100% | 2001-01-03 | 2001-03-23 | 58d | finish no earlier than 2001-03-23 | R3 | 464h | 464h |  | Rel-4 | Juha | RP-11 |  |  | 25.851, 25.946 |
| 2179 | 61 | **small Technical Enhancements and Improvements for Rel4** | 2178d? | 2000-01-03 A | 2008-05-06 A | 100% | 2000-01-03 | 2008-05-06 | 2178d? |  | All | 17424h | 17424h | TEI4 | Rel-4 |  |  |  |  |  |
| 2180 | 537.1 | Small Technical Enhancements and Improvements for Rel-4 Conformance Testing | 2178d? | 2000-01-03 A | 2008-05-06 A | 100% | 2000-01-03 | 2008-05-06 | 2178d? | finish no earlier than 2008-12-31 | R5,T1 | 17424h | 17424h | TEI4_Test | Rel-4 | Ingbert |  |  |  |  |
| 2181 | 62 | **Rel-4 Evolutions of the transport in the UTRAN** | 525d | 2000-08-21 A | 2002-08-23 A | 100% | 2000-08-21 | 2002-08-23 | 525d |  | RP | 8600h | 8600h | ETRAN | Rel-4 | Issam |  | Alcatel | Francois Courau |  |
| 2182 | 62.1 | QoS optimization for AAL2 connections over Iub and Iur interfaces | 160d | 2000-08-21 A | 2001-03-30 A | 100% | 2000-08-21 | 2001-03-30 | 160d | finish no earlier than 2001-03-30 | R3 | 1280h | 1280h | ETRAN-QoSAAL2 | Rel-4 | Juha |  | Japan Telecom | T. Yoshimura |  |
| 2183 | 62.2 | Transport bearer modification procedure on Iub, Iur, and Iu | 130d | 2000-10-02 A | 2001-03-30 A | 100% | 2000-10-02 | 2001-03-30 | 130d | finish no earlier than 2001-03-30 | R3 | 1040h | 1040h | ETRAN-MigrMod | Rel-4 | Juha |  | Japan Telecom | T. Yoshimura |  |
| 2184 | 62.3 | **Deleted - Conformance Test Aspects of Rel-4 evolutions of the transport in UTRAN** | 130d | 2002-02-25 A | 2002-08-23 A | 100% | 2002-02-25 | 2002-08-23 | 130d |  | T1 | 2080h | 2080h |  | Rel-4 | Ingbert |  |  |  |  |
| 2185 | 62.3.1 | Deleted - Testing RAB support enhancements | 130d | 2002-02-25 A | 2002-08-23 A | 100% | 2002-02-25 | 2002-08-23 | 130d | finish no earlier than 2002-08-23 | T1 | 1040h | 1040h | CT-RABS? | Rel-4 | Ingbert |  |  |  | 34.108, 34. 121, 34.122, 34.123 p 1,2, 34.123 pt 3 |
| 2186 | 63 | **Rel-4 Evolutions of the transport in the CN** | 215d | 2000-05-29 A | 2001-03-23 A | 100% | 2000-05-29 | 2001-03-23 | 215d |  | N4,N1,N2,S2 | 7968h | 7968h | CNTRSP | Rel-4 | Kimmo |  |  |  |  |
| 2187 | 63.1 | **IP Transport of CN protocols (e.g., CAP, MAP)** | 77d | 2000-12-07 A | 2001-03-23 A | 100% | 2000-12-07 | 2001-03-23 | 77d |  | N4 | 2808h | 2808h | SS7IP | Rel-4 | Kimmo |  |  |  |  |
| 2188 | 63.1.1 | **Stage 3** | 77d | 2000-12-07 A | 2001-03-23 A | 100% | 2000-12-07 | 2001-03-23 | 77d |  | N4 | 2192h | 2192h |  | Rel-4 | Kimmo |  |  |  |  |
| 2189 | 63.1.1.1 | CAP | 77d | 2000-12-07 A | 2001-03-23 A | 100% | 2000-12-07 | 2001-03-23 | 77d | finish no earlier than 2001-03-23 | N2 | 616h | 616h |  | Rel-4 | Kimmo |  |  |  |  |
| 2190 | 63.1.1.2 | MAP | 77d | 2000-12-07 A | 2001-03-23 A | 100% | 2000-12-07 | 2001-03-23 | 77d | finish no earlier than 2001-03-23 | N4 | 616h | 616h |  | Rel-4 | Kimmo |  |  |  |  |
| 2191 | 63.1.1.3 | BSSAP+ | 43d | 2001-01-15 A | 2001-03-14 A | 100% | 2001-01-15 | 2001-03-14 | 43d | finish no earlier than 2001-03-14 | N1 | 344h | 344h | SS7IP-BSSAP+ | Rel-4 | Frederic |  |  |  |  |

Notes:
- 2167: -
- 2168: -
- 2169: -
- 2170: -
- 2171: -
- 2172: Still exist? To be clarified by GERAN4/5. Marked as stopped 12/2008
- 2173: Marked as stopped 12/2008
- 2174: Marked as stopped 12/2008
- 2175: Marked as stopped 12/2008
- 2176: Marked as stopped 12/2008
- 2177: -
- 2178: Marked as stopped 12/2008
- 2179: "Joker" WI, to be used for a Rel 4 CR not related to any feature and with very limited impact on the system
- 2180: "Joker" WI, to be used for small modifications applicable to Rel 4 conformance testing. Moved in from the Stoyan/Testing WP
- 2181: -
- 2182: -
- 2183: -
- 2184: Marked as stopped 12/2008
- 2185: Marked as stopped 12/2008
- 2186: -
- 2187: -
- 2188: -
- 2189: -
- 2190: -
- 2191: -

| ID | WBS | Task | Duration | Start | Finish | Complete | Baseline start | Baseline finish | Baseline duration | Constraint | Resources | Work | Actual work | Text4 | Text5 | Text6 | Text8 | Text1 | Text3 | Text12 |
| --- | --- | --- | --- | --- | --- | --- | --- | --- | --- | --- | --- | --- | --- | --- | --- | --- | --- | --- | --- | --- |
| 2192 | 63.2 | **FS on Transport and control separation in the PS CN domain** | 215d | 2000-05-29 A | 2001-03-23 A | 100% | 2000-05-29 | 2001-03-23 | 215d |  | S2 | 3440h | 3440h | Ericsson | Juan-Antonio.Ibanez@eed.ericsson.se | Rel-4 | Maurice |  |  |  |
| 2193 | 63.2.1 | Architectural impacts | 215d | 2000-05-29 A | 2001-03-23 A | 100% | 2000-05-29 | 2001-03-23 | 215d | finish no earlier than 2001-03-23 | S2 | 1720h | 1720h |  |  | Rel-4 | Maurice |  |  |  |
| 2194 | 64 | **Rel-4 Improvements of Radio Interface** | 700d | 2000-07-10 A | 2003-03-14 A | 100% | 2000-07-10 | 2003-03-14 | 700d |  | RP | 28624h | 28624h |  |  | Rel-4 |  | RInImp |  |  |
| 2195 | 64.1 | UTRA repeater specification (master) | 183d | 2000-07-10 A | 2001-03-21 A | 100% | 2000-07-10 | 2001-03-21 | 183d | finish no earlier than 2001-03-21 | R4 | 1464h | 1464h | Mikom, Allgon | T. Kummetz, Mikom; Alf Ahlström, Allgon | Rel-4 | Issam | RInImp-REP |  |  |
| 2196 | 64.2 | DSCH power control improvement in soft handover | 140d | 2000-09-11 A | 2001-03-23 A | 100% | 2000-09-11 | 2001-03-23 | 140d | finish no earlier than 2001-03-23 | R1 | 1120h | 1120h | Nokia | antti.toskala@nokia.com | Rel-4 | Patrick | RInImp-DSCHsho |  |  |
| 2197 | 64.3 | UMTS 1800 | 320d | 2000-09-25 A | 2001-12-14 A | 100% | 2000-09-25 | 2001-12-14 | 320d | finish no earlier than 2001-12-14 | R4 | 2560h | 2560h | Motorola | Howard Benn | Rel-4 | Issam | RInImp-UMTS18 |  |  |
| 2198 | 64.4 | UMTS 1900 | 195d | 2001-03-19 A | 2001-12-14 A | 100% | 2001-03-19 | 2001-12-14 | 195d | finish no earlier than 2001-12-14 | R4 | 1560h | 1560h | Motorola | Howard Benn | Rel-4 | Issam | RInImp-UMTS19 | 25.101 |  |
| 2199 | 64.5 | FS on High Speed downlink packet access | 155d | 2000-08-21 A | 2001-03-23 A | 100% | 2000-08-21 | 2001-03-23 | 155d | finish no earlier than 2001-03-23 | R2 | 1240h | 1240h | Motorola | A. Ghosh | Rel-4 | Joern | RInImp-HSDPA |  |  |
| 2200 | 64.6 | Deleted - FS on improved common DL channel for Cell-FACH state | 340d | 2000-09-11 A | 2001-12-28 A | 100% | 2000-09-11 | 2001-12-28 | 340d | finish no earlier than 2001-12-28 | R2 | 2720h | 2720h | GBT | J. Kwak | Rel-4 | Joern | RInImp-DLCFACH |  | RP-14 |
| 2201 | 64.7 | **Conformance Test Spec. Rel-4 improvements in Radio Interface** | 375d | 2001-10-08 A | 2003-03-14 A | 100% | 2001-10-08 | 2003-03-14 | 375d |  | T1 | 12360h | 12360h |  |  | Rel-4 | Ingbert |  |  |  |
| 2202 | 64.7.1 | Deleted - Testing Improved usage of downlink resource in FDD for CCTrCHs of dedicated type | 140d | 2002-02-18 A | 2002-08-30 A | 100% | 2002-02-18 | 2002-08-30 | 140d | finish no earlier than 2002-08-30 | T1 | 1120h | 1120h |  |  | Rel-4 | Ingbert |  |  | TP-17 |
| 2203 | 64.7.2 | Deleted - Testing Terminal Power saving features | 140d | 2002-02-18 A | 2002-08-30 A | 100% | 2002-02-18 | 2002-08-30 | 140d | finish no earlier than 2002-08-30 | T1 | 1120h | 1120h |  |  | Rel-4 | Ingbert |  |  | TP-17 |
| 2204 | 64.7.3 | Deleted - Testing DSCH power control improvement in soft handover | 140d | 2002-02-18 A | 2002-08-30 A | 100% | 2002-02-18 | 2002-08-30 | 140d | finish no earlier than 2002-08-30 | T1 | 1120h | 1120h |  |  | Rel-4 | Ingbert |  |  | TP-17 |
| 2205 | 64.7.4 | Testing UMTS 1800 | 180d | 2001-10-08 A | 2002-06-14 A | 100% | 2001-10-08 | 2002-06-14 | 180d | finish no earlier than 2002-06-14 | T1 | 1440h | 1440h |  |  | Rel-4 | Ingbert |  | 34.108, 34,121, 34.122, 34.123-1 |  |
| 2206 | 64.7.5 | Testing UMTS 1900 | 180d | 2001-10-08 A | 2002-06-14 A | 100% | 2001-10-08 | 2002-06-14 | 180d | finish no earlier than 2002-06-14 | T1 | 1440h | 1440h |  |  | Rel-4 | Ingbert |  | 34.108, 34,121, 34.122, 34.123-1 |  |
| 2207 | 64.7.6 | Testing UMTS 1800 - TTCN | 195d | 2002-06-17 A | 2003-03-14 A | 100% | 2002-06-17 | 2003-03-14 | 195d | finish no earlier than 2003-03-14 | T1 | 1560h | 1560h |  |  | Rel-4 | Ingbert |  | 34.123-3 |  |
| 2208 | 64.7.7 | Testing UMTS 1900 - TTCN | 195d | 2002-06-17 A | 2003-03-14 A | 100% | 2002-06-17 | 2003-03-14 | 195d | finish no earlier than 2003-03-14 | T1 | 1560h | 1560h |  |  | Rel-4 | Ingbert |  | 34.123-3 |  |
| 2209 | 65 | **Rel-4 RAN improvements** | 938d? | 2000-08-14 A | 2004-03-17 A | 100% | 2000-08-14 | 2004-03-17 | 938d? |  | RP | 29336h | 29336h |  |  | Rel-4 |  | RANimp |  |  |
| 2210 | 65.1 | Node B synchronization for TDD | 160d | 2000-08-14 A | 2001-03-23 A | 100% | 2000-08-14 | 2001-03-23 | 160d | finish no earlier than 2001-03-23 | R1 | 1280h | 1280h | Siemens | S. Oestreich | Rel-4 | Patrick | RANimp-NBsync |  |  |
| 2211 | 65.2 | RAB support enhancement for Rel-4 | 155d | 2000-08-21 A | 2001-03-23 A | 100% | 2000-08-21 | 2001-03-23 | 155d | finish no earlier than 2001-03-23 | R2 | 1240h | 1240h | Ericsson | M. Israelsson, A. Krishnarajah | Rel-4 | Joern | RANimp-RABSE |  |  |
| 2212 | 65.4 | **Deleted - Conformance Test Aspects - Rel-4 RAN Improvements** | 577d? | 2002-01-01 A | 2004-03-17 A | 100% | 2002-01-01 | 2004-03-17 | 577d? |  | T1 | 19312h | 19312h |  |  | Rel-4 | Ingbert |  |  |  |
| 2213 | 65.4.1 | Deleted - Testing Radio access bearer support enhancments | 175d | 2002-01-01 A | 2002-09-02 A | 100% | 2002-01-01 | 2002-09-02 | 175d | finish no earlier than 2002-09-02 | T1 | 1400h | 1400h |  |  | Rel-4 | Ingbert |  |  | TP-17 |
| 2214 | 65.4.2 | Deleted - Testing RAB support enhancements-Robust Header Compression | 332d | 2002-05-28 A | 2003-09-03 A | 100% | 2002-05-28 | 2003-09-03 | 332d | finish no earlier than 2003-09-03 | T1 | 2656h | 2656h |  |  | Rel-4 | Ingbert | RABimp-RoCH | 34.123-1, -2 | TP-21 |
| 2215 | 65.4.3 | Deleted - Testing RAB support enhancements-Robust Header Compression - TTCN | 472d | 2002-05-28 A | 2004-03-17 A | 100% | 2002-05-28 | 2004-03-17 | 472d | finish no earlier than 2004-03-17 | T1 | 3776h | 3776h |  |  | Rel-4 | Ingbert |  | 34.123-3 | TP-23 |
| 2216 | 65.4.4 | Testing of Extended Robut Header Compression | 270d | 2002-09-18 A | 2003-09-30 A | 100% | 2002-09-18 | 2003-09-30 | 270d | finish no earlier than 2003-09-30 | T1 | 2160h | 2160h |  |  | Rel-4 | Ingbert | Ext-RoHC | 34.123-1, -2 |  |
| 2217 | 65.4.5 | Deleted - Testing of Extended Robut Header Compression - TTCN | 325d | 2002-09-18 A | 2003-12-16 A | 100% | 2002-09-18 | 2003-12-16 | 325d | finish no earlier than 2003-12-16 | T1 | 2600h | 2600h |  |  | Rel-4 | Ingbert |  | 34.123-3 | TP-22 |
| 2218 | 541.3.6 | Deleted - General changes to TS34.121 corresponding to release 4 | 263d? | 2003-03-03 A | 2004-03-03 A | 100% | 2003-03-03 | 2004-03-03 | 263d? | finish no earlier than 2004-03-03 | T1 | 2104h | 2104h |  |  | Rel-4 | Ingbert | RANimp-test | 34.108, 34.121 | TP-23 |

Notes:
- 2192: -
- 2193: -
- 2194: -
- 2195: -
- 2196: -
- 2197: -
- 2198: -
- 2199: -
- 2200: Stopped at RP#14
- 2201: -
- 2202: Marked as stopped 12/2008
- 2203: Marked as stopped 12/2008
- 2204: Marked as stopped 12/2008
- 2205: -
- 2206: -
- 2207: -
- 2208: -
- 2209: -
- 2210: -
- 2211: 29 Nov 2000: split into ROHC and non-ROHC part; 5 Mar 2001: splitting off of ROHC for Rel-4 agreed by R2
- 2212: Marked as stopped 12/2008
- 2213: Marked as stopped 12/2008
- 2214: UID changed. Marked as stopped 12/2008
- 2215: UID changed. Marked as stopped 12/2008
- 2216: Marked as closed 12/2008 (was marked 15% complete)
- 2217: Marked as stopped 12/2008
- 2218: Marked as stopped 12/2008

| ID | WBS | Task | Duration | Start | Finish | Complete | Baseline start | Baseline finish | Baseline duration | Constraint | Resources | Work | Actual work | Text1 | Text4 | Text6 | Text8 | Text12 | Text3 | Text5 |
| --- | --- | --- | --- | --- | --- | --- | --- | --- | --- | --- | --- | --- | --- | --- | --- | --- | --- | --- | --- | --- |
| 2219 | 66 | **Rel-4 Emergency call enhancements** | 628d | 2000-01-03 A | 2002-05-28 A | 100% | 2000-01-03 | 2002-05-28 | 628d |  | N1,S1,T1 | 3600h | 3600h | EMC1 | Ericsson | Rel-4 | Frederic |  |  |  |
| 2220 | 66.1 | **For CS based calls** | 628d | 2000-01-03 A | 2002-05-28 A | 100% | 2000-01-03 | 2002-05-28 | 628d |  | N1 | 3600h | 3600h | EMC1-CS | Ericsson | Rel-4 | Frederic |  |  |  |
| 2221 | 66.1.1 | Distinction in CS domain of emergency call types to different emergency services | 40d | 2000-05-01 A | 2000-06-23 A | 100% | 2000-05-01 | 2000-06-23 | 40d | finish no earlier than 2000-06-23 | S1 | 320h | 320h | EMC1-CS |  | Rel-4 | Alain |  |  |  |
| 2222 | 66.1.2 | Distinction in CS domain of emergency calls to different emergency types | 22d | 2000-08-24 A | 2000-09-22 A | 100% | 2000-08-24 | 2000-09-22 | 22d | finish no earlier than 2000-09-22 | N1 | 176h | 176h | EMC1-CS |  | Rel-4 | Frederic |  |  |  |
| 2223 | 66.1.3 | Deleted - Conformance Test Aspects - Emergency call enhancements | 151d | 2000-01-03 A | 2000-07-28 A | 100% | 2000-01-03 | 2000-07-28 | 151d |  | T1 | 1200h | 1200h | EMC1-CS |  | Rel-4 | Ingbert | TP-08 |  |  |
| 2224 | 66.1.4 | Testing CS based emergency calls | 67d | 2002-02-25 A | 2002-05-28 A | 100% | 2002-02-25 | 2002-05-28 | 67d | finish no earlier than 2002-05-28 | T1 | 536h | 536h | EMC1-CS |  | Rel-4 | Ingbert |  | 34.123-1 |  |
| 2225 | 66.1.5 | Testing CS based emergency calls - TTCN | 134d | 2001-11-22 A | 2002-05-28 A | 100% | 2001-11-22 | 2002-05-28 | 134d | finish no earlier than 2002-05-28 | T1 | 1072h | 1072h | EMC1-CS |  | Rel-4 | Ingbert |  | 34.123-3 |  |
| 2226 | 67 | **Rel-4 Terminal interfaces** | 315d | 2000-01-03 A | 2001-03-15 A | 100% | 2000-01-03 | 2001-03-15 | 315d |  | T2 | 14296h | 14296h | TI |  | Rel-4 | Kimmo |  |  |  |
| 2227 | 67.1 | **AT commands enhancements** | 314d | 2000-01-03 A | 2001-03-14 A | 100% | 2000-01-03 | 2001-03-14 | 314d |  | T2 | 5016h | 5016h | TI-ATC |  | Rel-4 |  |  | 27.007 |  |
| 2228 | 67.1.1 | Specification of AT commands for new services | 314d | 2000-01-03 A | 2001-03-14 A | 100% | 2000-01-03 | 2001-03-14 | 314d | finish no earlier than 2001-03-14 | T2 | 2504h | 2504h |  |  | Rel-4 |  |  | 27.007 |  |
| 2229 | 67.2 | **Wide Area Data Synchronization** | 314d | 2000-01-03 A | 2001-03-14 A | 100% | 2000-01-03 | 2001-03-14 | 314d |  | T2 | 5016h | 5016h | TI-WADS |  | Rel-4 |  |  |  |  |
| 2230 | 67.2.1 | Continues evolution of Synchronization protocol | 314d | 2000-01-03 A | 2001-03-14 A | 100% | 2000-01-03 | 2001-03-14 | 314d | finish no earlier than 2001-03-14 | T2 | 2504h | 2504h | TI-SYNC-EVOL |  | Rel-4 |  |  | 27.903, 27.103 |  |
| 2231 | 67.3 | Terminal local model | 218d | 2000-05-16 A | 2001-03-15 A | 100% | 2000-05-16 | 2001-03-15 | 218d | finish no earlier than 2001-03-15 | T2 | 1744h | 1744h | TLM | Ericsson | Rel-4 |  |  | 23.227 | Olga.Tome@ECS.ERICSSON.SE |
| 2232 | 68 | **Rel-4 Location Services enhancements** | 455d | 2000-04-03 A | 2001-12-28 A | 100% | 2000-04-03 | 2001-12-28 | 455d |  | S2 | 26799.2h | 26799.2h | LCS1 | Nokia | Rel-4 | Maurice |  |  | Jan Kall |
| 2233 | 68.1 | CBS interactions | 455d | 2000-04-03 A | 2001-12-28 A | 100% | 2000-04-03 | 2001-12-28 | 455d | finish no earlier than 2001-12-28 | T2 | 3640h | 3640h | LCS1-CBS |  | Rel-4 |  |  | 23.041 |  |
| 2234 | 68.2 | LCS support in the CS domain | 180d | 2000-05-15 A | 2001-01-19 A | 100% | 2000-05-15 | 2001-01-19 | 180d | finish no earlier than 2001-01-19 | S2 | 1440h | 1440h | LCS1-CS |  | Rel-4 | Maurice |  |  |  |
| 2235 | 68.3 | **LCS support in the PS domain** | 435d | 2000-05-01 A | 2001-12-28 A | 100% | 2000-05-01 | 2001-12-28 | 435d |  | S2 | 13560h | 13560h | LCS1-PS |  | Rel-4 | Maurice |  |  |  |
| 2236 | 68.3.1 | Stage 1 | 40d | 2000-07-03 A | 2000-08-25 A | 100% | 2000-07-03 | 2000-08-25 | 40d | start no earlier than 2000-07-03 | S1 | 320h | 320h |  | Pacific Bell Wireless | Rel-4 | Alain |  | 22.071 | Randolph Wohlert (rwohlert@tri.sbc.com) |
| 2237 | 68.3.2 | Stage 2 | 190d | 2000-05-01 A | 2001-01-19 A | 100% | 2000-05-01 | 2001-01-19 | 190d | finish no earlier than 2001-01-19 | S2 | 1520h | 1520h |  |  | Rel-4 | Maurice |  | 23.271 |  |
| 2238 | 68.3.3 | **Stage 3** | 355d | 2000-08-21 A | 2001-12-28 A | 100% | 2000-08-21 | 2001-12-28 | 355d |  | N1 | 8240h | 8240h |  |  | Rel-4 | Frederic |  |  |  |
| 2239 | 68.3.3.1 | Layer 3 LCS signalling UE (MS) -SGSN (UMTS PS and and GSM-GPRS) | 355d | 2000-08-21 A | 2001-12-28 A | 100% | 2000-08-21 | 2001-12-28 | 355d | finish no earlier than 2001-12-28 | N1 | 2840h | 2840h |  | Nokia | Rel-4 | Frederic |  |  | Janne Muhonen |
| 2240 | 68.3.3.2 | MAP impacts of LCS | 160d | 2000-08-21 A | 2001-03-30 A | 100% | 2000-08-21 | 2001-03-30 | 160d | finish no earlier than 2001-03-30 | N4 | 1280h | 1280h |  |  | Rel-4 | Kimmo |  |  |  |
| 2241 | 68.3.3.3 | GTP signalling for LCS | 160d | 2000-08-21 A | 2001-03-30 A | 100% | 2000-08-21 | 2001-03-30 | 160d | finish no earlier than 2001-03-30 | N4 | 1280h | 1280h |  |  | Rel-4 | Kimmo |  |  |  |
| 2242 | 68.4 | **UE positioning Rel-4** | 260d | 2000-04-03 A | 2001-03-30 A | 100% | 2000-04-03 | 2001-03-30 | 260d |  | RP | 4591.2h | 4591.2h | LCS1-UEpos |  | Rel-4 | Issam |  |  |  |
| 2243 | 68.4.1 | Iub/Iur interfaces for methods Rel 99 | 233.9d | 2000-04-03 A | 2001-03-30 A | 100% | 2000-04-03 | 2001-03-30 | 233.9d | finish no earlier than 2001-03-30 | R3 | 1871.2h | 1871.2h | LCS1-UEpos-IubIur | Ericsson | Rel-4 | Juha |  |  | Yun-Chao Hu |
| 2244 | 68.4.2 | UE positioning enhancements - IPDL for TDD | 150d | 2000-08-28 A | 2001-03-23 A | 100% | 2000-08-28 | 2001-03-23 | 150d | finish no earlier than 2001-03-23 | R2 | 1200h | 1200h | LCS1-UEpos-enh | Siemens | Rel-4 | Joern |  |  | M. Beckmann |

Notes:
- 2219: -
- 2220: WI approved in TSG_10
- 2221: -
- 2222: Calls to different emergency services such as ambulance, fire brigade, police, etc. can be routed to respective different emergency centres. / NP-000447 is the stage 3 changes for CS call control protocol.
- 2223: UID changed. Marked as stopped 12/2008
- 2224: -
- 2225: -
- 2226: -
- 2227: -
- 2228: goal not completely achieved because of missing input
- 2229: AS: Rel5 changed to Rel4 according to SP#10 decision, milestone on testing added
- 2230: -
- 2231: -
- 2232: -
- 2233: -
- 2234: Only MAP impact foreseen so far. To be further split if needed.
- 2235: -
- 2236: To be also considered: External LCS client identity, and Privacy options when PDP-context and when no PDP-context is established
- 2237: AS: 23.271 completed at SP#10
- 2238: -
- 2239: -
- 2240: Missing work task
- 2241: -
- 2242: UID changed
- 2243: 27/11: WG corrected; rapporteur corrected
- 2244: 5 Mar 2001: splitting off of IPDL for TDD for Rel-4 agreed by R2

| ID | WBS | Task | Duration | Start | Finish | Complete | Baseline start | Baseline finish | Baseline duration | Constraint | Resources | Work | Actual work | Text1 | Text6 | Text8 | Text3 | Text4 | Text5 | Text12 |
| --- | --- | --- | --- | --- | --- | --- | --- | --- | --- | --- | --- | --- | --- | --- | --- | --- | --- | --- | --- | --- |
| 2245 | 69 | **Rel-4 UICC/(U)SIM enhancements and interworking** | 175d | 2000-07-24 A | 2001-03-23 A | 100% | 2000-07-24 | 2001-03-23 | 175d |  | T3 | 2800h | 2800h | UICC1 | Rel-4 | Xavier |  |  |  |  |
| 2246 | 69.1 | Common PCN Handset Specification (CPHS) | 175d | 2000-07-24 A | 2001-03-23 A | 100% | 2000-07-24 | 2001-03-23 | 175d | finish no earlier than 2001-03-23 | T3 | 1400h | 1400h | UICC1-CPHS | Rel-4 |  | 27.103 | One2One |  |  |
| 2247 | 70 | **Rel-4 (U)SIM toolkit enhancements** | 210d | 2000-06-05 A | 2001-03-23 A | 100% | 2000-06-05 | 2001-03-23 | 210d |  | T3 | 3360h | 3360h | USAT1-LocLnk | Rel-4 | Xavier |  | Gemplus | Jean-Francois Rubon |  |
| 2248 | 70.1 | USAT local link | 210d | 2000-06-05 A | 2001-03-23 A | 100% | 2000-06-05 | 2001-03-23 | 210d | finish no earlier than 2001-03-23 | T3 | 1680h | 1680h | USAT1-LocLnk | Rel-4 | Xavier |  | Gemplus | Jean-Francois Rubon |  |
| 2249 | 71 | **Rel-4 Security enhancements** | 576d | 2000-01-03 A | 2002-03-15 A | 100% | 2000-01-03 | 2002-03-15 | 576d |  | S3 | 24152h | 24152h |  | Rel-4 | Dionisio |  | Vodafone | Peter.Howard@vodafone.com |  |
| 2250 | 71.1 | Evolution of GSM CS algorithms (e.g. A5/3 development and deployment) | 272d | 2000-01-03 A | 2001-01-15 A | 100% | 2000-01-03 | 2001-01-15 | 272d | finish no earlier than 2001-01-15 | S3 | 2168h | 2168h | SEC1-CSALGO1 | Rel-4 | Dionisio |  |  |  |  |
| 2251 | 71.2 | **Evolution of GSM PS algorithms (e.g. GEA 2 deployment)** | 219d | 2000-02-22 A | 2000-12-22 A | 100% | 2000-02-22 | 2000-12-22 | 219d |  | S3 | 6024h | 6024h | SEC1-PSALGO1 | Rel-4 | Dionisio |  |  |  |  |
| 2252 | 71.2.1 | Main aspects | 199d | 2000-02-22 A | 2000-11-24 A | 100% | 2000-02-22 | 2000-11-24 | 199d | finish no earlier than 2000-11-24 | S3 | 1592h | 1592h | SEC1-PSALGO1 | Rel-4 | Dionisio |  |  |  |  |
| 2253 | 71.2.2 | Impact on GTP | 200d | 2000-03-20 A | 2000-12-22 A | 100% | 2000-03-20 | 2000-12-22 | 200d | finish no earlier than 2000-12-22 | N4 | 1600h | 1600h | SEC1-PSALGO1 | Rel-4 | Kimmo |  |  |  |  |
| 2254 | 71.2.3 | GEA capability indication in MS CM | 135d | 2000-06-19 A | 2000-12-22 A | 100% | 2000-06-19 | 2000-12-22 | 135d | finish no earlier than 2000-12-22 | N1 | 1080h | 1080h | SEC1-PSALGO1-GEACAP | Rel-4 | Frederic |  | Vodafone Airtouch | Duncan Mills |  |
| 2255 | 71.3 | **Deleted - MAP application layer security** | 576d | 2000-01-03 A | 2002-03-15 A | 100% | 2000-01-03 | 2002-03-15 | 576d |  | S3 | 11352h | 11352h | SEC1-MAPAL | Rel-4 | Dionisio |  |  |  | SP-15 |
| 2256 | 71.3.1 | Deleted - Main aspects | 199d | 2000-02-21 A | 2001-03-29 A | 100% | 2000-02-21 | 2001-03-29 | 199d | start no earlier than 2000-02-21 | S3 | 1592h | 1592h |  | Rel-4 | Dionisio |  |  |  | SP-11 |
| 2257 | 71.3.2 | Deleted - Other stage 3 aspects | 199d | 2000-02-22 A | 2000-11-24 A | 100% | 2000-02-22 | 2000-11-24 | 199d | finish no earlier than 2000-11-24 | N4 | 1592h | 1592h |  | Rel-4 | Kimmo |  |  |  | CP-10 |
| 2258 | 71.3.3 | Deleted - Visibility and Configurability of security | 576d | 2000-01-03 A | 2002-03-15 A | 100% | 2000-01-03 | 2002-03-15 | 576d | finish no earlier than 2002-03-15 | S3 | 4600h | 4600h | SEC1-VCS | Rel-4 | Dionisio |  | France Telecom | Sebastien.nguyenngoc@rd.francetelecom.com | SP-15 |
| 2259 | 72 | **Rel-4 Charging and OAM&P** | 221d | 2000-12-01 A | 2001-10-05 A | 100% | 2000-12-01 | 2001-10-05 | 221d |  | S5 | 10472h | 10472h | OAM | Rel-4 | Dionisio |  | VoiceStream, Motorola |  |  |
| 2260 | 72.1 | Rel4 Principles, high level Requirements and Architecture | 145d | 2000-12-01 A | 2001-06-21 A | 100% | 2000-12-01 | 2001-06-21 | 145d | finish no earlier than 2001-06-21 | S5 | 1160h | 1160h | OAM-AR/PR | Rel-4 | Dionisio | 32.101, 32.102 | Motorola, Telia | Michael.Truss@MOTOROLA.COM; Tommy.R.Berggren@TELIA.SE |  |
| 2261 | 72.2 | Rel4 Performance Management | 216d | 2000-12-01 A | 2001-09-28 A | 100% | 2000-12-01 | 2001-09-28 | 216d | finish no earlier than 2001-06-21 | S5 | 1728h | 1728h |  | Rel-4 | Dionisio | 32.4xy, 52.402 | T-Mobile | karl-heinz.nenner@t-mobile.de |  |
| 2262 | 72.3 | Fault Management | 221d | 2000-12-01 A | 2001-10-05 A | 100% | 2000-12-01 | 2001-10-05 | 221d | finish no earlier than 2001-06-21 | S5 | 1768h | 1768h |  | Rel-4 | Dionisio | 32.111-1/4 | Lucent |  |  |
| 2263 | 72.4 | Configuration Management | 145d | 2000-12-01 A | 2001-06-21 A | 100% | 2000-12-01 | 2001-06-21 | 145d | finish no earlier than 2001-06-21 | S5 | 1160h | 1160h | OAM-CM | Rel-4 | Dionisio | 32.106-1/8 | Ericsson | thomas.tovinger@ericsson.com |  |
| 2264 | 72.5 | Rel4 Charging Management | 216d | 2000-12-01 A | 2001-09-28 A | 100% | 2000-12-01 | 2001-09-28 | 216d | finish no earlier than 2001-06-21 | S5 | 1728h | 1728h | OAM-CH | Rel-4 | Dionisio | 32.200, 32.205, 32.215, 32.235 | T-Mobile | karl-heinz.nenner@t-mobile.de |  |
| 2265 | 72.6 | UTRAN Operations and Maintenance procedures | 145d | 2000-12-01 A | 2001-06-21 A | 100% | 2000-12-01 | 2001-06-21 | 145d | finish no earlier than 2001-06-21 | S5 | 1160h | 1160h | UOAM | Rel-4 | Dionisio | 32.800 | Mannesmann Mobilfunk | bert.boden@d2mannesmann.de |  |
| 2266 | 73 | **Global Text Telephony** | 2537d? | 2000-01-03 A | 2009-09-18 A | 100% | 2000-01-03 | 2009-09-18 | 2537d? |  | S1,S2,S4,T1,R5 | 44928h | 44928h | GTT | Rel-4 | Maurice |  | Ericsson | gunnar.hellstrom@omnitor.se |  |
| 2267 | 73.1 | Stage 1 | 188d | 2000-04-05 A | 2000-12-22 A | 100% | 2000-04-05 | 2000-12-22 | 188d | finish no earlier than 2000-12-22 | S1 | 1504h | 1504h | GTT | Rel-4 | Alain | 22.976, 22.226 |  |  |  |
| 2268 | 73.2 | Stage 2 | 206d | 2000-01-03 A | 2000-10-13 A | 100% | 2000-01-03 | 2000-10-13 | 206d |  | S2 | 1640h | 1640h | GTT | Rel-4 | Maurice | 23.226 |  |  |  |

Notes:
- 2245: -
- 2246: 28/5/2001: CRs approved at TP-11. WI complete.
- 2247: -
- 2248: 25/5/2001:CR was approved at TP-11. WI is complete
- 2249: Added BB UE authentication and rapporteur added. TO BE DELETED
- 2250: Approved SP#17
- 2251: A5/3 development will consider new GEA algorithm based on Kasumi
- 2252: Complete TSG#09 (09/2000). S3#17: Proposed for deletion. TO BE DELETED
- 2253: -
- 2254: -
- 2255: REPLACED BY NDS-MAP and NDS-IP. Completed Auto Key Management -> Rel-6. Marked as stopped 12/2008
- 2256: UID changed. Marked as stopped 12/2008
- 2257: UID changed. Marked as stopped 12/2008
- 2258: CR approved at SA3#21 awaiting comments from CN1. Marked as stopped 12/2008
- 2259: SP#13 approved WID
- 2260: -
- 2261: -
- 2262: -
- 2263: -
- 2264: -
- 2265: -
- 2266: SP#12 updated WID SP-000162=>SP-010340
- 2267: -
- 2268: -

| ID | WBS | Task | Type | Duration | Start | Finish | Complete | Baseline start | Baseline finish | Baseline duration | Total slack | Constraint | Resources | Work | Actual work | Text1 | Text6 | Text8 | Text9 | Text12 |
| --- | --- | --- | --- | --- | --- | --- | --- | --- | --- | --- | --- | --- | --- | --- | --- | --- | --- | --- | --- | --- |
| 2269 | 73.3 | **Specification of Cellular Text telephone Modem** |  | 136d | 2000-09-11 A | 2001-03-19 A | 100% | 2000-09-11 | 2001-03-19 | 136d |  |  | S4 | 2704h | 2704h | GTT-CTM | Rel-4 | Paolo |  |  |
| 2270 | 73.3.1 | General description and C-code |  | 66d | 2000-09-11 A | 2000-12-11 A | 100% | 2000-09-11 | 2000-12-11 | 66d |  | finish no earlier than 2000-12-11 | S4 | 528h | 528h | GTT-CTM | Rel-4 | Paolo |  |  |
| 2271 | 73.3.2 | Minimum Performance requirements |  | 136d | 2000-09-11 A | 2001-03-19 A | 100% | 2000-09-11 | 2001-03-19 | 136d |  | finish no earlier than 2001-03-19 | S4 | 1088h | 1088h | GTT-CTM | Rel-4 | Paolo |  |  |
| 2272 | 73.5 | Deleted - Conformance Test Aspects - Global Text Telephony |  | 2348d? | 2000-09-21 A | 2009-09-18 A | 100% | 2000-09-21 | 2009-09-18 | 2348d? |  | finish no earlier than 2009-09-18 | R5,T1 | 18784h | 18784h | GTT_Test | Rel-4 | Ingbert | PCG-23 | RP-45 |
| 2273 | 550 | Release 1999 Features | milestone | 0d? | 2000-01-01 | 2000-01-01 |  | 2000-01-01 | 2000-01-01 | 0d? | 3057d |  | NP,SP,TP,SMG |  |  |  | R99 |  |  |  |
| 2274 | 551 | **UMTS Features** |  | 261d? | 1999-01-01 A | 1999-12-31 A | 100% | 1999-01-01 | 1999-12-31 | 261d? |  |  | S1,S2,S4,SMG,N3,N4,RP | 25056h | 25056h |  | R99 |  |  |  |
| 2275 | 551.1 | UMTS_SERVICES |  | 261d? | 1999-01-01 A | 1999-12-31 A | 100% | 1999-01-01 | 1999-12-31 | 261d? |  | start no earlier than 1999-01-01 | S1 | 2088h | 2088h | UMTS_SERVICES | R99 |  |  |  |
| 2276 | 551.2 | UMTS phase 1 |  | 261d? | 1999-01-01 A | 1999-12-31 A | 100% | 1999-01-01 | 1999-12-31 | 261d? |  | start no earlier than 1999-01-01 | S1 | 2088h | 2088h | UMTS1 | R99 |  |  |  |
| 2277 | 551.3 | UMTS Capabilities |  | 261d? | 1999-01-01 A | 1999-12-31 A | 100% | 1999-01-01 | 1999-12-31 | 261d? |  | start no earlier than 1999-01-01 | S1 | 2088h | 2088h | UMTS_Capabil | R99 |  |  |  |
| 2278 | 551.4 | Architecture of the GSM-UMTS platform |  | 261d? | 1999-01-01 A | 1999-12-31 A | 100% | 1999-01-01 | 1999-12-31 | 261d? |  | start no earlier than 1999-01-01 | S2,N4 | 2088h | 2088h |  | R99 |  |  |  |
| 2279 | 551.5 | UMTS Terrestrial Radio Access Network |  | 261d? | 1999-01-01 A | 1999-12-31 A | 100% | 1999-01-01 | 1999-12-31 | 261d? |  | start no earlier than 1999-01-01 | RP | 2088h | 2088h | UTRAN | R99 |  |  |  |
| 2280 | 551.6 | UMTS 1800, UMTS 1900 |  | 261d? | 1999-01-01 A | 1999-12-31 A | 100% | 1999-01-01 | 1999-12-31 | 261d? |  | start no earlier than 1999-01-01 | R2 | 2088h | 2088h | Rlnlmp19, Rlnlmp18 | R99 |  |  |  |
| 2281 | 551.7 | Mandatory speech codec for narrowband telephony service |  | 261d? | 1999-01-01 A | 1999-12-31 A | 100% | 1999-01-01 | 1999-12-31 | 261d? |  | start no earlier than 1999-01-01 | S4 | 2088h | 2088h | Mandatory_Speech_Codec, AMR-NB, AMR | R99 | Paolo |  |  |
| 2282 | 551.8 | Codec for low bitrate multimedia telephony service |  | 261d? | 1999-01-01 A | 1999-12-31 A | 100% | 1999-01-01 | 1999-12-31 | 261d? |  | start no earlier than 1999-01-01 | S4 | 2088h | 2088h | Low_bit_rate_codec_for_MM_Tel., H.324M | R99 | Paolo |  |  |
| 2283 | 551.9 | 3G Audio-Visual Terminal characteristics |  | 261d? | 1999-01-01 A | 1999-12-31 A | 100% | 1999-01-01 | 1999-12-31 | 261d? |  | start no earlier than 1999-01-01 | S4 | 2088h | 2088h | WI5TAC, 3G-AVT, Terminal_Acoustic_Characteristics | R99 |  |  |  |
| 2284 | 551.10 | Updates_for_UMTS |  | 261d? | 1999-01-01 A | 1999-12-31 A | 100% | 1999-01-01 | 1999-12-31 | 261d? |  | start no earlier than 1999-01-01 | N3 | 2088h | 2088h | Updates_for_UMTS | R99 |  |  |  |
| 2285 | 551.11 | UMTS |  | 261d? | 1999-01-01 A | 1999-12-31 A | 100% | 1999-01-01 | 1999-12-31 | 261d? |  | start no earlier than 1999-01-01 | N3 | 2088h | 2088h | UMTS | R99 |  |  |  |
| 2286 | 552 | **UMTS and GSM Features** |  | 261d? | 1999-01-01 A | 1999-12-31 A | 100% | 1999-01-01 | 1999-12-31 | 261d? |  |  | S1,S2,SMG,T2,N1,N2,N3,N4,R2,R3 | 114840h | 114840h |  | R99 |  |  |  |
| 2287 | 552.1 | Multimedia Messaging Service |  | 261d? | 1999-01-01 A | 1999-12-31 A | 100% | 1999-01-01 | 1999-12-31 | 261d? |  | start no earlier than 1999-01-01 | T2 | 2088h | 2088h | MMS | R99 |  |  |  |
| 2288 | 552.2 | Location Services |  | 261d? | 1999-01-01 A | 1999-12-31 A | 100% | 1999-01-01 | 1999-12-31 | 261d? |  | start no earlier than 1999-01-01 | S1,S2,S3,SMG1,SMG2,SMG12,N1,N2,N4,R2,R3 | 2088h | 2088h | LCS | R99 |  |  |  |
| 2289 | 552.3 | **Customised Application for Mobile network Enhanced Logic Phase 3** |  | 261d? | 1999-01-01 A | 1999-12-31 A | 100% | 1999-01-01 | 1999-12-31 | 261d? |  |  | S1,S2,N2,N4 | 6264h | 6264h | CAMEL3 | R99 |  |  |  |
| 2290 | 552.3.1 | Global view |  | 261d? | 1999-01-01 A | 1999-12-31 A | 100% | 1999-01-01 | 1999-12-31 | 261d? |  | start no earlier than 1999-01-01 | S1,S2,N2,N4 | 2088h | 2088h | CAMEL3 | R99 |  |  |  |
| 2291 | 552.3.2 | Multiple Subscriber Profile (MSP) based on CAMEL phase 3 |  | 261d? | 1999-01-01 A | 1999-12-31 A | 100% | 1999-01-01 | 1999-12-31 | 261d? |  | start no earlier than 1999-01-01 | S1 | 2088h | 2088h | CAMEL3 | R99 |  |  |  |
| 2292 | 552.4 | Short Message Service enhancements / Enhanced Messaging Service (EMS) |  | 261d? | 1999-01-01 A | 1999-12-31 A | 100% | 1999-01-01 | 1999-12-31 | 261d? |  | start no earlier than 1999-01-01 | T2 | 2088h | 2088h | EMS | R99 |  |  |  |
| 2293 | 552.5 | Mobile Station Execution Environment |  | 261d? | 1999-01-01 A | 1999-12-31 A | 100% | 1999-01-01 | 1999-12-31 | 261d? |  | start no earlier than 1999-01-01 | S1,SMG1,T2 | 2088h | 2088h | MExE | R99 |  |  |  |
| 2294 | 552.6 | MS_Classmark |  | 261d? | 1999-01-01 A | 1999-12-31 A | 100% | 1999-01-01 | 1999-12-31 | 261d? |  | start no earlier than 1999-01-01 | N1 | 2088h | 2088h | MS_Classmark | R99 |  |  |  |

Notes:
- 2269: -
- 2270: - / Text3: 26.226, 26.230
- 2271: - / Text3: 26.231
- 2272: RP#45 work item abandoned/closed (it was never really started)
- 2273: -
- 2274: -
- 2275: - / Text3: 22.101
- 2276: - / Text3: 22.100
- 2277: Requirement for high quality speech in UMTS Phase 1 but not in R99 / Text3: 22.105
- 2278: wid Architecture overview of the GSM-UMTS System, Architecture the GSM-UMTS Platform and New Access Network to Core Network (BSS-NSS) interface / Text3: 23.002, 23.008, 23.060, 23.101, 23.110
- 2279: - / Text3: 22.011, 22.038, 22.060, 22.078, 22.100, 22.101, 22.105, 22.115, 22.129, 23.002, 23.060, 24.007, 24.008, 25.101, 25.102, 25.104, 25.105, 25.113, 25.123, 25.133, 25.141, 25.142, 25.201, 25.211, 25.212, 25.213, 25.214, 25.215, 25.221, 25.222, 25.223, 25.224,
- 2280: - / Text3: 25.307 CR#0002, 0003 Inclusion of release independent RF related information
- 2281: Define the default speech codec for UMTS (both for FDD and TDD). Definition limited to selection of one codec among several existing ones/proposed codecs: GSM AMR, IS127 EVRC, ITU G.729 and MPEG-4 speech codec. / Text3: 04.08, 05.01, 05.02, 05.03, 05.05, 05.08, 05.09, 05.09, 05.50, 08.60, 08.61, 11.21, 26.071, 26.073, 26.074, 26.090, 26.091, 26.092, 26.093, 26.094, 26.101, 26.102, 26.103, 26.104, 26.975
- 2282: - / Text3: 26.104, 26.110, 26.111, 26.911, 26.912, 26.915
- 2283: - / Text3: 26.131, 26.132
- 2284: - / Text3: 24.022, 27.001, 29.007
- 2285: - / Text3: 27.060, 29.061
- 2286: -
- 2287: MMS allows users to send/receive messages e.g. almost unlimited text length, images, audio and video clips and new content types. R99 only includes the concept. MMS stage 3 is not included in 23.140. Rel-4 adds detailed architecture and protocols. / Text3: 22.140, 23.040, 23.140
- 2288: LCS provide ability to localize a terminal. Location data is used to provide services to end-user (e.g. local map indicating closest restaurants), for emergency services or for a UMTS network entity (RNC to direct beam when space diversity is used) / Text3: 02.07, 03.71, 04.31, 04.35, 04.71, 05.05, 08.08, 08.31, 08.71, 09.31, 22.071, 23.002, 23.003, 23.007, 23.008, 23.016, 23.018, 23.032, 23.171, 24.007, 24.008, 24.030, 24.080, 25.305, 25.306, 25.331, 25.413, 25.423, 29.002, 29.010
- 2289: CAMEL is a network feature providing mechanisms to support services of operators which are not covered by standardised services, even when roaming outside the HPLMN. / Text3: 22.101, 23.008, 23.012, 23.016, 23.018, 23.060, 23.072, 23.078, 23.079, 23.082, 23.093, 29.002, 29.078
- 2290: - / Text3: 22.078, 23.078, 29.078
- 2291: MSP is an optional service enabling mobile subscribers to have several profiles associated with a single IMSI, with each profile being a subscription option. Each profile may be used for mobile originated and mobile terminated calls. / Text3: 22.097 (Advanced Addressing)
- 2292: SMS for 3G terminals compatible with GSM SMS. Added Enhanced Messaging Service (EMS) allowing small pictures, sounds, animations to be transferred via SMS. / Text3: 23.038, 23.039, 23.040, 23.042
- 2293: MExE provides a standardized MS execution environment and ability to negotiate its supported capabilities with a MExE SP. R99 enhances SIM MExE certificate management, security clarifications, QoS and defines two MExE classmarks WAP/Personal-Java based. / Text3: 02.57, 22.057, 22.101, 23.057
- 2294: MExE classmark identifies a category of MExE UE supporting MExE functionality with a minimum level of processing, memory, display, and interactive capabilities. Several MExE classmarks may be defined. / Text3: 24.008

| ID | WBS | Task | Duration | Start | Finish | Complete | Baseline start | Baseline finish | Baseline duration | Constraint | Resources | Work | Actual work | Text1 | Text6 |
| --- | --- | --- | --- | --- | --- | --- | --- | --- | --- | --- | --- | --- | --- | --- | --- |
| 2295 | 552.7 | **MultiCall** | 261d? | 1999-01-01 A | 1999-12-31 A | 100% | 1999-01-01 | 1999-12-31 | 261d? |  | S1,N1,N2,N4 | 4176h | 4176h | Multicall | R99 |
| 2296 | 552.7.1 | Multicall | 261d? | 1999-01-01 A | 1999-12-31 A | 100% | 1999-01-01 | 1999-12-31 | 261d? | start no earlier than 1999-01-01 | S1 | 2088h | 2088h | Multicall | R99 |
| 2297 | 552.8 | Virtual Home Environment | 261d? | 1999-01-01 A | 1999-12-31 A | 100% | 1999-01-01 | 1999-12-31 | 261d? | start no earlier than 1999-01-01 | S1,SMG1,S2 | 2088h | 2088h | VHE | R99 |
| 2298 | 552.9 | Open Service Access | 261d? | 1999-01-01 A | 1999-12-31 A | 100% | 1999-01-01 | 1999-12-31 | 261d? | start no earlier than 1999-01-01 | S1,S2,N5 | 2088h | 2088h | OSA | R99 |
| 2299 | 552.10 | Super Charger mechanism for signalling traffic associated with mobility | 261d? | 1999-01-01 A | 1999-12-31 A | 100% | 1999-01-01 | 1999-12-31 | 261d? | start no earlier than 1999-01-01 | N2,N4 | 2088h | 2088h | Super_Charger | R99 |
| 2300 | 552.11 | Follow_Me service | 261d? | 1999-01-01 A | 1999-12-31 A | 100% | 1999-01-01 | 1999-12-31 | 261d? | start no earlier than 1999-01-01 | S1,N2,N4 | 2088h | 2088h | Follow_Me | R99 |
| 2301 | 552.12 | Wide area network Synchronization and object exchange | 261d? | 1999-01-01 A | 1999-12-31 A | 100% | 1999-01-01 | 1999-12-31 | 261d? | start no earlier than 1999-01-01 | T2 | 2088h | 2088h | SYNC | R99 |
| 2302 | 552.13 | **Terminal Interfaces** | 261d? | 1999-01-01 A | 1999-12-31 A | 100% | 1999-01-01 | 1999-12-31 | 261d? |  | T2 | 8352h | 8352h |  | R99 |
| 2303 | 552.13.1 | AT commands for 3GPP | 261d? | 1999-01-01 A | 1999-12-31 A | 100% | 1999-01-01 | 1999-12-31 | 261d? | start no earlier than 1999-01-01 | T2 | 2088h | 2088h |  | R99 |
| 2304 | 552.13.2 | Physical interfaces | 261d? | 1999-01-01 A | 1999-12-31 A | 100% | 1999-01-01 | 1999-12-31 | 261d? | start no earlier than 1999-01-01 | T2 | 2088h | 2088h |  | R99 |
| 2305 | 552.13.3 | Multiplexer | 261d? | 1999-01-01 A | 1999-12-31 A | 100% | 1999-01-01 | 1999-12-31 | 261d? | start no earlier than 1999-01-01 | T2 | 2088h | 2088h | MUX MS-TE | R99 |
| 2306 | 552.14 | **Bearer Services** | 261d? | 1999-01-01 A | 1999-12-31 A | 100% | 1999-01-01 | 1999-12-31 | 261d? |  | S1,T2,N1,N3 | 27144h | 27144h |  | R99 |
| 2307 | 552.14.1 | **Circuit Switched Bearer Services** | 261d? | 1999-01-01 A | 1999-12-31 A | 100% | 1999-01-01 | 1999-12-31 | 261d? |  | S1,N3 | 14616h | 14616h | Circuit_switched_Bearer_Services | R99 |
| 2308 | 552.14.1.1 | Circuit Switched Bearer Services | 261d? | 1999-01-01 A | 1999-12-31 A | 100% | 1999-01-01 | 1999-12-31 | 261d? | start no earlier than 1999-01-01 | S1,N3 | 2088h | 2088h | CS_Bearerss_in_UMTS | R99 |
| 2309 | 552.14.1.2 | CS_Bearers | 261d? | 1999-01-01 A | 1999-12-31 A | 100% | 1999-01-01 | 1999-12-31 | 261d? | start no earlier than 1999-01-01 | N3 | 2088h | 2088h | CS_Bearers | R99 |
| 2310 | 552.14.1.3 | CS_Bearerss | 261d? | 1999-01-01 A | 1999-12-31 A | 100% | 1999-01-01 | 1999-12-31 | 261d? | start no earlier than 1999-01-01 | N3 | 2088h | 2088h | CS_Bearerss | R99 |
| 2311 | 552.14.1.4 | CS_Data | 261d? | 1999-01-01 A | 1999-12-31 A | 100% | 1999-01-01 | 1999-12-31 | 261d? | start no earlier than 1999-01-01 | N3 | 2088h | 2088h | CS_Data | R99 |
| 2312 | 552.14.1.5 | CS_Data_Bearers | 261d? | 1999-01-01 A | 1999-12-31 A | 100% | 1999-01-01 | 1999-12-31 | 261d? | start no earlier than 1999-01-01 | N3 | 2088h | 2088h | CS_Data_Bearers | R99 |
| 2313 | 552.14.1.6 | Deleted - Circuit Switched Bearer Services | 261d? | 1999-01-01 A | 1999-12-31 A | 100% | 1999-01-01 | 1999-12-31 | 261d? | start no earlier than 1999-01-01 | N3 | 2088h | 2088h | CSBS | R99 |
| 2314 | 552.14.2 | Frame Tunnelling Mode | 261d? | 1999-01-01 A | 1999-12-31 A | 100% | 1999-01-01 | 1999-12-31 | 261d? | start no earlier than 1999-01-01 | T2,N1,N3 | 2088h | 2088h | FTM | R99 |
| 2315 | 552.14.3 | Access to ISPs and Intranets – Wireless/Remote access to LANs | 261d? | 1999-01-01 A | 1999-12-31 A | 100% | 1999-01-01 | 1999-12-31 | 261d? | start no earlier than 1999-01-01 | N3 | 2088h | 2088h | Interworking with PDN (DHCP) | R99 |
| 2316 | 552.14.4 | **PHS Internet Access Forum Specification** | 261d? | 1999-01-01 A | 1999-12-31 A | 100% | 1999-01-01 | 1999-12-31 | 261d? |  | S1,N3 | 6264h | 6264h | PIAFS | R99 |
| 2317 | 552.14.4.1 | Personal Handyphone System Internet Access Forum Standard (PIAFS) | 261d? | 1999-01-01 A | 1999-12-31 A | 100% | 1999-01-01 | 1999-12-31 | 261d? | start no earlier than 1999-01-01 | S1 | 2088h | 2088h | PIAFS | R99 |
| 2318 | 552.14.4.2 | Support_of_PIAFS_in_UMTS | 261d? | 1999-01-01 A | 1999-12-31 A | 100% | 1999-01-01 | 1999-12-31 | 261d? | start no earlier than 1999-01-01 | N3 | 2088h | 2088h | Support_of_PIAFS_in_UMTS | R99 |

Notes:
- 2295: Multicall allows several simultaneous CS calls with dedicated bearers of independent traffic and performance characteristics. R99 Multicall was defined as a supplementary service limited to one CS bearer to be used for speech at any time. / Text3: 22.030, 22.083, 22.087, 23.008, 23.009, 23.016, 23.018, 23.108, 23.135, 24.008, 24.080, 24.135, 29.002, 29.010
- 2296: - / Text3: 22.030, 22.083, 22.087
- 2297: Information exists in SP#5-8 reports & in SP-99416,SP-000095,SP 000155. OSA allows service development by operators and 3rd parties by making use of network functionality through open, standardised, secure, extensible and scalable interfaces. / Text3: 02.01, 22.105, 22.121,23.127
- 2298: Open Service Architecture became in later Releases Open Service Access. Produced by Parlay, ETSI SPAN (TISPAN), 3GPP SA1 (Stage 1), SA2 (Stage 2) and CN5 (Stage 3), resulting in a single set of standard OSA APIs for the whole development community. / Text3: 22.121, 23.127, 29.198, 29.998
- 2299: Super Charger reduces mobility management cost by reducing the volume of location update signalling. It changes subscriber data management associated with inter-VLR and SGSN location updates. It also applies to packet services (SGSN replaces VLR and … / Text3: 21.905, 23.007, 23.008, 23.012, 23.016, 23.018, 23.040, 23.060, 23.116, 23.912, 29.002
- 2300: Follow Me enables a mobile subscriber A to manipulate the Follow Me data of a party B in such a way that - under certain conditions - subsequent calls directed to party B will be forwarded to subscriber A. It is PLMN-specific and control based on USSD / Text3: 21.905, 22.004, 22.030, 22.082, 22.090, 22.094, 23.090, 24.090, 22.094, 23.011, 23.015, 23.082, 29.002
- 2301: Allows data stored in ME/USIM to be synchronized with the outside world. TS 27.103 defines protocols based upon IrMC level 4 and will evaluate new technologies (XML) for inclusion. From Rel-4 IrMC was replaced by SyncML in 27.103. / Text3: 27.103, 27.903
- 2302: -
- 2303: AT commands to control a 3G ME via an external Terminal Equipment (TE), fully compatible with GSM AT commands. R99 adds new AT commands e.g. to control Advanced Speech Call Items (ASCI) services. / Text3: 27.005, 27.007
- 2304: Conclusion: 3GPP should not produce any technical specification for terminal interfaces other than radio interface and USIM interface. SDOs could develop own optional physical connector specification based on market requirements / Text3: 27.901
- 2305: Multiplexing protocol allowing a number of simultaneous sessions between a MS and a terminal; used to send any data (voice, SMS, USSD, fax etc.). 27.010 describes the protocol, but not the commands or data transported with it. / Text3: 27.010
- 2306: -
- 2307: CS and real-time data services provided for interworking with PSTN/ISDN so that user is unaware of access network used (UMTS, GSM or handover between ANs). Transparent(constant delay) & non-transparent(zero error with flow control) services are supported / Text3: 22.002, 23.910, 27.001, 29.007
- 2308: CS and real-time data services provided for interworking with PSTN/ISDN so that user is unaware of access network used (UMTS, GSM or handover between ANs). Transparent(constant delay) & non-transparent(zero error with flow control) services are supported / Text3: 22.002, 23.910, 27.001, 29.007
- 2309: - / Text3: 29.007
- 2310: - / Text3: 04.21, 23.910, 27.001, 29.007
- 2311: - / Text3: 27.001, 27.002, 27.003, 29.007
- 2312: - / Text3: 23.910, 27.001, 29.007
- 2313: No CR or new TS/TR approved under this WI / Text3: 29.007
- 2314: FTM is a type of async non-transparent CS bearer service (22.002). Generic term for HDLC and HDLC-related transmission protocols. Converts async non-transp data stream towards mobile side & sync data stream using X.31 flag stuffing on fixed network side. / Text3: 22.002, 27.001, 27.007, 29.007
- 2315: Access to an Intranet or ISP by running DHCP between the TE and a server in the Intranet/ISP domain. / Text3: 29.061
- 2316: PIAFS is one type of CS bearer data service (22.002). It refers to async CS tx protocol over ISDN 64 kbit/s unrestricted digital line. Facilitates interworking between PHS-MS and UMTS-UE & UMTS-UE and existing PIAFS TA (Terminal Adapter). / Text3: 22.002, 27.001, 27.007, 29.007
- 2317: PIAFS was originally standardised by the PHS Internet Access Forum in Japan. More information can be found at: http://www.infopro.or.jp/piaf / Text3: 22.002
- 2318: - / Text3: 27.001, 27.007, 29.007

| ID | WBS | Task | Duration | Start | Finish | Complete | Baseline start | Baseline finish | Baseline duration | Constraint | Resources | Work | Actual work | Text1 | Text6 |
| --- | --- | --- | --- | --- | --- | --- | --- | --- | --- | --- | --- | --- | --- | --- | --- |
| 2319 | 552.15 | **Universal Integrated Circuit Card (UICC) and Universal Subscriber Identity Module (USIM)** | 261d? | 1999-01-01 A | 1999-12-31 A | 100% | 1999-01-01 | 1999-12-31 | 261d? |  | T3 | 27144h | 27144h | UICC, USIM | R99 |
| 2320 | 552.15.1 | UICC / Terminal interface; Physical and logical characteristics | 261d? | 1999-01-01 A | 1999-12-31 A | 100% | 1999-01-01 | 1999-12-31 | 261d? | start no earlier than 1999-01-01 | T3 | 2088h | 2088h | UICC | R99 |
| 2321 | 552.15.2 | UICC/(U)SIM enhancements and interworking | 261d? | 1999-01-01 A | 1999-12-31 A | 100% | 1999-01-01 | 1999-12-31 | 261d? | start no earlier than 1999-01-01 | T3 | 2088h | 2088h | UICC1 | R99 |
| 2322 | 552.15.3 | Characteristics of the USIM application | 261d? | 1999-01-01 A | 1999-12-31 A | 100% | 1999-01-01 | 1999-12-31 | 261d? | start no earlier than 1999-01-01 | T3 | 2088h | 2088h | USIM | R99 |
| 2323 | 552.15.4 | UICC Application Identifiers | 261d? | 1999-01-01 A | 1999-12-31 A | 100% | 1999-01-01 | 1999-12-31 | 261d? | start no earlier than 1999-01-01 | T3 | 2088h | 2088h | AID, Application_Identifiers | R99 |
| 2324 | 552.15.5 | SIM Application Toolkit | 261d? | 1999-01-01 A | 1999-12-31 A | 100% | 1999-01-01 | 1999-12-31 | 261d? | start no earlier than 1999-01-01 | S1,T3 | 2088h | 2088h | SAT | R99 |
| 2325 | 552.15.6 | USIM Application Toolkit | 261d? | 1999-01-01 A | 1999-12-31 A | 100% | 1999-01-01 | 1999-12-31 | 261d? | start no earlier than 1999-01-01 | T3 | 2088h | 2088h | USAT | R99 |
| 2326 | 552.15.7 | Bearer Independent Protocol for SAT applications to exchange data over the GSM network | 261d? | 1999-01-01 A | 1999-12-31 A | 100% | 1999-01-01 | 1999-12-31 | 261d? | start no earlier than 1999-01-01 | T3 | 2088h | 2088h | BIP | R99 |
| 2327 | 552.15.8 | Administrative commands and functions for IC cards | 261d? | 1999-01-01 A | 1999-12-31 A | 100% | 1999-01-01 | 1999-12-31 | 261d? | start no earlier than 1999-01-01 | T3 | 2088h | 2088h |  | R99 |
| 2328 | 552.15.9 | USIM and UICC requirements | 261d? | 1999-01-01 A | 1999-12-31 A | 100% | 1999-01-01 | 1999-12-31 | 261d? | start no earlier than 1999-01-01 | T3 | 2088h | 2088h |  | R99 |
| 2329 | 552.15.10 | SIM_API | 261d? | 1999-01-01 A | 1999-12-31 A | 100% | 1999-01-01 | 1999-12-31 | 261d? | start no earlier than 1999-01-01 | T3 | 2088h | 2088h | SIM_API | R99 |
| 2330 | 552.15.11 | SIM_toolkit_API | 261d? | 1999-01-01 A | 1999-12-31 A | 100% | 1999-01-01 | 1999-12-31 | 261d? | start no earlier than 1999-01-01 | SMG9,T3 | 2088h | 2088h | SIM_toolkit | R99 |
| 2331 | 552.15.12 | Deleted - 1.8 Volt SIM ME interface | 261d? | 1999-01-01 A | 1999-12-31 A | 100% | 1999-01-01 | 1999-12-31 | 261d? | start no earlier than 1999-01-01 | SMG9 | 2088h | 2088h | SMIME_1.8V | R99 |
| 2332 | 552.16 | **USIM/UICC Testing** | 261d? | 1999-01-01 A | 1999-12-31 A | 100% | 1999-01-01 | 1999-12-31 | 261d? |  | T3 | 10440h | 10440h |  | R99 |
| 2333 | 552.16.1 | Terminal tests for the UICC Interface | 261d? | 1999-01-01 A | 1999-12-31 A | 100% | 1999-01-01 | 1999-12-31 | 261d? | start no earlier than 1999-01-01 | T3 | 2088h | 2088h |  | R99 |
| 2334 | 552.16.2 | USIM application test specification | 261d? | 1999-01-01 A | 1999-12-31 A | 100% | 1999-01-01 | 1999-12-31 | 261d? | start no earlier than 1999-01-01 | T3 | 2088h | 2088h |  | R99 |
| 2335 | 552.16.3 | USIM conformance test specification | 261d? | 1999-01-01 A | 1999-12-31 A | 100% | 1999-01-01 | 1999-12-31 | 261d? | start no earlier than 1999-01-01 | T3 | 2088h | 2088h |  | R99 |
| 2336 | 552.16.4 | SIM toolkit test specification | 261d? | 1999-01-01 A | 1999-12-31 A | 100% | 1999-01-01 | 1999-12-31 | 261d? | start no earlier than 1999-01-01 | T3 | 2088h | 2088h |  | R99 |
| 2337 | 552.17 | **Security** | 261d? | 1999-01-01 A | 1999-12-31 A | 100% | 1999-01-01 | 1999-12-31 | 261d? |  | S3,N2,N4 | 8352h | 8352h | Security | R99 |
| 2338 | 552.17.1 | Fraud Information Gathering Service (for connection-orientated services) | 261d? | 1999-01-01 A | 1999-12-31 A | 100% | 1999-01-01 | 1999-12-31 | 261d? | start no earlier than 1999-01-01 | S3 | 2088h | 2088h | FIGS | R99 |
| 2339 | 552.17.2 | Immediate Service Termination / SECurity Immediate Service Termination | 261d? | 1999-01-01 A | 1999-12-31 A | 100% | 1999-01-01 | 1999-12-31 | 261d? | start no earlier than 1999-01-01 | S3,N2,N4 | 2088h | 2088h | IST, SECIST | R99 |
| 2340 | 552.17.3 | Core_Network_Security | 261d? | 1999-01-01 A | 1999-12-31 A | 100% | 1999-01-01 | 1999-12-31 | 261d? | start no earlier than 1999-01-01 | N4 | 2088h | 2088h | Core_Network_Security | R99 |
| 2341 | 553 | **GSM Features** | 261d? | 1999-01-01 A | 1999-12-31 A | 100% | 1999-01-01 | 1999-12-31 | 261d? |  | S1,S2,SMG,T2,N1,N2,N3,N4 | 50112h | 50112h |  | R99 |
| 2342 | 553.1 | **Dual Transfer Mode within GSM and GPRS** | 261d? | 1999-01-01 A | 1999-12-31 A | 100% | 1999-01-01 | 1999-12-31 | 261d? |  | SMG,N1 | 6264h | 6264h | DTM | R99 |
| 2343 | 553.1.1 | Class A Dual Transfer Mode | 261d? | 1999-01-01 A | 1999-12-31 A | 100% | 1999-01-01 | 1999-12-31 | 261d? | start no earlier than 1999-01-01 | SMG | 2088h | 2088h | Class_A_Dual_Transfer_Mode_(DTM) | R99 |
| 2344 | 553.1.2 | Dual Transfer Mode | 261d? | 1999-01-01 A | 1999-12-31 A | 100% | 1999-01-01 | 1999-12-31 | 261d? | start no earlier than 1999-01-01 | SMG,N1 | 2088h | 2088h | DTM | R99 |

Notes:
- 2319: For 3G, GSM 11.11 was divided into two parts: a platform comprised of basic physical, electrical and logical specification (31.101) and an application specification (31.102)
- 2320: Defines a generic Terminal/Integrated Circuit Card (ICC) interface. Is independent of 3G USIM application => platform for any IC card application. Ensures interoperability between ICC and terminal independently of manufacturer, card issuer or operator. / Text3: 31.101 (Since 10/2000, ETSI EP SCP is responsible for the generic Terminal/Integrated Circuit Card (ICC) interface TS 102 221)
- 2321: - / Text3: 31.102, 31.900
- 2322: Defines Universal Subscriber Identity Module (USIM) application for 3G telecom network operation & resides on UICC, an IC card specified in 31.101. UICC can be used as a multi-application card: several USIMs and/or other applications can co-exist / Text3: 31.102
- 2323: Defines and administers Application IDentifiers (AID) for UICC. AID is used to address an application in the card. Consists of Registered application provider ID (RID) & Proprietary application ID exception (PIX - according to ISO/IEC 7816-5). / Text3: 21.111, 31.110
- 2324: - / Text3: 11.14, 22.030, 22.100, 22.101
- 2325: Defines UICC - ME interface, and mandatory ME procedures for USAT. Based on GSM 11.14 (SIM Application Toolkit). Commands and procedures defined in USIM and 3G Terminal for using USAT. Service and security requirements defined in 22.100 and 22.101. / Text3: 31.111
- 2326: Defines at SIM-ME interface a basic protocol allowing SIM Toolkit applications to determine available bearers and to exchange data by selecting using the most appropriate bearer available (CS data, GPRS, SMS, Unstructured Supplementary Service Data (USSD) / Text3: 03.48, 11.10, 11.14
- 2327: Defines function and syntax of administrative commands for telecommunication IC Card used during installation, activation and de-activation of applications. Compliant to ISO/IEC 7816 series. Handed over to ETSI Project Smart Card Platform (SCP) in 2000. / Text3: ETSI TS 102 222
- 2328: High level requirements for 3GPP IC card and its interface to 3GPP terminal (USIM&UICC reqs). Service&security reqs in 322.01,22.00. USIM is a 3GPP application on an IC card. Inter-operates with 3GPP terminals and provides access to 3GPP services / Text3: 21.111
- 2329: - / Text3: 03.19
- 2330: - / Text3: 03.48, 11.11, 11.14
- 2331: No CR or new TS/TR approved under this WI / Text3: 11.18
- 2332: -
- 2333: Test spec for the interface between UICC and terminal (originally based GSM 11.10-1 clause 27). Ensures UICC - terminal interoperability independently of manufacturer, card issuer or operator. Tests for applications residing on UICC are in 31.121 / Text3: 31.120
- 2334: Application test spec originally based on GSM 11.17. Aspects related to UICC administrative management phase are not defined. Any internal technical realisation of either UICC or terminal is only specified where these are reflected over the interface. / Text3: 31.121
- 2335: Conformance Test specification for UICC defined in 31.101 with USIM defined in 31.102. / Text3: 31.122
- 2336: SIM Application Toolkit (SAT) has major impact on ME design and enhances SIM/ME interface. Contains tests for SIM/ME interface optional features (no network related signalling issues involved). Doesn't form basis for any type approval or regulatory tests. / Text3: 11.10-4
- 2337: - / Text3: 02.09, 03.20, 21.133, 22.022, 23.003, 23.007, 23.008, 23.012, 23.018, 24.007, 24.008, 24.010, 24.011, 29.002, 29.060, 33.102, 33.103, 33.105, 33.107, 35.201
- 2338: HPLMN can monitor its subscribers in VPLMN, which collects info on a defined set of monitored subscribers activities & sends it to HPLMN, which can perform service limitation control eg Operator Determined Barring (ODB) and IST to limit financial exposure / Text3: 22.031, 23.031
- 2339: HPLMN can terminate all activities of its subscriber in VPLMN, if decides (based on info via eg FIGS) that a roaming subscriber is behaving in fraudulent/suspicious way. HPLMN can terminate all subscriber activities including calls in progress. / Text3: 03.35, 22.032, 23.008, 23.016, 23.035, 29.002
- 2340: - / Text3: 29.002
- 2341: -
- 2342: WID on BSS co-ordination of Radio Resource allocation for class A GPRS services - GSM Radio Access (R99) / Text3: 03.55, 03.64, 04.18, 04.60, 05.01, 05.02, 05.08, 08.08, 23.060, 24.007, 24.008
- 2343: - / Text3: 05.10
- 2344: - / Text3: 03.55, 03.64, 04.18, 05.01, 05.02, 05.08, 24.008

| ID | WBS | Task | Duration | Start | Finish | Complete | Baseline start | Baseline finish | Baseline duration | Constraint | Resources | Work | Actual work | Text1 | Text6 |
| --- | --- | --- | --- | --- | --- | --- | --- | --- | --- | --- | --- | --- | --- | --- | --- |
| 2345 | 553.2 | **General Packet Radio Service enahancements** | 261d? | 1999-01-01 A | 1999-12-31 A | 100% | 1999-01-01 | 1999-12-31 | 261d? |  | S1,S2,SMG1,SMG2,SMG7,N1,N2,N3,N4,T2 | 8352h | 8352h | GPRS enhancements | R99 |
| 2346 | 553.2.1 | General Packet Radio Service | 261d? | 1999-01-01 A | 1999-12-31 A | 100% | 1999-01-01 | 1999-12-31 | 261d? | start no earlier than 1999-01-01 | S1,S2,SMG1,SMG2,SMG7,N1,N2,N3,N4,T2 | 2088h | 2088h | GPRS | R99 |
| 2347 | 553.2.2 | GPRS2 | 261d? | 1999-01-01 A | 1999-12-31 A | 100% | 1999-01-01 | 1999-12-31 | 261d? | start no earlier than 1999-01-01 | SMG1,N2 | 2088h | 2088h | GPRS2 | R99 |
| 2348 | 553.2.3 | GPRS Tunnelling Protocol enhancement | 261d? | 1999-01-01 A | 1999-12-31 A | 100% | 1999-01-01 | 1999-12-31 | 261d? | start no earlier than 1999-01-01 | N4,N2 | 2088h | 2088h | GTP_enhancement | R99 |
| 2349 | 553.3 | **Enhanced Data rates for GSM Evolution - Phase 1** | 261d? | 1999-01-01 A | 1999-12-31 A | 100% | 1999-01-01 | 1999-12-31 | 261d? |  | SMG2,SMG1,SMG3,SMG4,SMG7,SMG9,SMG10,N1,N3,T2 | 25056h | 25056h | EDGE - Phase 1 | R99 |
| 2350 | 553.3.1 | Enhanced Data rates for GSM Evolution | 261d? | 1999-01-01 A | 1999-12-31 A | 100% | 1999-01-01 | 1999-12-31 | 261d? | start no earlier than 1999-01-01 | SMG2,SMG1,SMG3,SMG4,SMG7,SMG9,SMG10,N1,N3,T2 | 2088h | 2088h | EDGE | R99 |
| 2351 | 553.3.2 | EDGE-Layer1 | 261d? | 1999-01-01 A | 1999-12-31 A | 100% | 1999-01-01 | 1999-12-31 | 261d? | start no earlier than 1999-01-01 | SMG2 | 2088h | 2088h | EDGE-Layer1 | R99 |
| 2352 | 553.3.3 | High Speed Circuit Switched Data | 261d? | 1999-01-01 A | 1999-12-31 A | 100% | 1999-01-01 | 1999-12-31 | 261d? | start no earlier than 1999-01-01 | SMG1,SMG2,SMG7 | 2088h | 2088h | HSCSD | R99 |
| 2353 | 553.3.4 | Enhanced Circuit Switched Data - Phase 1 | 261d? | 1999-01-01 A | 1999-12-31 A | 100% | 1999-01-01 | 1999-12-31 | 261d? | start no earlier than 1999-01-01 | S1,SMG | 2088h | 2088h | ECSD | R99 |
| 2354 | 553.3.5 | EDGE-Enhanced Circuit Switched Data | 261d? | 1999-01-01 A | 1999-12-31 A | 100% | 1999-01-01 | 1999-12-31 | 261d? | start no earlier than 1999-01-01 | SMG2 | 2088h | 2088h | EDGE-ECSD | R99 |
| 2355 | 553.3.6 | Enhanced GPRS - Phase 1 | 261d? | 1999-01-01 A | 1999-12-31 A | 100% | 1999-01-01 | 1999-12-31 | 261d? | start no earlier than 1999-01-01 | SMG,N1 | 2088h | 2088h | EGPRS | R99 |
| 2356 | 553.3.7 | EDGE-EGPRS | 261d? | 1999-01-01 A | 1999-12-31 A | 100% | 1999-01-01 | 1999-12-31 | 261d? | start no earlier than 1999-01-01 | SMG2 | 2088h | 2088h | EDGE-EGPRS | R99 |
| 2357 | 553.3.8 | Packet Flow Context (PFC) | 261d? | 1999-01-01 A | 1999-12-31 A | 100% | 1999-01-01 | 1999-12-31 | 261d? | start no earlier than 1999-01-01 | SMG2 | 2088h | 2088h | PFC | R99 |
| 2358 | 553.3.9 | Support for EGPRS in ANSI-136 networks and EDGE COMPACT | 261d? | 1999-01-01 A | 1999-12-31 A | 100% | 1999-01-01 | 1999-12-31 | 261d? | start no earlier than 1999-01-01 | SMG | 2088h | 2088h | EDGE-Compact | R99 |
| 2359 | 553.3.10 | EGPRS COMPACT | 261d? | 1999-01-01 A | 1999-12-31 A | 100% | 1999-01-01 | 1999-12-31 | 261d? | start no earlier than 1999-01-01 | SMG | 2088h | 2088h | EGPRS-Compact | R99 |
| 2360 | 553.3.11 | COMPACT | 261d? | 1999-01-01 A | 1999-12-31 A | 100% | 1999-01-01 | 1999-12-31 | 261d? | start no earlier than 1999-01-01 | SMG,N1 | 2088h | 2088h | COMPACT | R99 |
| 2361 | 553.4 | GSM_400 | 261d? | 1999-01-01 A | 1999-12-31 A | 100% | 1999-01-01 | 1999-12-31 | 261d? | start no earlier than 1999-01-01 | SMG2,SMG7,T2 | 2088h | 2088h | GSM_400 | R99 |
| 2362 | 553.5 | GSM_450 | 261d? | 1999-01-01 A | 1999-12-31 A | 100% | 1999-01-01 | 1999-12-31 | 261d? | start no earlier than 1999-01-01 | SMG2 | 2088h | 2088h | GSM_450 | R99 |
| 2363 | 553.6 | GSM_700 | 261d? | 1999-01-01 A | 1999-12-31 A | 100% | 1999-01-01 | 1999-12-31 | 261d? | start no earlier than 1999-01-01 | SMG2 | 2088h | 2088h | GSM_700 | R99 |
| 2364 | 553.7 | Deleted - GERAN | 261d? | 1999-01-01 A | 1999-12-31 A | 100% | 1999-01-01 | 1999-12-31 | 261d? | start no earlier than 1999-01-01 | SMG2,S2 | 2088h | 2088h | GERAN | R99 |
| 2365 | 554 | **GSM Features transposed to UMTS** | 261d? | 1999-01-01 A | 1999-12-31 A | 100% | 1999-01-01 | 1999-12-31 | 261d? |  | S1,S3,T2,N2,N4 | 16704h | 16704h |  | R99 |
| 2366 | 554.1 | Cell Broadcast Service | 261d? | 1999-01-01 A | 1999-12-31 A | 100% | 1999-01-01 | 1999-12-31 | 261d? | start no earlier than 1999-01-01 | T2 | 2088h | 2088h | CBS | R99 |
| 2367 | 554.2 | **GSM mobile number portability euro MNP / North American MNP** | 261d? | 1999-01-01 A | 1999-12-31 A | 100% | 1999-01-01 | 1999-12-31 | 261d? |  | S1,N2,N4 | 4176h | 4176h | MNP | R99 |
| 2368 | 554.2.1 | Mobile Number Portability | 261d? | 1999-01-01 A | 1999-12-31 A | 100% | 1999-01-01 | 1999-12-31 | 261d? | start no earlier than 1999-01-01 | N2,N4 | 2088h | 2088h | MNP | R99 |
| 2369 | 554.3 | Automatic establishment of roaming relations | 261d? | 1999-01-01 A | 1999-12-31 A | 100% | 1999-01-01 | 1999-12-31 | 261d? | start no earlier than 1999-01-01 | S1 | 2088h | 2088h |  | R99 |
| 2370 | 554.4 | Advanced addressing | 261d? | 1999-01-01 A | 1999-12-31 A | 100% | 1999-01-01 | 1999-12-31 | 261d? | start no earlier than 1999-01-01 | S1 | 2088h | 2088h |  | R99 |
| 2371 | 554.5 | UMTS numbering, addressing and identities | 261d? | 1999-01-01 A | 1999-12-31 A | 100% | 1999-01-01 | 1999-12-31 | 261d? | start no earlier than 1999-01-01 | S1 | 2088h | 2088h |  | R99 |
| 2372 | 554.6 | Lawful Interception | 261d? | 1999-01-01 A | 1999-12-31 A | 100% | 1999-01-01 | 1999-12-31 | 261d? | start no earlier than 1999-01-01 | S3 | 2088h | 2088h | LI | R99 |

Notes:
- 2345: GPRS was introduced in Release 97. Release 99 brings a number of essential corrections e.g. on Downlink Power Control, Timing Advance procedure, Cell reselection delay time, PBCCH scheduling, PTCCH mapping, etc. / Text3: 05.02, 05.05, 05.08, 05.10, 05.50, 11.21, 23.064, 24.008, 24.060
- 2346: - / Text3: 02.60, 03.22, 03.64, 04.18, 04.60, 04.64, 04.65, 05.01, 05.02, 05.05, 05.08, 05.10, 08.08, 08.18, 11.10-1, 11.21, 22.041, 22.060, 23.003, 23.007, 23.060, 23.107, 23.122, 24.007, 24.008, 27.007, 27.060, 29.002, 29.016, 29.018, 29.060, 29.061
- 2347: Introduction of EGPRS (S1) + Introduction of Reserved Service Labels in the APN (N2) / Text3: 02.60, 23.003
- 2348: - / Text3: 23.003, 23.008, 29.060
- 2349: EDGE is independent of the frequency bands, so it can be deployed e.g. in 900 and 1900 MHz bands. The new physical layer based on 8-PSK modulation is introduced and EGPRS and ECSD facilitate the new modulation in single and multi slot constellation. / Text3: 10.59, 02.34, 02.60, 03.30, 05.10, 05.50, 11.26
- 2350: - / Text3: 02.34, 03.10, 03.20, 03.64, 04.03, 04.04, 04.06, 04.08, 04.18, 04.21, 04.22, 04.60, 04.64, 05.01, 05.02, 05.03, 05.04, 05.05, 05.08, 05.10, 05.50, 07.01, 07.02, 07.03, 08.08, 08.20, 08.58, 08.60, 09.07, 09.18, 11.10-1, 11.11, 11.21, 11.26, 23.034, 24.008,
- 2351: - / Text3: 05.05, 05.10, 05.50
- 2352: No additional features for R99. / Text3: 02.34, 04.18, 11.10-1
- 2353: ECSD supports both transparent and non-transparent services, up to 64 kbit/s and 57.6 kbit/s respectively. See Tdoc SMG2 670/99 ECSD Concept Evaluation for more info / Text3: 05.02, 08.58, 22.034
- 2354: - / Text3: 05.03
- 2355: - / Text3: 02.07, 03.64, 04.14, 04.18, 04.60, 05.05, 05.08, 24.008
- 2356: - / Text3: 05.03, 05.05, 05.08
- 2357: - / Text3: 04.18
- 2358: Support for EGPRS in ANSI-136 networks and EDGE Compact (for ANSI-136 networks only). COMPACT = Deployment of services in spectrum below 1 MHz / Text3: 03.22, 03.30, 03.64, 05.01, 05.02, 05.03, 05.05, 05.08, 05.10
- 2359: COMPACT = Deployment of services in spectrum below 1 MHz / Text3: 04.18, 05.02
- 2360: COMPACT = Deployment of services in spectrum below 1 MHz / Text3: 03.22, 04.18, 04.60, 05.08, 23.122, 24.008
- 2361: - / Text3: 02.17, 03.22, 03.30, 04.04, 04.18, 04.60, 05.01, 05.02, 05.05, 05.08, 05.10, 05.50, 08.18, 08.58, 11.21, 24.008, 27.007 / Text8: GSM in the 400 MHz bands allows to deploy GSM within frequency bands in the range 450 to 500 MHz, previously used for analogue cellular systems. See Tdoc SMG2 190/99 and 595/99 for further info.
- 2362: - / Text3: 03.22, 03.30, 05.01, 05.05, 05.08
- 2363: - / Text3: 05.05
- 2364: No CR or new TS/TR approved under this WI / Text3: G2: 04.18 CR#A248 , 04.60 CR#B090
- 2365: -
- 2366: Moved to CT1 at TSG-T closure. Applicability of the Cell Broadcast Service (as defined for GSM network) to 3G networks / Text3: 23.041
- 2367: R98 MNP: mobile subscriber ability to change PLMN operator within the same country whilst retaining its original MS ISDN number (MSISDN). IMSI is changed, only MSISDN is kept. R99 adds requirements for North American Service Provider Number Portability. / Text3: 22.066
- 2368: - / Text3: 23.018, 23.066, 29.002
- 2369: framework for commercial and technical interworking between UMTS Home Environments and Serving Networks who have no direct prior commercial agreements with each other. / Text3: 22.101, 22.971
- 2370: - / Text3: 22.101, 22.75U, 22.975
- 2371: Also new requirements for Single and Multiple Numbering scheme was added (CR#20 and 21). Deleted the term International Mobile User Identifier (IMUI) and changed IMSI (International Mobile Station Identifier=>International Mobile Subscriber Identity. / Text3: 22.101
- 2372: Defines an interception system in UMTS that supports a number of regional interception regulations. Regional interception requirements shall be met in using specific (regional) mediation functions allowing only required information to be transported. / Text3: 33.106, 33.107

| ID | WBS | Task | Duration | Start | Finish | Complete | Baseline start | Baseline finish | Baseline duration | Constraint | Resources | Work | Actual work | Text1 | Text6 |
| --- | --- | --- | --- | --- | --- | --- | --- | --- | --- | --- | --- | --- | --- | --- | --- |
| 2373 | 555 | **Charging** | 261d? | 1999-01-01 A | 1999-12-31 A | 100% | 1999-01-01 | 1999-12-31 | 261d? |  | S1,S5 | 6264h | 6264h | CH | R99 |
| 2374 | 555.1 | Charging | 261d? | 1999-01-01 A | 1999-12-31 A | 100% | 1999-01-01 | 1999-12-31 | 261d? | start no earlier than 1999-01-01 | S1 | 2088h | 2088h | Charging | R99 |
| 2375 | 555.2 | OAM Charging Management | 261d? | 1999-01-01 A | 1999-12-31 A | 100% | 1999-01-01 | 1999-12-31 | 261d? | start no earlier than 1999-01-01 | S5 | 2088h | 2088h | OAMCH, CH | R99 |
| 2376 | 556 | **Operations, Administration, Maintenance and Provisioning (OAM&P)** | 261d? | 1999-01-01 A | 1999-12-31 A | 100% | 1999-01-01 | 1999-12-31 | 261d? |  | S5 | 12528h | 12528h | OAM | R99 |
| 2377 | 556.1 | OAM Principles and High-level Requirements | 261d? | 1999-01-01 A | 1999-12-31 A | 100% | 1999-01-01 | 1999-12-31 | 261d? | start no earlier than 1999-01-01 | S5 | 2088h | 2088h | PR, Princs_&_Reqs_(PR) | R99 |
| 2378 | 556.2 | OAM Architecture | 261d? | 1999-01-01 A | 1999-12-31 A | 100% | 1999-01-01 | 1999-12-31 | 261d? | start no earlier than 1999-01-01 | S5 | 2088h | 2088h | OAMAR, AR, Telecom_Management_Arch_(AR) | R99 |
| 2379 | 556.3 | OAM Configuration Management | 261d? | 1999-01-01 A | 1999-12-31 A | 100% | 1999-01-01 | 1999-12-31 | 261d? | start no earlier than 1999-01-01 | S5 | 2088h | 2088h | OAMCM, CM | R99 |
| 2380 | 556.4 | OAM Fault Management | 261d? | 1999-01-01 A | 1999-12-31 A | 100% | 1999-01-01 | 1999-12-31 | 261d? | start no earlier than 1999-01-01 | S5 | 2088h | 2088h | OAMFM | R99 |
| 2381 | 556.5 | OAM Performance Management | 261d? | 1999-01-01 A | 1999-12-31 A | 100% | 1999-01-01 | 1999-12-31 | 261d? | start no earlier than 1999-01-01 | S5 | 2088h | 2088h | OAMPM, PM | R99 |
| 2382 | 557 | Vocabulary | 261d? | 1999-01-01 A | 1999-12-31 A | 100% | 1999-01-01 | 1999-12-31 | 261d? | start no earlier than 1999-01-01 | S1 | 2088h | 2088h | Vocabulary | R99 |
| 2383 | 558 | Emergency | 261d? | 1999-01-01 A | 1999-12-31 A | 100% | 1999-01-01 | 1999-12-31 | 261d? | start no earlier than 1999-01-01 | S1 | 2088h | 2088h | Emergency | R99 |
| 2384 | 559 | GSM General Bearer Services (GBS) and interworking scenarios support in UMTS | 261d? | 1999-01-01 A | 1999-12-31 A | 100% | 1999-01-01 | 1999-12-31 | 261d? | start no earlier than 1999-01-01 | S1 | 2088h | 2088h | GSM_to_UMTS_Evol | R99 |
| 2385 | 560 | GPRS_Mobile_IP_interworking | 261d? | 1999-01-01 A | 1999-12-31 A | 100% | 1999-01-01 | 1999-12-31 | 261d? | start no earlier than 1999-01-01 | N3 | 2088h | 2088h | GPRS_Mobile_IP_interworking | R99 |
| 2386 | 561 | GSM/UMTS interworking | 261d? | 1999-01-01 A | 1999-12-31 A | 100% | 1999-01-01 | 1999-12-31 | 261d? | start no earlier than 1999-01-01 | N1,N2,N4,R3,S1,SMG | 2088h | 2088h | 2G3Ginterworking | R99 |
| 2387 | 562 | Handover | 261d? | 1999-01-01 A | 1999-12-31 A | 100% | 1999-01-01 | 1999-12-31 | 261d? | start no earlier than 1999-01-01 | S1,SMG2,N1,N2,N4 | 2088h | 2088h | Handover | R99 |
| 2388 | 563 | 2G3Ghandover | 261d? | 1999-01-01 A | 1999-12-31 A | 100% | 1999-01-01 | 1999-12-31 | 261d? | start no earlier than 1999-01-01 | SMG2 | 2088h | 2088h | 2G3Ghandover | R99 |
| 2389 | 564 | Service Provider Name Indication | 261d? | 1999-01-01 A | 1999-12-31 A | 100% | 1999-01-01 | 1999-12-31 | 261d? | start no earlier than 1999-01-01 | S1 | 2088h | 2088h | SPANME | R99 |
| 2390 | 565 | Data & Data_CleanUp | 261d? | 1999-01-01 A | 1999-12-31 A | 100% | 1999-01-01 | 1999-12-31 | 261d? | start no earlier than 1999-01-01 | SMG1 | 2088h | 2088h | Data, Data_CleanUp | R99 |
| 2391 | 566 | Unstructured Supplementary Service Data | 261d? | 1999-01-01 A | 1999-12-31 A | 100% | 1999-01-01 | 1999-12-31 | 261d? | start no earlier than 1999-01-01 | SMG1,N4 | 2088h | 2088h | USSD | R99 |
| 2392 | 567 | Man-Machine Interface (MMI) of the User Equipment (UE) | 261d? | 1999-01-01 A | 1999-12-31 A | 100% | 1999-01-01 | 1999-12-31 | 261d? | start no earlier than 1999-01-01 | S1 | 2088h | 2088h | MMI | R99 |
| 2393 | 568 | Network Identity and Timezone (NITZ) | 261d? | 1999-01-01 A | 1999-12-31 A | 100% | 1999-01-01 | 1999-12-31 | 261d? | start no earlier than 1999-01-01 | SMG1,SMG3 | 2088h | 2088h | NITZ | R99 |
| 2394 | 569 | Operator Determined Barring for Packet Oriented Services | 261d? | 1999-01-01 A | 1999-12-31 A | 100% | 1999-01-01 | 1999-12-31 | 261d? | start no earlier than 1999-01-01 | S1 | 2088h | 2088h | ODB_Enh. | R99 |
| 2395 | 570 | Packet Flow Management | 261d? | 1999-01-01 A | 1999-12-31 A | 100% | 1999-01-01 | 1999-12-31 | 261d? | start no earlier than 1999-01-01 | SMG2 | 2088h | 2088h | Packet_Flow_Management | R99 |
| 2396 | 571 | GPRS_Point-To-Multipoint Group call | 261d? | 1999-01-01 A | 1999-12-31 A | 100% | 1999-01-01 | 1999-12-31 | 261d? | start no earlier than 1999-01-01 | SMG1 | 2088h | 2088h | GPRS_PTMG | R99 |

Notes:
- 2373: -
- 2374: WID SP-99271 Charging and accounting / Text3: 22.115, 23.121
- 2375: WID SP-99581 SA5 Year 2000 Work plan / Text3: 32.005, 32.015
- 2376: WID SP-99581 SA5 Year 2000 Work plan
- 2377: WID SP-99581 SA5 Year 2000 Work plan / Text3: 32.101
- 2378: WID SP-99581 SA5 Year 2000 Work plan / Text3: 32.101, 32.102
- 2379: WID SP-99273 Configuration management / Text3: 32.106, 32.106-1, 32.106-2, 32.106-3, 32.106-4, 32.106-5, 32.106-6, 32.106-7, 32.106-8
- 2380: WID SP-99272 Fault management / Text3: 32.111, 32.111-1, 32.111-2, 32.111-3, 32.111-4
- 2381: WID SP-99274 Performance management / Text3: 12.04, 32.104
- 2382: - / Text3: 21.905
- 2383: - / Text3: 22.101
- 2384: UMTS shall support GSM General Bearer Services (GBS) and interworking scenarios as specified in 02.02 / Text3: 22.105
- 2385: - / Text3: 29.061
- 2386: - / Text3: 03.22, 04.18, 04.60, 05.02, 05.08, 05.10, 08.08, 08.18, 08.58, 09.08, 22.011, 23.003, 23.009, 23.014, 23.034, 23.122, 24.007, 24.008, 24.011, 24.080, 29.108
- 2387: - / Text3: 04.18, 08.08, 08.58, 22.129, 23.009, 29.002, 29.010
- 2388: - / Text3: 04.18, 04.60, 05.02, 05.08, 05.10, 08.08, 29.010
- 2389: Service Provider Name Indication included in R98 (02.07) was not carried into R99 (22.101), but is in the SIM/USIM specification for R99 / Text3: 22.101
- 2390: - / Text3: 02.01, 02.02, 02.04, 02.34
- 2391: No additional features for R99. / Text3: 02.04, 02.90, 23.090, 29.002
- 2392: Data services streamlining + Support for Anonymous Call Rejection / Text3: 22.030
- 2393: - / Text3: 02.42, 04.08
- 2394: Remove ODB for Packet Oriented Services from R99 / Text3: 22.041
- 2395: - / Text3: 08.18
- 2396: - / Text3: 02.60

| ID | WBS | Task | Duration | Start | Finish | Complete | Baseline start | Baseline finish | Baseline duration | Constraint | Resources | Work | Actual work | Text6 | Text8 |
| --- | --- | --- | --- | --- | --- | --- | --- | --- | --- | --- | --- | --- | --- | --- | --- |
| 2397 | 572 | **Call Forwarding** | 261d? | 1999-01-01 A | 1999-12-31 A | 100% | 1999-01-01 | 1999-12-31 | 261d? |  | SMG1,N2,N4 | 8352h | 8352h | R99 |  |
| 2398 | 572.1 | Call Forwarding enhancements | 261d? | 1999-01-01 A | 1999-12-31 A | 100% | 1999-01-01 | 1999-12-31 | 261d? | start no earlier than 1999-01-01 | N4,N2 | 2088h | 2088h | R99 |  |
| 2399 | 572.2 | Call_Forwarding | 261d? | 1999-01-01 A | 1999-12-31 A | 100% | 1999-01-01 | 1999-12-31 | 261d? | start no earlier than 1999-01-01 | SMG1,N2 | 2088h | 2088h | R99 |  |
| 2400 | 572.3 | Call_Forwarding_Enhancements | 261d? | 1999-01-01 A | 1999-12-31 A | 100% | 1999-01-01 | 1999-12-31 | 261d? | start no earlier than 1999-01-01 | N4 | 2088h | 2088h | R99 |  |
| 2401 | 573 | **Quality of Service** | 261d? | 1999-01-01 A | 1999-12-31 A | 100% | 1999-01-01 | 1999-12-31 | 261d? |  | S2,T2,N1,N2,N4 | 10440h | 10440h | R99 |  |
| 2402 | 573.1 | End-to-end UMTS Quality of Service management | 261d? | 1999-01-01 A | 1999-12-31 A | 100% | 1999-01-01 | 1999-12-31 | 261d? | start no earlier than 1999-01-01 | S2,T2,N1,N2,N4 | 2088h | 2088h | R99 |  |
| 2403 | 573.2 | End-to-end QoS for PS Domain including IMS | 261d? | 1999-01-01 A | 1999-12-31 A | 100% | 1999-01-01 | 1999-12-31 | 261d? | start no earlier than 1999-01-01 | S2 | 2088h | 2088h | R99 |  |
| 2404 | 573.3 | GPRS-enhanced_QoS | 261d? | 1999-01-01 A | 1999-12-31 A | 100% | 1999-01-01 | 1999-12-31 | 261d? | start no earlier than 1999-01-01 | T2 | 2088h | 2088h | R99 |  |
| 2405 | 573.4 | QoS_enhancements | 261d? | 1999-01-01 A | 1999-12-31 A | 100% | 1999-01-01 | 1999-12-31 | 261d? | start no earlier than 1999-01-01 | N2,N1,N4 | 2088h | 2088h | R99 |  |
| 2406 | 574 | Support of Localised Service Area | 261d? | 1999-01-01 A | 1999-12-31 A | 100% | 1999-01-01 | 1999-12-31 | 261d? | start no earlier than 1999-01-01 | SMG2,SMG3,SMG7,N2 | 2088h | 2088h | R99 |  |
| 2407 | 575 | Transcoder_location | 261d? | 1999-01-01 A | 1999-12-31 A | 100% | 1999-01-01 | 1999-12-31 | 261d? | start no earlier than 1999-01-01 | S2 | 2088h | 2088h | R99 |  |
| 2408 | 576 | Antenna_test_methods | 261d? | 1999-01-01 A | 1999-12-31 A | 100% | 1999-01-01 | 1999-12-31 | 261d? | start no earlier than 1999-01-01 | SMG2 | 2088h | 2088h | R99 |  |
| 2409 | 577 | WBAMR / high quality speech in UMTS Phase 1 but not in R99 | 261d? | 1999-01-01 A | 1999-12-31 A | 100% | 1999-01-01 | 1999-12-31 | 261d? | start no earlier than 1999-01-01 | S1 | 2088h | 2088h | R99 |  |
| 2410 | 578 | **Codec** | 261d? | 1999-01-01 A | 1999-12-31 A | 100% | 1999-01-01 | 1999-12-31 | 261d? |  | S4 | 14616h | 14616h | R99 | Paolo |
| 2411 | 578.1 | Codec(s)_for_Multimedia_Telephony_Service | 261d? | 1999-01-01 A | 1999-12-31 A | 100% | 1999-01-01 | 1999-12-31 | 261d? | start no earlier than 1999-01-01 | S4 | 2088h | 2088h | R99 | Paolo |
| 2412 | 578.2 | QoS for Speech and Multimedia Codec | 261d? | 1999-01-01 A | 1999-12-31 A | 100% | 1999-01-01 | 1999-12-31 | 261d? | start no earlier than 1999-01-01 | S4 | 2088h | 2088h | R99 | Paolo |
| 2413 | 578.3 | Tandem Free Operation - Adaptive Multi-Rate codec types | 261d? | 1999-01-01 A | 1999-12-31 A | 100% | 1999-01-01 | 1999-12-31 | 261d? | start no earlier than 1999-01-01 | S4 | 2088h | 2088h | R99 | Paolo |
| 2414 | 578.4 | Noise Suppression for AMR | 261d? | 1999-01-01 A | 1999-12-31 A | 100% | 1999-01-01 | 1999-12-31 | 261d? | start no earlier than 1999-01-01 | S4 | 2088h | 2088h | R99 | Paolo |
| 2415 | 578.5 | Out-of-Band Transcoder | 261d? | 1999-01-01 A | 1999-12-31 A | 100% | 1999-01-01 | 1999-12-31 | 261d? | start no earlier than 1999-01-01 | N1 | 2088h | 2088h | R99 |  |
| 2416 | 578.6 | Out-of-Band Transcoder Control | 261d? | 1999-01-01 A | 1999-12-31 A | 100% | 1999-01-01 | 1999-12-31 | 261d? | start no earlier than 1999-01-01 | N1 | 2088h | 2088h | R99 |  |
| 2417 | 579 | Advanced Speech Call Items enhancements | 261d? | 1999-01-01 A | 1999-12-31 A | 100% | 1999-01-01 | 1999-12-31 | 261d? | start no earlier than 1999-01-01 | SMG1,SMG2,SMG3,SMG7,SMG9,N1,C1,N4,S1,T2 | 2088h | 2088h | R99 |  |
| 2418 | 580 | Call Control improvements | 261d? | 1999-01-01 A | 1999-12-31 A | 100% | 1999-01-01 | 1999-12-31 | 261d? | start no earlier than 1999-01-01 | N1 | 2088h | 2088h | R99 |  |
| 2419 | 581 | Multimedia | 261d? | 1999-01-01 A | 1999-12-31 A | 100% | 1999-01-01 | 1999-12-31 | 261d? | start no earlier than 1999-01-01 | N1,N3 | 2088h | 2088h | R99 |  |
| 2420 | 582 | Sub-System Number allocation for RANAP, RNSAP | 261d? | 1999-01-01 A | 1999-12-31 A | 100% | 1999-01-01 | 1999-12-31 | 261d? | start no earlier than 1999-01-01 | N2 | 2088h | 2088h | R99 |  |
| 2421 | 583 | Intranet / ISP access with DHCP end-to-end | 261d? | 1999-01-01 A | 1999-12-31 A | 100% | 1999-01-01 | 1999-12-31 | 261d? | start no earlier than 1999-01-01 | N3 | 2088h | 2088h | R99 |  |
| 2422 | 584 | Point_to_Multipoint_Services | 261d? | 1999-01-01 A | 1999-12-31 A | 100% | 1999-01-01 | 1999-12-31 | 261d? | start no earlier than 1999-01-01 | N3 | 2088h | 2088h | R99 |  |
| 2423 | 585 | Facsimile | 261d? | 1999-01-01 A | 1999-12-31 A | 100% | 1999-01-01 | 1999-12-31 | 261d? | start no earlier than 1999-01-01 | S1 | 2088h | 2088h | R99 |  |
| 2424 | 586 | Realtime_NT_FAX_in_UMTS | 261d? | 1999-01-01 A | 1999-12-31 A | 100% | 1999-01-01 | 1999-12-31 | 261d? | start no earlier than 1999-01-01 | N3 | 2088h | 2088h | R99 |  |
| 2425 | 587 | Gateway Location Register (GLR) - Mobile Application Part (MAP) specification | 261d? | 1999-01-01 A | 1999-12-31 A | 100% | 1999-01-01 | 1999-12-31 | 261d? | start no earlier than 1999-01-01 | N4 | 2088h | 2088h | R99 |  |
| 2426 | 588 | Multiple Subscriber Profile phase 2 | 261d? | 1999-01-01 A | 1999-12-31 A | 100% | 1999-01-01 | 1999-12-31 | 261d? | start no earlier than 1999-01-01 | S1,N4 | 2088h | 2088h | R99 |  |
| 2427 | 589 | Prepaging | 261d? | 1999-01-01 A | 1999-12-31 A | 100% | 1999-01-01 | 1999-12-31 | 261d? | start no earlier than 1999-01-01 | N2,N4 | 2088h | 2088h | R99 |  |
| 2428 | 590 | Downlink Advanced Receiver Performance | 261d? | 1999-01-01 A | 1999-12-31 A | 100% | 1999-01-01 | 1999-12-31 | 261d? | start no earlier than 1999-01-01 | SMG | 2088h | 2088h | R99 |  |
| 2429 | 591 | Harmonized Standard | 261d? | 1999-01-01 A | 1999-12-31 A | 100% | 1999-01-01 | 1999-12-31 | 261d? | start no earlier than 1999-01-01 | SMG2 | 2088h | 2088h | R99 |  |
| 2430 | 592 | Streamlining of specifications | 261d? | 1999-01-01 A | 1999-12-31 A | 100% | 1999-01-01 | 1999-12-31 | 261d? | start no earlier than 1999-01-01 | N3 | 2088h | 2088h | R99 |  |
| 2431 | 593 | R99_Service_Clean_up | 261d? | 1999-01-01 A | 1999-12-31 A | 100% | 1999-01-01 | 1999-12-31 | 261d? | start no earlier than 1999-01-01 | N3 | 2088h | 2088h | R99 |  |

Notes:
- 2397: -
- 2398: No additional features for R99. / Text1: CF_enhancements / Text3: 23.078, 23.079, 23.082, 29.002, 29.078
- 2399: - / Text1: Call_Forwarding / Text3: 02.82, 29.002
- 2400: - / Text1: Call_Forwarding_Enhancements / Text3: 23.082
- 2401: WID SMG 98-0781 End To End UMTS QoS Management
- 2402: WID SMG 98-0781 End To End UMTS QoS Management / Text1: QoS / Text3: 23.107, 23.907, 24.008
- 2403: - / Text1: E2EQoS / Text3: 23.060, 23.170
- 2404: AT-commands for Enhanced QoS Support management / Text1: GPRS-enhanced_QoS / Text3: 27.007
- 2405: - / Text1: QoS_enhancements / Text3: 23.008, 23.016, 24.008, 29.002, 29.060
- 2406: Mechanism which can be used as a platform for providing special tariffs and/or special set of service features for certain subscribers within a regionally restricted area or areas. No additional features for R99. / Text1: SoLSA / Text3: 04.08, 04.18, 08.08, 11.10-1, 29.002
- 2407: UE location identification: background information and associated primitives 2. Transcoder location at the core network and source depending coding belonging to the non-access stratum. / Text1: Transcoder_location / Text3: 23.110
- 2408: - / Text1: Antenna_test_methods / Text3: 03.30
- 2409: Add requirement for high quality speech in UMTS Phase 1 but not in R99 / Text1: WBAMR / Text3: 22.105
- 2410: -
- 2411: - / Text1: Multimedia_Codec, CSM, WI2MMC, Codec(s)_for_CS_MM_Tel._Serv, Codec(s)_for_MM_Tel_Service, Codec_for_Multimedia_Telephony / Text3: 26.911, 26.104, 26.111
- 2412: - / Text1: QoS_for_Speech_&_MM_Codecs_/_AMR / Text3: 26.102, 26.912
- 2413: UMTS_AMR2 is default Codec Type in R99 dual_mode terminals / Text1: TFOAMR / Text3: 26.103
- 2414: Combination of the AMR speech codec and the Noise Suppression function. TS 06.77 and TR 06.78 only apply to GSM. They apply to UMTS from Rel-4 onwards, when they were converted to TS 26.077 and TR 26.078. / Text1: AMRNS / Text3: 06.77, 06.78
- 2415: Transcoder handling in the CN at inter-system handover and relocation + Introduction of UMTS AMR / Text1: OoBT / Text3: 23.009, 24.008
- 2416: 24.008 CR#0572 in NP-020220 was approved under this WI / Text1: OoBTC / Text3: 24.008 CR#0572 in NP-020220
- 2417: - / Text1: ASCI / Text3: 02.30, 02.68, 03.68, 03.69, 04.18, 08.08, 11.10-1, 11.11, 23.067, 23.094, 24.008, 24.067, 27.007, 29.002
- 2418: Minor improvements to 24.007 and 24.008 to increase the number of simultaneous calls/sessions from the present 7: the TI value is increased (NP-99441). / Text1: CC_Related_items / Text3: 24.007, 24.008
- 2419: - / Text1: Multimedia / Text3: 24.008, 27.001, 29.007
- 2420: Sub-System Number allocation for Radio Access Network Application Part, Radio Network Subsystem Application Part / Text1: SSN_allocation / Text3: 23.003
- 2421: Access to an Intranet/ISP with DHCP end to end / Text1: ISPaccess / Text3: 29.061
- 2422: Support for the IP-Multicast protocol / Text1: Point_to_Multipoint_Services / Text3: 29.061
- 2423: - / Text1: FAX / Text3: 22.003, 22.100
- 2424: Asynchronous Interface for real-time NT Fax + Introduction of Asynchronous interface for Real-time non-transparent FAX / Text1: Realtime_NT_FAX_in_UMTS / Text3: 27.001, 27.003
- 2425: - / Text1: GLR / Text3: 29.120
- 2426: - / Text1: MSP2 / Text3: 22.097, 23.072, 23.083, 23.084, 23.091, 23.093, 23.097
- 2427: - / Text1: Prepaging / Text3: 23.018, 23.082, 29.002
- 2428: Re-definition of channel quality measure used for AMR link adaptation for DARP MS / Text3: 05.09
- 2429: - / Text1: HS / Text3: 13.21
- 2430: - / Text1: Streamlining / Text3: 27.060, 29.061
- 2431: - / Text1: R99_Service_Clean_up / Text3: 03.10, 27.001, 27.002, 27.003, 27.060, 29.007, 29.061

| ID | WBS | Task | Type | Duration | Start | Finish | Complete | Baseline start | Baseline finish | Baseline duration | Total slack | Constraint | Resources | Work | Actual work | Text1 | Text6 | Text3 |
| --- | --- | --- | --- | --- | --- | --- | --- | --- | --- | --- | --- | --- | --- | --- | --- | --- | --- | --- |
| 2432 | 594 | **small Technical Enhancements and Improvements for R99** |  | 261d? | 1999-01-01 A | 1999-12-31 A | 100% | 1999-01-01 | 1999-12-31 | 261d? |  |  | N3 | 6264h | 6264h | TEI | R99 |  |
| 2433 | 594.1 | TEI_[CS_Data] |  | 261d? | 1999-01-01 A | 1999-12-31 A | 100% | 1999-01-01 | 1999-12-31 | 261d? |  | start no earlier than 1999-01-01 | N3 | 2088h | 2088h | TEI_[CS_Data] | R99 |  |
| 2434 | 594.2 | TEI_[GPRS] |  | 261d? | 1999-01-01 A | 1999-12-31 A | 100% | 1999-01-01 | 1999-12-31 | 261d? |  | start no earlier than 1999-01-01 | N3 | 2088h | 2088h | TEI_[GPRS] | R99 |  |
| 2435 | 595 | **R99 UE Conformance Testing** |  | 261d? | 1999-01-01 A | 1999-12-31 A | 100% | 1999-01-01 | 1999-12-31 | 261d? |  |  | R5,T1 | 4176h | 4176h | TEI_Test | R99 | 34.108, 34.121, 34.122, 34.123-1, 34.123-2, 34.123-3 |
| 2436 | 595.1 | Deleted - RTEI |  | 261d? | 1999-01-01 A | 1999-12-31 A | 100% | 1999-01-01 | 1999-12-31 | 261d? |  | start no earlier than 1999-01-01 | T1 | 2088h | 2088h | RTEI | R99 | 34.123-1 CR#0650, 0651, 34.123-3 CR#0148, 0149, 0150 |
| 2437 | 595.2 | Common test environments for User Equipment (UE); Conformance testing | milestone | 0d? | 1999-01-01 A | 1999-01-01 A | 100% | 1999-01-01 | 1999-01-01 | 0d? |  | start no earlier than 1999-01-01 | R5,T1 |  |  | TEI_Test | R99 | 34.108 |
| 2438 | 595.3 | Terminal conformance specification, Radio transmission and reception (FDD) | milestone | 0d? | 1999-01-01 A | 1999-01-01 A | 100% | 1999-01-01 | 1999-01-01 | 0d? |  | start no earlier than 1999-01-01 | R5,T1 |  |  | TEI_Test | R99 | 34.121 |
| 2439 | 595.4 | Terminal conformance specification, Radio transmission and reception (TDD) | milestone | 0d? | 1999-01-01 A | 1999-01-01 A | 100% | 1999-01-01 | 1999-01-01 | 0d? |  | start no earlier than 1999-01-01 | R5,T1 |  |  | TEI_Test | R99 | 34.122 |
| 2440 | 595.5 | UE conformance specification; Part 1: Protocol conformance specification | milestone | 0d? | 1999-01-01 A | 1999-01-01 A | 100% | 1999-01-01 | 1999-01-01 | 0d? |  | start no earlier than 1999-01-01 | R5,T1 |  |  | TEI_Test | R99 | 34.123-1 |
| 2441 | 595.6 | UE conformance specification; Part 2: Implementation Conformance Statement (ICS) specification | milestone | 0d? | 1999-01-01 A | 1999-01-01 A | 100% | 1999-01-01 | 1999-01-01 | 0d? |  | start no earlier than 1999-01-01 | R5,T1 |  |  | TEI_Test | R99 | 34.123-2 |
| 2442 | 595.7 | UE conformance specification; Part 3: Abstract test suites (ATSs) | milestone | 0d? | 1999-01-01 A | 1999-01-01 A | 100% | 1999-01-01 | 1999-01-01 | 0d? |  | start no earlier than 1999-01-01 | R5,T1 |  |  | TEI_Test | R99 | 34.123-3 |
| 2443 | 596 | Deleted - Dual Tone Multi-Frequency signalling : Support in the whole 3GPP system |  | 261d? | 1999-01-01 A | 1999-12-31 A | 100% | 1999-01-01 | 1999-12-31 | 261d? |  | start no earlier than 1999-01-01 | N1 | 2088h | 2088h | DTMF | R99 | 23.014 CR#0004 |
| 2444 | 597 | Deleted - Intersystem_Change |  | 261d? | 1999-01-01 A | 1999-12-31 A | 100% | 1999-01-01 | 1999-12-31 | 261d? |  | start no earlier than 1999-01-01 | G3new | 2088h | 2088h | Intersystem_Change | R99 | 04.18 CR#A243 |
| 2445 | 598 | Deleted - Long_Forwardedto_Numbers |  | 261d? | 1999-01-01 A | 1999-12-31 A | 100% | 1999-01-01 | 1999-12-31 | 261d? |  | start no earlier than 1999-01-01 | N2 | 2088h | 2088h | Long_Forwardedto_Numbers | R99 | 29.002 |
| 2446 | 599 | Deleted - RANimp-FSEarlyUE |  | 261d? | 1999-01-01 A | 1999-12-31 A | 100% | 1999-01-01 | 1999-12-31 | 261d? |  | start no earlier than 1999-01-01 | R3 | 2088h | 2088h | RANimp-FSEarlyUE | R99 | 25.413 CR#0520, 0538, 0565, 0563, 0541, 0540, 0539, 0547 |
| 2447 | 600 | Release 1999 Studies |  | 1d? | 2000-01-03 | 2000-01-03 |  | 2000-01-03 | 2000-01-03 | 1d? | 3056d |  | S1,T2 | 8h |  |  | R99 |  |
| 2448 | 601 | Advanced Addressing/Numbering |  | 261d? | 1999-01-01 A | 1999-12-31 A | 100% | 1999-01-01 | 1999-12-31 | 261d? |  | start no earlier than 1999-01-01 | S1 | 2088h | 2088h | Numbering | R99 | 22.975 |
| 2449 | 602 | Combined GSM and Mobile IP mobility handling in UMTS IP CN |  | 261d? | 1999-01-01 A | 1999-12-31 A | 100% | 1999-01-01 | 1999-12-31 | 261d? |  | start no earlier than 1999-01-01 | S2 | 2088h | 2088h |  | R99 | 23.923 |
| 2450 | 603 | UE Capabilities Requirements |  | 261d? | 1999-01-01 A | 1999-12-31 A | 100% | 1999-01-01 | 1999-12-31 | 261d? |  | start no earlier than 1999-01-01 | T2 | 2088h | 2088h | UCR | R99 | 21.904 |
| 2451 | 604 | Electrical safety requirements and regulations |  | 261d? | 1999-01-01 A | 1999-12-31 A | 100% | 1999-01-01 | 1999-12-31 | 261d? |  | start no earlier than 1999-01-01 | T2 | 2088h | 2088h |  | R99 | 34.907 |
| 2452 | 605 | Specific Absorbtion Rate (SAR) requirements and regulations in different regions |  | 261d? | 1999-01-01 A | 1999-12-31 A | 100% | 1999-01-01 | 1999-12-31 | 261d? |  | start no earlier than 1999-01-01 | T2 | 2088h | 2088h |  | R99 | 34.925 |
| 2453 | 606 | Multi-mode UE issues |  | 261d? | 1999-01-01 A | 1999-12-31 A | 100% | 1999-01-01 | 1999-12-31 | 261d? |  | start no earlier than 1999-01-01 | T2 | 2088h | 2088h |  | R99 | 21.810, 21.910 |
| 2454 | 607 | Provision of fax service in GSM and UMTS |  | 261d? | 1999-01-01 A | 1999-12-31 A | 100% | 1999-01-01 | 1999-12-31 | 261d? |  | start no earlier than 1999-01-01 | T2 | 2088h | 2088h |  | R99 | 22.945 |
| 2455 | 608 | Separating Radio Resources and Mobility Management specific parts of the MS Classmark |  | 261d? | 1999-01-01 A | 1999-12-31 A | 100% | 1999-01-01 | 1999-12-31 | 261d? |  | start no earlier than 1999-01-01 | T2 | 2088h | 2088h |  | R99 | 23.814 |

Notes:
- 2432: -
- 2433: -
- 2434: -
- 2435: Specifies Conformance Tests for a 3G UE to be recognised as 3GPP-standard compliant. A 3GPP-external body, GCF (Global Certification Forum), delivers certificates to prove that a UE has correctly passed tests and is then conform to the 3GPP standard.
- 2436: No CR or new TS/TR approved under this WI
- 2437: -
- 2438: measurement procedures for the conformance test of the UE that contain transmitting characteristics, receiving characteristics and performance requirements in addition to requirements for support of RRM (Radio Resource Management) in FDD mode.
- 2439: measurement procedures for the conformance test of the UE that contain transmitting characteristics, receiving characteristics and performance requirements in addition to requirements for support of RRM (Radio Resource Management) in TDD mode.
- 2440: TS 34.123, composed of three parts, actually specifies the protocol conformance testing for the 3G UE. Part 1 describes the overall test structure.
- 2441: Part 2 contains the applicability of each test case defined as the Implementation Conformance Statement (ICS) proforma, in compliance with the relevant requirements, and in accordance with the relevant guidance given in ISO/IEC 9646-7 and ETS 300 406.
- 2442: Part 3 specifies the protocol conformance testing in TTCN for the 3G UE at the Uu interface. It defines the TTCN test specification and design considerations in Abstract Test Suites based on the test cases specified in prose in part 1.
- 2443: No CR or new TS/TR approved under this WI
- 2444: No CR or new TS/TR approved under this WI
- 2445: -
- 2446: No CR or new TS/TR approved under this WI
- 2447: -
- 2448: Study on requirements for numbering and addressing for UMTS
- 2449: -
- 2450: Moved to CT1 at TSG-T closure
- 2451: Moved to RAN4 at TSG-T closure. TR summarizes differences between international and national standards relevant to IEC60950 and refers to regulations for conformity assessment due to different regulatory environments in different countries / regions.
- 2452: Moved to RAN4 at TSG-T closure.
- 2453: Moved to CT1 at TSG-T closure. Consequences on roaming capabilities and service availability (e.g. handover) of multi-mode UEs while roaming in various regions with various network configurations. Case studies for each of the possible scenarios in specs
- 2454: CP#27: Moved to C1 on closure of T2; see TP-050062. CP#28: C1->C3
- 2455: CP#27: change of WG as a result of closure of CN and T.
